# 3GPP_Release-2000

Schedule from MS Project, 1999-01-01 to 2013-03-15, A marks actual dates.

## Calendars

- Standard: Mon-Fri 08:00-12:00, 13:00-17:00; Sat-Sun off. Exceptions (off unless hours are given): 2000-01-15 08:00-12:00, 13:00-17:00, 2009-05-30 08:00-12:00, 13:00-17:00.

## Resources

| Resource |
| --- |
| NP |
| N1 |
| N2 |
| N3 |
| N4 |
| N5 |
| TP |
| T1 |
| T2 |
| T3 |
| RP |
| R1 |
| R2 |
| R3 |
| R4 |
| SP |
| S1 |
| S2 |
| S3 |
| S4 |
| S5 |
| PCG |
| GP |
| No |
| CN4 |
| ? |
| WG G2 |
| G2 |
| G1 |
| G4 |
| G3 |
| All |
| Generic |
| MLST |
| G5 |
| S3, G2 |
| WG T2 |
| GP,G1 |
| G4,G5 |
| OMA |
| GP-G2 |
| Yes |
| GP, |
| N4, |
| GP, N1 |
| CT5 |
| C5 |
| C1 |
| C4 |
| C3 |
| C6 |
| G1, |
| 4 |
| ct |
| c,s,r |
| CT,RAN,SA |
| G2, |
| G1, G3 |
| CT6 |
| CT1 |
| CT1, CT3, CT4 |
| C1, C3, C4 |
| CP |
| R5 |
| C |
| Rel-8 |
| GP, G2 |
| R1,R4 |
| S5,C1 |
| CT,RAN,SA,GERAN |
| S3,C1,C4 |
| 5 |
| S1,C1,C3,C4,S5 |
| S1,C1,C3,C5 |
| S1,C1,C3,C4 |
| S1,S5 |
| S2,S3 |
| RAN,SA |
| RP,S5 |
| S2,CT |
| S1,CT |
| S1,CT,GERAN |
| S1,C5 |
| S3,CT |
| S4,CT |
| C1,SA |
| S1,S2 |
| S1,S4 |
| S2,S2,S3,CT |
| S2,S3,CT |
| S1,CT,GX |
| S1,S4,CT |
| S2,S2,S3,S5,CT |
| S1,S2,CT |
| S1,S2,S3,CT |
| S1,S2,S3,S5CT |
| S1,S2,S3,S5,CT |
| S2,S5,CT |
| S4,S3 |
| S1,C1 |
| CP,C1 |
| C1,C3 |
| C1,C3,C4 |
| S1,S5,CT |
| C4,C3 |
| CP,RAN,SA,GERAN |
| S1,S2,S3,S5,CP |
| S2,S3,CP |
| S2,CP |
| S1,CP,GX |
| S1,CP |
| S1,S4,CP |
| S1,S2,CP |
| S1,S2,S3,CP |
| S2,S5,CP |
| S3,CP |
| S1,S5,CP |
| RAN,SA,GERAN |
| S1,S2,S3,S5,C1,C3,C4,C6 |
| S2,S3,C1,C3,C4 |
| S2,C4 |
| S2,C1,C3,C4 |
| S2,C1,C4 |
| S2,S3,C1,C4 |
| S1,C1,C4,G2 |
| C1,C4 |
| S1,C1,C3 |
| S1,S4,C1,C3,C4 |
| S1,S2,S3,C1,C3,C4 |
| S2,S5,C3 |
| S1,S2,C1,C4 |
| S2,C1 |
| S2,C1,C3 |
| S3,C1,C3,C4 |
| S1,S5,C1,C3,C4 |
| S2,C3,C4 |
| C3,C1 |
| R2,R4 |
| R2,R5 |
| RP,R5 |
| RP,S5,R5 |
| R1,R5 |
| S1,C1,R5 |
| S1,C1,S4,R5 |
| GERAN |
| G3new |
| G1, G3new |
| C4,C1,C3 |
| R1.R4 |
| R1, R4 |
| R2,R3 |
| C3,C4 |
| S4,C3 |
| S4,C3,C1,C4 |
| S1,S2,C1 |
| S1,S2<C1,C3,C4 |
| S1,S2,C1,C3,C4 |
| S5,C1,C3,C4 |
| GP,C4 |
| C4,C1 |
| S2,S1 |
| RP,SP,GP |
| RP,SP,CP,GP |
| CP,GP,RP,SP |
| GP,C4,S4 |
| S1,C1,C4 |
| S1,S2,C3,C1 |
| R2,R4,R3 |
| CP,GP, RP,SP |
| S2,S1,C1,S5 |
| S2,S1,C1 |
| S1,C1,S4 |
| S1,S2,GP,C4,R2 |
| S1,GP,R2 |
| S1,C6 |
| S1,S2,C1,S4 |
| S2,S3,S5,C1,C3,C4 |
| S2,S5,C1 |
| S2,S3,S5 |
| CP,GP, RP,SP,TP |
| S2,C4,C1 |
| S1,C1,C4,S3 |
| S2,S5 |
| S3,C1 |
| S3,C4 |
| S1,C4 |
| S2,S5,C3,C1 |
| S2,S1,S5,C1,C4 |
| S1,R1,C3 |
| S1,C1,R2 |
| S2,S1,C1,C4 |
| S1,C1,C6 |
| GP,S4,C4,C1,C3 |
| C3,C1,C4 |
| S1,C4,C1 |
| S1,S3 |
| S1,S2,S5,C3,C4 |
| R4,G1 |
| G1,R4 |
| RP,GP |
| R4,GP |
| R3,R2 |
| C6,RP,SP |
| R5,C6 |
| CP,RP,SP |
| RP,SP,CP |
| R3,S5 |
| S1,S2,RP |
| S1,S2,S5,RP |
| S2,S1,RP |
| Rel-9 |
| S3,C6 |
| S1,S2,S3,S5,RP |
| S2,S1,S3 |
| S1,S2,S3 |
| S1,S2,S3,S5 |
| C6,R5 |
| S1,S2,RP,GP |
| S1,S2,S4,S5,RP,GP |
| GP,G2 |
| GP,GP, N1 |
| GP,S2,G1,G2 |
| GP,R2,R3,S2,G1,G2 |
| GP,S2,S5,R2,R3,G2,G1 |
| GP,R3 |
| N4,S2 |
| GP,RP |
| GP,S2,RP |
| G5,G4 |
| G4,R3 |
| S2,R2,R4 |
| S1,S2,R2,R4 |
| GP,S5 |
| S1,S2,S5 |
| R4,R5 |
| R4,R2,R3,R5 |
| S2,S5,N4,RP |
| S1,S2,S3,S5,NP |
| S2,S4,S5 |
| T2,S1,S4,S5 |
| SP,RP |
| S2,RP |
| S1,S2,CP,G2 |
| CP,SP |
| S1,G2 |
| SP,CP |
| S1,S2,S5,C3 |
| S1,C1,S3 |
| G1,G3new |
| C4, C3, C1C4 |
| C4,C3,C1 |
| S1,S2,S3,S5,R2,R3,R4 |
| S1,S2,S3,R2 |
| S2,S3,S5,C4,R2 |
| S1,S5,C1 |
| S1,S2,S3,C1,C3,C4,R2 |
| Ggp |
| S3,S2,C1,C4,G2 G3new |
| R1,R2,R3,R4 |
| R4,R1,R2,R3 |
| R4,R2,R3 |
| S1,C1,C4,R2 |
| R4,R2 |
| S2,C4,R2,R4 |
| S2,C4,R2 |
| S2,S3,S5,C3,C4,R2 |
| S1,S2,S4,T2 |
| S1,S2,S4 |
| S1,S2,S4,R5 |
| S3,S2,C1,C4,G2,G3new |
| GP,C1 |
| S1,S5,C4 |
| S1,S2,S3,S5,R2,R3,R4,GP |
| GP,C4,C3,C1 |
| SMG9 |
| SMG1 |
| SMG2 |
| N3,R5 |
| N1, N2, N4, G1, G2, R3, S1, SMG2 |
| S1,SMG1 |
| SMG1,N4 |
| N1,C1,N4,S1,T2,G2,SMG1,SMG2,SMG3,SMG7,SMG9 |
| SMG1,N2 |
| S1,S2,N2,N4 |
| N4,N2 |
| G1,G2 |
| G1,G2,C1 |
| G1,G2,N1 |
| SMG2, SMG1, SMG3, SMG4, SMG7, SMG9, SMG10, G1, G2, G3, N1, N3, T2 |
| SMG2,G1 |
| S1,G1,G2 |
| SMG1,N1,G1,G2 |
| G2,G1 |
| G1,G2,G3,S1,S2,SMG1,SMG2,SMG7,N1,N2,N3,N4,T2 |
| 23.003, 23.008, 29.060 |
| S1, S2, SMG1, SMG2, SMG12, G2, N1, N2, N4 |
| S1,S2,SMG1,SMG2,SMG12,G2,N1,N2,N4 |
| S1,SMG2,N1,N2,N4 |
| SMG1,T2 |
| S1,N1,N2,N4 |
| S1,S2,N5 |
| SMG2,SMG7,G2,T2 |
| S3,N1,N2,N3 |
| S3,N1,N2,N4 |
| SMG9,T3 |
| SMG2,SMG3,SMG7,G2,N2 |
| SMG2,N1,G1,G2 |
| S1,N2 |
| N1,N3 |
| S2,N1 |
| N1,N2,N4 |
| N2,N1,N4 |
| N2,N4 |
| S1,T3 |
| T2,N3 |
| S3,N2 |
| T2,S1 |
| S1,N4 |
| SMG1,SMG2,SMG7 |
| N1,S1,T1 |
| SMG1,SMG3 |
| N4,S2,N1 |
| S1,S2,SMG1,SMG2,SMG7,G1,G2,G3,N1,N2,N3,N4,T2 |
| SMG1,N3 |
| S1,N3 |
| CP,SP,SMG |
| CP,SP,TP,GP,SMG |
| NP,SP,TP,GP,SMG |
| NP,GP, RP,SP,TP |
| SMG2,SMG1,SMG3,SMG4,SMG7,SMG9,SMG10,G1,G2,G3,N1,N3,T2 |
| S1,N2,N4 |
| S1,S2,S3,C1,C3,C4,R2,R3 |
| R2,R3,R1,R4 |
| R2,R3,R4 |
| R2,R1,R3,R4 |
| S2,C4,R2,R3,R4 |
| S2,C4,R2,R1,R3,R4 |
| S2,S3,S5,C3,C4,R2,R3,R4 |
| R1,R2,R4 |
| R3,R1,R4 |
| S2, |
| S2,G2, |
| S1,S2,G2, |
| S1,S2,G2,R2,R3, |
| S1,S2,C4,G2,R2,R3 |
| S1,S2,N4,G2,R2,R3 |
| S1,S2,SMG1,SMG2,SMG12,G2,N1,N2,N4,R2,R3 |
| S1,SMG1,T2 |
| S1,SMG1,S2 |
| S1,N4,N2 |
| T2,N1,N3 |
| S3,N2,N4 |
| SMG1,SMG2,SMG3,SMG7,SMG9,N1,C1,N4,S1,T2,G2 |
| SMG1,N2,N4 |
| S2,T2,N1,N2,N4 |
| S1,T2 |
| S1,S2,C4 |
| S1,S2,N4,RP |
| S2,N4 |
| S1,S2,N3,N4,RP |
| S1,S2,SMG1,SMG2,SMG12,T2,G2,N1,N2,N4,R2,R3 |
| S1,T2,N1,N3 |
| S1,S2,SMG1,SMG2,SMG12,T2,G2,N1,N2,N3,N4,R2,R3 |
| S1,S2,S3,SMG1,SMG2,SMG12,G2,N1,N2,N4,R2,R3 |
| S1,S2,SMG,G1,G2,G3,N1,N2,N3,N4,T2 |
| S1,S2,SMG,T2,G2,N1,N2,N3,N4,R2,R3 |
| S1,S3,SMG,G1,G2,G3,N1,N2,N3,N4,T2 |
| S1,S3,T2,N2,N4 |
| S1,S2,SMG,T2,G1,G2,G3,N1,N2,N3,N4 |
| G2,S2 |
| T1,R5 |
| R5,T1 |
| S1,S2,S4,T1,R5 |
| S1,S2,S4,S5,T1,RP,GP |
| S1,S2,S3,S5,R2,R3,R4,GP,C1 |
| S1,S2,S3,SMG1,SMG2,SMG12,N1,N2,N4,R2,R3 |
| S1,S2,SMG,T2,N1,N2,N3,N4,R2,R3 |
| NP,SP,TP,SMG |
| S1,S2,SMG,T2,N1,N2,N3,N4 |
| SMG,N1 |
| SMG |
| S1,S2,SMG1,SMG2,SMG7,N1,N2,N3,N4,T2 |
| SMG2,SMG1,SMG3,SMG4,SMG7,SMG9,SMG10,N1,N3,T2 |
| S1,SMG |
| SMG2,SMG7,T2 |
| SMG2,S2 |
| N1,N2,N4,R3,S1,SMG |
| SMG2,SMG3,SMG7,N2 |
| SMG1,SMG2,SMG3,SMG7,SMG9,N1,C1,N4,S1,T2 |
| S1,S2,SMG,N3,N4,RP |
| S1,S2,S4,SMG,N3,N4,RP |
| S2,C1,C4,R2,R1,R3,R4 |
| R2,S2,S4 |
| G3new,R5 |
| GP,R4 |
| S2,S4,R2 |
| SP,GP |
| RP,SP |
| S2,S1,S3,S5 |
| S3,S1 |
| N4,N1,N2,S2 |
| S2,G1,G2,R2,R3 |
| S2,G1,G2 |
| G1,G2,R2,R3 |
| N4,T3 |
| S3,S2,N1,N4,T3,OMA |
| T2,S1,S4,S5,OMA |
| S2,N3 |
| S4,S1 |
| N4,N3,S1 |
| R5,G3new |
| R4,R2,R1 |
| S2,R2 |
| C3, C4,C1 |
| S3,C1,C4,C3 |
| C1,C4,C3 |
| S2,C1,C4,C3 |
| R3,R5 |
| S1,S2,C3 |
| R1,R2 |
| S3,C1,C4,G2,G3new |
| R1,R3 |
| GP,N1 |
| R1,R2,R3 |
| R3,R2,R4 |
| R4,R3 |
| S1,S2,R2,R3 |
| S1,S2,S3,C1,C3,C4,R2,R3,R5 |
| S2,S1,S5 |
| C4, C1 |
| C3, C1, C4 |
| S2,S1,S3,S5,C4,C1 |
| S2,C3,C1,C4 |
| S2,S1,S5,C3 |
| GP,S2,C1 |
| GP,S2,C1,G2 |
| G2,S2,C1 |
| v |
| G3new,G1,G2 |
| G1,G2,C1,G3new |
| S2,S1,S5,C1,C3 |
| C1,C3,C4,R5 |
| R2,R1 |
| S1<S2,N1,R2,R5 |
| S1,S2,N1,R2,R5 |
| S2,R5 |
| S1,S2,S5,R5 |
| S2,C1,C4,R2,R1,R3,R4,R5 |
| S1,S2,S3,S5,NP,R5 |
| S1,S2,S4,S5,RP,R5,GP |
| S1,S2,S3,S5,C1,C6,R2,R3,R4 |
| S1,S2,S3,S5,C1,C6,R2,R3,R4,GP |
| S4,R2 |
| S1,S2,C1,C4,G2 |
| S4,C3,C4 |
| S5,C1,C4 |
| S2,C4,C3,C1 |
| C4, C3, C1 |
| S2,S4,R2,C4,C3,C1 |
| GP1,GP2 |
| GP,GP1,GP2 |
| GP,G1,G2 |
| G2,R3 |
| S1,S2,S3,C1,C3,C4,G2 |
| GP,G1,C1 |
| S1,S2,C4,C3,C1 |
| - |
| GP,G1,G2,G3new |
| S1,S2,S3,C1,C3,C4,G2,R2,R3 |
| S1,S2,C1,C3,C4,G2,R2,R3 |
| C1,C6 |
| GP,G2,C4 |
| S2,C3 |
| R5,R4 |
| C4,GP,G2 |
| S1,S2,C1,C4,G2,R2,R3 |
| R1,R2,R4,S3 |
| S2,S5,C3,C1,C4 |
| S2,S4,C4,C3,C1 |
| S2,S4 |
| S3,S1,S2 |
| S1,S2,S3,C1,R2 |
| S3,S1,S2,C1,R2 |
| S2,C3,S5 |
| S1,S2,C1,C4,C3,G2,R2,R3 |
| S5,C4 |
| S2,S1,C3 |
| C1,C4,C3,C6 |
| S1,S2,C1,C4,C3,C6,G2,R2,R3 |
| R1,R2,R4,S3,C4,C6 |
| R4,R1,R4,R1,R2,R3,R3 |
| S2,R3,R2 |
| S1,S2,S5,CP |
| S1,S3,CP |
| C6,C1 |
| R4,R2,R1,R3 |
| R3,R1,R2 |
| R1,R4,R2,R3 |
| S2,C4,C1,C3 |
| R3,R1,R2,R4 |

## Schedule

| ID | WBS | Task | Type | Duration | Start | Finish | Complete | Remaining | Baseline start | Baseline finish | Baseline duration | Total slack | Constraint | Resources | Work | Actual work | Text6 | Text8 | Text1 | Text2 | Text4 | Text5 | Text7 | Text3 |
| --- | --- | --- | --- | --- | --- | --- | --- | --- | --- | --- | --- | --- | --- | --- | --- | --- | --- | --- | --- | --- | --- | --- | --- | --- |
| 1 | 1 | Version 2011 Apr 01 | milestone | 0d? | 2000-01-03 A | 2000-01-03 A | 100% |  | 2000-01-03 | 2000-01-03 | 0d? |  |  | - |  |  |  |  |  |  |  |  |  |  |
| 2 | 2 | Rel-9 Two GERAN exceptions to 05/2011 (VAMOS, AGNSSPTP) | milestone | 0d? | 2000-01-03 A | 2000-01-03 A | 100% |  | 2000-01-03 | 2000-01-03 | 0d? |  | finish no earlier than 1998-12-07 | - |  |  |  |  |  |  |  |  |  |  |
| 3 | 3 | Rel-10 Stage 3 freeze 03/2011. Exceptions to 06/2011 | milestone | 0d | 2000-01-03 A | 2000-01-03 A | 100% |  | 2000-01-03 | 2000-01-03 | 0d |  | finish no earlier than 1998-12-07 | - |  |  |  |  |  |  |  |  |  |  |
| 4 | 4 | Rel-11 Stage 1 freeze 09/2011 | milestone | 0d | 2000-01-03 A | 2000-01-03 A | 100% |  | 2000-01-03 | 2000-01-03 | 0d |  | finish no earlier than 1998-12-07 | - |  |  |  |  |  |  |  |  |  |  |
| 5 | 5 | Gantt: dark blue=done; light blue=to be done; grey: previous values; black=summary | milestone | 0d? | 2000-01-03 A | 2000-01-03 A | 100% |  | 2000-01-03 | 2000-01-03 | 0d? |  | finish no earlier than 1998-12-07 | - |  |  |  |  |  |  |  |  |  |  |
| 6 | 6 | Release 11 Features |  | 457d? | 2010-03-25 | 2011-12-23 |  |  | 2010-03-25 | 2011-12-23 | 457d? | 320d | finish no earlier than 2011-12-23 | SP,RP | 3656h |  | Rel-11 | All |  |  |  |  |  |  |
| 7 | 7 | **Support BroadBand forum Accesses Interworking** |  | 525d? | 2009-12-10 A | 2011-12-14 | 42% | 302.31d? | 2009-12-10 | 2011-12-14 | 525d? | 327d |  | S2,S1 | 20792h | 8819.55h | Rel-11 | Alain | BBAI | PCG-24 | Ericsson, Huawei | peter.bleckert@ericsson.com | SP-46 |  |
| 8 | 7.1 | TR on Stage 2 for BroadBand forum Accesses Interworking |  | 449d? | 2010-03-26 A | 2011-12-14 | 30% | 314.3d? | 2010-03-26 | 2011-12-14 | 449d? | 327d | finish no earlier than 2011-12-14 | S2 | 3592h | 1077.6h | Rel-11 | Maurice | BBAI | PCG-24 | Ericsson | stefan.rommer@ericsson.com | SP-47 | new TR 23.839 |
| 9 | 7.2 | Stage 1 Building Block I for BroadBand forum Accesses Interworking |  | 76d? | 2009-12-10 A | 2010-03-25 A | 100% |  | 2009-12-10 | 2010-03-25 | 76d? |  | start no earlier than 2009-12-10 | S1 | 608h | 608h | Rel-11 | Alain | BBAI | PCG-24 | Ericsson | peter.bleckert@ericsson.com | SP-46 | 22.278 CR#0058 |
| 10 | 7.3 | Stage 2 Building Block I for BroadBand forum Accesses Interworking |  | 389d? | 2010-03-26 A | 2011-09-21 | 45% | 213.95d? | 2010-03-26 | 2011-09-21 | 389d? | 387d | finish no earlier than 2011-09-21 | S2 | 3112h | 1400.4h | Rel-11 | Maurice | BBAI | PCG-24 | Ericsson | stefan.rommer@ericsson.com | SP-47 | 23.203, 23.401, 23.402 |
| 11 | 7.4 | Stage 1 Building Block II for BroadBand forum Accesses Interworking |  | 260d? | 2010-09-23 A | 2011-09-21 | 95% | 13d? | 2010-09-23 | 2011-09-21 | 260d? | 387d | finish no earlier than 2011-09-21 | S1 | 2080h | 1976h | Rel-11 | Alain | BBAI | PCG-25 | Ericsson | peter.bleckert@ericsson.com | SP-49 | 22.278 |
| 12 | 7.5 | Stage 2 Building Block II for BroadBand forum Accesses Interworking |  | 320d? | 2010-09-23 | 2011-12-14 |  |  | 2010-09-23 | 2011-12-14 | 320d? | 327d | finish no earlier than 2011-12-14 | S2 | 2560h |  | Rel-11 | Maurice | BBAI | PCG-24 | Ericsson | stefan.rommer@ericsson.com | SP-47 | 23.203, 23.401, 23.402 |
| 13 | 7.6 | Stage 1 Building Block III for BroadBand forum Accesses Interworking |  | 260d? | 2010-09-23 A | 2011-09-21 | 95% | 13d? | 2010-09-23 | 2011-09-21 | 260d? | 387d | finish no earlier than 2011-09-21 | S1 | 2080h | 1976h | Rel-11 | Alain | BBAI | PCG-25 | Huawei | Amar Deol (adeol@huawei.com) | SP-49 | 22.278 |
| 14 | 7.7 | Stage 2 Building Block III for BroadBand forum Accesses Interworking |  | 320d? | 2010-09-23 | 2011-12-14 |  |  | 2010-09-23 | 2011-12-14 | 320d? | 327d | finish no earlier than 2011-12-14 | S2 | 2560h |  | Rel-11 | Maurice | BBAI | PCG-24 | Huawei | marco.spini@huawei.com | SP-47 | 23.203, 23.401, 23.402 |
| 15 | 8 | **Advanced IP Interconnection of Services** |  | 517d? | 2010-03-25 A | 2012-03-16 | 58% | 217.66d? | 2010-03-25 | 2012-03-16 | 517d? | 260d |  | S1,S2 | 9840h | 5697.08h | Rel-11 | Alain | IPXS | PCG-24 | Telefónica | chris.friel@O2.com | SP-47 |  |
| 16 | 8.1 | Stage 1 for Advanced IP Interconnection of Services |  | 386d | 2010-03-25 A | 2011-09-15 | 90% | 38.6d | 2010-03-25 | 2011-09-15 | 386d | 391d | finish no earlier than 2011-09-15 | S1 | 3088h | 2779.2h | Rel-11 | Alain | IPXS | PCG-24 | Telefónica | chris.friel@O2.com | SP-47 | 22.101, 22.228 |
| 17 | 8.2 | Stage 2 for Advanced IP Interconnection of Services |  | 327d? | 2010-12-16 A | 2012-03-16 | 20% | 261.6d? | 2010-12-16 | 2012-03-16 | 327d? | 260d | finish no earlier than 2012-03-16 | S2 | 2616h | 523.2h | Rel-11 | Maurice | IPXS | PCG-26 | Ericsson | fredrik.lindholm@ericsson.com | SP-50 | 23.228 |
| 18 | 9 | **System Improvements to Machine-Type Communications** |  | 461d? | 2010-06-10 A | 2012-03-15 | 13% | 399.28d? | 2010-06-10 | 2012-03-15 | 461d? | 261d |  | S1,S2,S3 | 19448h | 2603.74h | Rel-11 | Alain | SIMTC | PCG-25 | KPN | toon.norp@tno.nl | SP-48 |  |
| 19 | 9.1 | Stage 1 for System Improvements to Machine-Type Communications |  | 331d? | 2010-06-10 A | 2011-09-15 | 20% | 264.8d? | 2010-06-10 | 2011-09-15 | 331d? | 391d | finish no earlier than 2011-09-15 | S1 | 2648h | 529.6h | Rel-11 | Alain | SIMTC | PCG-25 | KPN | toon.norp@tno.nl | SP-48 | 22.368 |
| 20 | 9.2 | TR on Stage 2 for System Improvements to Machine-Type Communications |  | 461d? | 2010-06-10 A | 2012-03-15 | 15% | 391.85d? | 2010-06-10 | 2012-03-15 | 461d? | 261d | finish no earlier than 2012-03-15 | S2 | 3688h | 553.2h | Rel-11 | Maurice | SIMTC | PCG-25 | Samsung | erik.guttman@partner.samsung.com | SP-48 | new TR 23.888 |
| 21 | 9.3 | TR on Security aspects of System Improvements to Machine-Type Communications |  | 321d? | 2010-09-23 A | 2011-12-15 | 40% | 192.6d? | 2010-09-23 | 2011-12-15 | 321d? | 326d | finish no earlier than 2011-12-15 | S3 | 2568h | 1027.2h | Rel-11 | Dionisio | SIMTC | PCG-25 | Samsung | Rajavelsamy R (rajvel@samsung.com) | SP-49 | new TR 33.8xy |
| 22 | 9.4 | Stage 2 on SA2 part for System Improvements to Machine-Type Communications |  | 461d? | 2010-06-10 | 2012-03-15 |  |  | 2010-06-10 | 2012-03-15 | 461d? | 261d | finish no earlier than 2012-03-15 | S2 | 3688h |  | Rel-11 | Maurice | SIMTC | PCG-25 | Samsung | erik.guttman@partner.samsung.com | SP-48 | Depends on the outcome of the Stage 2 TR |
| 23 | 9.5 | Stage 2 on Security part for System Improvements to Machine-Type Communications |  | 396d? | 2010-06-10 | 2011-12-15 |  |  | 2010-06-10 | 2011-12-15 | 396d? | 326d | finish no earlier than 2011-12-15 | S3 | 3168h |  | Rel-11 | Dionisio | SIMTC | PCG-25 | Samsung | Rajavelsamy R (rajvel@samsung.com) | SP-48 | Depends on the outcome of the Stage 2 Security TR |
| 24 | 10 | **Unstructured Supplementary Service Data (USSD) simulation service in IMS** |  | 0d? | 2010-06-10 A | 2010-06-10 A | 100% |  | 2010-06-10 | 2010-06-10 | 0d? |  |  | S1 |  |  | Rel-11 | Alain | USSI | PCG-25 | Deutsche Telekom | kurt.bischinger@t-mobile.at | SP-48 |  |
| 25 | 10.1 | Stage 1 for USSD simulation service in IMS | milestone | 0d? | 2010-06-10 A | 2010-06-10 A | 100% |  | 2010-06-10 | 2010-06-10 | 0d? |  | finish no earlier than 2010-06-10 | S1 |  |  | Rel-11 | Alain | USSI | PCG-25 | Deutsche Telekom | kurt.bischinger@t-mobile.at | SP-48 | 22.173 |

Notes:
- 1: -
- 2: -
- 3: -
- 4: -
- 5: -
- 6: -
- 7: SP#51 Stage 2 delayed by 6 months. Triggered by BBF WT 203, WT-134 (interworking btw 3GPP EPS and BBF's fixed broadband accesses). Stage 2 will be based on 3GPP Stage 1
- 8: SP#51 completion 06/11=>12/11. TR structure to follow the structure of the Building Blocks. Once a BB is completed, TR to be sent for SA Information. When all the BBs are completed, TR to be sent for SA approval.
- 9: SP#47 completed. Provide service requirements for supporting interworking between 3GPP EPS and the fixed broadband accesses defined by BBF
- 10: SP#51 completion 03/11=>09/11
- 11: SP#51 completion 03/11=>09/11
- 12: SP#51 completion 06/11=>12/11
- 13: SP#51 completion 03/11=>09/11
- 14: SP#51 completion 06/11=>12/11
- 15: SP#50 updated WID SP-100227=>SP-100876 (added Stage 2). Triggered by Rel-10 TR 22.893 UID_380083 Study on advanced requirements for IP interconnect (FS_IPXS)
- 16: SP#50 updated WID SP-100227=>SP-100876. Completion 12/10=>09/11
- 17: SP#50 updated WID SP-100227=>SP-100876 (added Stage 2)
- 18: SP#50 updated WID SP-100637=>SP-100699. Enhancements to Rel-10 Feature UID_410031 (Network Improvements for Machine Type Communications) based on Rel-11 Study on enhancements to MTC
- 19: SP#50 completion 12/10=>09/11
- 20: SP#50 updated WID SP-100637=>SP-100699. Completion 09/11=>03/12
- 21: SP#49 updated WID SP-100447=>SP-100637 (added security TR).
- 22: SP#50 updated WID SP-100637=>SP-100699. Completion 12/11=>03/12
- 23: -
- 24: SP#48 approved WID & Stage 1 completed. Specify a "CS domain USSD" like service over IMS (see GSM Mobile User Initiated USSD)
- 25: SP#48 completed

| ID | WBS | Task | Duration | Start | Finish | Complete | Remaining | Baseline start | Baseline finish | Baseline duration | Total slack | Constraint | Resources | Work | Actual work | Text1 | Text2 | Text4 | Text5 | Text6 | Text7 | Text8 |
| --- | --- | --- | --- | --- | --- | --- | --- | --- | --- | --- | --- | --- | --- | --- | --- | --- | --- | --- | --- | --- | --- | --- |
| 26 | 11 | **SRVCC aspect of enhancements for Multimedia Priority Service** | 395d? | 2010-06-10 A | 2011-12-14 | 9% | 358.75d? | 2010-06-10 | 2011-12-14 | 395d? | 327d |  | S2 | 9000h | 826.03h | eMPS_SRVCC | PCG-25 | Telcordia, NTT DoCoMo | Katsutoshi Nishida | Rel-11 | SP-48 | Maurice |
| 27 | 11.1 | TR on SRVCC for eMPS | 335d? | 2010-06-10 A | 2011-09-21 | 20% | 268d? | 2010-06-10 | 2011-09-21 | 335d? | 387d | finish no earlier than 2011-09-21 | S2 | 2680h | 536h | eMPS_SRVCC | PCG-25 | Telcordia, NTT DoCoMo | Katsutoshi Nishida | Rel-11 | SP-48 | Maurice |
| 28 | 11.2 | Stage 2 on SRVCC for eMPS | 395d? | 2010-06-10 | 2011-12-14 |  |  | 2010-06-10 | 2011-12-14 | 395d? | 327d | finish no earlier than 2011-12-14 | S2 | 3160h |  | eMPS_SRVCC | PCG-25 | Telcordia, NTT DoCoMo | Katsutoshi Nishida | Rel-11 | SP-48 | Maurice |
| 29 | 12 | **Single Radio Video Call Continuity for 3G-CS** | 169d? | 2010-10-15 A | 2011-06-08 | 80% | 33.79d? | 2010-10-15 | 2011-06-08 | 169d? | 462d |  | S2 | 2334.8h | 1867.88h | vSRVCC | PCG-26 | Samsung | Haris Zisimopoulos (haris.z@samsung.com) | Rel-11 | SP-50 | Maurice |
| 30 | 12.1 | Stage 2 for Single Radio Video Call Continuity for 3G-CS | 122.85d? | 2010-10-15 A | 2011-06-08 | 80% | 24.57d? | 2010-10-15 | 2011-06-08 | 122.85d? | 462d | finish no earlier than 2011-06-08 | S2 | 982.8h | 786.24h | vSRVCC | PCG-26 | Samsung | Haris Zisimopoulos (haris.z@samsung.com) | Rel-11 | SP-50 | Maurice |
| 31 | 13 | **Network Provided Location Information for IMS** | 465d? | 2010-06-10 A | 2012-03-21 | 23% | 359.14d? | 2010-06-10 | 2012-03-21 | 465d? | 257d |  | S2,S1,S5 | 13688h | 3116.05h | NWK-PL2IMS | PCG-25 | T-Mobile | michele.zarri@t-mobile.co.uk | Rel-11 | SP-48 | Maurice |
| 32 | 13.1 | Stage 1 for Network Provided Location Information for IMS | 126d? | 2010-12-15 A | 2011-06-08 | 90% | 12.6d? | 2010-12-15 | 2011-06-08 | 126d? | 462d | finish no earlier than 2011-06-08 | S1 | 1008h | 907.2h | NWK-PL2IMS | PCG-26 | n/a | n/a | Rel-11 | SP-50 | Alain |
| 33 | 13.2 | TR on Stage 2 for network provided location information to the IMS | 335d? | 2010-06-10 A | 2011-09-21 | 45% | 184.25d? | 2010-06-10 | 2011-09-21 | 335d? | 387d | finish no earlier than 2011-09-21 | S2 | 2680h | 1206h | NWK-PL2IMS | PCG-25 | T-Mobile | michele.zarri@t-mobile.co.uk | Rel-11 | SP-48 | Maurice |
| 34 | 13.3 | Stage 2 for Network Provided Location Information for IMS | 395d? | 2010-06-10 | 2011-12-14 |  |  | 2010-06-10 | 2011-12-14 | 395d? | 327d | finish no earlier than 2011-12-14 | S2 | 3160h |  | NWK-PL2IMS | PCG-25 | T-Mobile | michele.zarri@t-mobile.co.uk | Rel-11 | SP-48 | Maurice |
| 35 | 13.4 | Network Provided Location Information for IMS Charging | 390d? | 2010-09-23 A | 2012-03-21 | 5% | 370.5d? | 2010-09-23 | 2012-03-21 | 390d? | 257d | finish no earlier than 2012-03-21 | S5 | 3120h | 156h | NWK-PL2IMS_CH | PCG-25 | Nokia Siemens Networks | Gerald.Goermer@nsn.com | Rel-11 | SP-49 | Dionisio |
| 36 | 14 | **SIPTO Service Continuity of IP Data Session** | 256d? | 2010-09-23 A | 2011-09-15 | 90% | 25.59d? | 2010-09-23 | 2011-09-15 | 256d? | 391d |  | S1 | 4096h | 3686.52h | SIPTO_SC | PCG-25 | Vodafone | mona.mustapha@vodafone.com | Rel-11 | SP-49 | Alain |
| 37 | 14.1 | Stage 1 for SIPTO Service Continuity of IP Data Session | 256d? | 2010-09-23 A | 2011-09-15 | 90% | 25.6d? | 2010-09-23 | 2011-09-15 | 256d? | 391d | finish no earlier than 2011-09-15 | S1 | 2048h | 1843.2h | SIPTO_SC | PCG-25 | Vodafone | mona.mustapha@vodafone.com | Rel-11 | SP-49 | Alain |
| 38 | 15 | **LIPA Mobility and SIPTO at the Local Network** | 305d? | 2010-10-15 A | 2011-12-15 | 10% | 274.51d? | 2010-10-15 | 2011-12-15 | 305d? | 326d |  | S2,R3,R2 | 4510.8h | 451h | LIMONET | PCG-26 | Huawei | Patrice Hédé (patrice.hede@huawei.com) | Rel-11 | SP-50 | Maurice |
| 39 | 15.1 | Stage 2 for LIPA Mobility and SIPTO at the Local Network | 258.85d? | 2010-10-15 A | 2011-12-15 | 10% | 232.97d? | 2010-10-15 | 2011-12-15 | 258.85d? | 326d | finish no earlier than 2011-12-15 | S2 | 2070.8h | 207.08h | LIMONET | PCG-26 | Huawei | Patrice Hédé (patrice.hede@huawei.com) | Rel-11 | SP-50 | Maurice |
| 40 | 16 | **QoS Control Based on Subscriber Spending Limits** | 390d? | 2010-09-23 A | 2012-03-21 | 34% | 257.25d? | 2010-09-23 | 2012-03-21 | 390d? | 257d |  | S1,S5 | 9344h | 3180.56h | QoS_SSL | PCG-25 | Vodafone | mona.mustapha@vodafone.com | Rel-11 | SP-49 | Alain |
| 41 | 16.1 | Stage 1 for QoS Control Based on Subscriber Spending Limits | 256d? | 2010-09-23 A | 2011-09-15 | 97% | 7.68d? | 2010-09-23 | 2011-09-15 | 256d? | 391d | finish no earlier than 2011-09-15 | S1 | 2048h | 1986.56h | QoS_SSL | PCG-25 | Vodafone | mona.mustapha@vodafone.com | Rel-11 | SP-49 | Alain |
| 42 | 16.2 | Stage 2 for QoS Control Based on Subscriber Spending Limits | 192d? | 2011-03-23 | 2011-12-15 |  |  | 2011-03-23 | 2011-12-15 | 192d? | 326d | finish no earlier than 2011-12-15 | S2 | 1536h |  | QoS_SSL | PCG-26 | Huawei | Xu Xia (xiatony@huawei.com) | Rel-11 | SP-51 | Maurice |
| 43 | 16.3 | Charging for QoS Control Based on Subscriber Spending Limits | 330d? | 2010-12-16 A | 2012-03-21 | 5% | 313.5d? | 2010-12-16 | 2012-03-21 | 330d? | 257d | finish no earlier than 2012-03-21 | S5 | 2640h | 132h | QoS_SSL | PCG-26 | Nokia Siemens Networks, Huawei | Gerald.Goermer@nsn.com, shan.mingjun@huawei.com | Rel-11 | SP-50 | Dionisio |
| 44 | 17 | **Optimized Service Charging and Allocation of Resources in IMS whilst Roaming** | 321d? | 2010-09-23 A | 2011-12-15 | 31% | 222.35d? | 2010-09-23 | 2011-12-15 | 321d? | 326d |  | S1,S2 | 9232h | 2837.18h | OSCAR | PCG-25 | Vodafone | mona.mustapha@vodafone.com | Rel-11 | SP-49 | Alain |
| 45 | 17.1 | TR on Stage 2 aspects of Optimized Service Charging and Allocation of Resources in IMS whilst Roaming | 256d? | 2010-09-23 A | 2011-09-15 | 30% | 179.2d? | 2010-09-23 | 2011-09-15 | 256d? | 391d | finish no earlier than 2011-09-15 | S2 | 2048h | 614.4h | OSCAR | PCG-25 | Vodafone | Susana.Sabater@vodafone.com | Rel-11 | SP-49 | Maurice |
| 46 | 17.2 | Stage 1 for Optimized Service Charging and Allocation of Resources in IMS whilst Roaming | 256d? | 2010-09-23 A | 2011-09-15 | 70% | 76.8d? | 2010-09-23 | 2011-09-15 | 256d? | 391d | finish no earlier than 2011-09-15 | S1 | 2048h | 1433.6h | OSCAR | PCG-25 | Vodafone | mona.mustapha@vodafone.com | Rel-11 | SP-49 | Alain |
| 47 | 17.3 | Stage 2 for Optimized Service Charging and Allocation of Resources in IMS whilst Roaming | 321d? | 2010-09-23 | 2011-12-15 |  |  | 2010-09-23 | 2011-12-15 | 321d? | 326d | finish no earlier than 2011-12-15 | S2 | 2568h |  | OSCAR | PCG-25 | Vodafone | Susana.Sabater@vodafone.com | Rel-11 | SP-49 | Maurice |
| 48 | 18 | **Non Voice Emergency Services** | 196d? | 2010-12-16 | 2011-09-15 |  |  | 2010-12-16 | 2011-09-15 | 196d? | 391d |  | S1 | 3136h |  | NOVES | PCG-26 | Qualcomm | dwilliams@qualcomm.com | Rel-11 | SP-50 | Alain |
| 49 | 18.1 | Stage 1 for NOVES | 196d? | 2010-12-16 | 2011-09-15 |  |  | 2010-12-16 | 2011-09-15 | 196d? | 391d | finish no earlier than 2011-09-15 | S1 | 1568h |  | NOVES | PCG-26 | Qualcomm | dwilliams@qualcomm.com | Rel-11 | SP-50 | Alain |

Notes:
- 26: SP#51 completion 03/11=>09/11. Analyze and if needed specify mechanisms for the priority handling of SRVCC with regard to LTE/EPC
- 27: SP#51 completion 03/11=>09/11 / Text3: 23.854
- 28: SP#51 completion 03/11=>12/11 / Text3: 23.216
- 29: Complete Stage 2 to support Single Radio VIDEO Call Continuity from E-UTRAN to UTRAN-CS based on the agreed architecture alternative in TR 23.886
- 30: SP#51 completion 03/11=>06/11. Triggered by Feasibility Study on video call handover capability in TR 23.886 UID_470048 Study on Single Radio Video Call Continuity for 3G-CS (FS_vSRVCC) / Text3: 23.203, 23.216, 23.237
- 31: SP#51 Stage 2 delayed by 6 months. Architecture solutions making Cell/PLMN ID (the UE is camped on) available to IMS nodes when the mobile operator needs to record this information either to fulfil legal obligations or for charging purposes.
- 32: SP#51 completion 03/11=>06/11 / Text3: 22.115
- 33: SP#51 completion 03/11=>09/11 / Text3: new TR 23.8bc
- 34: SP#51 completion 06/11=>12/11 / Text3: 23.060, 23.203, 23.228, 23.401
- 35: SP#51 updated WID SP-100638=>SP-110125. Stage 2/3. Stage 1 in SA1 TS 22.115 / Text3: 32.240 (Stage 2), 32.260, 32.298, 32.299
- 36: Linked to Rel-10 Local IP Access and Selected Internet IP Traffic Offload (LIPA_SIPTO)
- 37: SP#50 completion 12/10=>09/11 / Text3: 22.101, 22.220
- 38: Linked to UID_490030 SIPTO Service Continuity of IP Data Session (SIPTO_SC), UID_450035 Local IP Access and Selected IP Traffic Offload (LIPA_SIPTO), UID_460026 Support BBF Accesses Interworking (BBAI)
- 39: - / Text3: 23.060, 23.401, new TR 23.859
- 40: SP#51 updated WID SP-100773=>SP-110086 (added SA2 part)
- 41: SP#51 updated WID SP-100773=>SP-110086. Use cases & service requirements to allow: 1) modification of QoS based on subscribers spending limits 2) enforcing of spending limits for roaming subscribers without having dedicated support in the visited network / Text3: 22.115
- 42: SP#51 updated WID SP-100773=>SP-110086 (added SA2 part) / Text3: 23.203
- 43: SP#51 updated WID SP-100773=>SP-110086 (added SA2 part). Stage 3: Linked to CT3 TS 29.079 OMR within the IMS; Stage 3 (UID_480110) / Text3: Stage 2 (32.240, 32.296), Stage 3 (TS 32.29x for protocol specification)
- 44: SP#50 updated WID SP-100587=>SP-100701. Triggered by S1-102236/GSMA RILTE 10_007r1 (IREG LS_038 to 3GPP on Optimal Media Routing drawbacks)
- 45: SP#50 updated WID SP-100587=>SP-100701 / Text3: new TR 23.849
- 46: SP#50 completion 12/10=>09/11 / Text3: 22.115, 22.173
- 47: SP#50 updated WID SP-100587=>SP-100701 / Text3: TBD
- 48: Triggered by SA1 Rel-11 TR 22.871 Study on Non Voice Emergency Services (FS_NOVES)
- 49: - / Text3: 22.101

| ID | WBS | Task | Duration | Start | Finish | Complete | Remaining | Baseline start | Baseline finish | Baseline duration | Total slack | Constraint | Resources | Work | Actual work | Text1 | Text2 | Text4 | Text5 | Text6 | Text7 | Text8 |
| --- | --- | --- | --- | --- | --- | --- | --- | --- | --- | --- | --- | --- | --- | --- | --- | --- | --- | --- | --- | --- | --- | --- |
| 50 | 19 | **Interworking between Mobile Operators using the Evolved Packet System and Data Application Providers** | 125d? | 2010-12-16 A | 2011-06-08 | 90% | 12.5d? | 2010-12-16 | 2011-06-08 | 125d? | 462d |  | S1 | 2000h | 1800h | MOSAP | PCG-26 | Cisco | Vojislav Vucetic (vvucetic@cisco.com) | Rel-11 | SP-50 | Alain |
| 51 | 19.1 | Stage 1 for MOSAP | 125d? | 2010-12-16 A | 2011-06-08 | 90% | 12.5d? | 2010-12-16 | 2011-06-08 | 125d? | 462d | finish no earlier than 2011-06-08 | S1 | 1000h | 900h | MOSAP | PCG-26 | Cisco | Vojislav Vucetic (vvucetic@cisco.com) | Rel-11 | SP-50 | Alain |
| 52 | 20 | **Service Awareness and Privacy Policies** | 303.15d? | 2010-10-12 A | 2011-12-09 | 46% | 163.14d? | 2010-10-12 | 2011-12-09 | 303.15d? | 330d |  | S2,S1,C3 | 4936h | 1330.12h | SAPP | PCG-26 | Allot Communications | Alla Goldner (agoldner@llot.com) | Rel-11 | SP-50 | Maurice |
| 53 | 20.1 | Stage 1 for Service Awareness and Privacy Policies | 46.15d? | 2010-10-12 A | 2010-12-15 A | 100% |  | 2010-10-12 | 2010-12-15 | 46.15d? |  | finish no earlier than 2010-12-15 | S1 | 369.2h | 369.2h | SAPP | PCG-26 | Allot Communications | Alla Goldner (agoldner@llot.com) | Rel-11 | SP-50 | Maurice |
| 54 | 20.2 | Stage 2 for Service Awareness and Privacy Policies | 122.85d? | 2010-10-15 A | 2011-06-08 | 90% | 12.29d? | 2010-10-15 | 2011-06-08 | 122.85d? | 462d | finish no earlier than 2011-06-08 | S2 | 982.8h | 884.52h | SAPP | PCG-26 | Allot Communications | Alla Goldner (agoldner@llot.com) | Rel-11 | SP-50 | Maurice |
| 55 | 20.3 | CT3 part of Service Awareness and Privacy Policies | 191d? | 2011-03-18 A | 2011-12-09 | 5% | 181.45d? | 2011-03-18 | 2011-12-09 | 191d? | 330d | finish no earlier than 2011-12-09 | C3 | 1528h | 76.4h | SAPP-CT3 | PCG-26 | Allot Communications | Alla Goldner (agoldner@llot.com) | Rel-11 | CP-51 | Jiwan |
| 56 | 21 | **VPLMN Autonomous CSG Roaming** | 305d? | 2010-10-15 | 2011-12-15 |  |  | 2010-10-15 | 2011-12-15 | 305d? | 326d |  | S2 | 4510.8h |  | VCSG | PCG-26 | Qualcomm | AC Mahendran (ac@qualcomm.com) | Rel-11 | SP-50 | Maurice |
| 57 | 21.1 | Stage 2 for VPLMN Autonomous CSG Roaming | 258.85d? | 2010-10-15 | 2011-12-15 |  |  | 2010-10-15 | 2011-12-15 | 258.85d? | 326d | finish no earlier than 2011-12-15 | S2 | 2070.8h |  | VCSG | PCG-26 | Qualcomm | AC Mahendran (ac@qualcomm.com) | Rel-11 | SP-50 | Maurice |
| 58 | 22 | **Support for 3GPP Voice Interworking with Enterprise IP-PBX** | 131d? | 2011-03-23 | 2011-09-21 |  |  | 2011-03-23 | 2011-09-21 | 131d? | 387d |  | S1 | 2096h |  | VINE | PCG-26 | Tatara Systems | Phillip Brown (pbrown@tatarasystems.com) | Rel-11 | SP-51 | Alain |
| 59 | 22.1 | Stage 1 for Support for 3GPP Voice Interworking with Enterprise IP-PBX | 131d? | 2011-03-23 | 2011-09-21 |  |  | 2011-03-23 | 2011-09-21 | 131d? | 387d | finish no earlier than 2011-09-21 | S1 | 1048h |  | VINE | PCG-26 | Tatara Systems | Phillip Brown (pbrown@tatarasystems.com) | Rel-11 | SP-51 | Alain |
| 60 | 23 | **Data Identification in Access Network Discovery and Selection Function (ANDSF)** | 192d? | 2011-03-23 | 2011-12-15 |  |  | 2011-03-23 | 2011-12-15 | 192d? | 326d |  | S2 | 4120h |  | DIDA | PCG-26 | Qualcomm | Gerardo Giaretta (gerardo@qualcomm.com) | Rel-11 | SP-51 | Maurice |
| 61 | 23.1 | TR on Stage 2 for Data Identification in ANDSF | 131d? | 2011-03-23 | 2011-09-21 |  |  | 2011-03-23 | 2011-09-21 | 131d? | 387d | finish no earlier than 2011-09-21 | S2 | 1048h |  | DIDA | PCG-26 | Qualcomm | Gerardo Giaretta (gerardo@qualcomm.com) | Rel-11 | SP-51 | Maurice |
| 62 | 23.2 | Stage 2 for Data Identification in ANDSF | 192d? | 2011-03-23 | 2011-12-15 |  |  | 2011-03-23 | 2011-12-15 | 192d? | 326d | finish no earlier than 2011-12-15 | S2 | 1536h |  | DIDA | PCG-26 | Qualcomm | Gerardo Giaretta (gerardo@qualcomm.com) | Rel-11 | SP-51 | Maurice |
| 63 | 24 | **Operator Policies for IP Interface Selection** | 192d? | 2011-03-23 | 2011-12-15 |  |  | 2011-03-23 | 2011-12-15 | 192d? | 326d |  | S2 | 4120h |  | OPIIS | PCG-26 | LG Electronics | saso.stojanovski@lge.com | Rel-11 | SP-51 | Maurice |
| 64 | 24.1 | TR on Stage 2 for Operator Policies for IP Interface Selection | 131d? | 2011-03-23 | 2011-09-21 |  |  | 2011-03-23 | 2011-09-21 | 131d? | 387d | finish no earlier than 2011-09-21 | S2 | 1048h |  | OPIIS | PCG-26 | LG Electronics | saso.stojanovski@lge.com | Rel-11 | SP-51 | Maurice |
| 65 | 24.2 | Stage 2 for Operator Policies for IP Interface Selection | 192d? | 2011-03-23 | 2011-12-15 |  |  | 2011-03-23 | 2011-12-15 | 192d? | 326d | finish no earlier than 2011-12-15 | S2 | 1536h |  | OPIIS | PCG-26 | LG Electronics | saso.stojanovski@lge.com | Rel-11 | SP-51 | Maurice |
| 66 | 25 | **LOcation-Based Selection of gaTEways foR WLAN** | 192d? | 2011-03-23 | 2011-12-15 |  |  | 2011-03-23 | 2011-12-15 | 192d? | 326d |  | S2 | 3072h |  | LOBSTER | PCG-26 | ZTE | zhu.chunhui@zte.com.cn | Rel-11 | SP-51 | Maurice |
| 67 | 25.1 | Stage 2 for LOBSTER | 192d? | 2011-03-23 | 2011-12-15 |  |  | 2011-03-23 | 2011-12-15 | 192d? | 326d | finish no earlier than 2011-12-15 | S2 | 1536h |  | LOBSTER | PCG-26 | ZTE | zhu.chunhui@zte.com.cn | Rel-11 | SP-51 | Maurice |
| 68 | 26 | EEA3 and EIA3 (new Encryption & Integrity EPS security Algorithms) | 661d? | 2009-06-04 A | 2011-12-15 | 50% | 330.5d? | 2009-06-04 | 2011-12-15 | 661d? | 326d | finish no earlier than 2011-12-15 | S3 | 5288h | 2644h | EEA3_EIA3 | PCG-23 | CATR | Yuan Qi (yuanqi@mail.ritt.com.cn) | Rel-11 | SP-44 | Dionisio |
| 69 | 27 | Specification of Protection against Unsolicited Communication for IMS | 266d? | 2010-06-10 A | 2011-06-16 | 30% | 186.2d? | 2010-06-10 | 2011-06-16 | 266d? | 456d | finish no earlier than 2011-06-16 | S3 | 2128h | 638.4h | SPUCI | PCG-25 | NEC | Anand R. Prasad (anand@bq.jp.nec.com) | Rel-11 | SP-48 | Dionisio |
| 70 | 28 | H(e)NB security features for UE mobility scenarios (Stage 2) | 192d? | 2011-03-23 | 2011-12-15 |  |  | 2011-03-23 | 2011-12-15 | 192d? | 326d | finish no earlier than 2011-12-15 | S3 | 1536h |  | HNB_mob_Sec | PCG-26 | Huawei | Marcus Wong (mwong@huawei.com) | Rel-11 | SP-51 | Dionisio |
| 71 | 29 | **Security aspects of Public Warning System** | 188d? | 2011-03-23 | 2011-12-09 |  |  | 2011-03-23 | 2011-12-09 | 188d? | 330d |  | S3,S1,S2,C1,R2 | 7056h |  | PWS_Sec | PCG-26 | Ericsson, Huawei | john.mattsson@ericsson.com, Lydia Xu (xuyixian@huawei.com) | Rel-11 | SP-51 | Dionisio |
| 72 | 29.1 | Stage 1 for Security aspects of Public Warning System | 56d? | 2011-03-23 | 2011-06-08 |  |  | 2011-03-23 | 2011-06-08 | 56d? | 462d | finish no earlier than 2011-06-08 | S1 | 448h |  | PWS_Sec | PCG-26 | Ericsson, Huawei | john.mattsson@ericsson.com, Lydia Xu (xuyixian@huawei.com) | Rel-11 | SP-51 | Alain |
| 73 | 29.2 | Stage 2 for Security aspects of Public Warning System | 131d? | 2011-03-23 | 2011-09-21 |  |  | 2011-03-23 | 2011-09-21 | 131d? | 387d | finish no earlier than 2011-09-21 | S2 | 1048h |  | PWS_Sec | PCG-26 | Ericsson, Huawei | john.mattsson@ericsson.com, Lydia Xu (xuyixian@huawei.com) | Rel-11 | SP-51 | Maurice |
| 74 | 29.3 | SA3 part for Security aspects of Public Warning System | 131d? | 2011-03-23 | 2011-09-21 |  |  | 2011-03-23 | 2011-09-21 | 131d? | 387d | finish no earlier than 2011-09-21 | S3 | 1048h |  | PWS_Sec | PCG-26 | Ericsson, Huawei | john.mattsson@ericsson.com, Lydia Xu (xuyixian@huawei.com) | Rel-11 | SP-51 | Dionisio |
| 75 | 29.4 | CT1 part for Security aspects of Public Warning System | 188d? | 2011-03-23 | 2011-12-09 |  |  | 2011-03-23 | 2011-12-09 | 188d? | 330d | finish no earlier than 2011-12-09 | C1 | 1504h |  | PWS_Sec | PCG-26 | Ericsson, Huawei | john.mattsson@ericsson.com, Lydia Xu (xuyixian@huawei.com) | Rel-11 | SP-51 | Frederic |
| 76 | 29.5 | RAN2 part for Security aspects of Public Warning System | 188d? | 2011-03-23 | 2011-12-09 |  |  | 2011-03-23 | 2011-12-09 | 188d? | 330d | finish no earlier than 2011-12-09 | R2 | 1504h |  | PWS_Sec | PCG-26 | Ericsson, Huawei | john.mattsson@ericsson.com, Lydia Xu (xuyixian@huawei.com) | Rel-11 | SP-51 | Joern |

Notes:
- 50: Linked to Rel-10 Feature UID_500006 PEST
- 51: - / Text3: 22.278
- 52: SP#50 Stage 1 completed. Triggered by the SA1,SA2 Rel-10 TR 23.813 Study on Policy solutions and enhancements (FS_PP) UID_440047
- 53: SP#50 completed. For deep packet inspection (i.e. Traffic Detection Functionality) SA1 indicated that no new requirements are needed (see Objective of FS_PP SA1,SA2 Rel-10 Study on Policy solutions and enhancements UID_440047 TR 23.813) / Text3: TR 23.813
- 54: - / Text3: 23.203
- 55: Stage 3 to support Application Detection and Control Functionality. Update Gx / introduce Sd reference points and procedures. Update S9 reference point in roaming scenarios / Text3: Stage 3: 29.212, 29.213, 29.214, 29.215
- 56: Linked to Rel-10 UID_450053 Enhanced Home NodeB / eNodeB (EHNB). Implements Rel-9 requirements for CSG support in SA1 TS 22.220
- 57: - / Text3: 23.002, 23.060, 23.401
- 58: Triggered by Rel-11 TR 22.809 Study on Support for 3GPP Voice Interworking with Enterprise IP-PBX (FS_VINE) UID_480033
- 59: - / Text3: 22.228
- 60: Linked to Rel-10 IFOM (IP Flow Mobility and seamless WLAN offload) UID_450041. Defines IP flow mobility, seamless and non seamless WLAN offload and respective ANDSF extensions
- 61: - / Text3: TR 23.8xy Data identification in ANDSF
- 62: - / Text3: 23.402
- 63: Linked to Rel-10 IFOM (IP Flow Mobility and seamless WLAN offload) UID_450041 (non-seamless WLAN offload aspects) & Rel-11 LIMONET (LIPA Mobility and SIPTO at the Local Network) UID_500028 (support traffic offload at local network)
- 64: - / Text3: TR 23.8xy Operator Policies for IP Interface Selection
- 65: - / Text3: 23.060, 23.401, 23.402
- 66: Related to UID_350027 SAE for support for non-3GPP accesses (SAES-SA-FP_n3GPP). Enhancements to ePDG and PDN GW selection functions for S2b and S2c based on UE location
- 67: - / Text3: 23.402
- 68: SP#49 moved to Rel-11. Develop new EPS algorithms acceptable to regions such as China / Text3: 35.xxx (EEA3 & EIA3 Algorithm Specification, Implementers’ test data, Design and evaluation report, Final project report), 33.401 (SAE Security Architecture)
- 69: SP#49 moved to Rel-11. Continuation of Rel-9 UID_410027/410029. Builds on TR 33.937 Study of Mechanisms for PUCI / Text3: new TR 33.8xy, TS 33.abc
- 70: Add HeNB Security extensions to Extended H(e)NB Features (EHNBF) UID_450053 / Text3: 33.320 Stage 2
- 71: SA3 review of PWS security requirements in 22.268 (as per LS S1-102385) and current ETWS security solution (C1 23.041, S2 23.401, R2 36.331) concluded need for further joint S1,S2,S3,C1,R2 work adding HeNB Security extensions to EHNBF UID_450053
- 72: Add HeNB Security extensions to Extended H(e)NB Features (EHNBF) UID_450053 / Text3: 22.268 PWS requirements
- 73: Add HeNB Security extensions to Extended H(e)NB Features (EHNBF) UID_450053 / Text3: 23.401 GPRS enhancements for E-UTRAN access
- 74: Add HeNB Security extensions to Extended H(e)NB Features (EHNBF) UID_450053 / Text3: 33.102, 33.401, 43.020, FFS a New TS 33.xxx PWS security architecture)
- 75: Add HeNB Security extensions to Extended H(e)NB Features (EHNBF) UID_450053 / Text3: 23.041 Technical realization of Cell Broadcast Service (CBS)
- 76: Add HeNB Security extensions to Extended H(e)NB Features (EHNBF) UID_450053 / Text3: 36.331 E-UTRA Radio Resource Control (RRC) Protocol specification

| ID | WBS | Task | Duration | Start | Finish | Complete | Remaining | Baseline start | Baseline finish | Baseline duration | Total slack | Constraint | Resources | Work | Actual work | Text1 | Text2 | Text4 | Text6 | Text7 | Text8 | Text11 |
| --- | --- | --- | --- | --- | --- | --- | --- | --- | --- | --- | --- | --- | --- | --- | --- | --- | --- | --- | --- | --- | --- | --- |
| 77 | 30 | **Codec for Enhanced Voice Services** | 645d? | 2010-03-25 A | 2012-09-12 | 30% | 450.8d? | 2010-03-25 | 2012-09-12 | 645d? | 132d |  | S4,S1 | 10328h | 3109.59h | EVS_codec | PCG-24 | Huawei | Rel-11 | SP-47 | Paolo |  |
| 78 | 30.1 | Stage 1 for EVS_codec | 1d? | 2010-03-25 A | 2010-03-25 A | 100% |  | 2010-03-25 | 2010-03-25 | 1d? |  | start no earlier than 2010-03-25 | S1 | 8h | 8h | EVS_codec | PCG-24 | Huawei | Rel-11 | SP-47 | Paolo |  |
| 79 | 30.2 | Codec for Enhanced Voice Services | 645d? | 2010-03-25 A | 2012-09-12 | 30% | 451.5d? | 2010-03-25 | 2012-09-12 | 645d? | 132d | finish no earlier than 2012-09-12 | S4 | 5160h | 1548h | EVS_codec | PCG-24 | Huawei | Rel-11 | SP-47 | Paolo |  |
| 80 | 31 | **OAM&P 11** | 448d? | 2011-03-23 | 2012-12-07 |  |  | 2011-03-23 | 2012-12-07 | 448d? | 70d |  | S5 | 22664h |  | OAM11 | PCG-26 |  | Rel-11 | SP-51 | Dionisio |  |
| 81 | 31.1 | **Network Infrastructure Management** | 261d? | 2011-03-23 | 2012-03-21 |  |  | 2011-03-23 | 2012-03-21 | 261d? | 257d |  | S5 | 4176h |  | OAM11-NIM | PCG-26 |  | Rel-11 | SP-51 | Dionisio |  |
| 82 | 31.1.1 | IRP framework enhancements to support Management of Converged Networks | 261d? | 2011-03-23 | 2012-03-21 |  |  | 2011-03-23 | 2012-03-21 | 261d? | 257d | finish no earlier than 2012-03-21 | S5 | 2088h |  | OAM-FMC-IRP | PCG-26 | Ericsson, Nokia Siemens Networks | Rel-11 | SP-51 | Dionisio |  |
| 83 | 31.2 | **Performance Management** | 448d? | 2011-03-23 | 2012-12-07 |  |  | 2011-03-23 | 2012-12-07 | 448d? | 70d |  | S5 | 8696h |  | OAM11-PM | PCG-26 |  | Rel-11 | SP-51 | Dionisio |  |
| 84 | 31.2.1 | IMS Performance Management enhancements | 191d? | 2011-03-23 | 2011-12-14 |  |  | 2011-03-23 | 2011-12-14 | 191d? | 327d | finish no earlier than 2011-12-14 | S5 | 1528h |  | OAM-ePM-IMS | PCG-26 | ZTE | Rel-11 | SP-51 | Dionisio |  |
| 85 | 31.2.2 | Enhanced Management of UE based network performance measurements | 448d? | 2011-03-23 | 2012-12-07 |  |  | 2011-03-23 | 2012-12-07 | 448d? | 70d | finish no earlier than 2012-12-07 | S5 | 3584h |  | OAM-ePM-UE | PCG-26 | Huawei, Ericsson, Nokia Siemens Networks | Rel-11 | SP-51 | Dionisio |  |
| 86 | 31.3 | **Self-Organizing Networks (SON) - OAM aspects** | 388d? | 2011-03-23 | 2012-09-14 |  |  | 2011-03-23 | 2012-09-14 | 388d? | 130d |  | S5 | 6208h |  | OAM11-SON | PCG-26 |  | Rel-11 | SP-51 | Dionisio |  |
| 87 | 31.3.1 | UTRAN Self-Organizing Networks (SON) management | 388d? | 2011-03-23 | 2012-09-14 |  |  | 2011-03-23 | 2012-09-14 | 388d? | 130d | finish no earlier than 2012-09-14 | S5 | 3104h |  | OAM-SON-UTRAN | PCG-26 | Huawei | Rel-11 | SP-51 | Dionisio |  |
| 88 | 32 | **Charging Management small Enhancements** | 585d? | 2010-03-25 A | 2012-06-20 | 52% | 280.08d? | 2010-03-25 | 2012-06-20 | 585d? | 192d |  | S5 | 11464h | 5975.34h | CH11 | PCG-26 |  | Rel-11 | SP-51 | Dionisio |  |
| 89 | 32.1 | Add solutions for Rc - reference point within the Online Charging System (OCS) | 520d? | 2010-03-25 A | 2012-03-21 | 85% | 78d? | 2010-03-25 | 2012-03-21 | 520d? | 257d | finish no earlier than 2012-03-21 | S5 | 4160h | 3536h | CH-Rc | PCG-24 | Huawei | Rel-11 | SP-47 | Dionisio |  |
| 90 | 32.2 | Charging for Policy Enhancements for Sponsored Connectivity and Coherent Access to Policy related Data Bases | 328d? | 2011-03-21 | 2012-06-20 |  |  | 2011-03-21 | 2012-06-20 | 328d? | 192d | finish no earlier than 2012-06-20 | S5 | 2624h |  | PEST-CH | PCG-26 | Ericsson | Rel-11 | SP-51 | Dionisio |  |
| 91 | 33 | Transit Inter Operator Identifier for IMS Interconnection Charging in multi operator environment | 261d? | 2011-03-23 A | 2012-03-21 | 10% | 234.9d? | 2011-03-23 | 2012-03-21 | 261d? | 257d | finish no earlier than 2012-03-21 | S5 | 2088h | 208.8h | IOI_IMS_CH | PCG-26 | Deutsche Telekom | Rel-11 | SP-51 | Dionisio |  |
| 92 | 34 | **User Data Convergence - Data Model** | 447d? | 2010-03-25 A | 2011-12-09 | 16% | 375.74d? | 2010-03-25 | 2011-12-09 | 447d? | 330d |  | S1,C4 | 10360h | 1651.7h | UDC_DM | PCG-25 | Telecom Italia | Rel-11 | CP-48 | Kimmo |  |
| 93 | 34.1 | Stage 1 for UDC Data Model | 56d? | 2010-03-25 A | 2010-06-10 A | 100% |  | 2010-03-25 | 2010-06-10 | 56d? |  | finish no earlier than 2010-06-10 | S1 | 448h | 448h | UDC_DM | PCG-25 | Telecom Italia | Rel-11 | CP-48 | Alain |  |
| 94 | 34.2 | Study on User Data Convergence (UDC) Data Model | 396d? | 2010-06-04 A | 2011-12-09 | 20% | 316.8d? | 2010-06-04 | 2011-12-09 | 396d? | 330d | finish no earlier than 2011-12-09 | C4 | 3168h | 633.6h | UDC_DM | PCG-25 | Telecom Italia | Rel-11 | CP-48 | Kimmo |  |
| 95 | 34.3 | User Data Convergence (UDC) Data Model | 396d? | 2010-06-04 | 2011-12-09 |  |  | 2010-06-04 | 2011-12-09 | 396d? | 330d | finish no earlier than 2011-12-09 | C4 | 3168h |  | UDC_DM | PCG-25 | Telecom Italia | Rel-11 | CP-48 | Kimmo |  |
| 96 | 35 | Definition of the UICC Application for Hosting Party Module | 261d? | 2011-03-18 A | 2012-03-16 | 5% | 247.95d? | 2011-03-18 | 2012-03-16 | 261d? | 260d | finish no earlier than 2012-03-16 | C6 | 2088h | 104.4h | HPM_UICC | PCG-26 | Gemalto | Rel-11 | CP-51 | Xavier |  |
| 97 | 36 | **Network-Based Positioning Support in LTE** | 921d? | 2009-03-09 A | 2012-09-14 | 17% | 768.62d? | 2009-03-09 | 2012-09-14 | 921d? | 130d |  | R2,R1,R3,R4 | 16256h | 2689.65h | LCS_LTE-NBPS | PCG-22 | TruePosition | Rel-11 | RP-43 | Joern |  |
| 98 | 36.1 | Core part: Network-Based Positioning Support in LTE | 455.5d? | 2009-03-09 A | 2011-12-09 | 50% | 227.75d? | 2009-03-09 | 2011-12-09 | 455.5d? | 330d | start no earlier than 2009-03-09 | R2,R1,R3,R4 | 3644h | 1822h | LCS_LTE-NBPS-Core | PCG-22 | TruePosition | Rel-11 | RP-43 | Joern | RP-110092 |
| 99 | 36.2 | Perf. part: Network-Based Positioning Support in LTE | 921d? | 2009-03-09 | 2012-09-14 |  |  | 2009-03-09 | 2012-09-14 | 921d? | 130d | finish no earlier than 2012-09-14 | R4 | 7368h |  | LCS_LTE-NBPS-Perf | PCG-22 | TruePosition | Rel-11 | RP-43 | Joern | RP-110093 |
| 100 | 37 | UE Over The Air (Antenna) conformance testing methodology - Laptop mounted equipment Free Space test | 521d? | 2009-09-18 A | 2011-09-16 | 70% | 156.3d? | 2009-09-18 | 2011-09-16 | 521d? | 390d | finish no earlier than 2011-09-16 | R4 | 4168h | 2917.6h | UEAnt_FSTest | PCG-23 | CATR | Rel-11 | RP-45 | Issam | RP-110045 |

Notes:
- 77: SP#49 SA4 completion =>03/12. Moved to Rel-11. SP#47 Stage 1 completed. Develop EVS codec for EPS based on TR 22.813 recommendations. Triggered by UID_370045 Study on enhanced voice service requirements for EPS (TR 22.813) / Text5: anisse.taleb@huawei.com
- 78: SP#47 completed / Text3: 22.173 / Text5: anisse.taleb@huawei.com
- 79: SP#51 completion 12/11=>09/12 / Text3: 26.xyz, 26.xyz, 26.xyz, 26.xyz, 26.xyz, 26.xyz, 26.xyz, 26.xyz, 26.xyz, 26.xyz, 26.9yz, 26.xyz / Text5: anisse.taleb@huawei.com
- 80: -
- 81: -
- 82: Triggered by SA5 Studies TR 32.833, 32.828, 32.831. Produce a TS set to reduce FMC operators' CAPEX/OPEX and facilitate OSS to integrate the various NM services consumed into the so-called end-to-end view of the FMC network under management / Text3: 32.abc (Various existing NRM IRPs), 32.101, 32.152, 32.622, new TS (32.xy1, 32.xy2, 32.xy3) / Text5: thomas.tovinger@ericsson.com, olaf.pollakowski@nsn.com
- 83: -
- 84: - / Text3: 32.409 / Text5: arsalan.naeem@zte.com.cn
- 85: - / Text3: 32.421, 32.422, 32.423, 32.441, 32.442, 32.446 / Text5: Zou Lan (zlan@huawei.com), ulf.hubinette@ericsson.com, gyula.bodog@nsn.com
- 86: -
- 87: - / Text3: UTRA 32.405, 32.500, 32.511, 32.521, 32.522, 32.526, 32.642, 32.646 / Text5: kai.zhangkai@huawei.com
- 88: -
- 89: SP#51 completetion 03/11=>09/11. WID updated SP-100078=>SP-110129. Moved to Rel-11. Stage 3 (Stage 1 in 22.115). Triggered by Rel-10 TR 32.825 SA5 Study on Rc Reference Point Functionalities and Message Flows (UID_410044) / Text3: 32.296, 32.299 / Text5: shan.mingjun@huawei.com
- 90: SA5 can only start when CT3 (and SA2) finalized work 03/11 / Text3: 32.251, 32.298, 32.299 / Text5: patrik.teppo@@ericsson.com
- 91: Coordination needed with CT1 and CT3 / Text3: 32.240, 32.260, 32.298, 32.299 / Text5: matthias.seibel@telekom.de
- 92: CP#51 moved to Rel-11. Completion 03/11=>12/11. SP#48 Stage 1 completed as Rel-10 ! / Text5: mauro.ficaccio@telecomitalia.it
- 93: SP#48 completed / Text3: 22.101 / Text5: mauro.ficaccio@telecomitalia.it
- 94: CP#51 moved to Rel-11. Completion 03/11=>12/11 / Text3: new TR 29.935 / Text5: mauro.ficaccio@telecomitalia.it
- 95: CP#51 moved to Rel-11. Completion 03/11=>12/11 / Text3: 29.335 / Text5: mauro.ficaccio@telecomitalia.it
- 96: Defines Stage 3 for UICC application residing in Hosting Party Module / Text3: 31.102, new TS 31.1xy Characteristics of the Hosting Party Identity Module (HPIM) / Text5: Denis.Lheriteau@gemalto.com
- 97: RP#50 moved to Rel-11. Updated WID RP-100135=>RP-101446 (corresponding to RP-101298 Phase 1: only SRS-based UTDOA). Split into Core & Perf parts / Text3: LTE / Text5: terri.brooks@trueposition.com
- 98: RP#50 moved to Rel-11. Split into Core & Perf parts / Text3: 36.111, 36.133, 36.214, 36.300, 36.305, 36.331, 36.413, 36.423, 36.455 / Text5: terri.brooks@trueposition.com
- 99: RP#50 moved to Rel-11. Split into Core & Perf parts / Text3: 36.104, 36.111, 36.133, 36.141 / Text5: terri.brooks@trueposition.com
- 100: RP#51 moved to Rel-11 / Text3: UTRA 25.144, 25.914, 34.114 / Text5: Guo Lin (guolin@emcite.com)

| ID | WBS | Task | Duration | Start | Finish | Complete | Remaining | Baseline start | Baseline finish | Baseline duration | Total slack | Constraint | Resources | Work | Actual work | Text1 | Text2 | Text4 | Text5 | Text6 | Text7 | Text8 | Text11 |
| --- | --- | --- | --- | --- | --- | --- | --- | --- | --- | --- | --- | --- | --- | --- | --- | --- | --- | --- | --- | --- | --- | --- | --- |
| 101 | 38 | **LTE-Advanced Carrier Aggregation of Band 3 and Band 7** | 391d? | 2010-12-10 A | 2012-06-08 | 4% | 375.18d? | 2010-12-10 | 2012-06-08 | 391d? | 200d |  | R4 | 8384h | 339.37h | LTE_CA_B3_B7 | PCG-25 | TeliaSonera | Ralf.Schuh@TeliaSonera.com | Rel-11 | RP-48 | Issam | RP#51 moved to Rel-11 |
| 102 | 38.1 | Core part: LTE-Advanced Carrier Aggregation of Band 3 and Band 7 | 266d? | 2010-12-10 A | 2011-12-16 | 10% | 239.4d? | 2010-12-10 | 2011-12-16 | 266d? | 325d | start no earlier than 2010-12-10 | R4 | 2128h | 212.8h | LTE_CA_B3_B7-Core | PCG-25 | TeliaSonera | Ralf.Schuh@TeliaSonera.com | Rel-11 | RP-48 | Issam | RP-110081 |
| 103 | 38.2 | Perf. part: LTE-Advanced Carrier Aggregation of Band 3 and Band 7 | 391d? | 2010-12-10 | 2012-06-08 |  |  | 2010-12-10 | 2012-06-08 | 391d? | 200d | finish no earlier than 2012-06-08 | R4 | 3128h |  | LTE_CA_B3_B7-Perf | PCG-25 | TeliaSonera | Ralf.Schuh@TeliaSonera.com | Rel-11 | RP-48 | Issam | RP-110082 |
| 104 | 39 | **Service continuity, counting improvements and location information for MBMS for LTE** | 466d? | 2010-06-04 | 2012-03-16 |  |  | 2010-06-04 | 2012-03-16 | 466d? | 260d |  | R2,R3 | 7456h |  | MBMS_LTE_SC | PCG-25 | Huawei | derek.richards@huawei.com | Rel-11 | RP-48 | Joern |  |
| 105 | 39.1 | Core part: Service continuity, counting improvements and location information for MBMS for LTE | 466d? | 2010-06-04 | 2012-03-16 |  |  | 2010-06-04 | 2012-03-16 | 466d? | 260d | finish no earlier than 2012-03-16 | R2,R3 | 3728h |  | MBMS_LTE_SC-Core | PCG-25 | Huawei | derek.richards@huawei.com | Rel-11 | RP-48 | Joern | RP-110084 |
| 106 | 40 | **LTE Advanced Carrier Aggregation of Band 4 and Band 17** | 396d? | 2010-12-10 | 2012-06-15 |  |  | 2010-12-10 | 2012-06-15 | 396d? | 195d |  | R4 | 8464h |  | LTE_CA_B4_B17 | PCG-26 | AT&T | marc.grant@att.com | Rel-11 | RP-50 | Issam |  |
| 107 | 40.1 | Core part: LTE Advanced Carrier Aggregation of Band 4 and Band 17 | 266d? | 2010-12-10 | 2011-12-16 |  |  | 2010-12-10 | 2011-12-16 | 266d? | 325d | finish no earlier than 2011-12-16 | R4 | 2128h |  | LTE_CA_B4_B17-Core | PCG-26 | AT&T | marc.grant@att.com | Rel-11 | RP-50 | Issam | RP-110094 |
| 108 | 40.2 | Perf. part: LTE Advanced Carrier Aggregation of Band 4 and Band 17 | 396d? | 2010-12-10 | 2012-06-15 |  |  | 2010-12-10 | 2012-06-15 | 396d? | 195d | finish no earlier than 2012-06-15 | R4 | 3168h |  | LTE_CA_B4_B17-Perf | PCG-26 | AT&T | marc.grant@att.com | Rel-11 | RP-50 | Issam | RP-110095 |
| 109 | 41 | **LTE Advanced Carrier Aggregation of Band 4 and Band 13** | 396d? | 2010-12-10 A | 2012-06-15 | 4% | 380.1d? | 2010-12-10 | 2012-06-15 | 396d? | 195d |  | R4 | 8464h | 340.02h | LTE_CA_B4_B13 | PCG-26 | Ericsson | christian.bergljung@stericsson.com | Rel-11 | RP-50 | Issam |  |
| 110 | 41.1 | Core part: LTE Advanced Carrier Aggregation of Band 4 and Band 13 | 266d? | 2010-12-10 A | 2011-12-16 | 10% | 239.4d? | 2010-12-10 | 2011-12-16 | 266d? | 325d | finish no earlier than 2011-12-16 | R4 | 2128h | 212.8h | LTE_CA_B4_B13-Core | PCG-26 | Ericsson | christian.bergljung@stericsson.com | Rel-11 | RP-50 | Issam | RP-110096 |
| 111 | 41.2 | Perf. part: LTE Advanced Carrier Aggregation of Band 4 and Band 13 | 396d? | 2010-12-10 | 2012-06-15 |  |  | 2010-12-10 | 2012-06-15 | 396d? | 195d | finish no earlier than 2012-06-15 | R4 | 3168h |  | LTE_CA_B4_B13-Perf | PCG-26 | Ericsson | christian.bergljung@stericsson.com | Rel-11 | RP-50 | Issam | RP-110097 |
| 112 | 42 | **Eight carrier HSDPA** | 521d? | 2010-12-10 A | 2012-12-07 | 4% | 498.51d? | 2010-12-10 | 2012-12-07 | 521d? | 70d |  | R1,R2,R3,R4 | 10944h | 472.55h | 8C_HSDPA | PCG-26 | Ericsson | johan.hultell@ericsson.com | Rel-11 | RP-50 | Patrick |  |
| 113 | 42.1 | Core part: Eight carrier HSDPA | 396d? | 2010-12-10 A | 2012-06-15 | 10% | 356.4d? | 2010-12-10 | 2012-06-15 | 396d? | 195d | finish no earlier than 2012-06-15 | R1,R2,R3,R4 | 3168h | 316.8h | 8C_HSDPA-Core | PCG-26 | Ericsson | johan.hultell@ericsson.com | Rel-11 | RP-50 | Patrick | RP-110085 |
| 114 | 42.2 | Perf. part: Eight carrier HSDPA | 521d? | 2010-12-10 | 2012-12-07 |  |  | 2010-12-10 | 2012-12-07 | 521d? | 70d | finish no earlier than 2012-12-07 | R4 | 4168h |  | 8C_HSDPA-Perf | PCG-26 | Ericsson | johan.hultell@ericsson.com | Rel-11 | RP-50 | Issam | RP-110086 |
| 115 | 43 | **UE demodulation performance requirements under multiple-cell scenario for 1.28Mcps TDD** | 201d? | 2010-12-10 A | 2011-09-16 | 35% | 130.66d? | 2010-12-10 | 2011-09-16 | 201d? | 390d |  | R4 | 3216h | 1125.52h | LCR_TDD_UE_demod_mc | PCG-26 | China Mobile | Li Nan (linan@chinamobile.com) | Rel-11 | RP-50 | Issam |  |
| 116 | 43.1 | Perf. part: UE demodulation performance requirements under multiple-cell scenario for 1.28Mcps TDD | 201d? | 2010-12-10 A | 2011-09-16 | 35% | 130.65d? | 2010-12-10 | 2011-09-16 | 201d? | 390d | finish no earlier than 2011-09-16 | R4 | 1608h | 562.8h | LCR_TDD_UE_demod_mc-Perf | PCG-26 | China Mobile | Li Nan (linan@chinamobile.com) | Rel-11 | RP-50 | Issam | RP-110087 |
| 117 | 44 | **Uplink Transmit Diversity for HSPA** | 461d? | 2010-12-10 A | 2012-09-14 | 2% | 451.37d? | 2010-10-25 | 2012-09-14 | 494.1d? | 130d |  | R1,R4,R2,R3 | 16360h | 341.83h | HSPA_UL_TxDiv | PCG-26 | Huawei | Wang Zongjie | Rel-11 | RP-50 | Patrick |  |
| 118 | 44.1 | Core part: Uplink Transmit Diversity for HSPA - Closed Loop | 331d? | 2010-12-10 A | 2012-03-16 | 10% | 297.9d? | 2010-10-25 | 2012-03-16 | 331d? | 260d | finish no earlier than 2012-03-16 | R1,R4,R2,R3 | 2648h | 264.8h | HSPA_UL_TxDiv-CL-Core | PCG-26 | Huawei | Wang Zongjie | Rel-11 | RP-50 | Patrick | RP-110088 |
| 119 | 44.2 | Perf. part: Uplink Transmit Diversity for HSPA - Closed Loop | 461d? | 2010-12-10 | 2012-09-14 |  |  | 2010-12-10 | 2012-09-14 | 461d? | 130d | finish no earlier than 2012-09-14 | R4 | 3688h |  | HSPA_UL_TxDiv-CL-Perf | PCG-26 | Huawei | Wang Zongjie | Rel-11 | RP-50 | Issam | RP-110089 |
| 120 | 44.3 | Core part: Uplink Transmit Diversity for HSPA - Open Loop | 331d? | 2010-12-10 | 2012-03-16 |  |  | 2010-12-10 | 2012-03-16 | 331d? | 260d | finish no earlier than 2012-03-16 | R4,R1,R2,R3 | 2648h |  | HSPA_UL_TxDiv-OL-Core | PCG-26 | Huawei | Wang Zongjie | Rel-11 | RP-50 | Patrick | RP-110090 |
| 121 | 44.4 | Perf. part: Uplink Transmit Diversity for HSPA - Open Loop | 461d? | 2010-12-10 | 2012-09-14 |  |  | 2010-12-10 | 2012-09-14 | 461d? | 130d | finish no earlier than 2012-09-14 | R4 | 3688h |  | HSPA_UL_TxDiv-OL-Perf | PCG-26 | Huawei | Wang Zongjie | Rel-11 | RP-50 | Issam | RP-110091 |
| 122 | 45 | **Introduction of New Configuration for 4C-HSDPA** | 326d? | 2011-03-18 | 2012-06-15 |  |  | 2011-03-18 | 2012-06-15 | 326d? | 195d |  | R4,R2 | 6744h |  | 4C_HSDPA_Config | PCG-26 | Telus Communications | Jorge Delrio | Rel-11 | RP-51 | Issam |  |
| 123 | 45.1 | Core part: Introduction of New Configuration for 4C-HSDPA | 191d? | 2011-03-18 | 2011-12-09 |  |  | 2011-03-18 | 2011-12-09 | 191d? | 330d | finish no earlier than 2011-12-09 | R4,R2 | 1528h |  | 4C_HSDPA_Config-Core | PCG-26 | Telus Communications | Jorge Delrio | Rel-11 | RP-51 | Issam |  |
| 124 | 45.2 | Perf. part: Introduction of New Configuration for 4C-HSDPA | 326d? | 2011-03-18 | 2012-06-15 |  |  | 2011-03-18 | 2012-06-15 | 326d? | 195d | finish no earlier than 2012-06-15 | R4,R2 | 2608h |  | 4C_HSDPA_Config-Perf | PCG-26 | Telus Communications | Jorge Delrio | Rel-11 | RP-51 | Issam |  |

Notes:
- 101: RP#51 moved to Rel-11. In Europe Band 3, Band 7 and Band 20 are interesting for LTE and LTE-Advanced deployment. Different CA combinations for these bands are of high priority for Region 1. This work covers the Band 3 and Band 7 combination / Text3: LTE
- 102: RP#51 moved to Rel-11 / Text3: 36.101, 36.104, 36.113, 36.124, 36.133, 36.141, 36.307, 36.331, new TR 36.cde (LTE-Advanced CA of Band 3 and Band 7 for DL/UL with 40 MHz/20 MHz)
- 103: RP#51 completion 12/11=>06/12 / Text3: 36.101, 36.104, 36.133, 36.307, new TR 36.cde (LTE-Advanced CA of Band 3 and Band 7 for DL/UL with 40 MHz/20 MHz)
- 104: RP#51 completion 06/11=>03/12 (Moved to Rel-11). WID updated RP-100690=>RP-110402 / Text3: LTE
- 105: RP#51 completion 06/11=>03/12 (Moved to Rel-11. On hold in RAN3 until RAN2 makes progress). WID updated RP-100690=>RP-110402 / Text3: 25.446, 36.300, 36.304, 36.321, 36.322, 36.323, 36.331, 36.440, 36.441, 36.442, 36.443, 36.444, 36.445
- 106: Stage 3 / Text3: LTE
- 107: - / Text3: 36.101, 36.104, 36.133, 36.141, 36.307, new TR 36.8xy (LTE-Advanced CA of Band 4 and Band 13 for the DL/UL with 20 MHz/10 MHz), TR 36.8ab (LTE-Advanced CA of Band 4 and Band 13 for the DL/UL with 20 MHz/20 MHz)
- 108: - / Text3: 36.101, 36.104, 36.133, 36.307
- 109: Stage 3 / Text3: LTE
- 110: - / Text3: 36.101, 36.104, 36.133, 36.307, new TR 36.8xy (LTE-Advanced CA of Band 4 and Band 13 for the DL/UL with 20 MHz/10 MHz), TR 36.8ab (LTE-Advanced CA of Band 4 and Band 13 for the DL/UL with 20 MHz/20 MHz)
- 111: - / Text3: 36.101, 36.104, 36.133, 36.141, 36.307
- 112: Stage 3 / Text3: UTRA
- 113: - / Text3: 25.101, 25.104, 25.133, 25.211, 25.212, 25.213, 25.214, 25.215, 25.308, 25.331, 25.423, 25.433, 26.306
- 114: - / Text3: 25.101, 25.104, 25.133, 25.141
- 115: Stage 3 / Text3: UTRA
- 116: - / Text3: 25.102
- 117: Stage 2/3 / Text3: UTRA
- 118: RP#51 updated WID RP-101438=>RP-110374 (Changed lead WG) / Text3: 25.101, 25.104, 25.133, 25.211, 25.212, 25.213, 25.214, 25.215, 25.306, 25.319, 25.321, 25.331, 25.423, 25.433
- 119: - / Text3: 25.101, 25.104, 25.133, 25.141
- 120: RP#51 updated WID RP-101438=>RP-110374 (Changed lead WG) / Text3: 25.101, 25.133, 25.306, 25.319, 25.321, 25.331, 25.423, 25.433
- 121: - / Text3: 25.101, 25.133
- 122: - / Text3: UTRA
- 123: - / Text3: 25.101, 25.104, 25.141, 25.317
- 124: - / Text3: 25.101, 25.104, 25.141, 25.317

| ID | WBS | Task | Duration | Start | Finish | Baseline start | Baseline finish | Baseline duration | Total slack | Constraint | Resources | Work | Text1 | Text2 | Text4 | Text5 | Text6 | Text7 | Text8 |
| --- | --- | --- | --- | --- | --- | --- | --- | --- | --- | --- | --- | --- | --- | --- | --- | --- | --- | --- | --- |
| 125 | 46 | **Non-contiguous 4C-HSDPA operation** | 451d? | 2011-03-18 | 2012-12-07 | 2011-03-18 | 2012-12-07 | 451d? | 70d |  | R4,R2,R3 | 9824h | NC_4C_HSDPA | PCG-26 | Ericsson | Muhammad Kazmi | Rel-11 | RP-51 | Issam |
| 126 | 46.1 | Core part: Non-contiguous 4C-HSDPA operation | 326d? | 2011-03-18 | 2012-06-15 | 2011-03-18 | 2012-06-15 | 326d? | 195d | finish no earlier than 2012-06-15 | R4,R2,R3 | 2608h | NC_4C_HSDPA-Core | PCG-26 | Ericsson | Muhammad Kazmi | Rel-11 | RP-51 | Issam |
| 127 | 46.2 | Perf. part: Non-contiguous 4C-HSDPA operation | 451d? | 2011-03-18 | 2012-12-07 | 2011-03-18 | 2012-12-07 | 451d? | 70d | finish no earlier than 2012-12-07 | R4 | 3608h | NC_4C_HSDPA-Perf | PCG-26 | Ericsson | Muhammad Kazmi | Rel-11 | RP-51 | Issam |
| 128 | 47 | **Further Enhancements to CELL_FACH** | 451d? | 2011-03-18 | 2012-12-07 | 2011-03-18 | 2012-12-07 | 451d? | 70d |  | R1,R2,R3,R4 | 9824h | eCELL_FACH | PCG-26 | Qualcomm | Ravi Agarwal | Rel-11 | RP-51 | Patrick |
| 129 | 47.1 | Core part: Further Enhancements to CELL_FACH | 326d? | 2011-03-18 | 2012-06-15 | 2011-03-18 | 2012-06-15 | 326d? | 195d | finish no earlier than 2012-06-15 | R2,R1,R3,R4 | 2608h | eCELL_FACH-Core | PCG-26 | Qualcomm | Ravi Agarwal | Rel-11 | RP-51 | Joern |
| 130 | 47.2 | Perf. part: Further Enhancements to CELL_FACH | 451d? | 2011-03-18 | 2012-12-07 | 2011-03-18 | 2012-12-07 | 451d? | 70d | finish no earlier than 2012-12-07 | R4 | 3608h | eCELL_FACH-Perf | PCG-26 | Qualcomm | Heechoon Lee | Rel-11 | RP-51 | Issam |
| 131 | 48 | **Further Enhanced Non CA-based ICIC for LTE** | 326d? | 2011-03-18 | 2012-06-15 | 2011-03-18 | 2012-06-15 | 326d? | 195d |  | R1,R2,R3,R4 | 7824h | eICIC_enh_LTE | PCG-26 | China Mobile | Xiaodong Xu (xuxiaodong@chinamobile.com) | Rel-11 | RP-51 | Patrick |
| 132 | 48.1 | Core part: Further Enhanced Non CA-based ICIC for LTE | 326d? | 2011-03-18 | 2012-06-15 | 2011-03-18 | 2012-06-15 | 326d? | 195d | finish no earlier than 2012-06-15 | R1,R2,R3,R4 | 2608h | eICIC_enh_LTE-Core | PCG-26 | China Mobile | Xiaodong Xu (xuxiaodong@chinamobile.com) | Rel-11 | RP-51 | Patrick |
| 133 | 48.2 | Perf. part: Further Enhanced Non CA-based ICIC for LTE | 326d? | 2011-03-18 | 2012-06-15 | 2011-03-18 | 2012-06-15 | 326d? | 195d | finish no earlier than 2012-06-15 | R4 | 2608h | eICIC_enh_LTE-Perf | PCG-26 | China Mobile | Xiaodong Xu (xuxiaodong@chinamobile.com) | Rel-11 | RP-51 | Issam |
| 134 | 49 | **LTE Carrier Aggregation Enhancements** | 521d? | 2011-03-18 | 2013-03-15 | 2011-03-18 | 2013-03-15 | 521d? | 0d |  | R1,R2,R3,R4 | 11464h | LTE_eCA | PCG-26 | Nokia | Lars Lindh | Rel-11 | RP-51 | Patrick |
| 135 | 49.1 | Core part: LTE Carrier Aggregation Enhancements | 391d? | 2011-03-18 | 2012-09-14 | 2011-03-18 | 2012-09-14 | 391d? | 130d | finish no earlier than 2012-09-14 | R1,R2,R3,R4 | 3128h | LTE_eCA-Core | PCG-26 | Nokia | Lars Lindh | Rel-11 | RP-51 | Patrick |
| 136 | 49.2 | Perf. part: LTE Carrier Aggregation Enhancements | 521d? | 2011-03-18 | 2013-03-15 | 2011-03-18 | 2013-03-15 | 521d? | 0d | finish no earlier than 2013-03-15 | R4 | 4168h | LTE_eCA-Perf | PCG-26 | Nokia | Lars Lindh | Rel-11 | RP-51 | Issam |
| 137 | 50 | **LTE Advanced Carrier Aggregation of Band 4 and Band 12** | 326d? | 2011-03-18 | 2012-06-15 | 2011-03-18 | 2012-06-15 | 326d? | 195d |  | R4,R2 | 6744h | LTE_CA_B4_B12 | PCG-26 | US Cellular | Sebastian THALANANY | Rel-11 | RP-51 | Issam |
| 138 | 50.1 | Core part: LTE Advanced Carrier Aggregation of Band 4 and Band 12 | 191d? | 2011-03-18 | 2011-12-09 | 2011-03-18 | 2011-12-09 | 191d? | 330d | finish no earlier than 2011-12-09 | R4,R2 | 1528h | LTE_CA_B4_B12-Core | PCG-26 | US Cellular | Sebastian THALANANY | Rel-11 | RP-51 | Issam |
| 139 | 50.2 | Perf. part: LTE Advanced Carrier Aggregation of Band 4 and Band 12 | 326d? | 2011-03-18 | 2012-06-15 | 2011-03-18 | 2012-06-15 | 326d? | 195d | finish no earlier than 2012-06-15 | R4,R2 | 2608h | LTE_CA_B4_B12-Perf | PCG-26 | US Cellular | Sebastian THALANANY | Rel-11 | RP-51 | Issam |
| 140 | 51 | **LTE Advanced Carrier Aggregation of Band 5 and Band 12** | 326d? | 2011-03-18 | 2012-06-15 | 2011-03-18 | 2012-06-15 | 326d? | 195d |  | R4,R2 | 6744h | LTE_CA_B5_B12 | PCG-26 | US Cellular | Sebastian THALANANY | Rel-11 | RP-51 | Issam |
| 141 | 51.1 | Core part: LTE Advanced Carrier Aggregation of Band 5 and Band 12 | 191d? | 2011-03-18 | 2011-12-09 | 2011-03-18 | 2011-12-09 | 191d? | 330d | finish no earlier than 2011-12-09 | R4,R2 | 1528h | LTE_CA_B5_B12-Core | PCG-26 | US Cellular | Sebastian THALANANY | Rel-11 | RP-51 | Issam |
| 142 | 51.2 | Perf. part: LTE Advanced Carrier Aggregation of Band 5 and Band 12 | 326d? | 2011-03-18 | 2012-06-15 | 2011-03-18 | 2012-06-15 | 326d? | 195d | finish no earlier than 2012-06-15 | R4,R2 | 2608h | LTE_CA_B5_B12-Perf | PCG-26 | US Cellular | Sebastian THALANANY | Rel-11 | RP-51 | Issam |
| 143 | 52 | **LTE Advanced Carrier Aggregation of Band 20 and Band 7** | 326d? | 2011-03-18 | 2012-06-15 | 2011-03-18 | 2012-06-15 | 326d? | 195d |  | R4 | 6744h | LTE_CA_B20_B7 | PCG-26 | Huawei | Steven Chen | Rel-11 | RP-51 | Issam |
| 144 | 52.1 | Core part: LTE Advanced Carrier Aggregation of Band 20 and Band 7 | 191d? | 2011-03-18 | 2011-12-09 | 2011-03-18 | 2011-12-09 | 191d? | 330d | finish no earlier than 2011-12-09 | R4 | 1528h | LTE_CA_B20_B7-Core | PCG-26 | Huawei | Steven Chen | Rel-11 | RP-51 | Issam |
| 145 | 52.2 | Perf. part: LTE Advanced Carrier Aggregation of Band 20 and Band 7 | 326d? | 2011-03-18 | 2012-06-15 | 2011-03-18 | 2012-06-15 | 326d? | 195d | finish no earlier than 2012-06-15 | R4 | 2608h | LTE_CA_B20_B7-Perf | PCG-26 | Huawei | Steven Chen | Rel-11 | RP-51 | Issam |
| 146 | 53 | **LTE Advanced Carrier Aggregation Band 2 and Band 17** | 326d? | 2011-03-18 | 2012-06-15 | 2011-03-18 | 2012-06-15 | 326d? | 195d |  | R4 | 7824h | LTE_CA_B2_B17 | PCG-26 | AT&T | marc.grant@att.com | Rel-11 | RP-51 | Issam |
| 147 | 53.1 | Core part: LTE Advanced Carrier Aggregation Band 2 and Band 17 | 326d? | 2011-03-18 | 2012-06-15 | 2011-03-18 | 2012-06-15 | 326d? | 195d | finish no earlier than 2012-06-15 | R4 | 2608h | LTE_CA_B2_B17-Core | PCG-26 | AT&T | marc.grant@att.com | Rel-11 | RP-51 | Issam |
| 148 | 53.2 | Perf. part: LTE Advanced Carrier Aggregation Band 2 and Band 17 | 326d? | 2011-03-18 | 2012-06-15 | 2011-03-18 | 2012-06-15 | 326d? | 195d | finish no earlier than 2012-06-15 | R4 | 2608h | LTE_CA_B2_B17-Perf | PCG-26 | AT&T | marc.grant@att.com | Rel-11 | RP-51 | Issam |

Notes:
- 125: Stage 3 / Text3: UTRA
- 126: - / Text3: 25.101, 25.104, 25.133, 25.331, 25.423, 25.433
- 127: - / Text3: 25.101, 25.104, 25.133, 25.141
- 128: Stage 2/3 / Text3: UTRA
- 129: - / Text3: 25.101, 25.104, 25.133, 25.211, 25.212, 25.213, 25.214, 25.306, 25.308, 25.319, 25.321, 25.331, 25.423, 25.433
- 130: - / Text3: 25.101, 25.104, 25.133, 25.141
- 131: Stage 2/3 / Text3: LTE
- 132: - / Text3: 36.101, 36.133, 36.201, 36.211, 36.212, 36.213, 36.214, 36.300, 36.304, 36.321, 36.331, 36.413, 36.423
- 133: - / Text3: 36.101, 36.104, 36.133, 36.141
- 134: Stage 3. Triggered by Rel-11 UID_500015 Study on HSDPA Multipoint Transmission (FS_HSDPA_MP_TX) / Text3: LTE
- 135: Text3: 36.101, 36.104, 36.133, 36.201, 36.211, 36.212, 36.213, 36.300, 36.302, 36.306, 36.321, 36.331, 36.413, 36.423
- 136: Text3: 36.101, 36.104, 36.133, 36.141
- 137: Stage 3 (DL/UL 20/10MHz & DL/UL 20/20MHz) / Text3: LTE
- 138: - / Text3: 36.101, 36.104, 36.133, 36.141, 36.307, new TR 36.8xy (DL/UL 20/10MHz)
- 139: - / Text3: 36.101, 36.104, 36.133, 36.307
- 140: Stage 3 (DL/UL 20/10MHz & (DL/UL 20/20MHz) / Text3: LTE
- 141: - / Text3: 36.101, 36.104, 36.133, 36.141, 36.307, new TR 36.8xy (DL/UL 20/10MHz)
- 142: - / Text3: 36.101, 36.104, 36.133, 36.307
- 143: Stage 3 (DL/UL 30/20MHz; 1 UL active & DL/UL 30/30MHz; 2 UL active) / Text3: LTE
- 144: Text3: 36.101, 36.104, 36.133, 36.141, 36.307, 37.104, 37.141, new TR 36.8xy (DL/UL 30/20MHz; 1 UL active)
- 145: Text3: 36.101, 36.104, 36.133, 36.141, 36.307
- 146: Stage 3 / Text3: LTE
- 147: Text3: 36.101, 36.104, 36.133, 36.141, 36.307, new TR 36.8xy (DL/UL 10/15/20MHz)
- 148: Text3: 36.101, 36.104, 36.133, 36.307

| ID | WBS | Task | Duration | Start | Finish | Complete | Remaining | Baseline start | Baseline finish | Baseline duration | Total slack | Constraint | Resources | Work | Actual work | Text1 | Text2 | Text4 | Text6 | Text7 | Text8 | Text11 |
| --- | --- | --- | --- | --- | --- | --- | --- | --- | --- | --- | --- | --- | --- | --- | --- | --- | --- | --- | --- | --- | --- | --- |
| 149 | 54 | **LTE Advanced Carrier Aggregation Band 4 and Band 5** | 326d? | 2011-03-18 | 2012-06-15 |  |  | 2011-03-18 | 2012-06-15 | 326d? | 195d |  | R4 | 7824h |  | LTE_CA_B4_B5 | PCG-26 | AT&T | Rel-11 | RP-51 | Issam |  |
| 150 | 54.1 | Core part: LTE Advanced Carrier Aggregation Band 4 and Band 5 | 326d? | 2011-03-18 | 2012-06-15 |  |  | 2011-03-18 | 2012-06-15 | 326d? | 195d | finish no earlier than 2012-06-15 | R4 | 2608h |  | LTE_CA_B4_B5-Core | PCG-26 | AT&T | Rel-11 | RP-51 | Issam |  |
| 151 | 54.2 | Perf. part: LTE Advanced Carrier Aggregation Band 4 and Band 5 | 326d? | 2011-03-18 | 2012-06-15 |  |  | 2011-03-18 | 2012-06-15 | 326d? | 195d | finish no earlier than 2012-06-15 | R4 | 2608h |  | LTE_CA_B4_B5-Perf | PCG-26 | AT&T | Rel-11 | RP-51 | Issam |  |
| 152 | 55 | **LTE Advanced Carrier Aggregation Band 5 and Band 17** | 326d? | 2011-03-18 | 2012-06-15 |  |  | 2011-03-18 | 2012-06-15 | 326d? | 195d |  | R4 | 7824h |  | LTE_CA_B5_B17 | PCG-26 | AT&T | Rel-11 | RP-51 | Issam |  |
| 153 | 55.1 | Core part: LTE Advanced Carrier Aggregation Band 5 and Band 17 | 326d? | 2011-03-18 | 2012-06-15 |  |  | 2011-03-18 | 2012-06-15 | 326d? | 195d | finish no earlier than 2012-06-15 | R4 | 2608h |  | LTE_CA_B5_B17-Core | PCG-26 | AT&T | Rel-11 | RP-51 | Issam |  |
| 154 | 55.2 | Perf. part: LTE Advanced Carrier Aggregation Band 5 and Band 17 | 326d? | 2011-03-18 | 2012-06-15 |  |  | 2011-03-18 | 2012-06-15 | 326d? | 195d | finish no earlier than 2012-06-15 | R4 | 2608h |  | LTE_CA_B5_B17-Perf | PCG-26 | AT&T | Rel-11 | RP-51 | Issam |  |
| 155 | 56 | **New Band LTE Downlink FDD 716-728 MHz** | 326d? | 2011-03-18 | 2012-06-15 |  |  | 2011-03-18 | 2012-06-15 | 326d? | 195d |  | R4 | 7304h |  | LTE_DL_FDD700 | PCG-26 | AT&T | Rel-11 | RP-51 | Issam |  |
| 156 | 56.1 | Core part: New Band LTE Downlink FDD 716-728 MHz | 261d? | 2011-03-18 | 2012-03-16 |  |  | 2011-03-18 | 2012-03-16 | 261d? | 260d | finish no earlier than 2012-03-16 | R4 | 2088h |  | LTE_DL_FDD700-Core | PCG-26 | AT&T | Rel-11 | RP-51 | Issam |  |
| 157 | 56.2 | Perf. part: New Band LTE Downlink FDD 716-728 MHz | 326d? | 2011-03-18 | 2012-06-15 |  |  | 2011-03-18 | 2012-06-15 | 326d? | 195d | finish no earlier than 2012-06-15 | R4 | 2608h |  | LTE_DL_FDD700-Perf | PCG-26 | AT&T | Rel-11 | RP-51 | Issam |  |
| 158 | 57 | **LTE RAN Enhancements for Diverse Data Applications** | 326d? | 2011-03-18 | 2012-06-15 |  |  | 2011-03-18 | 2012-06-15 | 326d? | 195d |  | R2 | 5216h |  | LTE_eDDA | PCG-26 | Research In Motion | Rel-11 | RP-51 | Joern |  |
| 159 | 57.1 | Core part: LTE RAN Enhancements for Diverse Data Applications | 326d? | 2011-03-18 | 2012-06-15 |  |  | 2011-03-18 | 2012-06-15 | 326d? | 195d | finish no earlier than 2012-06-15 | R2 | 2608h |  | LTE_eDDA-Core | PCG-26 | Research In Motion | Rel-11 | RP-51 | Joern |  |
| 160 | 58 | **LTE E850 - Lower Band for Region 2 (non-US)** | 261d? | 2011-03-18 | 2012-03-16 |  |  | 2011-03-18 | 2012-03-16 | 261d? | 260d |  | R1,R2,R4 | 5704h |  | LTE_E850_LB | PCG-26 | NII Holdings | Rel-11 | RP-51 | Patrick |  |
| 161 | 58.1 | Core part: LTE E850 - Lower Band for Region 2 (non-US) | 191d? | 2011-03-18 | 2011-12-09 |  |  | 2011-03-18 | 2011-12-09 | 191d? | 330d | finish no earlier than 2011-12-09 | R1,R2,R4 | 1528h |  | LTE_E850_LB-Core | PCG-26 | NII Holdings | Rel-11 | RP-51 | Patrick |  |
| 162 | 58.2 | Perf. part: LTE E850 - Lower Band for Region 2 (non-US) | 261d? | 2011-03-18 | 2012-03-16 |  |  | 2011-03-18 | 2012-03-16 | 261d? | 260d | finish no earlier than 2012-03-16 | R4 | 2088h |  | LTE_E850_LB-Perf | PCG-26 | NII Holdings | Rel-11 | RP-51 | Issam |  |
| 163 | 59 | **Carrier based HetNet ICIC for LTE** | 191d? | 2011-03-18 | 2011-12-09 |  |  | 2011-03-18 | 2011-12-09 | 191d? | 330d |  | R3,R1,R2 | 3056h |  | LTE_CA_HetNet_ICIC | PCG-26 | Nokia Siemens Networks | Rel-11 | RP-51 | Juha |  |
| 164 | 59.1 | Core part: Carrier based HetNet ICIC for LTE | 191d? | 2011-03-18 | 2011-12-09 |  |  | 2011-03-18 | 2011-12-09 | 191d? | 330d | finish no earlier than 2011-12-09 | R3,R1,R2 | 1528h |  | LTE_CA_HetNet_ICIC-Core | PCG-26 | Nokia Siemens Networks | Rel-11 | RP-51 | Juha |  |
| 165 | 60 | **Full Support of Multi-Operator Core Network by GERAN** | 191d? | 2011-03-04 A | 2011-11-25 | 8% | 176.31d? | 2011-03-04 | 2011-11-25 | 191d? | 340d |  | G2,S2,C1 | 5500.8h | 305.6h | Full_MOCN-GERAN | PCG-26 | Alcatel-Lucent | Rel-11 | GP-49 | Paolo |  |
| 166 | 60.1 | GERAN part of Full Support of Multi-Operator Core Network by GERAN | 191d? | 2011-03-04 A | 2011-11-25 | 20% | 152.8d? | 2011-03-04 | 2011-11-25 | 191d? | 340d | finish no earlier than 2011-11-25 | G2 | 1528h | 305.6h | Full_MOCN-GERAN | PCG-26 | Alcatel-Lucent | Rel-11 | GP-49 | Gert |  |
| 167 | 60.2 | SA2 part of Full Support of Multi-Operator Core Network by GERAN | 152.8d? | 2011-03-04 | 2011-11-25 |  |  | 2011-03-04 | 2011-11-25 | 152.8d? | 340d | start no earlier than 2011-03-04 | S2 | 1222.4h |  | Full_MOCN-GERAN | PCG-26 | Alcatel-Lucent | Rel-11 | GP-49 | Maurice |  |
| 168 | 60.3 | CT1 part of Full Support of Multi-Operator Core Network by GERAN | 152.8d? | 2011-03-04 | 2011-11-25 |  |  | 2011-03-04 | 2011-11-25 | 152.8d? | 340d | start no earlier than 2011-03-04 | C1 | 1222.4h |  | Full_MOCN-GERAN | PCG-26 | Alcatel-Lucent | Rel-11 | GP-49 | Frederic |  |
| 169 | 61 | (Small) Technical Enhancements and Improvements for Rel-11 | 402d? | 2010-06-10 A | 2011-12-23 | 20% | 321.6d? | 2010-06-10 | 2011-12-23 | 402d? | 320d | finish no earlier than 2011-12-23 | All | 3216h | 643.2h | TEI11 | PCG-25 |  | Rel-11 | SP-48 | All |  |
| 170 | 62 | Release 11 Studies | 525d? | 2009-12-10 A | 2012-06-20 | 40% | 315d? | 2009-12-10 | 2012-06-20 | 525d? | 192d | finish no earlier than 2012-06-20 | SP,GP | 1086.4h |  |  |  |  | Rel-11 |  | All |  |
| 171 | 63 | Study on IMS Evolution | 786d? | 2008-09-18 A | 2011-09-21 | 80% | 157.2d? | 2008-09-18 | 2011-09-21 | 786d? | 387d | finish no earlier than 2011-09-21 | S2 | 6288h | 5030.4h | FS_eIMS | PCG-21 | China Mobile | Rel-11 | SP-41 | Maurice |  |
| 172 | 64 | Study on Multi Access PDN connectivity and IP flow Mobility | 786d? | 2008-09-18 A | 2011-09-21 | 75% | 196.5d? | 2008-09-18 | 2011-09-21 | 786d? | 387d | finish no earlier than 2011-09-21 | S2,S1 | 6288h | 4716h | FS_MAPIM | PCG-21 | Qualcomm | Rel-11 | SP-41 | Maurice |  |
| 173 | 65 | Study on Policy solutions and enhancements | 600d? | 2009-06-04 A | 2011-09-21 | 75% | 150d? | 2009-06-04 | 2011-09-21 | 600d? | 387d | finish no earlier than 2011-09-21 | S2,S1 | 4800h | 3600h | FS_PP | PCG-23 | AT&T | Rel-11 | SP-44 | Maurice |  |
| 174 | 66 | Study on IPv6 Migration | 600d? | 2009-06-04 A | 2011-09-21 | 80% | 120d? | 2009-06-04 | 2011-09-21 | 600d? | 387d | finish no earlier than 2011-09-21 | S2 | 4800h | 3840h | FS_IP6M | PCG-23 | China Mobile | Rel-11 | SP-44 | Maurice |  |
| 175 | 67 | Study on IMS based Peer-to-Peer Content Distribution Services | 284d? | 2009-05-12 A | 2010-06-10 A | 100% |  | 2009-05-12 | 2010-06-10 | 284d? |  | finish no earlier than 2010-06-10 | S1,S2 | 2272h | 2272h | FS_IMS_P2P | PCG-23 | China Mobile | Rel-11 | SP-45 | Alain |  |
| 176 | 68 | Study on IMS based Peer-to-Peer Content Distribution Services (Stage 2) | 321d? | 2010-09-23 A | 2011-12-15 | 20% | 256.8d? | 2010-09-23 | 2011-12-15 | 321d? | 326d | finish no earlier than 2011-12-15 | S2,S1 | 2568h | 513.6h | FS_IMS_P2P_CDS | PCG-25 | China Mobile | Rel-11 | SP-49 | Maurice |  |
| 177 | 69 | Study on Non Voice Emergency Services | 390d? | 2009-12-10 A | 2011-06-08 | 90% | 39d? | 2009-12-10 | 2011-06-08 | 390d? | 462d | finish no earlier than 2010-12-16 | S1 | 3120h | 2808h | FS_NOVES | PCG-24 | Qualcomm | Rel-11 | SP-46 | Alain |  |
| 178 | 70 | Study on UICC/USIM enhancements | 462d? | 2009-12-10 A | 2011-09-16 | 55% | 207.9d? | 2009-12-10 | 2011-09-16 | 462d? | 390d | finish no earlier than 2011-09-16 | S1 | 3696h | 2032.8h | FS_U2e | PCG-24 | Giesecke & Devrient | Rel-11 | SP-46 | Alain |  |
| 179 | 71 | Study on Single Radio Voice Call Continuity from UTRAN/GERAN to E-UTRAN/HSPA | 465d? | 2009-12-10 A | 2011-09-21 | 70% | 139.5d? | 2009-12-10 | 2011-09-21 | 465d? | 387d | finish no earlier than 2011-09-21 | S2 | 3720h | 2604h | FS_rSRVCC | PCG-24 | Orange | Rel-11 | SP-46 | Maurice |  |
| 180 | 72 | Study on Alternatives to E.164 for Machine-Type Communications | 387d? | 2010-03-25 A | 2011-09-16 | 25% | 290.25d? | 2010-03-25 | 2011-09-16 | 387d? | 390d | finish no earlier than 2011-09-16 | S1 | 3096h | 774h | FS_AMTC | PCG-24 | T-Mobile USA | Rel-11 | SP-47 | Alain |  |
| 181 | 73 | Study on enhancements for Machine-Type Communications (MTC) | 332d? | 2010-06-10 A | 2011-09-16 | 30% | 232.4d? | 2010-06-10 | 2011-09-16 | 332d? | 390d | finish no earlier than 2011-09-16 | S1 | 2656h | 796.8h | FS_MTCe | PCG-25 | Huawei | Rel-11 | SP-48 | Alain |  |
| 182 | 74 | Study on Support for 3GPP Voice Interworking with Enterprise IP-PBX | 130d? | 2010-09-23 A | 2011-03-23 A | 100% |  | 2010-09-23 | 2011-03-23 | 130d? |  | finish no earlier than 2011-02-21 | S1,S2 | 1040h | 1040h | FS_VINE | PCG-25 | Tatara Systems | Rel-11 | SP-48 | Alain |  |
| 183 | 75 | Study on IMS Network-Independent Public User Identities | 185d? | 2010-09-23 A | 2011-06-08 | 60% | 74d? | 2010-09-23 | 2011-06-08 | 185d? | 462d | finish no earlier than 2011-06-08 | S1 | 1480h | 888h | FS_INIPUI | PCG-25 | Vodafone | Rel-11 | SP-49 | Alain |  |
| 184 | 76 | Study on Integration of Single Sign-On (SSO) frameworks with 3GPP networks | 257d? | 2010-09-23 A | 2011-09-16 | 40% | 154.2d? | 2010-09-23 | 2011-09-16 | 257d? | 390d | finish no earlier than 2011-09-16 | S1 | 2056h | 822.4h | FS_SSO_Int | PCG-25 | InterDigital | Rel-11 | SP-49 | Alain |  |
| 185 | 77 | Study on Security aspects of Integration of Single Sign-On (SSO) frameworks with 3GPP networks | 196d? | 2010-12-16 A | 2011-09-15 | 20% | 156.8d? | 2010-12-16 | 2011-09-15 | 196d? | 391d | finish no earlier than 2011-09-15 | S3 | 1568h | 313.6h | FS_SSO_Int_Sec | PCG-26 | Ericsson | Rel-11 | SP-50 | Dionisio |  |
| 186 | 78 | Study on Core Network Overload solutions | 321d? | 2010-09-23 A | 2011-12-15 | 30% | 224.7d? | 2010-09-23 | 2011-12-15 | 321d? | 326d | finish no earlier than 2011-12-15 | S2 | 2568h | 770.4h | FS_CNO | PCG-25 | Huawei | Rel-11 | SP-49 | Maurice |  |
| 187 | 79 | Study on Continuity of Data Sessions to Local Networks | 197d? | 2010-12-16 A | 2011-09-16 | 20% | 157.6d? | 2010-12-16 | 2011-09-16 | 197d? | 390d | finish no earlier than 2011-09-16 | S1 | 1576h | 315.2h | FS_CSN | PCG-26 | NEC | Rel-11 | SP-50 | Alain |  |
| 188 | 80 | Study on Non-MTC Mobile Data Applications impacts | 197d? | 2010-12-16 A | 2011-09-16 | 25% | 147.75d? | 2010-12-16 | 2011-09-16 | 197d? | 390d | finish no earlier than 2011-09-16 | S1 | 1576h | 394h | FS_MODAI | PCG-26 | Huawei, China Mobile | Rel-11 | SP-50 | Alain |  |
| 189 | 81 | Study on System Enhancements for Energy Efficiency | 261d? | 2010-12-16 A | 2011-12-15 | 10% | 234.9d? | 2010-12-16 | 2011-12-15 | 261d? | 326d | finish no earlier than 2011-12-15 | S2 | 2088h | 208.8h | FS_SEEE | PCG-26 | Huawei | Rel-11 | SP-50 | Maurice |  |
| 190 | 82 | Study on S2a Mobility based On GTP and WLAN access to EPC | 192d? | 2011-03-23 | 2011-12-15 |  |  | 2011-03-23 | 2011-12-15 | 192d? | 326d | start no earlier than 2011-03-23 | S2 | 1536h |  | FS_SaMOG | PCG-26 | ZTE | Rel-11 | SP-51 | Maurice |  |
| 191 | 83 | Study on Roaming Architecture for Voice over IMS with Local Breakout | 192d? | 2011-03-23 | 2011-12-15 |  |  | 2011-03-23 | 2011-12-15 | 192d? | 326d | start no earlier than 2011-03-23 | S2 | 1536h |  | FS_RAVEL | PCG-26 | Deutsche Telekom | Rel-11 | SP-51 | Maurice |  |
| 192 | 84 | Study on UTRAN key management enhancements | 906d? | 2007-12-20 A | 2011-06-08 | 80% | 181.2d? | 2007-12-20 | 2011-06-08 | 906d? | 462d | finish no earlier than 2011-06-08 | S3 | 7248h | 5798.4h | FS_UKM | PCG-21 | Ericsson | Rel-11 | SP-38 | Dionisio |  |
| 193 | 85 | Study on Extended IMS Media Plane Security features | 260d? | 2010-06-10 A | 2011-06-08 | 45% | 143d? | 2010-06-10 | 2011-06-08 | 260d? | 462d | finish no earlier than 2011-06-08 | S3 | 2080h | 936h | FS_eMEDIASEC | PCG-25 | Vodafone | Rel-11 | SP-48 | Dionisio |  |
| 194 | 86 | Study on Single Sign On (SSO) Application Security for IMS - based on SIP Digest | 260d? | 2010-06-10 A | 2011-06-08 | 60% | 104d? | 2010-06-10 | 2011-06-08 | 260d? | 462d | finish no earlier than 2011-06-08 | S3 | 2080h | 1248h | FS_SSO_APS | PCG-25 | Nokia | Rel-11 | SP-48 | Dionisio |  |
| 195 | 87 | Study on version handling | 315d? | 2010-03-25 A | 2011-06-08 | 65% | 110.25d? | 2010-03-25 | 2011-06-08 | 315d? | 462d | finish no earlier than 2011-06-08 | S5 | 2520h | 1638h | FS_OAM_VH | PCG-24 | Ericsson | Rel-11 | SP-47 | Dionisio |  |
| 196 | 88 | Study on Management of Converged Networks | 395d? | 2010-06-10 A | 2011-12-14 | 16% | 331.8d? | 2010-06-10 | 2011-12-14 | 395d? | 327d | finish no earlier than 2011-12-14 | S5 | 3160h | 505.6h | FS_ManCon | PCG-25 | Nokia Siemens Networks | Rel-11 | SP-48 | Dionisio |  |
| 197 | 89 | Study on User Data Convergence (UDC) information model handling and provisioning: Example Use Cases | 320d? | 2010-09-23 A | 2011-12-14 | 20% | 256d? | 2010-09-23 | 2011-12-14 | 320d? | 327d | finish no earlier than 2011-12-14 | S5 | 2560h | 512h | FS_UDC_AppUseCase | PCG-25 | Alcatel-Lucent | Rel-11 | SP-49 | Dionisio |  |
| 198 | 90 | Study on OAM aspects of inter-RAT Energy Saving | 191d? | 2011-03-23 | 2011-12-14 |  |  | 2011-03-23 | 2011-12-14 | 191d? | 327d | start no earlier than 2011-03-23 | S5 | 1528h |  | FS_OAM_ES_iRAT | PCG-26 | Nokia Siemens Networks | Rel-11 | SP-51 | Dionisio |  |
| 199 | 91 | Study on management of Heterogeneous Networks | 191d? | 2011-03-23 | 2011-12-14 |  |  | 2011-03-23 | 2011-12-14 | 191d? | 327d | start no earlier than 2011-03-23 | S5 | 1528h |  | FS_OAM_HetNet | PCG-26 | Ericsson | Rel-11 | SP-51 | Dionisio |  |
| 200 | 92 | Study on impacts on UE-Core Network signalling from Energy Saving | 261d? | 2010-06-04 A | 2011-06-03 | 85% | 39.15d? | 2010-06-04 | 2011-06-03 | 261d? | 465d | finish no earlier than 2011-06-03 | C1 | 2088h | 1774.8h | FS_UE-CN_ES | PCG-25 | NEC | Rel-11 | CP-48 | Frederic |  |
| 201 | 93 | Study on EPC Nodes Restoration | 261d? | 2010-09-17 A | 2011-09-16 | 70% | 78.3d? | 2010-09-17 | 2011-09-16 | 261d? | 390d | finish no earlier than 2011-09-16 | C4 | 2088h | 1461.6h | FS_EPC_NR | PCG-25 | ZTE | Rel-11 | CP-49 | Kimmo |  |
| 202 | 94 | Study on GERAN improvements for Machine-Type Communications | 327.5d? | 2010-05-24 A | 2011-09-02 | 20% | 262d? | 2010-05-24 | 2011-09-02 | 327.5d? | 400d | finish no earlier than 2011-09-02 | G1,G2 | 2620h | 524h | FS_NIMTC_GERAN | PCG-24 | Ericsson | Rel-11 | GP-44 | Paolo |  |
| 203 | 95 | Study on Signal Precoding enhancements for EGPRS2 DL | 261d? | 2010-09-03 A | 2011-09-02 | 60% | 104.4d? | 2010-09-03 | 2011-09-02 | 261d? | 400d | finish no earlier than 2011-09-02 | G1,G2 | 2088h | 1252.8h | FS_SPEED | PCG-25 | Ericsson | Rel-11 | GP-46 | Paolo |  |
| 204 | 96 | Study on Solutions for GSM/EDGE BTS Energy Saving | 261d? | 2010-09-03 A | 2011-09-02 | 5% | 247.95d? | 2010-09-03 | 2011-09-02 | 261d? | 400d | finish no earlier than 2011-09-02 | G1,G2 | 2088h | 104.4h | FS_Energy_BTS | PCG-25 | Nokia Siemens Networks, Vodafone | Rel-11 | GP-47 | Paolo |  |
| 205 | 97 | Study on Measurement of Radiated Performance for MIMO and multi-antenna reception for HSPA and LTE terminals | 651.8d? | 2009-03-06 A | 2011-12-09 | 65% | 228.13d? | 2009-03-06 | 2011-12-09 | 651.8d? | 330d | finish no earlier than 2011-12-09 | R4 | 5214.4h | 3389.37h | FS_HSPA_LTE_measRP_MIMO_multi-antenna | PCG-22 | Vodafone | Rel-11 | RP-43 | Issam | RP-110098 |
| 206 | 98 | Study on Extending 850 MHz | 526d? | 2009-05-30 A | 2011-06-03 | 70% | 157.8d? | 2009-05-30 | 2011-06-03 | 526d? | 465d | finish no earlier than 2011-06-03 | R4 | 4208h | 2945.6h | FS_e850 | PCG-23 | Ericsson | Rel-11 | RP-44 | Issam | RP-110099 |
| 207 | 99 | Study on RAN improvements for Machine-Type Communications | 446d? | 2009-09-18 A | 2011-06-03 | 40% | 267.6d? | 2009-09-18 | 2011-06-03 | 446d? | 465d | finish no earlier than 2011-06-03 | R2,R1,R3,R4 | 3568h | 1427.2h | FS_NIMTC_RAN | PCG-23 | Huawei | Rel-11 | RP-45 | Joern | RP-110100 |
| 208 | 100 | Study on Coordinated Multi-Point operation for LTE | 200d? | 2010-12-10 A | 2011-09-15 | 20% | 160d? | 2010-12-10 | 2011-09-15 | 200d? | 391d | finish no earlier than 2011-09-15 | R1,R2,R3 | 1600h | 320h | FS_CoMP_LTE | PCG-24 | Samsung | Rel-11 | RP-47 | Patrick | RP-110101 |
| 209 | 101 | Study on Network Energy Saving for E-UTRAN | 316d? | 2010-02-02 A | 2011-06-03 | 90% | 31.6d? | 2010-02-02 | 2011-06-03 | 316d? | 465d | finish no earlier than 2011-06-03 | R3,R2 | 2528h | 2275.2h | FS_Energy_LTE | PCG-24 | China Mobile | Rel-11 | RP-47 | Juha | RP-110102 |
| 210 | 102 | Study on Signalling and procedure for interference avoidance for in-device coexistence | 261d? | 2010-06-04 A | 2011-06-03 | 80% | 52.2d? | 2010-06-04 | 2011-06-03 | 261d? | 465d | finish no earlier than 2011-06-03 | R2,R4 | 2088h | 1670.4h | FS_SPIA_IDC | PCG-25 | China Mobile | Rel-11 | RP-48 | Joern | RP-110103 |
| 211 | 103 | Study on UE Application Layer Data Throughput Performance | 200d? | 2010-12-10 A | 2011-09-15 | 5% | 190d? | 2010-12-10 | 2011-09-15 | 200d? | 391d | finish no earlier than 2011-09-15 | R5,R4 | 1600h | 80h | FS_UE_App_Data_Perf | PCG-26 | Spirent | Rel-11 | RP-50 | Ingbert | RP-110104 |
| 212 | 104 | Study on Uplink MIMO | 200d? | 2010-12-10 A | 2011-09-15 | 30% | 140d? | 2010-12-10 | 2011-09-15 | 200d? | 391d | finish no earlier than 2011-09-15 | R1 | 1600h | 480h | FS_UTRA_UL_MIMO | PCG-26 | Qualcomm | Rel-11 | RP-50 | Patrick | RP-110105 |
| 213 | 105 | Study on HSDPA Multipoint Transmission | 200d? | 2010-12-10 A | 2011-09-15 | 30% | 140d? | 2010-12-10 | 2011-09-15 | 200d? | 391d | finish no earlier than 2011-09-15 | R1,R2,R3 | 1600h | 480h | FS_HSDPA_MP_TX | PCG-26 | Nokia Siemens Networks | Rel-11 | RP-50 | Patrick | RP-110106 |
| 214 | 106 | Study on Inclusion of RF Pattern Matching Technologies as a positioning method in the E-UTRAN | 261d? | 2010-12-10 A | 2011-12-09 | 5% | 247.95d? | 2010-12-10 | 2011-12-09 | 261d? | 330d | finish no earlier than 2011-12-09 | R4 | 2088h | 104.4h | FS_LCS_LTE_RFPMT | PCG-26 | Polaris Wireless | Rel-11 | RP-50 | Issam | RP-110107 |
| 215 | 107 | Study on HetNet mobility improvements for LTE | 326d? | 2011-03-18 | 2012-06-15 |  |  | 2011-03-18 | 2012-06-15 | 326d? | 195d | finish no earlier than 2012-06-15 | R2,R1,R3,R4 | 2608h |  | FS_HetNet_eMOB_LTE | PCG-26 | Alcatel-Lucent | Rel-11 | RP-51 | Joern |  |
| 216 | 108 | Study on Enhanced Uplink Transmission for LTE | 191d? | 2011-03-18 | 2011-12-09 |  |  | 2011-03-18 | 2011-12-09 | 191d? | 330d | finish no earlier than 2011-12-09 | R1 | 1528h |  | FS_eUL_TX_LTE | PCG-26 | Huawei | Rel-11 | RP-51 | Patrick |  |
| 217 | 109 | Study on further enhancements for HNB and HeNB | 191d? | 2011-03-18 | 2011-12-09 |  |  | 2011-03-18 | 2011-12-09 | 191d? | 330d | start no earlier than 2011-03-18 | R3,R2 | 1528h |  | FS_EHNB_enh | PCG-26 | Alcatel-Lucent | Rel-11 | RP-51 | Juha |  |
| 218 | 110 | Study on further Downlink MIMO enhancements for LTE-Advanced | 191d? | 2011-03-18 | 2011-12-09 |  |  | 2011-03-18 | 2011-12-09 | 191d? | 330d | start no earlier than 2011-03-18 | R1 | 1528h |  | FS_LTE_eDL_MIMO_enh | PCG-26 | Alcatel-Lucent | Rel-11 | RP-51 | Patrick |  |

Notes:
- 149: Stage 3 / Text3: LTE / Text5: marc.grant@att.com
- 150: Text3: 36.101, 36.104, 36.133, 36.141, 36.307, new TR 36.8xy (DL/UL 10/15/20MHz) / Text5: marc.grant@att.com
- 151: Text3: 36.101, 36.104, 36.133, 36.307 / Text5: marc.grant@att.com
- 152: Stage 3 / Text3: LTE / Text5: marc.grant@att.com
- 153: Text3: 36.101, 36.104, 36.133, 36.141, 36.307, new TR 36.8xy (DL/UL 10/15/20MHz) / Text5: marc.grant@att.com
- 154: Text3: 36.101, 36.104, 36.133, 36.141, 36.307 / Text5: marc.grant@att.com
- 155: Stage 3 / Text3: LTE / Text5: marc.grant@att.com
- 156: Text3: 36.101, 36.104, 36.141, 36.307 / Text5: marc.grant@att.com
- 157: Text3: 36.101, 36.104, 36.133, 36.141, 36.307 / Text5: marc.grant@att.com
- 158: Stage 3 ? / Text3: LTE / Text5: Gordon Young (gyoung@rim.com)
- 159: Text3: 36.300, 36.321, 36.331 / Text5: Gordon Young (gyoung@rim.com)
- 160: Stage 3 / Text3: UTRA, LTE / Text5: bill.shvodian@nii.com
- 161: - / Text3: 25.461, 25.466, 36.101, 36.104, 36.113, 36.124, 36.133, 36.307, 36.331 / Text5: bill.shvodian@nii.com
- 162: - / Text3: 36.101, 36.104, 36.133, 36.141 / Text5: bill.shvodian@nii.com
- 163: Stage 2/3 / Text3: LTE / Text5: krzysztof.kordybach@nsn.com
- 164: - / Text3: 36.300, 36.413, 36.420, 36.423 / Text5: krzysztof.kordybach@nsn.com
- 165: GP#49 approved WID. Standardization of management of MOCN supporting MSs/UEs in GERAN. Continuation of Rel-10 MOCN-GERAN UID_490001 / Text3: GERAN 43.022, 44.018, 45.002 / Text5: michel.robert@alcatel-lucent.com
- 166: GP#49 approved WID / Text3: GERAN 43.022, 44.018, 45.002 / Text5: michel.robert@alcatel-lucent.com
- 167: GP#49 approved WID. SA2 Stage 2 TS 23.251 / Text3: GERAN 43.022, 44.018, 45.002 / Text5: michel.robert@alcatel-lucent.com
- 168: GP#49 approved WID. CT1 Stage 3 TS 24.008 / Text3: GERAN 43.022, 44.018, 45.002 / Text5: michel.robert@alcatel-lucent.com
- 169: SP#50 EU-Alert is introduced under Public Warning System in parallel with the already existing ETWS and CMAS. SA1 22.268 CR#9r1 adds EU-ALERT specific requirements & CT1 23.041 CRs#
- 170: -
- 171: SP#51 moved to Rel-11 / Text3: 23.812 / Text5: Li Gang (ligangyf@chinamobile.com), Yu Qing (yuqing@chinamobile.com)
- 172: SP#51 moved to Rel-11. Spin-off UID_430035 MAPCON and UID_450041 IFOM / Text3: 23.861 / Text5: Gerardo Giaretta (gerardog@qualcomm.com)
- 173: SP#51 moved to Rel-11 / Text3: 23.813 / Text5: farooq.bari@att.com
- 174: SP#51 moved to Rel-11 / Text3: 23.975 / Text5: Li Lianyuan (lilianyuan@chinamobile.com), Liu Hong (liuhongyfw@chinamobile.com)
- 175: SP#48 completed / Text3: 22.906 / Text5: Li Gang (ligangyf@chinamobile.com)
- 176: Triggered by TR 22.906 SA1 Study on IMS based Peer-to-Peer Content Distribution Services UID_450047 / Text3: 23.844 / Text5: Yu Qing (yuqing@chinamobile.com)
- 177: SP#51 completion 03/11=>06/11. Spin-off Feature UID_500030 Non Voice Emergency Services (NOVES) / Text3: 22.871 / Text5: dwilliams@qualcomm.com
- 178: SP#51 completion 03/11=>09/11. Triggered by GSMA Smart SIM and 3GNBK projects, and to evolve from traditional USAT to multimedia USIM toolkit support, particularly to Smart Card Web Server / Text3: 22.817 / Text5: Ilario ilario.macchi@gi-de.com
- 179: SP#51 moved to Rel-11. Study on "reverse direction" from UTRAN/GERAN to E-UTRAN/HSPA (Rel-8 SRVCC was in the other direction E-UTRAN/HSPA to GERAN/UTRAN) / Text3: 23.885 / Text5: delphin.barankanira@orange-ftgroup.com
- 180: SP#51 completion 06/11=>09/11. Determine an alternative to E.164 for identifying individual devices and route messages between those devices / Text3: 22.988 / Text5: gary.jones@T-Mobile.com
- 181: SP#51 completion 06/11=>09/11. Study Network improvements for MTC Device to MTC Device communications via one or more PLMNs (direct-mode communication between devices is out of scope), etc. Align also with ETSI TC M2M work. / Text3: 22.888 / Text5: laurence.meriau@huawei.com
- 182: SP#51 completed. Support Interworking between 3GPP networks and Enterprise environments to provide enterprise voice services via 3GPP mobile devices / Text3: 22.809 / Text5: Phillip Brown (pbrown@tatarasystems.com)
- 183: SP#51 completion 03/11=>06/11. TR 22.894 v100 for Information / Text3: 22.894 / Text5: mona.mustapha@vodafone.com
- 184: SP#51 completion 06/11=>09/11. Linked to SA3 Study on Single Sign On (SSO) Application Security for IMS - based on SIP Digest (UID_480048), SA3 TR 33.924 Extended Identity Management (GBA-IdM) and SA3 TR 33.980 (LibSec) / Text3: 22.895 / Text5: christopher.wallace@interdigital.com
- 185: Linked to SA1 FS_SSO_Int (Study Integration of SSO frameworks with 3GPP networks),SA3 FS_SSO_APS (Study SSO Application Security for IMS - based on SIP Digest),GBA-IdM (33.924),LIBSEC (33.980 Interworking of Liberty Alliance IFF, Identity Web SF and GAA) / Text3: 33.8xx / Text5: vesa.lehtovirta@ericsson.com
- 186: Linked to CT4 UID_490014 Study on EPC Nodes Restoration. Support from CT4 and RAN WGs is anticipated. / Text3: 23.843 / Text5: David Xiang (dxiang@huawei.com)
- 187: Linked to SA1 Rel-11 Feature UID_490030 SIPTO Service Continuity of IP Data Session (SIPTO_SC) / Text3: 22.896 / Text5: joerg.swetina@nw.neclab.eu
- 188: Linked to UID_490036 SA2 Rel-11 TR 23.843 Study on Core Network Overload solutions (FS_CNO) / Text3: 22.801 / Text5: Amar Deol (adeol@huawei.com), Gang Li
- 189: Linked to SA5, CT, (GE(RAN) studies on Energy saving & SA5 Rel-10 implementation Work Item on Energy Saving Management architectures and management solutions / Text3: 23.866 / Text5: frank.mademann@huawei.com
- 190: Linked to Rel-8 UID_350027 SAE for support for non-3GPP accesses, Rel-10 UID_480037 SMOG (S2b Mobility based on GTP), Rel-11 UID_4600026 BBAI (Support for BBF Accesses Interworking) / Text3: 23.8xy / Text5: zhu.chunhui@zte.com.cn
- 191: Linked to Rel-11 OSCAR (Optimized Service Charging and Allocation of Resources in IMS whilst Roaming) UID_490032. Related to LBO/home routing decision / Text3: 23.850 / Text5: michele.zarri@telekom.com
- 192: SP#51 completion 03/11=>06/11 (moved to Rel-11). SP#50 TR 33.859 v100 for Information / Text3: 33.859 / Text5: Karl Norrman
- 193: SP#51 completion 03/11=>06/11 (moved to Rel-11). Continuation of Rel-9 Feature UID_430036 IMS Media Plane Security (MEDIASEC). Study solutions and extensions to features and functionality described in TR 33.828 and TS 33.328. / Text3: 33.8xy / Text5: Peter.Howard@vodafone.com
- 194: SP#51 completion 03/11=>06/11 (moved to Rel-11). Study reuse of non-UICC credentials (in particular SIP Digest) to provide security for the access to applications. Provide reference material for IMS based non-UICC based SSO to applications / Text3: 33.914 / Text5: Silke.Holtmanns@nokia.com
- 195: SP#51 moved to Rel-11. Completion 03/11=>06/11 / Text3: 32.830 / Text5: thomas.tovinger@ericsson.com
- 196: SP#51 moved to Rel-11. Completion 03/11=>12/11 / Text3: 32.833 / Text5: olaf.pollakowski@nsn.com
- 197: SP#51 updated WID SP-100502=>SP-110127. Completion 03/11=>12/11 (moved to Rel-11) / Text3: 32.901 / Text5: Nick Mazzarella (njmazzarella@alcatel-lucent.com)
- 198: Triggered by Rel-10 UID_430044 TR 32.826 Study on Telecommunication Management; Energy Savings Management (FS_OAM_ESM) and UID_470037 OAM aspects of Energy Saving in Radio Networks (OAM-ES) / Text3: 32.8xy / Text5: clemens.suerbaum@nsn.com
- 199: - / Text3: 32.8xy / Text5: yunxi.li@ericsson.com
- 200: CP#51 TR 24.826 v100 for Information. Moved to Rel-11. Linked to SA5 UID_430044 (FS_OAM-ESM) & UID_470037 (OAM-ES), RAN3 UID_470015 (FS_Energy_LTE), RAN1 UID_460016 (FS_Energy_UMTS) / Text3: 24.826 / Text5: gottfried.punz@nw.neclab.eu
- 201: CP#51 moved to Rel-11. Completion 03/11=>09/11 to continue work in Rel-11 especially to cover handling of Idle mode Signalling Reduction (ISR). Linked to SA2 UID_490036 Study on Core Network Overload solutions / Text3: 23.857 / Text5: lu.fei1@zte.com.cn
- 202: GP#48 completion 03/11=>09/11. Moved to Rel-11. GP#44 approved SID / Text3: GERAN 43.868 / Text5: paul.schliwa-bertling@ericsson.com
- 203: GP#49 completion 03/11=>09/11 (=>Rel-11). GP#46 approved SID. Precoded EGPRS2 DL provides significant performance gains for EGPRS2 (in interference and sensitivity limited scenarios, allowing significant increase to data capacity and spectral efficiency) / Text3: GERAN 45.860 / Text5: marten.sundberg@ericsson.com
- 204: GP#47 approved SID / Text3: GERAN 45.8xy / Text5: juergen.hofmann@nsn.com, leo.patanapongpibul@vodafone.com
- 205: RP#51 completion 03/11=>12/11 (Moved to Rel-11) / Text3: UTRA, LTE 37.976 / Text5: soonleh.ling@vodafone.com
- 206: RP#50 completion 12/10=>06/11. RP#51 moved to Rel-11 / Text3: UTRA, LTE 37.806 / Text5: christian.bergljung@stericsson.com
- 207: RP#51 completion 03/11=>06/11 (RAN overload study in RAN2. Was on hold until 03/11 closing UID_490023 NIMTC-RAN_over). Triggered by TR 22.868 Study on Facilitating Machine to Machine Communication in GSM and UMTS (M2M) UID_7027 and Rel-10 NIMTC UID_410030 / Text3: UTRA, LTE 37.868 / Text5: Jeff Gao (gaoyq@huawei.com)
- 208: - / Text3: LTE 36.8xx / Text5: bruno.clerckx@samsung.com
- 209: RP#51 completion 03/11=>06/11. TR 36.927 v111 2nd time for Information / Text3: LTE 36.927 / Text5: Yang Ning (yangning@chinamobile.com)
- 210: RP#51 completion 03/11=>06/11. Study coexistence scenario of LTE and Industrial, Scientific and Medical (ISM) Radio within the same device working in adjacent frequencies / Text3: LTE 36.816 / Text5: Zhenping Hu (huzhenping@chinamobile.com)
- 211: LTE, UTRA / Text3: LTE, UTRA 37.901 / Text5: ron.borsato@spirent.com
- 212: UTRA / Text3: UTRA 25.8xy / Text5: Sharad Sambhwani
- 213: UTRA / Text3: UTRA 25.8xy / Text5: Karri Ranta-aho
- 214: LTE RP#51 updated WID RP-101445=>RP-110385. / Text3: LTE 36.809 / Text5: Robert Gross (rgross@polariswireless.com)
- 215: LTE / Text3: LTE 36.8xy / Text5: Sudeep Palat
- 216: LTE / Text3: LTE 36.8xy / Text5: Yunzhe Hou
- 217: LTE, UTRA / Text3: LTE, UTRA 37.8xy / Text5: Martin,Warner@alcatel-lucent.com
- 218: LTE / Text3: LTE 36.8xy / Text5: Federico Boccardi

| ID | WBS | Task | Duration | Start | Finish | Complete | Remaining | Baseline start | Baseline finish | Baseline duration | Total slack | Constraint | Resources | Work | Actual work | Text1 | Text2 | Text4 | Text5 | Text6 | Text7 | Text8 | Text9 | Text12 | Text11 |
| --- | --- | --- | --- | --- | --- | --- | --- | --- | --- | --- | --- | --- | --- | --- | --- | --- | --- | --- | --- | --- | --- | --- | --- | --- | --- |
| 219 | 111 | Study on Interference analysis between 800~900 MHz bands | 131d? | 2011-03-18 | 2011-09-16 |  |  | 2011-03-18 | 2011-09-16 | 131d? | 390d | finish no earlier than 2011-09-16 | R4 | 1048h |  | FS_B800_B900_Interf_LTE | PCG-26 | LG Uplus | Koo Yeon Sang (yskoo@lguplus.co.kr) | Rel-11 | RP-51 | Issam |  |  |  |
| 220 | 112 | Study on Further Enhancements to LTE TDD for DL-UL Interference Management and Traffic Adaptation | 261d? | 2011-03-18 | 2012-03-16 |  |  | 2011-03-18 | 2012-03-16 | 261d? | 260d | finish no earlier than 2012-03-16 | R1,R4 | 2088h |  | FS_LTE_TDD_eIMTA | PCG-26 | CATT | Zukang Shen (shenzukang@datangmobile.cn) | Rel-11 | RP-51 | Patrick |  |  |  |
| 221 | 113 | Release 10 Features | 295.2d? | 2008-12-11 A | 2011-06-08 | 80% | 59.04d? | 2008-12-11 | 2011-06-08 | 295.2d? | 462d | finish no earlier than 2011-06-08 | CP,GP,RP,SP | 2361.6h | 1889.28h |  |  |  |  | Rel-10 |  |  |  |  |  |
| 222 | 114 | **Enhancements for Multimedia Priority Service** | 1311d? | 2006-03-13 A | 2011-03-18 A | 100% |  | 2006-03-13 | 2011-03-18 | 1311d? |  |  | S1,S2,C4,C3,C1 | 28072h | 28072h | eMPS | PCG-21 | Telcordia | jgarraha@telcordia.com | Rel-10 | SP-39 | Alain |  |  |  |
| 223 | 114.1 | Stage 1 on enhancements for Multimedia Priority Service | 584d? | 2006-03-13 A | 2008-06-05 A | 100% |  | 2006-03-13 | 2008-06-05 | 584d? |  | start no earlier than 2006-03-12 | S1 | 4672h | 4672h | ePRIOR | PCG-21 | Telcordia | jgarraha@telcordia.com | Rel-10 | SP-39 | Alain |  |  |  |
| 224 | 114.2 | **Stage 2 on enhancements for Multimedia Priority Service** | 206d? | 2009-12-10 A | 2010-09-23 A | 100% |  | 2009-12-10 | 2010-09-23 | 206d? |  |  | S2 | 6592h | 6592h | eMPS | PCG-24 | Telcordia, NTT DoCoMo | Vijay Varma, Katsutoshi Nishida | Rel-10 | SP-46 | Maurice |  |  |  |
| 225 | 114.2.1 | Stage 2 on eMPS for CSFB | 206d? | 2009-12-10 A | 2010-09-23 A | 100% |  | 2009-12-10 | 2010-09-23 | 206d? |  | finish no earlier than 2010-09-24 | S2 | 1648h | 1648h | eMPS | PCG-24 | Telcordia, NTT DoCoMo | Vijay Varma, Katsutoshi Nishida | Rel-10 | SP-46 | Maurice |  |  |  |
| 226 | 114.2.2 | Stage 2 on eMPS for EPS Bearer Service | 206d? | 2009-12-10 A | 2010-09-23 A | 100% |  | 2009-12-10 | 2010-09-23 | 206d? |  | finish no earlier than 2010-12-09 | S2 | 1648h | 1648h | eMPS | PCG-24 | Telcordia, NTT DoCoMo | Vijay Varma, Katsutoshi Nishida | Rel-10 | SP-46 | Maurice |  |  |  |
| 227 | 114.2.3 | Stage 2 on eMPS for IMS Aspects | 206d? | 2009-12-10 A | 2010-09-23 A | 100% |  | 2009-12-10 | 2010-09-23 | 206d? |  | finish no earlier than 2010-12-09 | S2 | 1648h | 1648h | eMPS | PCG-24 | Telcordia, NTT DoCoMo | Vijay Varma, Katsutoshi Nishida | Rel-10 | SP-46 | Maurice |  |  |  |
| 228 | 114.3 | TR on Stage 2 on enhancements for Multimedia Priority Service | 266d? | 2009-12-10 A | 2010-12-16 A | 100% |  | 2009-12-10 | 2010-12-16 | 266d? |  | finish no earlier than 2011-03-17 | S2 | 2128h | 2128h | eMPS | PCG-24 | Telcordia, NTT DoCoMo | Vijay Varma, Katsutoshi Nishida | Rel-10 | SP-46 | Maurice |  |  |  |
| 229 | 114.4 | **Stage 3 on enhancements for Multimedia Priority Service** | 131d? | 2010-09-17 A | 2011-03-18 A | 100% |  | 2010-09-17 | 2011-03-18 | 131d? |  |  | C4,C3,C1 | 4192h | 4192h | eMPS-CN | PCG-25 | Ericsson | Philip.hodges@ericsson.com | Rel-10 | CP-49 | Kimmo |  |  |  |
| 230 | 114.4.1 | CT4 part on Stage 3 on enhancements for Multimedia Priority Service | 131d? | 2010-09-17 A | 2011-03-18 A | 100% |  | 2010-09-17 | 2011-03-18 | 131d? |  | start no earlier than 2010-09-17 | C4 | 1048h | 1048h | eMPS-CN | PCG-25 | Ericsson | Philip.hodges@ericsson.com | Rel-10 | CP-49 | Kimmo |  |  |  |
| 231 | 114.4.2 | CT3 part on Stage 3 on enhancements for Multimedia Priority Service | 131d? | 2010-09-17 A | 2011-03-18 A | 100% |  | 2010-09-17 | 2011-03-18 | 131d? |  | start no earlier than 2010-09-17 | C3 | 1048h | 1048h | eMPS-CN | PCG-25 | Ericsson | Philip.hodges@ericsson.com | Rel-10 | CP-49 | Jiwan |  |  |  |
| 232 | 114.4.3 | CT1 part on Stage 3 on enhancements for Multimedia Priority Service | 131d? | 2010-09-17 A | 2011-03-18 A | 100% |  | 2010-09-17 | 2011-03-18 | 131d? |  | start no earlier than 2010-09-17 | C1 | 1048h | 1048h | eMPS-CN | PCG-25 | Ericsson | Philip.hodges@ericsson.com | Rel-10 | CP-49 | Frederic |  |  |  |
| 233 | 115 | **Network Improvements for Machine-Type Communications** | 708d? | 2008-09-18 A | 2011-06-03 | 82% | 129.07d? | 2008-09-18 | 2011-06-03 | 708d? | 465d |  | S1,S2,C1,C4,C3,C6,G2,R2,R3 | 24025.2h | 17108.8h | NIMTC | PCG-21 | KPN | toon.norp@tno.nl | Rel-10 | SP-41 | Alain |  |  |  |
| 234 | 115.1 | Stage 1 for Network Improvements for Machine-Type Communications | 397d? | 2008-09-18 A | 2010-03-25 A | 100% |  | 2008-09-18 | 2010-03-25 | 397d? |  | finish no earlier than 2009-12-10 | S1 | 3176h | 3176h | NIMTC | PCG-21 | KPN | toon.norp@tno.nl | Rel-10 | SP-41 | Alain |  |  |  |
| 235 | 115.2 | Deleted - TR on Stage 2 for Network Improvements for Machine-Type Communications | 321d? | 2009-09-24 A | 2010-12-16 A | 100% |  | 2009-09-24 | 2010-12-16 | 321d? |  | finish no earlier than 2010-11-30 | S2 | 2568h | 2568h | NIMTC | PCG-23 | Samsung | erik.guttman@partner.samsung.com | Rel-10 | SP-45 | Maurice | PCG-26 | SP-50 |  |
| 236 | 115.3 | Stage 2 for Network Improvements for Machine-Type Communications | 19d? | 2010-08-30 A | 2010-09-23 A | 100% |  | 2010-08-30 | 2010-09-23 | 19d? |  | finish no earlier than 2010-09-17 | S2 | 152h | 152h | NIMTC | PCG-23 | Samsung | erik.guttman@partner.samsung.com | Rel-10 | SP-45 | Maurice |  |  |  |
| 237 | 115.4 | Deleted - Security for Network Improvements for Machine-Type Communications | 193.15d? | 2009-12-10 A | 2010-09-23 A | 100% |  | 2009-12-10 | 2010-09-23 | 193.15d? |  | finish no earlier than 2010-09-23 | S3 | 1545.2h | 1545.2h | NIMTC | PCG-24 | Samsung | Rajavelsamy R (rajvel@samsung.com) | Rel-10 | SP-46 | Dionisio | PCG-25 | SP-49 |  |
| 238 | 115.5 | **CN part of Stage 3 for Network Improvements for Machine-Type Communications** | 261d? | 2010-06-04 A | 2011-06-03 | 65% | 92.5d? | 2010-06-04 | 2011-06-03 | 261d? | 465d |  | C1,C4,C3,C6 | 8360h | 4675.6h | NIMTC | PCG-25 | Ericsson | mikael.wass@ericsson.com | Rel-10 | CP-48 | Frederic |  |  |  |
| 239 | 115.5.1 | CT1 part of Stage 3 for Network Improvements for Machine-Type Communications | 261d? | 2010-06-04 A | 2011-06-03 | 85% | 39.15d? | 2010-06-04 | 2011-06-03 | 261d? | 465d | finish no earlier than 2011-06-03 | C1 | 2088h | 1774.8h | NIMTC | PCG-25 | Ericsson | mikael.wass@ericsson.com | Rel-10 | CP-48 | Frederic |  |  | Exception sheet in CP-110154 |
| 240 | 115.5.2 | CT3 part of Stage 3 for Network Improvements for Machine-Type Communications | 261d? | 2010-06-04 A | 2011-06-03 | 30% | 182.7d? | 2010-06-04 | 2011-06-03 | 261d? | 465d | finish no earlier than 2010-12-10 | C3 | 2088h | 626.4h | NIMTC | PCG-25 | Ericsson | mikael.wass@ericsson.com | Rel-10 | CP-48 | Jiwan | PCG-26 |  | Exception sheet in CP-110137 |
| 241 | 115.5.3 | CT4 part of Stage 3 for Network Improvements for Machine-Type Communications | 206d? | 2010-06-04 A | 2011-03-18 A | 100% |  | 2010-06-04 | 2011-03-18 | 206d? |  | finish no earlier than 2011-03-18 | C4 | 1648h | 1648h | NIMTC | PCG-25 | Ericsson | mikael.wass@ericsson.com | Rel-10 | CP-48 | Kimmo |  |  |  |
| 242 | 115.5.4 | CT6 part of Stage 3 for Network Improvements for Machine-Type Communications | 56d? | 2011-03-18 | 2011-06-03 |  |  | 2011-03-18 | 2011-06-03 | 56d? | 465d | finish no earlier than 2011-06-03 | C6 | 448h |  | NIMTC | PCG-26 | Sagem-Orga | heiko.kruse@sagem-orga.com | Rel-10 | CP-51 | Xavier |  |  | Exception sheet in CP-110291 |
| 243 | 115.6 | Charging for Network Improvements for Machine-Type Communication | 3d? | 2011-03-21 A | 2011-03-23 A | 100% |  | 2011-03-21 | 2011-03-23 | 3d? |  | start no earlier than 2011-03-21 | S5 | 24h | 24h | NIMTC-CH | PCG-26 | Ericsson | patrik.teppo@@ericsson.com | Rel-10 | SP-51 | Dionisio |  |  |  |
| 244 | 115.7 | GERAN part of Network Improvements for Machine-Type Communications (Stage 3) | 186d? | 2010-09-03 A | 2011-05-20 | 50% | 93d? | 2010-09-03 | 2011-05-20 | 186d? | 475d | finish no earlier than 2011-05-20 | G2 | 1488h | 744h | NIMTC | PCG-25 | Vodafone, Ericsson | leo.patanapongpibul@vodafone.com, john.diachina@ericsson.com | Rel-10 | GP-47 | Gert |  |  | Exception sheet in GP-110506 |
| 245 | 115.8 | RAN mechanisms to avoid CN overload due to Machine-Type Communications | 131d? | 2010-09-17 A | 2011-03-18 A | 100% |  | 2010-09-17 | 2011-03-18 | 131d? |  | finish no earlier than 2011-03-18 | R2,R3 | 1048h | 1048h | NIMTC-RAN_overload | PCG-25 | Huawei | Jeff Gao (gaoyq@huawei.com) | Rel-10 | RP-49 | Joern |  |  | RP-110063 |

Notes:
- 219: LTE / Text3: LTE 36.8xy
- 220: LTE / Text3: LTE 36.8xy
- 221: -
- 222: CP#51 completed. SP#49 moved Stage 1 from Rel-9 & Completed Stage 2. SP#40 Stage 1 completed. Continuation of Rel-8 Feature PRIOR (UID_340044)
- 223: ePRIOR started Mar 2006 as a Rel-8 Feature. It was delayed to Rel-9 (completed at SP#40), then moved to Rel-10 at SP#49 and demoted to Building Block level. / Text3: 22.153, 22.278
- 224: SP#49 completed. Updated WID SP-100166=>SP-100647
- 225: SP#49 completed / Text3: 23.002, 23.203, 23.221, 23.228, 23.272, 23.401
- 226: SP#49 completed / Text3: 23.002, 23.203, 23.221, 23.228, 23.272, 23.401
- 227: SP#49 completed / Text3: 23.002, 23.203, 23.221, 23.228, 23.272, 23.401
- 228: SP#50 completed / Text3: new TR 23.854
- 229: CP#51 completed / Text3: Stage 3
- 230: CP#51 completed / Text3: 23.008, 29.002, 29.228, 29.229, 29.272, 29.274, 29.277, 29.328, 29.329
- 231: CP#51 completed / Text3: 29.212, 29.213, 29.214
- 232: CP#51 completed / Text3: 24.008, 24.229, 24.301
- 233: SP#50 updated WID SP-090832=>SP-100863 (document the SA2 work). SP#49 Security stopped. SP#47 Stage 1 completed. Triggered by Rel-8 UID_7027 Study on Facilitating Machine to Machine Communication in GSM and UMTS (FS_M2M) TR 22.868
- 234: SA#47 completed / Text3: 22.011, new 22.368
- 235: SP#50 updated WID SP-090832=>SP-100863 (TR 23.888 not submitted for approval to conclude Rel-10 NIMTC as it will continue to serve as basis for Rel-11 SIMTC work item) / Text3: new TR 23.888
- 236: SP#49 completed. SP#50 updated WID SP-090832=>SP-100863 (document the SA2 work) / Text3: 23.060, 23.236, 23.401
- 237: SP#49 stopped (activity moved to Rel-11 under UID_490028 TR on Security aspects of System Improvements to Machine-Type Communications (SIMTC) / Text3: new 33.868
- 238: CP#51 updated WID CP-10088=>CP-110147 (identified CT3 impact) / Text3: Stage 3
- 239: CP#51 completion 03/11=>06/11 (exception in CP-110154) / Text3: 23.122, 24.008, 24.301, new 24.368
- 240: CP#51 completion 03/11=>06/11 (exception in CP-110137. Updated WID CP-10088=>CP-110147 (identified CT3 impact: updates to Diameter over Gx, Gx/S9, S9 interfaces) / Text3: 29.212, 29.213, 29.215
- 241: CP#51 completed. Updated WID CP-10088=>CP-110147 / Text3: 23.003, 23.008, 29.002, 29.060, 29.230, 29.272, 29.274, 29.275, 29.282
- 242: CP#51 exception in CP-110291 for work on (U)SIM OTA support of low priority configuration, Device binding between USIM and MTC device & USIM aspects of EAB / Text3: 31.102
- 243: SP#51 completed / Text3: 32.251, 32.298, 32.299
- 244: GP#49 completion 03/11=>05/11 (exception in GP-110506). GP#47 approved WID / Text3: 44.018, 44.060
- 245: Stage 3. RP#51 completed / Text3: UTRA, LTE 25.331, 25.413, 36.331, 36.413

| ID | WBS | Task | Duration | Start | Finish | Complete | Baseline start | Baseline finish | Baseline duration | Constraint | Resources | Work | Actual work | Text1 | Text2 | Text4 | Text6 | Text7 | Text8 |
| --- | --- | --- | --- | --- | --- | --- | --- | --- | --- | --- | --- | --- | --- | --- | --- | --- | --- | --- | --- |
| 246 | 116 | **Multi Access PDN Connectivity** | 527d? | 2009-03-13 A | 2011-03-18 A | 100% | 2009-03-13 | 2011-03-18 | 527d? |  | S2,C4,C1,C3 | 9592h | 9592h | MAPCON | PCG-22 | Telecom Italia | Rel-10 | SP-43 | Maurice |
| 247 | 116.1 | Stage 2 for Multi Access PDN Connectivity | 401d? | 2009-03-13 A | 2010-09-23 A | 100% | 2009-03-13 | 2010-09-23 | 401d? |  | S2 | 3208h | 3208h | MAPCON |  | Telecom Italia | Rel-10 |  | Maurice |
| 248 | 116.2 | **CT aspects of Multi Access PDN Connectivity** | 90d? | 2010-11-15 A | 2011-03-18 A | 100% | 2010-11-15 | 2011-03-18 | 90d? |  | C4,C1,C3 | 2168h | 2168h | MAPCON-St3 | PCG-26 | ZTE | Rel-10 | CP-50 | Kimmo |
| 249 | 116.2.1 | CT4 aspects of Multi Access PDN Connectivity | 20d? | 2010-11-15 A | 2010-12-10 A | 100% | 2010-11-15 | 2010-12-10 | 20d? | start no earlier than 2010-12-10 | C4 | 160h | 160h | MAPCON-St3 | PCG-26 | ZTE | Rel-10 | CP-50 | Kimmo |
| 250 | 116.2.2 | CT1 aspects of Multi Access PDN Connectivity | 71d? | 2010-12-10 A | 2011-03-18 A | 100% | 2010-12-10 | 2011-03-18 | 71d? | start no earlier than 2010-12-10 | C1 | 568h | 568h | MAPCON-St3 | PCG-26 | ZTE | Rel-10 | CP-50 | Frederic |
| 251 | 116.2.3 | CT3 aspects of Multi Access PDN Connectivity | 90d? | 2010-11-15 A | 2011-03-18 A | 100% | 2010-11-15 | 2011-03-18 | 90d? | finish no earlier than 2011-03-18 | C3 | 720h | 720h | MAPCON-St3 | PCG-26 | ZTE | Rel-10 | CP-50 | Jiwan |
| 252 | 117 | **IMS Service Continuity – Inter Device Transfer enhancements** | 467d? | 2009-06-04 A | 2011-03-18 A | 100% | 2009-06-04 | 2011-03-18 | 467d? |  | S1,S2,C1 | 9600h | 9600h | IMS_SC_eIDT | PCG-23 | Huawei | Rel-10 | SP-44 | Alain |
| 253 | 117.1 | Stage 1 - IMS Service Continuity – Inter Device Transfer enhancements | 211d? | 2009-06-04 A | 2010-03-25 A | 100% | 2009-06-04 | 2010-03-25 | 211d? | finish no earlier than 2010-03-25 | S1 | 1688h | 1688h | IMS_SC_eIDT | PCG-23 | Huawei | Rel-10 | SP-44 | Alain |
| 254 | 117.2 | Stage 2 - IMS Inter-UE Transfer enhancements | 261d? | 2009-09-24 A | 2010-09-23 A | 100% | 2009-09-24 | 2010-09-23 | 261d? | finish no earlier than 2010-09-23 | S2 | 2088h | 2088h | IMS_SC_eIDT | PCG-23 | Huawei | Rel-10 | SP-45 | Maurice |
| 255 | 117.3 | Stage 3 - IMS Inter-UE Transfer enhancements | 261d? | 2010-03-19 A | 2011-03-18 A | 100% | 2010-03-19 | 2011-03-18 | 261d? | start no earlier than 2010-03-19 | C1 | 2088h | 2088h | IMS_SC_eIDT | PCG-24 | Huawei | Rel-10 | CP-47 | Frederic |
| 256 | 118 | **IP-Short-Message-Gateway enhancements for CPM-SMS Interworking** | 257d? | 2009-09-24 A | 2010-09-17 A | 100% | 2009-09-24 | 2010-09-17 | 257d? |  | S1,S2,C3 | 5792.8h | 5792.8h | CPM-SMS | PCG-23 | China Mobile | Rel-10 | SP-45 | Alain |
| 257 | 118.1 | Stage 1 for CPM-SMS | 131d? | 2009-09-24 A | 2010-03-25 A | 100% | 2009-09-24 | 2010-03-25 | 131d? | finish no earlier than 2010-03-25 | S1 | 1048h | 1048h | CPM-SMS | PCG-23 | China Mobile | Rel-10 | SP-45 | Alain |
| 258 | 118.2 | Stage 2 for CPM-SMS | 130.1d? | 2009-09-24 A | 2010-03-25 A | 100% | 2009-09-24 | 2010-03-25 | 130.1d? | finish no earlier than 2010-03-25 | S2 | 1040.8h | 1040.8h | CPM-SMS | PCG-23 | Orange | Rel-10 | SP-45 | Maurice |
| 259 | 118.3 | Stage 3 for IP-Short-Message-Gateway enhancements for CPM-SMS Interworking | 206d? | 2009-12-04 A | 2010-09-17 A | 100% | 2009-12-04 | 2010-09-17 | 206d? | finish no earlier than 2010-09-17 | C3 | 1648h | 1648h | CPM-SMS | PCG-24 | Ericsson | Rel-10 | CP-46 | Jiwan |
| 260 | 119 | **Completion of Communications on Not Logged-in** | 387d? | 2009-09-24 A | 2011-03-18 A | 100% | 2009-09-24 | 2011-03-18 | 387d? |  | S1,C1,C3 | 5800h | 5800h | CCNL | PCG-23 | Deutsche Telekom | Rel-10 | SP-45 | Alain |
| 261 | 119.1 | Stage 1 for Completion of Communications on Not Logged-in | 1d? | 2009-09-24 A | 2009-09-24 A | 100% | 2009-09-24 | 2009-09-24 | 1d? | start no earlier than 2009-09-24 | S1 | 8h | 8h | CCNL | PCG-23 | Deutsche Telekom | Rel-10 | SP-45 | Alain |
| 262 | 119.2 | CT1 part of Stage 3 for Completion of Communications on Not Logged-in | 261d? | 2010-03-19 A | 2011-03-18 A | 100% | 2010-03-19 | 2011-03-18 | 261d? | finish no earlier than 2011-03-18 | C1 | 2088h | 2088h | CCNL | PCG-24 | Deutsche Telekom | Rel-10 | CP-47 | Frederic |
| 263 | 119.3 | CT3 part of Stage 3 for Completion of Communications on Not Logged-in | 76d? | 2010-06-04 A | 2010-09-17 A | 100% | 2010-06-04 | 2010-09-17 | 76d? | finish no earlier than 2010-09-17 | C3 | 608h | 608h | CCNL | PCG-25 | Deutsche Telekom | Rel-10 | CP-48 | Jiwan |
| 264 | 120 | **Local IP Access and Selected Internet IP Traffic Offload** | 390d? | 2009-09-24 A | 2011-03-23 A | 100% | 2009-09-24 | 2011-03-23 | 390d? |  | S2,S1,S3,S5,C4,C1 | 28656h | 28656h | LIPA_SIPTO | PCG-23 | Huawei, China Mobile | Rel-10 | SP-45 | Maurice |
| 265 | 120.1 | Stage 1 for Local IP Access and Selected Internet IP Traffic Offload | 131d? | 2009-09-24 A | 2010-03-25 A | 100% | 2009-09-24 | 2010-03-25 | 131d? | finish no earlier than 2010-03-25 | S1 | 1048h | 1048h | LIPA_SIPTO | PCG-23 | Huawei, China Mobile | Rel-10 | SP-45 | Alain |
| 266 | 120.2 | TR on Local IP Access and Selected Internet IP Traffic Offload | 387d? | 2009-09-24 A | 2011-03-18 A | 100% | 2009-09-24 | 2011-03-18 | 387d? | finish no earlier than 2011-03-18 | S2 | 3096h | 3096h | LIPA_SIPTO | PCG-23 | Huawei, China Mobile | Rel-10 | SP-45 | Maurice |
| 267 | 120.3 | Security for Local IP Access and Selected Internet IP Traffic Offload | 261d? | 2009-09-24 A | 2010-09-23 A | 100% | 2009-09-24 | 2010-09-23 | 261d? | finish no earlier than 2010-09-23 | S3 | 2088h | 2088h | LIPA_SIPTO | PCG-23 | Huawei, Qualcomm | Rel-10 | SP-45 | Dionisio |
| 268 | 120.4 | OAM&P for Local IP Access and Selected Internet IP Traffic Offload | 390d? | 2009-09-24 A | 2011-03-23 A | 100% | 2009-09-24 | 2011-03-23 | 390d? | finish no earlier than 2011-03-23 | S5 | 3120h | 3120h | LIPA_SIPTO | PCG-23 | Huawei, China Mobile | Rel-10 | SP-45 | Dionisio |
| 269 | 120.5 | Charging for Local IP Access and Selected Internet IP Traffic Offload | 335d? | 2009-12-10 A | 2011-03-23 A | 100% | 2009-12-10 | 2011-03-23 | 335d? | finish no earlier than 2011-03-23 | S5 | 2680h | 2680h | LIPA_SIPTO | PCG-24 | Huawei, China Mobile | Rel-10 | SP-46 | Dionisio |
| 270 | 120.6 | Stage 2 for Local IP Access | 261d? | 2009-09-24 A | 2010-09-23 A | 100% | 2009-09-24 | 2010-09-23 | 261d? | finish no earlier than 2010-08-10 | S2 | 2088h | 2088h | LIPA | PCG-23 | Huawei, China Mobile | Rel-10 | SP-45 | Maurice |

Notes:
- 246: CP#51 completed. SP#49 Stage 2 completed. Triggered by TR 23.861 UID_410043 FS_MAPIM. Stage 1 in Rel-9 22.278 (6.2 - IP session control) / Text5: ivano.guardini@telecomitalia.it
- 247: SP#49 completed. Triggered by TR 23.861 UID_410043 FS_MAPIM. Stage 1 in Rel-9 22.278 (6.2 - IP session control) / Text3: 23.237, 23.401, 23.402 / Text5: ivano.guardini@telecomitalia.it
- 248: CP#51 completed / Text5: Xingyue (Joy) Zhou (zhou.xingyue@zte.com.cn)
- 249: CP#50 completed / Text3: 29.273, 29.272, 29.002, 23.008 / Text5: Xingyue (Joy) Zhou (zhou.xingyue@zte.com.cn)
- 250: CP#51 completed / Text3: 24.302, 24.312 / Text5: Xingyue (Joy) Zhou (zhou.xingyue@zte.com.cn)
- 251: CP#51 completed / Text3: 29.215 / Text5: Xingyue (Joy) Zhou (zhou.xingyue@zte.com.cn)
- 252: CP#51 completed. SP#47 Stage 1 completed. Rel-9 set Inter-Device Transfer requirements UID_410033 (IMS_SCC-IDT). Adds IDT scenarios and requirements / Text5: Amar Deol (adeol@huawei.com)
- 253: SA#47 completed / Text3: 22.228 / Text5: Amar Deol (adeol@huawei.com)
- 254: SP#49 completed / Text3: 23.237, 23.292, new 23.831 / Text5: Lee Valerius (lvalerius@huawei.com)
- 255: CP#51 completed. WID updated CP-100334=>CP-110285 / Text3: 24.216, 24.229, 24.237, new (24.837, 24.337) / Text5: georg.mayer@huawei.com
- 256: SP#47 Stage 1 completed. IP-SM-GW enhancements for interworking with OMA CPM / Text5: Qing Huang (huangqing@chinamobile.com)
- 257: SA#47 completed. External requirements (Stage 1 in OMA-RD-CPM-V1_0-20090310-C) / Text3: 22.340 / Text5: Qing Huang
- 258: SP#47 completed / Text3: 23.204, new TR 23.824 / Text5: antoine.mouquet@orange-ftgroup.com
- 259: CP#49 completed. Linked to Rel-8 UID_340031 Service-Level Interworking for Messaging Services (MESSIW) 23.204 / Text3: 29.311 / Text5: Jan Holm
- 260: CP#51 completed. SP#45 Stage 1 completed / Text5: Kurt Bischinger
- 261: SP#45 completed / Text3: 22.173 CR#0056r1 / Text5: Kurt Bischinger
- 262: CP#51 completed / Text3: 24.173, 24.642 / Text5: martin.huelsemann@telekom.de
- 263: CP#49 completed / Text3: 29.165 / Text5: martin.huelsemann@telekom.de
- 264: TSG#51 completed. Updated WID SP-100696=>SP-110131. SP#49 Stage 2 & Security completed. UID_400035 Enhanced Home NodeB/eNodeB (EHNB) formerly covered Local IP Access to Internet and Local access to Home Network from the Home NodeB/eNodeB / Text5: patrice.hede@huawei.com, Tao Sun (suntao@chinamobile.com)
- 265: SP#47 completed / Text3: 22.101, 22.220 / Text5: Amar Deol (adeolf@huawei.com), Gang Li (ligangyf@chinamobile.com)
- 266: SP#51 completed. TR 23.829 for Approval / Text3: new TR 23.829 / Text5: patrice.hede@huawei.com, Tao Sun (suntao@chinamobile.com)
- 267: SP#49 completed / Text3: 33.102, 33.107, 33.108, 33.320, 33.401 / Text5: Marcus Wong (mwong@huawei.com), Brian Rosenberg (bmr@qualcomm.com)
- 268: SP#51 completed. Updated WID SP-100696=>SP-110131 / Text3: 32.581, 32.582, 32.584, 32.591, 32.592, 32.642, 32.646, 32.772, 32.782 / Text5: Zou Lan (zlan@huawei.com), Chen Gang (chengang@chinamobile.com)
- 269: SP#51 completed. Updated WID SP-100696=>SP-110131 / Text3: 32.251 / Text5: shan.mingjun@huawei.com, Ai Chen (chenai@chinamobile.com)
- 270: SP#49 completed (has impacts to RAN) / Text3: 23.060, 23.401 / Text5: patrice.hede@huawei.com, Tao Sun (suntao@chinamobile.com)

| ID | WBS | Task | Duration | Start | Finish | Complete | Remaining | Baseline start | Baseline finish | Baseline duration | Total slack | Constraint | Resources | Work | Actual work | Text1 | Text2 | Text4 | Text5 | Text6 | Text7 | Text8 | Text11 |
| --- | --- | --- | --- | --- | --- | --- | --- | --- | --- | --- | --- | --- | --- | --- | --- | --- | --- | --- | --- | --- | --- | --- | --- |
| 271 | 120.7 | **Stage 3 for Local IP Access** | 206d? | 2010-06-04 A | 2011-03-18 A | 100% |  | 2010-06-04 | 2011-03-18 | 206d? |  |  | C4,C1 | 4944h | 4944h | LIPA | PCG-25 | China Mobile | Zhang Hao (zhanghao@chinamobile.com) | Rel-10 | CP-48 | Kimmo |  |
| 272 | 120.7.1 | CT4 part of Stage 3 for Local IP Access | 206d? | 2010-06-04 A | 2011-03-18 A | 100% |  | 2010-06-04 | 2011-03-18 | 206d? |  | finish no earlier than 2011-03-18 | C4 | 1648h | 1648h | LIPA | PCG-25 | China Mobile | Zhang Hao (zhanghao@chinamobile.com) | Rel-10 | CP-48 | Kimmo |  |
| 273 | 120.7.2 | CT1 part of Stage 3 for Local IP Access | 206d? | 2010-06-04 A | 2011-03-18 A | 100% |  | 2010-06-04 | 2011-03-18 | 206d? |  | finish no earlier than 2011-03-18 | C1 | 1648h | 1648h | LIPA | PCG-25 | China Mobile | Zhang Hao (zhanghao@chinamobile.com) | Rel-10 | CP-48 | Frederic |  |
| 274 | 120.8 | Stage 2 for SIPTO for macro networks | 261d? | 2009-09-24 A | 2010-09-23 A | 100% |  | 2009-09-24 | 2010-09-23 | 261d? |  | finish no earlier than 2010-09-23 | S2 | 2088h | 2088h | SIPTO | PCG-23 | Huawei, China Mobile | patrice.hede@huawei.com, Tao Sun (suntao@chinamobile.com) | Rel-10 | SP-45 | Maurice |  |
| 275 | 120.9 | **Stage 3 for SIPTO for macro networks** | 206d? | 2010-06-04 A | 2011-03-18 A | 100% |  | 2010-06-04 | 2011-03-18 | 206d? |  |  | C4,C1 | 4384h | 4384h | SIPTO | PCG-25 | Huawei | Caixia Qi (qcxmay@huawei.com) | Rel-10 | CP-48 | Kimmo |  |
| 276 | 120.9.1 | CT4 part of Stage 3 for SIPTO for macro networks | 206d? | 2010-06-04 A | 2011-03-18 A | 100% |  | 2010-06-04 | 2011-03-18 | 206d? |  | finish no earlier than 2011-03-18 | C4 | 1648h | 1648h | SIPTO | PCG-25 | Huawei | Caixia Qi (qcxmay@huawei.com) | Rel-10 | CP-48 | Kimmo |  |
| 277 | 120.9.2 | CT1 part of Stage 3 for SIPTO for macro networks | 136d? | 2010-06-04 A | 2010-12-10 A | 100% |  | 2010-06-04 | 2010-12-10 | 136d? |  | finish no earlier than 2011-03-18 | C1 | 1088h | 1088h | SIPTO | PCG-25 | Huawei | Caixia Qi (qcxmay@huawei.com) | Rel-10 | CP-48 | Frederic |  |
| 278 | 121 | **IP Flow Mobility and seamless WLAN offload** | 390d? | 2009-09-24 A | 2011-03-23 A | 100% |  | 2009-09-24 | 2011-03-23 | 390d? |  |  | S2,S1,S5,C1,C3 | 12680h | 12680h | IFOM | PCG-23 | Qualcomm | Gerardo Giaretta (gerardo@qualcomm.com) | Rel-10 | SP-45 | Maurice |  |
| 279 | 121.1 | Stage 1 for IP Flow Mobility and seamless WLAN offload | 56d? | 2009-09-24 A | 2009-12-10 A | 100% |  | 2009-09-24 | 2009-12-10 | 56d? |  | finish no earlier than 2009-12-10 | S1 | 448h | 448h | IFOM | PCG-23 | Qualcomm | David Williams (dwilliam@qualcomm.com) | Rel-10 | SP-45 | Alain |  |
| 280 | 121.2 | Stage 2 for IP Flow Mobility and seamless WLAN offload | 261d? | 2009-09-24 A | 2010-09-23 A | 100% |  | 2009-09-24 | 2010-09-23 | 261d? |  | finish no earlier than 2010-09-23 | S2 | 2088h | 2088h | IFOM | PCG-23 | Qualcomm | Gerardo Giaretta (gerardo@qualcomm.com) | Rel-10 | SP-45 | Maurice |  |
| 281 | 121.3 | Charging for IP Flow Mobility and seamless WLAN offload | 260d? | 2010-03-25 A | 2011-03-23 A | 100% |  | 2010-03-25 | 2011-03-23 | 260d? |  | finish no earlier than 2011-03-23 | S5 | 2080h | 2080h | IFOM | PCG-24 | Alcatel-Lucent | maryse.gardella@alcatel-lucent.com | Rel-10 | SP-47 | Dionisio |  |
| 282 | 121.4 | **Stage 3 for IP Flow Mobility and seamless WLAN offload** | 206d? | 2010-06-04 A | 2011-03-18 A | 100% |  | 2010-06-04 | 2011-03-18 | 206d? |  |  | C1,C3 | 4944h | 4944h | IFOM-CT | PCG-25 | Qualcomm | Patrick Stupar (pstupar@qualcomm.com) | Rel-10 | CP-48 | Frederic |  |
| 283 | 121.4.1 | CT1 part of Stage 3 for IP Flow Mobility and seamless WLAN offload | 206d? | 2010-06-04 A | 2011-03-18 A | 100% |  | 2010-06-04 | 2011-03-18 | 206d? |  | finish no earlier than 2011-03-18 | C1 | 1648h | 1648h | IFOM-CT | PCG-25 | Qualcomm | Patrick Stupar (pstupar@qualcomm.com) | Rel-10 | CP-48 | Frederic |  |
| 284 | 121.4.2 | CT3 part of Stage 3 for IP Flow Mobility and seamless WLAN offload | 206d? | 2010-06-04 A | 2011-03-18 A | 100% |  | 2010-06-04 | 2011-03-18 | 206d? |  | finish no earlier than 2011-03-18 | C3 | 1648h | 1648h | IFOM-CT | PCG-25 | Qualcomm | Patrick Stupar (pstupar@qualcomm.com) | Rel-10 | CP-48 | Jiwan |  |
| 285 | 122 | **Enabling Coder Selection and Rate Adaptation for UTRAN and E-UTRAN for Load Adaptive Applications** | 442d? | 2009-09-24 A | 2011-06-03 | 96% | 16.95d? | 2009-09-24 | 2011-06-03 | 442d? | 465d |  | S2,S4,C4,C3,C1 | 16664h | 14020.8h | ECSRA_LAA | PCG-23 | Qualcomm | AC Mahendran (ac@qualcomm.com) | Rel-10 | SP-45 | Maurice |  |
| 286 | 122.1 | TR on Enabling Coder Selection and Rate Adaptation for UTRAN and E-UTRAN for Load Adaptive Applications | 186d? | 2009-09-24 A | 2010-06-10 A | 100% |  | 2009-09-24 | 2010-06-10 | 186d? |  | finish no earlier than 2010-09-23 | S2,S4 | 1488h | 1488h | ECSRA_LAA | PCG-23 | Qualcomm | AC Mahendran (ac@qualcomm.com) | Rel-10 | SP-45 | Maurice |  |
| 287 | 122.2 | SA4 review of TR on Enabling Coder Selection and Rate Adaptation for UTRAN and E-UTRAN for Load Adaptive Applications | 320d? | 2009-09-24 A | 2010-12-15 A | 100% |  | 2009-09-24 | 2010-12-15 | 320d? |  | finish no earlier than 2010-12-15 | S4 | 2560h | 2560h | ECSRA_LAA | PCG-23 | Qualcomm | AC Mahendran (ac@qualcomm.com) | Rel-10 | SP-45 | Paolo |  |
| 288 | 122.3 | Stage 2 for Enabling Coder Selection and Rate Adaptation for UTRAN and E-UTRAN for Load Adaptive Applications | 261d? | 2009-09-24 A | 2010-09-23 A | 100% |  | 2009-09-24 | 2010-09-23 | 261d? |  | finish no earlier than 2010-09-23 | S2 | 2088h | 2088h | ECSRA_LAA | PCG-23 | Qualcomm | AC Mahendran (ac@qualcomm.com) | Rel-10 | SP-45 | Maurice |  |
| 289 | 122.4 | SA4 aspects of Enabling Coder Selection and Rate Adaptation for UTRAN and E-UTRAN for Load Adaptive Applications | 130d? | 2010-09-23 A | 2011-03-23 A | 100% |  | 2010-09-23 | 2011-03-23 | 130d? |  | finish no earlier than 2011-03-23 | S4 | 1040h | 1040h | ECSRA_LAA | PCG-25 | Qualcomm | AC Mahendran (ac@qualcomm.com) | Rel-10 | SP-49 | Paolo |  |
| 290 | 122.5 | **CN aspects of Enabling Coder Selection and Rate Adaptation for UTRAN and E-UTRAN for Load Adaptive Applications** | 186d? | 2010-09-17 A | 2011-06-03 | 90% | 18.6d? | 2010-09-17 | 2011-06-03 | 186d? | 465d |  | C4,C3,C1 | 5952h | 5356.8h | ECSRA_LAA-CN | PCG-25 | Ericsson | Philip.hodges@ericsson.com | Rel-10 | CP-49 | Kimmo | Exception sheet in CP-110272 |
| 291 | 122.5.1 | CT4 part of CN aspects of Enabling Coder Selection and Rate Adaptation for UTRAN and E-UTRAN for Load Adaptive Applications | 186d? | 2010-09-17 A | 2011-06-03 | 90% | 18.6d? | 2010-09-17 | 2011-06-03 | 186d? | 465d | start no earlier than 2010-09-17 | C4 | 1488h | 1339.2h | ECSRA_LAA-CN | PCG-25 | Ericsson | Philip.hodges@ericsson.com | Rel-10 | CP-49 | Kimmo | Exception sheet in CP-110272 |
| 292 | 122.5.2 | CT3 part of CN aspects of Enabling Coder Selection and Rate Adaptation for UTRAN and E-UTRAN for Load Adaptive Applications | 186d? | 2010-09-17 A | 2011-06-03 | 90% | 18.6d? | 2010-09-17 | 2011-06-03 | 186d? | 465d | finish no earlier than 2011-06-03 | C3 | 1488h | 1339.2h | ECSRA_LAA-CN | PCG-25 | Ericsson | Philip.hodges@ericsson.com | Rel-10 | CP-49 | Jiwan | Exception sheet in CP-110272 |
| 293 | 122.5.3 | CT1 part of CN aspects of Enabling Coder Selection and Rate Adaptation for UTRAN and E-UTRAN for Load Adaptive Applications | 186d? | 2010-09-17 A | 2011-06-03 | 90% | 18.6d? | 2010-09-17 | 2011-06-03 | 186d? | 465d | start no earlier than 2010-09-17 | C1 | 1488h | 1339.2h | ECSRA_LAA-CN | PCG-25 | Ericsson | Philip.hodges@ericsson.com | Rel-10 | CP-49 | Frederic | Exception sheet in CP-110272 |
| 294 | 123 | **Extended H(e)NB features** | 467d? | 2008-12-11 A | 2010-09-23 A | 100% |  | 2008-12-11 | 2010-09-23 | 467d? |  |  | S1,S2,S3 | 4344h | 4344h | EHNBF | PCG-23 | NEC | joerg.swetina@nw.neclab.eu | Rel-10 | SP-45 | Alain |  |
| 295 | 123.1 | Stage 1 of Extended H(e)NB features | 131d? | 2009-09-24 A | 2010-03-25 A | 100% |  | 2009-09-24 | 2010-03-25 | 131d? |  | finish no earlier than 2010-03-25 | S1 | 1048h | 1048h | EHNBF | PCG-23 | NEC | joerg.swetina@nw.neclab.eu | Rel-10 | SP-45 | Alain |  |
| 296 | 123.2 | IMS aspects of Architecture for Home NodeB | 336d? | 2008-12-11 A | 2010-03-25 A | 100% |  | 2008-12-11 | 2010-03-25 | 336d? |  | finish no earlier than 2010-03-25 | S2 | 2688h | 2688h | EHNB-IMS | PCG-22 | Alcatel-Lucent | Nicolas Drevon | Rel-10 | SP-42 | Maurice |  |
| 297 | 123.3 | Extended H(e)NB Security features (Stage 2) | 76d? | 2010-06-10 A | 2010-09-23 A | 100% |  | 2010-06-10 | 2010-09-23 | 76d? |  | finish no earlier than 2010-09-23 | S3 | 608h | 608h | EHNBF-Sec | PCG-25 | Huawei | Marcus Wong (mwong@huawei.com) | Rel-10 | SP-48 | Dionisio |  |

Notes:
- 271: CP#51 completed
- 272: CP#51 completed / Text3: 23.008, 23.015, 29.002, 29.060, 29.272, 29.274, 29.281, 29.303
- 273: CP#51 completed / Text3: 24.008, 24.301
- 274: SP#49 completed (SIPTO GW selection for wild card APN and for GERAN. Serving-GW selection for SIPTO. Corrections and Clarifications of the SIPTO procedure) / Text3: 23.060, 23.401
- 275: CP#51 completed. Updated WID CP-100419=>CP-110091
- 276: CP#51 completed. Updated WID CP-100419=>CP-110091 / Text3: 23.003, 23.008, 29.002, 29.272, 29.303
- 277: CP#50 completed / Text3: 24.008, 24.301
- 278: Triggered by Rel-10 TR 23.861 (UID_410043 Study on Multi Access PDN connectivity and IP flow mobility - MAPIM)
- 279: SP#46completed / Text3: 22.278
- 280: SP#49 completed / Text3: 23.203, 23.402, new 23.261
- 281: SP#51 completed / Text3: 32.240, 32.251, 32.252, 32.298, 32.299
- 282: CP#51 completed / Text3: Stage 3
- 283: CP#51 completed / Text3: 24.008, 24.301, 24.302, 24.303, 24.312, 24.327
- 284: CP#51 completed / Text3: 29.212, 29.213, 29.214, 29.215
- 285: SP#49 SA2 completed. Triggered by Rel-9 UID_440013 Vocoder rate adaptation for LTE / Text3: UTRA, LTE
- 286: SP#48 completed / Text3: new 23.860
- 287: SP#50 completed / Text3: new 23.860
- 288: SP#49 completed / Text3: 23.060, 23.203, 23.228, 23.401
- 289: SP#51 completed / Text3: 26.114
- 290: CP#51 completion 03/11=>06/11 (exception in CP-110272) / Text3: Stage 2/3
- 291: CP#51 completion 03/11=>06/11 (exception in CP-110272) / Text3: 23.334, 29.334, 29.238, 23.333, 29.333, 29.232, 29.332
- 292: CP#51 completion 03/11=>06/11 (exception in CP-110272) / Text3: 29.162, 29.163, 29.213, 29.235, 29.292
- 293: CP#51 completion 03/11=>06/11 (exception in CP-110272) / Text3: 24.229
- 294: SP#49 completed. Adds extensions to Rel-9 functionality in UID_400035 Enhanced Home NodeB / eNodeB (EHNB) / Text3: UTRA, LTE
- 295: SP#47 completed / Text3: 22.220
- 296: SP#47 completed. Chosen solution has no normative impacts / Text3: new 23.832
- 297: SP#49 completed / Text3: 33.320

| ID | WBS | Task | Type | Duration | Start | Finish | Complete | Remaining | Baseline start | Baseline finish | Baseline duration | Total slack | Constraint | Resources | Work | Actual work | Text1 | Text2 | Text4 | Text5 | Text6 | Text7 | Text8 | Text11 | Text9 | Text12 |
| --- | --- | --- | --- | --- | --- | --- | --- | --- | --- | --- | --- | --- | --- | --- | --- | --- | --- | --- | --- | --- | --- | --- | --- | --- | --- | --- |
| 298 | 124 | **Optimal Media Routing** |  | 314d? | 2010-03-25 A | 2011-06-08 | 86% | 45.29d? | 2010-03-25 | 2011-06-08 | 314d? | 462d |  | S2,S5,C3,C1,C4 | 10984h | 7105.63h | OMR | PCG-24 | Alcatel-Lucent | andy.bennett@alcatel-lucent.com | Rel-10 | SP-46 | Maurice |  |  |  |
| 299 | 124.1 | Stage 2 for Optimal Media Routing | milestone | 0d? | 2010-03-25 A | 2010-03-25 A | 100% |  | 2010-03-25 | 2010-03-25 | 0d? |  |  | S2 |  |  | OMR | PCG-24 | Alcatel-Lucent | andy.bennett@alcatel-lucent.com | Rel-10 | SP-46 | Maurice |  |  |  |
| 300 | 124.2 | **Stage 3 for Optimal Media Routing** |  | 261d? | 2010-06-04 A | 2011-06-03 | 99% | 1.01d? | 2010-06-04 | 2011-06-03 | 261d? | 465d |  | C3,C1,C4 | 7472h | 7005.63h | OMR | PCG-25 | Alcatel-Lucent | jim.calme@alcatel-lucent.com | Rel-10 | CP-48 | Jiwan |  |  |  |
| 301 | 124.2.1 | CT3 part of Stage 3 for Optimal Media Routeing |  | 261d? | 2010-06-04 A | 2011-06-03 | 99% | 2.61d? | 2010-06-04 | 2011-06-03 | 261d? | 465d | finish no earlier than 2011-06-03 | C3 | 2088h | 2067.12h | OMR | PCG-25 | Alcatel-Lucent | jim.calme@alcatel-lucent.com | Rel-10 | CP-48 | Jiwan | CP#51 exception to 06/11 |  |  |
| 302 | 124.2.2 | CT1 part of Stage 3 for Optimal Media Routeing |  | 206d? | 2010-06-04 A | 2011-03-18 A | 100% |  | 2010-06-04 | 2011-03-18 | 206d? |  | finish no earlier than 2011-03-18 | C1 | 1648h | 1648h | OMR | PCG-25 | Alcatel-Lucent | jim.calme@alcatel-lucent.com | Rel-10 | CP-48 | Frederic |  |  |  |
| 303 | 124.2.3 | Deleted - CT4 part of Stage 3 for Optimal Media Routeing |  | 206d? | 2010-06-04 A | 2011-03-18 A | 100% |  | 2010-06-04 | 2011-03-18 | 206d? |  | finish no earlier than 2011-03-18 | C4 | 1648h | 1648h | OMR | PCG-25 | Alcatel-Lucent | jim.calme@alcatel-lucent.com | Rel-10 | CP-48 | Kimmo |  | PCG-26 | CP-51 |
| 304 | 124.3 | Charging for Optimal Media Routing |  | 125d? | 2010-12-16 A | 2011-06-08 | 10% | 112.5d? | 2010-12-16 | 2011-06-08 | 125d? | 462d | finish no earlier than 2011-06-08 | S5 | 1000h | 100h | OMR | PCG-26 | Alcatel-Lucent | maryse.gardella@alcatel-lucent.com | Rel-10 | SP-50 | Dionisio | Exception sheet in SP-110151 |  |  |
| 305 | 125 | **IMS Emergency Session Enhancements** |  | 312d? | 2010-03-25 A | 2011-06-03 | 98% | 7.62d? | 2010-03-25 | 2011-06-03 | 312d? | 465d |  | S1,S2,C1 | 4560h | 2021.6h | IESE | PCG-24 | Deutsche Telekom, T-Mobile | michele.zarri@t-mobile.co.uk | Rel-10 | SP-47 | Maurice |  |  |  |
| 306 | 125.1 | Stage 1 for IMS Emergency Session Enhancements |  | 1d? | 2010-03-25 A | 2010-03-25 A | 100% |  | 2010-03-25 | 2010-03-25 | 1d? |  | start no earlier than 2010-03-25 | S1 | 8h | 8h | IESE | PCG-24 | Deutsche Telekom, T-Mobile | Kurt Bischinger | Rel-10 | SP-47 | Alain |  |  |  |
| 307 | 125.2 | Stage 2 for IMS Emergency Session Enhancements |  | 131d? | 2010-03-25 A | 2010-09-23 A | 100% |  | 2010-03-25 | 2010-09-23 | 131d? |  | finish no earlier than 2010-09-23 | S2 | 1048h | 1048h | IESE | PCG-24 | Deutsche Telekom, T-Mobile | michele.zarri@t-mobile.co.uk | Rel-10 | SP-47 | Maurice |  |  |  |
| 308 | 125.3 | Stage 3 for IMS Emergency Session Enhancements |  | 126d? | 2010-12-10 A | 2011-06-03 | 95% | 6.3d? | 2010-12-10 | 2011-06-03 | 126d? | 465d | finish no earlier than 2011-06-03 | C1 | 1008h | 957.6h | IESE | PCG-26 | Deutsche Telekom | reinhard.lauster@t-mobile.at | Rel-10 | CP-50 | Frederic | Exception sheet in CP-110155 |  |  |
| 309 | 126 | **S2b Mobility based on GTP** |  | 202d? | 2010-06-10 A | 2011-03-18 A | 100% |  | 2010-06-10 | 2011-03-18 | 202d? |  |  | S2,C4,C3,C1 | 5856h | 5856h | SMOG | PCG-25 | Alcatel-Lucent | bruno.landais@alcatel-lucent.com | Rel-10 | SP-48 | Maurice |  |  |  |
| 310 | 126.1 | Stage 2 for S2b Mobility based on GTP |  | 76d? | 2010-06-10 A | 2010-09-23 A | 100% |  | 2010-06-10 | 2010-09-23 | 76d? |  | finish no earlier than 2010-09-23 | S2 | 608h | 608h | SMOG | PCG-25 | Alcatel-Lucent | bruno.landais@alcatel-lucent.com | Rel-10 | SP-48 | Maurice |  |  |  |
| 311 | 126.2 | **Stage 3 for S2b Mobility based on GTP** |  | 131d? | 2010-09-17 A | 2011-03-18 A | 100% |  | 2010-09-17 | 2011-03-18 | 131d? |  |  | C4,C3,C1 | 3632h | 3632h | SMOG-St3 | PCG-25 | Alcatel-Lucent | bruno.landais@alcatel-lucent.com | Rel-10 | CP-49 | Kimmo |  |  |  |
| 312 | 126.2.1 | CT4 part of Stage 3 for S2b Mobility based on GTP |  | 131d? | 2010-09-17 A | 2011-03-18 A | 100% |  | 2010-09-17 | 2011-03-18 | 131d? |  | finish no earlier than 2011-03-18 | C4 | 1048h | 1048h | SMOG-St3 | PCG-25 | Alcatel-Lucent | bruno.landais@alcatel-lucent.com | Rel-10 | CP-49 | Kimmo |  |  |  |
| 313 | 126.2.2 | CT3 part of Stage 3 for S2b Mobility based on GTP |  | 131d? | 2010-09-17 A | 2011-03-18 A | 100% |  | 2010-09-17 | 2011-03-18 | 131d? |  | finish no earlier than 2011-03-18 | C3 | 1048h | 1048h | SMOG-St3 | PCG-25 | Alcatel-Lucent | bruno.landais@alcatel-lucent.com | Rel-10 | CP-49 | Jiwan |  |  |  |
| 314 | 126.2.3 | CT1 part of Stage 3 for S2b Mobility based on GTP |  | 61d? | 2010-09-17 A | 2010-12-10 A | 100% |  | 2010-09-17 | 2010-12-10 | 61d? |  | finish no earlier than 2010-12-10 | C1 | 488h | 488h | SMOG-St3 | PCG-25 | Alcatel-Lucent | bruno.landais@alcatel-lucent.com | Rel-10 | CP-49 | Frederic |  |  |  |
| 315 | 127 | **Policy Enhancements for Sponsored Connectivity and Coherent Access to Policy related Databases** |  | 113.15d? | 2010-10-12 A | 2011-03-18 A | 100% |  | 2010-10-12 | 2011-03-18 | 113.15d? |  |  | S2,C3 | 1473.2h | 1473.2h | PEST | PCG-26 | Qualcomm | AC Mahendran (ac@qualcomm.com) | Rel-10 | SP-50 | Maurice |  |  |  |
| 316 | 127.1 | Stage 2 for Policy Enhancements for Sponsored Connectivity and Coherent Access to Policy related Databases | milestone | 0d? | 2010-10-12 A | 2010-12-15 A | 100% |  | 2010-10-12 | 2010-12-15 | 0d? |  | finish no earlier than 2010-12-15 | S2 |  |  | PEST | PCG-26 | Qualcomm | AC Mahendran (ac@qualcomm.com) | Rel-10 | SP-50 | Maurice |  |  |  |
| 317 | 127.2 | CT3 aspects of Policy Enhancements for Sponsored Connectivity and Coherent Access to Policy related Databases |  | 71d? | 2010-12-10 A | 2011-03-18 A | 100% |  | 2010-12-10 | 2011-03-18 | 71d? |  | finish no earlier than 2011-03-18 | C3 | 568h | 568h | PEST-CT3 | PCG-26 | ZTE | zhou.xiaoyun@zte.com.cn | Rel-10 | CP-50 | Jiwan |  |  |  |
| 318 | 128 | **Lawful Interception in the 3GPP Rel-10** |  | 315d? | 2010-03-25 A | 2011-06-08 | 92% | 26.52d? | 2010-03-25 | 2011-06-08 | 315d? | 462d |  | S3 | 20480h | 18755.8h | LI10 | PCG-24 | PIDS, BT | Koen Jaspers (k.b.jaspers@minjus.nl), alex.leadbeater@bt.com | Rel-10 | SP-47 | Dionisio | Exception sheet in SP-110027 |  |  |
| 319 | 128.1 | LI for CAT (Customer Alerting Tones) |  | 315d? | 2010-03-25 A | 2011-06-08 | 80% | 63d? | 2010-03-25 | 2011-06-08 | 315d? | 462d | finish no earlier than 2011-03-23 | S3 | 2520h | 2016h | LI10 | PCG-24 | PIDS, BT | Koen Jaspers (k.b.jaspers@minjus.nl), alex.leadbeater@bt.com | Rel-10 | SP-47 | Dionisio | Exception sheet in SP-110027 |  |  |
| 320 | 128.2 | LI for CRS (Customized Ringing Signal) |  | 315d? | 2010-03-25 A | 2011-06-08 | 80% | 63d? | 2010-03-25 | 2011-06-08 | 315d? | 462d | finish no earlier than 2011-03-23 | S3 | 2520h | 2016h | LI10 | PCG-24 | PIDS, BT | Koen Jaspers (k.b.jaspers@minjus.nl), alex.leadbeater@bt.com | Rel-10 | SP-47 | Dionisio | Exception sheet in SP-110027 |  |  |
| 321 | 128.3 | LI for EPS enhancements |  | 315d? | 2010-03-25 A | 2011-06-08 | 80% | 63d? | 2010-03-25 | 2011-06-08 | 315d? | 462d | finish no earlier than 2011-03-23 | S3 | 2520h | 2016h | LI10 | PCG-24 | PIDS, BT | Koen Jaspers (k.b.jaspers@minjus.nl), alex.leadbeater@bt.com | Rel-10 | SP-47 | Dionisio | Exception sheet in SP-110027 |  |  |
| 322 | 128.4 | LI for VCC (Voice Call Continuity) |  | 260d? | 2010-03-25 A | 2011-03-23 A | 100% |  | 2010-03-25 | 2011-03-23 | 260d? |  | finish no earlier than 2011-03-23 | S3 | 2080h | 2080h | LI10 | PCG-24 | PIDS, BT | Koen Jaspers (k.b.jaspers@minjus.nl), alex.leadbeater@bt.com | Rel-10 | SP-47 | Dionisio |  |  |  |
| 323 | 128.5 | LI for MEDIASEC (IMS Media security) |  | 260d? | 2010-03-25 A | 2011-03-23 A | 100% |  | 2010-03-25 | 2011-03-23 | 260d? |  | finish no earlier than 2011-03-23 | S3 | 2080h | 2080h | LI10 | PCG-24 | PIDS, BT | Koen Jaspers (k.b.jaspers@minjus.nl), alex.leadbeater@bt.com | Rel-10 | SP-47 | Dionisio |  |  |  |
| 324 | 128.6 | LI for H(e)NB also with Local IP Access and Selected IP Traffic Offload (LIPA, SIPTO) |  | 260d? | 2010-03-25 A | 2011-03-23 A | 100% |  | 2010-03-25 | 2011-03-23 | 260d? |  | finish no earlier than 2011-03-23 | S3 | 2080h | 2080h | LI10 | PCG-24 | PIDS, BT | Koen Jaspers (k.b.jaspers@minjus.nl), alex.leadbeater@bt.com | Rel-10 | SP-47 | Dionisio |  |  |  |
| 325 | 128.7 | LI for MBMS_LTE_enh (Multimedia Broadcast and Multicast Service enhancements) |  | 260d? | 2010-03-25 A | 2011-03-23 A | 100% |  | 2010-03-25 | 2011-03-23 | 260d? |  | finish no earlier than 2011-03-23 | S3 | 2080h | 2080h | LI10 | PCG-24 | PIDS, BT | Koen Jaspers (k.b.jaspers@minjus.nl), alex.leadbeater@bt.com | Rel-10 | SP-47 | Dionisio |  |  |  |
| 326 | 128.8 | LI for LCLS (Local Call Local Switch) |  | 260d? | 2010-03-25 A | 2011-03-23 A | 100% |  | 2010-03-25 | 2011-03-23 | 260d? |  | finish no earlier than 2011-03-23 | S3 | 2080h | 2080h | LI10 | PCG-24 | PIDS, BT | Koen Jaspers (k.b.jaspers@minjus.nl), alex.leadbeater@bt.com | Rel-10 | SP-47 | Dionisio |  |  |  |
| 327 | 129 | Optimization of IMS based PSS and MBMS User Service |  | 260d? | 2010-03-25 A | 2011-03-23 A | 100% |  | 2010-03-25 | 2011-03-23 | 260d? |  | finish no earlier than 2011-03-23 | S4 | 2080h | 2080h | OPT_IMS_PSS_MBMS_US | PCG-24 | Ericsson | markus.kampmann@ericsson.com | Rel-10 | SP-47 | Paolo |  |  |  |
| 328 | 130 | HTTP-based Streaming and Download Services |  | 315d? | 2010-03-25 A | 2011-06-08 | 75% | 78.75d? | 2010-03-25 | 2011-06-08 | 315d? | 462d | finish no earlier than 2011-06-08 | S4 | 2520h | 1890h | HTTP_SDS | PCG-24 | Qualcomm | Thomas Stockhammer (c_tstock@qualcomm.com) | Rel-10 | SP-47 | Paolo | Exception sheet in SP-110044 |  |  |
| 329 | 131 | PSS and MBMS enhancements |  | 205d? | 2010-06-10 A | 2011-03-23 A | 100% |  | 2010-06-10 | 2011-03-23 | 205d? |  | finish no earlier than 2011-03-23 | S4 | 1640h | 1640h | MBS_Enh | PCG-25 | Ericsson | Markus.Kampmann@ericsson.com | Rel-10 | SP-48 | Paolo |  |  |  |
| 330 | 132 | Enhancements and Addition of Audio Tests to 26.131 and 26.132 |  | 260d? | 2010-06-10 A | 2011-06-08 | 55% | 117d? | 2010-06-10 | 2011-06-08 | 260d? | 462d | finish no earlier than 2011-06-08 | S4 | 2080h | 1144h | EAAT | PCG-25 | Vodafone | ramin.afchar@vodafone.com | Rel-10 | SP-48 | Paolo | Exception sheet in SP-110043 |  |  |
| 331 | 133 | Video Coding Enhancements in MTSI |  | 3d? | 2011-03-21 A | 2011-03-23 A | 100% |  | 2011-03-21 | 2011-03-23 | 3d? |  | start no earlier than 2011-03-21 | S4 | 24h | 24h | VCEM | PCG-26 | Ericsson | frederic.gabin@ericsson.com | Rel-10 | SP-51 | Paolo |  |  |  |

Notes:
- 298: SP#47 Stage 2 completed. Triggered by TR 23.894 (UID_370050 Study on System enhancements for the use of IMS services in local breakout)
- 299: SP#47 completed / Text3: 23.228
- 300: CP#51 completion 03/11=>06/11. WID updated CP-100327=>CP-110134
- 301: CP#51 completion 03/11=>06/11. WID updated CP-100327=>CP-110134 / Text3: 29.162, 29.163, 29.165, 29.235, new TS 29.079
- 302: CP#51 completed. WID updated CP-100327=>CP-110134 / Text3: 24.229
- 303: CP#51 stopped (CT4 specs not impacted). WID updated CP-100327=>CP-110134
- 304: SP#51 completion 03/11=>06/11 (exception in SP-110151). Stage 3: Linked to CT3 TS 29.079 OMR within the IMS; Stage 3 (UID_480110) / Text3: 32.260, 32.298, 32.299
- 305: SP#49 completed. Source of external requirements: ETSI TISPAN TS 181.019 (Business Communication Requirements)
- 306: SP#47 completed / Text3: 22.101 CR#0343
- 307: SP#49 completed / Text3: 23.167
- 308: CP#51 completion 03/11=>06/11 (exception in CP-110155) / Text3: 24.229
- 309: CP#51 completed. SP#49 Stage 2 completed. Related to Rel-10 UID_470049 Study on S2b mobility based on GTP (TR23.834), UID_350027 SAE for support for non-3GPP accesses. Stage1 in Rel-8 UID_320022 Reqs for evolution of 3GPP system architecture (AIPN-SAE)
- 310: SP#49 completed / Text3: 23.002, 23.203, 23.402
- 311: CP#51 Stage 3 completed
- 312: CP#51 completed / Text3: 23.003, 23.007, 23.008, 29.273, 29.274, 29.281, 29.303
- 313: CP#51 completed / Text3: 29.212, 29.213, 29.215
- 314: CP#50 completed / Text3: 24.302
- 315: CP#51 completed. SP#50 Stage 2 completed. Triggered by the SA1,SA2 Rel-10 TR 23.813 Study on Policy solutions and enhancements (FS_PP) UID_440047. Provides Video Call seamless service continuity for 3G/LTE terminal user
- 316: SP#51 updated WID SP-100702=>SP-110196. SA#49 work completed as SA2 CRs approved under TEI10 (SP-10557) / Text3: 23.002, 23.203
- 317: CP#51 completed / Text3: 29.212, 29.213, 29.214, 29.215
- 318: SP#51 completion 03/11=>06/11 (exception in SP-110027 for CAT, CRS and EPS enhancements / Text3: 33.106 (LI requirements), 33.107 (LI architecture and functions), 33.108 (Handover interface for LI)
- 319: SP#51 completion 03/11=>06/11 (exception in SP-110027) / Text3: 33.106, 33.107, 33.108
- 320: SP#51 completion 03/11=>06/11 (exception in SP-110027) / Text3: 33.106, 33.107, 33.108
- 321: SP#51 completion 03/11=>06/11 (exception in SP-110027) / Text3: 33.106, 33.107, 33.108
- 322: SP#51 completed / Text3: 33.106, 33.107, 33.108
- 323: SP#51 completed / Text3: 33.106, 33.107, 33.108
- 324: SP#51 completed / Text3: 33.106, 33.107, 33.108
- 325: SP#51 completed / Text3: 33.106, 33.107, 33.108
- 326: SP#51 completed / Text3: 33.106, 33.107, 33.108
- 327: SP#51 completed. Work to enhance UID_430046 Rel-9 IMS_PSS_MBMS_US_EXT / Text3: 26.237
- 328: SP#51 completion 03/11=>06/11 (Exception in SP-110044). Work to enhance UID_430038 Rel-9 PSS and MBMS extensions / Text3: 26.234, 26.244, 26.346, new 26.247 (Progressive Download and Dynamic Adaptive Streaming over HTTP (3GP-DASH))
- 329: SP#51 completed. Linked to Rel-9 Feature UID_430038 PSS and MBMS extensions (PMA-MBS_Ext). / Text3: 26.234, 26.346
- 330: SP#51 completion 03/11=>06/11 (Exception in SP-110043). Reduce fragmentation in acoustic testing (3GPP SA4, ETSI STQ, GCF CAG, CTIA) & Review existing acoustic tests to determine need for new spec / Text3: 26.131, 26.132
- 331: SP#51 completed. Linked to Rel-7 UID_7040 Multimedia Telephony Service for IMS - Media handling and interaction in MTSI (MTSI-MHI) / Text3: 26.114

| ID | WBS | Task | Duration | Start | Finish | Complete | Remaining | Baseline start | Baseline finish | Baseline duration | Total slack | Constraint | Resources | Work | Actual work | Text1 | Text2 | Text6 | Text7 | Text8 | Text4 | Text11 | Text9 | Text12 |
| --- | --- | --- | --- | --- | --- | --- | --- | --- | --- | --- | --- | --- | --- | --- | --- | --- | --- | --- | --- | --- | --- | --- | --- | --- |
| 332 | 134 | **OAM&P 10** | 390d? | 2009-12-10 A | 2011-06-08 | 92% | 32.07d? | 2009-12-10 | 2011-06-08 | 390d? | 462d |  | S5,C4 | 43536h | 36311.9h | OAM10 | PCG-24 | Rel-10 | SP-46 | Dionisio |  |  |  |  |
| 333 | 134.1 | **Network Infrastructure Management** | 390d? | 2009-12-10 A | 2011-06-08 | 84% | 63.73d? | 2009-12-10 | 2011-06-08 | 390d? | 462d |  | S5 | 13376h | 11190.1h | OAM10-NIM | PCG-24 | Rel-10 | SP-46 | Dionisio |  |  |  |  |
| 334 | 134.1.1 | Common RAT Network Resource Model (NRM) | 390d? | 2009-12-10 A | 2011-06-08 | 95% | 19.5d? | 2009-12-10 | 2011-06-08 | 390d? | 462d | finish no earlier than 2011-06-08 | S5 | 3120h | 2964h | RAT_NRM_common | PCG-24 | Rel-10 | SP-46 | Dionisio | Ericsson | Exception sheet in SP-110144 |  |  |
| 335 | 134.1.2 | IRP Solution Set specification organisation improvements | 260d? | 2010-03-25 A | 2011-03-23 A | 100% |  | 2010-03-25 | 2011-03-23 | 260d? |  | finish no earlier than 2011-03-23 | S5 | 2080h | 2080h | OAM-IRP-SS | PCG-24 | Rel-10 | SP-47 | Dionisio | Nokia Siemens Networks, Huawei |  |  |  |
| 336 | 134.1.3 | Deleted - Service Oriented Architecture (SOA) for IRP continuation from Rel-9 | 260d? | 2010-03-25 A | 2011-03-23 A | 100% |  | 2010-03-25 | 2011-03-23 | 260d? |  | finish no earlier than 2011-06-08 | S5 | 2080h | 2080h | OAM-SOA-IRP | PCG-24 | Rel-10 | SP-47 | Dionisio | Nokia Siemens Networks, Ericsson |  | PCG-26 | SP-51 |
| 337 | 134.1.4 | IRP Overview, Profiles & Usage Guide | 260d? | 2010-06-10 A | 2011-06-08 | 70% | 78d? | 2010-06-10 | 2011-06-08 | 260d? | 462d | finish no earlier than 2011-06-08 | S5 | 2080h | 1456h | OAM-NIM-IRP_OPU | PCG-25 | Rel-10 | SP-48 | Dionisio | Nokia Siemens Networks | Exception sheet in SP-110145 |  |  |
| 338 | 134.1.5 | Alarm Correlation and Root Cause Analysis | 56d? | 2011-03-23 | 2011-06-08 |  |  | 2011-03-23 | 2011-06-08 | 56d? | 462d | start no earlier than 2011-03-23 | S5 | 448h |  | OAM-AC-RCA | PCG-26 | Rel-10 | SP-51 | Dionisio | Ericsson | Exception sheet in SP-110147 |  |  |
| 339 | 134.1.6 | Inventory Management Network Resource Model enhancements | 56d? | 2011-03-23 | 2011-06-08 |  |  | 2011-03-23 | 2011-06-08 | 56d? | 462d | start no earlier than 2011-03-23 | S5 | 448h |  | OAM-IM-NMR | PCG-26 | Rel-10 | SP-51 | Dionisio | Nokia Siemens Networks | Exception sheet in SP-110142 |  |  |
| 340 | 134.2 | **Self-Organizing Networks (SON) - OAM aspects** | 390d? | 2009-12-10 A | 2011-06-08 | 94% | 23.16d? | 2009-12-10 | 2011-06-08 | 390d? | 462d |  | S5 | 11000h | 10346.7h | OAM10-SON | PCG-24 | Rel-10 | SP-46 | Dionisio |  |  |  |  |
| 341 | 134.2.1 | SON Self-optimization management continuation | 390d? | 2009-12-10 A | 2011-06-08 | 85% | 58.5d? | 2009-12-10 | 2011-06-08 | 390d? | 462d | finish no earlier than 2011-03-23 | S5 | 3120h | 2652h | LTE-SON-OAM_SO | PCG-24 | Rel-10 | SP-46 | Dionisio | Huawei | Exception sheet in SP-110146 |  |  |
| 342 | 134.2.2 | SON Self-healing management | 335d? | 2009-12-10 A | 2011-03-23 A | 100% |  | 2009-12-10 | 2011-03-23 | 335d? |  | finish no earlier than 2011-03-23 | S5 | 2680h | 2680h | LTE-SON-OAM_SH | PCG-24 | Rel-10 | SP-46 | Dionisio | ZTE |  |  |  |
| 343 | 134.2.3 | OAM aspects of Energy Saving in Radio Networks | 260d? | 2010-03-25 A | 2011-03-23 A | 100% |  | 2010-03-25 | 2011-03-23 | 260d? |  | finish no earlier than 2011-03-23 | S5 | 2080h | 2080h | OAM-ES | PCG-24 | Rel-10 | SP-47 | Dionisio | Nokia Siemens Networks |  |  |  |
| 344 | 134.3 | Subscription Management (SuM) evolution | 260d? | 2010-03-25 A | 2011-03-23 A | 100% |  | 2010-03-25 | 2011-03-23 | 260d? |  | finish no earlier than 2011-03-23 | S5 | 2080h | 2080h | OAM10-SuM | PCG-24 | Rel-10 | SP-47 | Dionisio | Ericsson |  |  |  |
| 345 | 134.4 | **Performance Management** | 315d? | 2010-03-25 A | 2011-06-08 | 97% | 8.9d? | 2010-03-25 | 2011-06-08 | 315d? | 462d |  | S5,C4 | 13960h | 11991h | OAM10-PM | PCG-24 | Rel-10 | SP-47 | Dionisio |  |  |  |  |
| 346 | 134.4.1 | Key Performance Indicators (KPIs) for IMS | 260d? | 2010-03-25 A | 2011-03-23 A | 100% |  | 2010-03-25 | 2011-03-23 | 260d? |  | finish no earlier than 2011-03-23 | S5 | 2080h | 2080h | OAM-PM-KPI_IMS | PCG-24 | Rel-10 | SP-47 | Dionisio | China Mobile |  |  |  |
| 347 | 134.4.2 | Key Performance Indicators (KPIs) for EPC | 260d? | 2010-03-25 A | 2011-03-23 A | 100% |  | 2010-03-25 | 2011-03-23 | 260d? |  | finish no earlier than 2011-03-23 | S5 | 2080h | 2080h | OAM-PM-KPI_EPC | PCG-24 | Rel-10 | SP-47 | Dionisio | China Mobile |  |  |  |
| 348 | 134.4.3 | **Management of UE based network performance measurements** | 315d? | 2010-03-25 A | 2011-06-08 | 91% | 29.62d? | 2010-03-25 | 2011-06-08 | 315d? | 462d |  | S5,C4 | 5200h | 4711.04h | OAM-PM-UE | PCG-24 | Rel-10 | SP-47 | Dionisio | Huawei, Nokia Siemens Networks, Ericsson | Exception sheet in SP-110143 |  |  |
| 349 | 134.4.3.1 | Management of UE based network performance measurements | 315d? | 2010-03-25 A | 2011-06-08 | 90% | 31.5d? | 2010-03-25 | 2011-06-08 | 315d? | 462d | finish no earlier than 2011-06-08 | S5 | 2520h | 2268h | OAM-PM-UE | PCG-24 | Rel-10 | SP-47 | Dionisio | Huawei, Nokia Siemens Networks, Ericsson | Exception sheet in SP-110143 |  |  |
| 350 | 134.4.3.2 | CN aspects of Management of UE based network performance measurements | 20d? | 2011-02-21 A | 2011-03-18 A | 100% |  | 2011-02-21 | 2011-03-18 | 20d? |  | start no earlier than 2011-02-21 | C4 | 160h | 160h | OAM-PM-UE | PCG-26 | Rel-10 | CP-51 | Kimmo | Nokia Siemens Networks |  |  |  |
| 351 | 134.4.4 | 3G HNB and LTE HeNB Subsystem performance measurements | 260d? | 2010-03-25 A | 2011-03-23 A | 100% |  | 2010-03-25 | 2011-03-23 | 260d? |  | finish no earlier than 2011-03-23 | S5 | 2080h | 2080h | OAM-PM-HeNS | PCG-24 | Rel-10 | SP-47 | Dionisio | China Mobile |  |  |  |
| 352 | 135 | **Charging Management small Enhancements** | 470d? | 2009-06-04 A | 2011-03-23 A | 100% |  | 2009-06-04 | 2011-03-23 | 470d? |  |  | S5 | 7520h | 7520h | CH10 | PCG-24 | Rel-10 | SP-47 | Dionisio |  |  |  |  |
| 353 | 135.1 | IWLAN mobility charging | 470d? | 2009-06-04 A | 2011-03-23 A | 100% |  | 2009-06-04 | 2011-03-23 | 470d? |  | finish no earlier than 2011-03-23 | S5 | 3760h | 3760h | eIWLAN_Mob | PCG-23 | Rel-10 | SP-44 | Dionisio | Orange |  |  |  |
| 354 | 136 | **Advice of Charge (AoC) service support enhancements** | 312d? | 2010-03-25 A | 2011-06-03 | 94% | 19.52d? | 2010-03-25 | 2011-06-03 | 312d? | 465d |  | S5,C1 | 6064h | 5684.66h | eAoC | PCG-24 | Rel-10 | SP-47 | Dionisio | Deutsche Telekom |  |  |  |
| 355 | 136.1 | SA5 part - AoC enhancements | 260d? | 2010-03-25 A | 2011-03-23 A | 100% |  | 2010-03-25 | 2011-03-23 | 260d? |  | finish no earlier than 2011-03-23 | S5 | 2080h | 2080h | eAoC | PCG-24 | Rel-10 | SP-47 | Dionisio | Deutsche Telekom |  |  |  |
| 356 | 136.2 | CT1 part - AoC enhancements (Stage 3) | 186d? | 2010-09-17 A | 2011-06-03 | 85% | 27.9d? | 2010-09-17 | 2011-06-03 | 186d? | 465d | finish no earlier than 2011-06-03 | C1 | 1488h | 1264.8h | eAoC | PCG-25 | Rel-10 | CP-49 | Frederic | Deutsche Telekom | Exception sheet in CP-110156 |  |  |
| 357 | 137 | IMS Stage 3 - IETF Protocol Alignment | 261d? | 2010-03-19 A | 2011-03-18 A | 100% |  | 2010-03-19 | 2011-03-18 | 261d? |  | finish no earlier than 2011-03-18 | C1 | 2088h | 2088h | IMSProtoc4 | PCG-24 | Rel-10 | CP-47 | Frederic | Alcatel-Lucent |  |  |  |
| 358 | 138 | Enhanced User Data Convergence (UDC) Model | 206d? | 2010-06-04 A | 2011-03-18 A | 100% |  | 2010-06-04 | 2011-03-18 | 206d? |  | finish no earlier than 2011-03-18 | C4 | 1648h | 1648h | eUDC | PCG-25 | Rel-10 | CP-48 | Kimmo | China Mobile |  |  |  |
| 359 | 139 | Further improvements of II-NNI Stage 3 based on operational feedback and evolution of other specifications | 206d? | 2010-06-04 A | 2011-03-18 A | 100% |  | 2010-06-04 | 2011-03-18 | 206d? |  | start no earlier than 2010-06-04 | C3 | 1648h | 1648h | II-NNI2 | PCG-25 | Rel-10 | CP-48 | Jiwan | Orange |  |  |  |
| 360 | 140 | AT Commands for IMS-configuration | 206d? | 2010-06-04 A | 2011-03-18 A | 100% |  | 2010-06-04 | 2011-03-18 | 206d? |  |  | C1 | 1648h | 1648h | AT_IMS | PCG-25 | Rel-10 | CP-48 | Frederic | Ericsson |  |  |  |
| 361 | 141 | AT Commands for USIM Application Toolkit (USAT) | 131d? | 2010-09-17 A | 2011-03-18 A | 100% |  | 2010-09-17 | 2011-03-18 | 131d? |  |  | C1 | 52.4h | 52.4h | AT_UICC | PCG-25 | Rel-10 | CP-49 | Frederic | ST-Ericsson |  |  |  |
| 362 | 142 | Communication Control for IMS by USIM (Stage 3) | 131d? | 2010-09-17 A | 2011-03-18 A | 100% |  | 2010-09-17 | 2011-03-18 | 131d? |  | start no earlier than 2010-09-17 | C6 | 1048h | 1048h | CC_IMS_USIM | PCG-25 | Rel-10 | CP-49 | Xavier | Gemalto |  |  |  |
| 363 | 143 | Dynamic view of SIP message for II-NNI (Stage 3) | 126d? | 2010-12-10 A | 2011-06-03 | 95% | 6.3d? | 2010-12-10 | 2011-06-03 | 126d? | 465d | finish no earlier than 2011-06-03 | C3 | 1008h | 957.6h | NNI_DV | PCG-26 | Rel-10 | CP-50 | Jiwan | NTT | Exception sheet in CP-110139 |  |  |
| 364 | 144 | Introduction of Smart Card Web Server launch functionality | 71d? | 2010-12-10 A | 2011-03-18 A | 100% |  | 2010-12-10 | 2011-03-18 | 71d? |  | finish no earlier than 2011-03-18 | C6 | 568h | 568h | SCWS_L | PCG-26 | Rel-10 | CP-50 | Xavier | Telecom Italia |  |  |  |
| 365 | 145 | USAT using AT Commands | 71d? | 2010-12-10 A | 2011-03-18 A | 100% |  | 2010-12-10 | 2011-03-18 | 71d? |  | finish no earlier than 2011-03-18 | C6 | 568h | 568h | USAT_AT | PCG-26 | Rel-10 | CP-50 | Xavier | Giesecke & Devrient |  |  |  |

Notes:
- 332: umbrella Feature
- 333: umbrella BB
- 334: SP#51 completion 03/11=>06/11 (exception in SP-110144). Share equipment btw several RATs (RET,TMA,repeaters) to reduce costs. With existing modelling is difficult to see that several cells are affected when an antenna tilt is changed etc / Text3: 32.616, 32.642, 32.646, 32.652, 32.656, 32.762, 32.766 new (32.791, 32.792, 32.796) / Text5: robert.petersen@ericsson.com
- 335: SP#51 completed / Text3: 32.153, new (32.111-6,32.126,32.176,32.306,32.316,32.326,32.336,32.346,32.356,32.366,32.376,32.386,32.396,32.416,32.446,32.506/26/36,32.606,32.616,32.626,32.636,32.646,32.656,32.666,32.676,32.696,32.716,32.726,32.736,32.746,32.756,32.766,32.776,32.786) / Text5: Jörg Schmidt (joerg@cox.net), Lan Zou (zlan@huawei.com)
- 336: SP#51 work stopped (Reason: lack of progress). Continuation of Rel-9 UID_440065 SOA for IRP (covering SOA Architecture & SOA-supporting Solution Set) to address SOA conforming Registration & Discovery capabilities / Text3: 32.101, 32.150 / Text5: Jörg Schmidt (joerg@cox.net), edwin.tse@ericsson.com
- 337: SP#51 completion 03/11=>06/11 (exception in SP-110145) / Text3: new TS 32.103 / Text5: Jörg Schmidt (joerg@cox.net)
- 338: SP#51 exception in SP-110147. Triggered by Rel-10 TR 32.832 Study on Alarm Correlation and Alarm Root Cause Analysis (UID_480045) and TR 32.829 Study on Harmonization of 3GPP Alarm IRP and TMF Interface Program Fault Management (UID_ 460038) / Text3: 32.111-1, 32.111-2, 32.111-6 / Text5: brendan.hassett@ericsson.com
- 339: SP#51 Exception in SP-110142. Inventory NRM specified in Rel-6 is mainly hardware related. Rel-10 TR 32.828 recommends extending the scope of inventory NRM. Additionally, NGMN Top OPE Recs, v1.0 sets inventory enhancements as one of top 10 priority items / Text3: 32.690, 32.691, 32.692, 32.696 / Text5: olaf.pollakowski@nsn.com
- 340: umbrella BB
- 341: SP#51 completion 03/11=>06/11 (exception in SP-110146). Updated WID SP-100756=>SP-110130. Cont'd Rel-9 SON self-optimization management UID_390007 / Text3: 32.425, 32.521, 32.522, 32.526, 32.762, 32.766 / Text5: Lan Zou (zlan@huawei.com)
- 342: SP#51 completed. WID updated SP-100776=>SP-110150. Work moved to Rel-10 after split of the Rel-9 UID_390007 SON self-optimization (removed Self-Healing handling) / Text3: 32.522, 32.526, 32.762, 32.766, new TS 32.541 / Text5: zhu.weihong@zte.com.cn
- 343: SP#51 completed. WID updated SP-100226=>SP-110128. Triggered by Rel-10 TR 32.826 Study on Telecommunication Management; Energy Savings Management (FS_OAM_ESM) UID_430044 / Text3: 32.425, 32.522, 32.526, 32.626, 32.762, 32.766, new 32.551 / Text5: clemens.suerbaum@nsn.com
- 344: SP#51 completed / Text3: 32.172, 32.175, 32.176 / Text5: leo.yang@ericsson.com
- 345: umbrella BB
- 346: SP#51 completed / Text3: new 32.454 / Text5: Li Jian (lijian@chinamobile.com), Liang Shuangchun (liangshuangchun@cmdi.chinamobile.com)
- 347: SP#51 completed / Text3: new 32.455 / Text5: Li Jian (lijian@chinamobile.com), Liang Shuangchun (liangshuangchun@cmdi.chinamobile.com)
- 348: SP#51 completion 03/11=>06/11 (exception in SP-110143). Stage 2/3. Linked to UID_460003 Minimization of drive tests for E-UTRAN and UTRAN (MDT_UMTSLTE) / Text5: Zou Lan (zlan@huawei.com), gyula.bodog@nsn.com, ulf.hubinette@ericsson.com
- 349: SP#51 completion 03/11=>06/11 (exception in SP-110143) / Text3: 32.421, 32.422, 32.423, 32.441, 32.442, 32.446 / Text5: Zou Lan (zlan@huawei.com), gyula.bodog@nsn.com, ulf.hubinette@ericsson.com
- 350: CP#51 completed under the SA5 WI code / Text3: 23.008 (CR#0330), 29.002 (CR#1007), 29.230 (CR#0207), 29.272 (CR#0329) / Text5: ulrich.wiehe@nsn.com
- 351: SP#51 completed / Text3: 32.582, 32.592, new (32.452, 32.453) / Text5: Chen Gang (chengang@chinamobile.com)
- 352: umbrella Feature
- 353: SP#51 completed. RAT differentiation for charging. Completes Rel-8 Feature IWLAN_Mob UID_370049 Mobility between 3GPP-WLAN Interworking and 3GPP Systems. Cooperation with CT1,CT3 on affected protocols / Text3: 32.240, 32.252, 32.298, 32.299 / Text5: Jean-Luc Garcia (jl.garcia@orange-ftgroup.com)
- 354: SP#51 completed SA5. Continuation of Rel-8 BB UID_80042: Advice of Charge (AoC) support in IMS Charging (IMSTSS). Stage 2/3 work / Text5: matthias.seibel@telekom.de
- 355: SP#51 completed. SA1 Stage 1 in 22.115 / Text3: 32.275, 32.280, 32.298, 32.299 / Text5: matthias.seibel@telekom.de
- 356: CP#51 completion 03/11=>06/11 (exception in CP-110156). SA1 Stage 1 in 22.115, 22.173, 22.024. Add mobile-specific CAI format and volume charging elements. Extensions to existing AoC XML / Text3: 24.647 / Text5: reinhard.lauster@t-mobile.at
- 357: CP#51 completed. Ensure protocol alignment between 3GPP Stage 3 IMS work and IETF. Review capabilities provided in SIP by IETF and document whether these capabilities are supported in the IM CN Subsystem or not / Text3: 23.218, 24.229, 24.930 / Text5: keith.drage@alcatel-lucent.com
- 358: CP#51 completed. Specify CRUD (Create/Read/Update/Delete) operations based on SOAP protocol, which may be used by the applications having no high real-time requirement to the data access operations / Text3: 29.335 / Text5: Lan Sizhong (lansizhong@chinamobile.com)
- 359: CP#51 completed. Improvements of Rel-9 Feature UID_440027 Operational description of the Inter-IMS Network to Network Interface (II-NNI) / Text3: 29.165 / Text5: beata.dobrowolska@orange-ftgroup.com
- 360: CP#51 completed. Specify 1) IMS-related AT-commands to configure MT and 2) IMS-related unsolicited response codes from MT to present to end-user / Text3: 27.007 / Text5: atle.monrad@ericsson.com
- 361: CP#51 completed / Text3: 27.007 / Text5: magnus.mk.karlsson@stericsson.com
- 362: CT#51 completed. Stage 1 in TS 22.038 USAT service description. Linked to CT6's UID_1273 Rel-5 BB Provisioning of IP-based multimedia services (24.229, 31.103) and UID_390021 Rel-8 BB CT6 aspects of SAE (31.102, 31.111) / Text3: 31.102, 31.103, 31.111 / Text5: Denis.Lheriteau@gemalto.com
- 363: CP#51 completion 03/11=>06/11 (exception in CP-110139). Linked to CT3 Rel-10 Feature UID_480014 Further improvements of II-NNI Stage 3 based on operational feedback and evolution of other specifications (II-NNI2) / Text3: 29.165 / Text5: arai.kenjiro@lab.ntt.co.jp
- 364: CP#51 completed. Define a solution which allows enabling to launch Smart Card Web Server services in an easy and simple manner / Text3: 31.102 / Text5: davide.pratone@telecomitalia.it
- 365: CP#51 completed. Stage 3 based on SA1 22.038CR#37r1 (Make USAT proactive capability reqs applicable to ME as a whole without regard to any particular configuration; e.g. a modem connected to an external display). Linked to CT1 Feature UID_ / Text3: Stage 3 31.102, 31.111 / Text5: enric.fort@gi-de.com

| ID | WBS | Task | Type | Duration | Start | Finish | Complete | Remaining | Baseline start | Baseline finish | Baseline duration | Total slack | Constraint | Resources | Work | Actual work | Text1 | Text2 | Text4 | Text5 | Text6 | Text7 | Text8 | Text11 |
| --- | --- | --- | --- | --- | --- | --- | --- | --- | --- | --- | --- | --- | --- | --- | --- | --- | --- | --- | --- | --- | --- | --- | --- | --- |
| 366 | 146 | **SRVCC enhancements (Stage 3)** |  | 71d? | 2010-12-10 A | 2011-03-18 A | 100% |  | 2010-12-10 | 2011-03-18 | 71d? |  |  | C1,C4 | 1704h | 1704h | eSRVCC | PCG-26 | China Mobile | Jiang Y (jiangyi@chinamobile.com) | Rel-10 | CP-50 | Frederic |  |
| 367 | 146.1 | CT1 part of Stage 3 for SRVCC enhancements - Stage 3 |  | 71d? | 2010-12-10 A | 2011-03-18 A | 100% |  | 2010-12-10 | 2011-03-18 | 71d? |  | finish no earlier than 2011-03-18 | C1 | 568h | 568h | eSRVCC | PCG-26 | China Mobile | Jiang Y (jiangyi@chinamobile.com) | Rel-10 | CP-50 | Frederic |  |
| 368 | 146.2 | CT4 part of Stage 3 for SRVCC enhancements - Stage 3 |  | 71d? | 2010-12-10 A | 2011-03-18 A | 100% |  | 2010-12-10 | 2011-03-18 | 71d? |  | finish no earlier than 2011-03-18 | C4 | 568h | 568h | eSRVCC | PCG-26 | China Mobile | Jiang Y (jiangyi@chinamobile.com) | Rel-10 | CP-50 | Kimmo |  |
| 369 | 147 | SRVCC in alerting phase (Stage 3) |  | 126d? | 2010-12-10 A | 2011-06-03 | 95% | 6.3d? | 2010-12-10 | 2011-06-03 | 126d? | 465d | finish no earlier than 2011-06-03 | C1 | 1008h | 957.6h | aSRVCC | PCG-26 | ZTE | li.shitao@zte.com.cn | Rel-10 | CP-50 | Frederic | No need for Exception sheet |
| 370 | 148 | **PCRF failure and restoration** |  | 71d? | 2010-12-10 A | 2011-03-18 A | 100% |  | 2010-12-10 | 2011-03-18 | 71d? |  |  | C4,C3 | 1562h | 1562h | PCRF_FR | PCG-26 | NEC | Toshiyuki Tamura (tamurato@aj.jp.nec.com) | Rel-10 | CP-50 | Kimmo |  |
| 371 | 148.1 | CT4 part of PCRF failure and restoration |  | 71d? | 2010-12-10 A | 2011-03-18 A | 100% |  | 2010-12-10 | 2011-03-18 | 71d? |  | finish no earlier than 2011-03-18 | C4 | 568h | 568h | PCRF_FR | PCG-26 | NEC | Toshiyuki Tamura (tamurato@aj.jp.nec.com) | Rel-10 | CP-50 | Kimmo |  |
| 372 | 148.2 | CT3 part of PCRF failure and restoration |  | 53.25d? | 2010-12-10 A | 2011-03-18 A | 100% |  | 2010-12-10 | 2011-03-18 | 53.25d? |  | start no earlier than 2010-12-10 | C3 | 426h | 426h | PCRF_FR | PCG-26 | NEC | Toshiyuki Tamura (tamurato@aj.jp.nec.com) | Rel-10 | CP-50 | Jiwan |  |
| 373 | 149 | Formalization of WLAN Files | milestone | 0d? | 2011-02-23 A | 2011-03-18 A | 100% |  | 2011-02-23 | 2011-03-18 | 0d? |  | start no earlier than 2011-03-16 | C1 |  |  | FoWF | PCG-26 | Deutsche Telekom | dieter.jacobsohn@telekom.de | Rel-10 | CP-51 | Frederic |  |
| 374 | 150 | CS and IMS Interworking for CAT service - Early Session model |  | 58d? | 2011-03-16 A | 2011-06-03 | 90% | 5.8d? | 2011-03-16 | 2011-06-03 | 58d? | 465d |  | C3 | 464h | 417.6h | CIIC_ES | PCG-26 | ZTE | li.shitao@zte.com.cn | Rel-10 | CP-51 | Jiwan | Exception sheet in CP-110138 |
| 375 | 151 | EPC Node Restoration (without Idle mode Signalling Reduction ISR activated) |  | 3d? | 2011-03-16 A | 2011-03-18 A | 100% |  | 2011-03-16 | 2011-03-18 | 3d? |  | finish no earlier than 2011-03-18 | C4 | 24h | 24h | EPC_NR | PCG-26 | Alcatel-Lucent | bruno.landais@alcatel-lucent.com | Rel-10 | CP-51 | Kimmo |  |
| 376 | 152 | EPC Node Restoration with Idle mode Signalling Reduction (ISR) activated |  | 58d? | 2011-03-16 A | 2011-06-03 | 90% | 5.8d? | 2011-03-16 | 2011-06-03 | 58d? | 465d | finish no earlier than 2011-03-18 | C4 | 464h | 417.6h | EPC_NR_ISR | PCG-26 | NEC | Toshiyuki Tamura (tamurato@aj.jp.nec.com) | Rel-10 | CP-51 | Kimmo | Exception sheet in CP-110286 |
| 377 | 153 | Mobile Terminating Roaming Forwarding with pre-paging |  | 58d? | 2011-03-16 A | 2011-06-03 | 90% | 5.8d? | 2011-03-16 | 2011-06-03 | 58d? | 465d | finish no earlier than 2011-03-18 | C4 | 464h | 417.6h | MTRF | PCG-26 | Ericsson | philip.hodges@ericsson.com | Rel-10 | CP-51 | Kimmo | Exception sheet in CP-110089 |
| 378 | 154 | **UICC access to IMS Specification** |  | 58d? | 2011-03-16 A | 2011-06-03 | 5% | 55.15d? | 2011-03-16 | 2011-06-03 | 58d? | 465d |  | C6,C1 | 952h | 46.82h | IMS-UICC-S | PCG-26 | Gemalto | Denis.Lheriteau@gemalto.com | Rel-10 | CP-51 | Xavier |  |
| 379 | 154.1 | CT6 part of UICC access to IMS Specification |  | 3d? | 2011-03-16 A | 2011-03-18 A | 100% |  | 2011-03-16 | 2011-03-18 | 3d? |  | start no earlier than 2011-03-16 | C6 | 24h | 24h | IMS-UICC-S | PCG-26 | Gemalto | Denis.Lheriteau@gemalto.com | Rel-10 | CP-51 | Xavier |  |
| 380 | 154.2 | CT1 part of UICC access to IMS Specification |  | 58d? | 2011-03-16 | 2011-06-03 |  |  | 2011-03-16 | 2011-06-03 | 58d? | 465d | start no earlier than 2011-03-16 | C1 | 464h |  | IMS-UICC-S | PCG-26 | Gemalto | Denis.Lheriteau@gemalto.com | Rel-10 | CP-51 | Frederic |  |
| 381 | 155 | 1.28 Mcps TDD Repeater |  | 599d? | 2007-12-04 A | 2010-03-19 A | 100% |  | 2007-12-04 | 2010-03-19 | 599d? |  | finish no earlier than 2010-03-19 | R4 | 4792h | 4792h | RANimp-Repeaters1.28TDD | PCG-21 | RITT | qinyan@chinattl.com | Rel-10 | RP-38 | Issam | RP-100039 |
| 382 | 156 | 1.28 Mcps TDD Multi-carrier HSUPA |  | 321d? | 2009-09-18 A | 2010-12-10 A | 100% |  | 2009-09-18 | 2010-12-10 | 321d? |  | finish no earlier than 2010-12-10 | R1,R2,R3,R4 | 2568h | 2568h | TDD_MC_HSUPA | PCG-23 | CATR | Aihui Song (songaihui@mail.ritt.com.cn) | Rel-10 | RP-45 | Patrick | RP-101079 |
| 383 | 157 | **1.28 Mcps TDD Home NodeB RF requirements** |  | 266d? | 2009-12-04 A | 2010-12-10 A | 100% |  | 2009-12-04 | 2010-12-10 | 266d? |  |  | R4 | 5304h | 5304h | HNB_LCRTDD_RF | PCG-24 | TD Tech | Li Rong (lirong@td-tech.com) | Rel-10 | RP-46 | Issam |  |
| 384 | 157.1 | Core part: 1.28Mcps TDD Home NodeB RF requirements |  | 131d? | 2009-12-04 A | 2010-06-04 A | 100% |  | 2009-12-04 | 2010-06-04 | 131d? |  | finish no earlier than 2010-12-10 | R4 | 1048h | 1048h | HNB_LCRTDD_RF-Core | PCG-24 | TD Tech | Li Rong (lirong@td-tech.com) | Rel-10 | RP-46 | Issam | RP-100446 |
| 385 | 157.2 | Perf. part: 1.28Mcps TDD Home NodeB RF requirements |  | 266d? | 2009-12-04 A | 2010-12-10 A | 100% |  | 2009-12-04 | 2010-12-10 | 266d? |  | finish no earlier than 2010-12-10 | R4 | 2128h | 2128h | HNB_LCRTDD_RF-Perf | PCG-24 | TD Tech | Li Rong (lirong@td-tech.com) | Rel-10 | RP-46 | Issam | RP-101081 |
| 386 | 158 | **Multi-User Multiple-Input and Multiple-Output (MU-MIMO) for 1.28Mcps TDD** |  | 316d? | 2010-03-19 A | 2011-06-03 | 50% | 157.56d? | 2010-03-19 | 2011-06-03 | 316d? | 465d |  | R1,R2,R3,R4 | 6584h | 3301.09h | MUMIMO_LCR_TDD | PCG-24 | CATT | Yanping Xing (xingyanping@datangmobile.cn) | Rel-10 | RP-47 | Patrick |  |
| 387 | 158.1 | Core part: MU-MIMO for 1.28Mcps TDD |  | 191d? | 2010-03-19 A | 2010-12-10 A | 100% |  | 2010-03-19 | 2010-12-10 | 191d? |  | finish no earlier than 2010-12-10 | R1,R2,R3 | 1528h | 1528h | MUMIMO_LCR_TDD-Core | PCG-24 | CATT | Yanping Xing (xingyanping@datangmobile.cn) | Rel-10 | RP-47 | Patrick | RP-101085 |
| 388 | 158.2 | Perf. part: MU-MIMO for 1.28Mcps TDD |  | 316d? | 2010-03-19 A | 2011-06-03 | 20% | 252.8d? | 2010-03-19 | 2011-06-03 | 316d? | 465d | finish no earlier than 2011-06-03 | R4 | 2528h | 505.6h | MUMIMO_LCR_TDD-Perf | PCG-24 | CATT | Sanjun Feng (fengsanjun@datangmobile.cn) | Rel-10 | RP-47 | Issam | RP-110049 |
| 389 | 159 | **AGNSS Minimum Performance for UTRAN** |  | 446d? | 2009-09-18 A | 2011-06-03 | 93% | 30d? | 2009-09-18 | 2011-06-03 | 446d? | 465d |  | R4,R5 | 8224h | 7670.79h | AGNSSPerf_UTRAN | PCG-23 | Thales | Michel.monnerat@thalesaleniaspace.com | Rel-10 | RP-45 | Issam |  |
| 390 | 159.1 | AGNSS Minimum Performance Specification Development |  | 321d? | 2009-09-18 A | 2010-12-10 A | 100% |  | 2009-09-18 | 2010-12-10 | 321d? |  | finish no earlier than 2010-12-10 | R4 | 2568h | 2568h | AGNSSPerf_UTRAN | PCG-23 | Thales | Michel.monnerat@thalesaleniaspace.com | Rel-10 | RP-45 | Issam | RP-101078 |
| 391 | 159.2 | AGNSS test case development for UMTS |  | 261d? | 2010-06-04 A | 2011-06-03 | 85% | 39.15d? | 2010-06-04 | 2011-06-03 | 261d? | 465d | finish no earlier than 2011-06-03 | R5 | 2088h | 1774.8h | AGNSSTest_UTRAN | PCG-25 | Thales | Michel.monnerat@thalesaleniaspace.com | Rel-10 | RP-48 | Ingbert | RP-110036 |

Notes:
- 366: Triggered by SA2 TR 23.856 Study on Single Radio Voice Call Continuity enhancements (FS_eSRVCC) UID_440049 / Text3: Stage 3
- 367: CP#51 completed / Text3: 24.229, 24.237
- 368: CP#51 completed / Text3: 23.003, 23.008, 29.002, 29.230, 29.272, 29.305, 29.328, 29.329
- 369: CP#51 completion 03/11=>06/11. WID updated CP-100839=>CP-110145. Builds on Rel-8 UID_390057 (IMS-Cont) TS 23.216 Stage 2. Provide Stage 3 for SRVCC PS-CS transfer of a call in alerting phase. Stage 2 TEI10 in TS 23.237 (6.3.2.1.4c/d, 6.3.2.1.7a/b) / Text3: 24.008, 24.237
- 370: CP#51 completed. Triggered by CT3 TR 29.816 Study on Policy and Charging Rules Function (PCRF) failure and restoration (FS_PCRF-FR) UID_450013 / Text3: Stage 2/3 work
- 371: CP#51 completed / Text3: Stage 2 23.007, Stage 3 29.230
- 372: CP#51 completed / Text3: Stage 3 29.212, 29.213, 29.214, 29.215
- 373: CP#51 completed. TS 24.235 for Info+Approval. Define the ME files as specified in 24.234 in OMA Device Management structure / Text3: Stage 3: 24.234, new 24.235
- 374: CP#51 exception sheet in CP-110138. Stage 1 in Rel-8 TS 22.182 Customized Alerting Tones (CAT) service. Stage 3 TS 24.182 defines 3 impl models: Gateway, Forking, Early Session. Specify missing CAT service interworking procedures btw CS & IMS networks / Text3: Stage 3 29.163, 29.235, 29.292
- 375: CP#51 completed. Triggered by DRAFT TR 23.857 Study on EPC Nodes Restoration (FS_EPC_NR) UID_490014 / Text3: Stage 2/3: 23.007, 29.274
- 376: CP#51 Exception sheet in CP-110286. Triggered by DRAFT TR 23.857 Study on EPC Nodes Restoration (FS_EPC_NR) UID_490014 / Text3: Stage 2/3: 23.007, 29.274
- 377: CP#51 Exception sheet in CP-110089. Provides Stage 2/3 alternative solution to Mobile Terminating Roaming Retry to solve roaming events during paging, in particular to support CSFB. Hence, no new Stage 1 requirements exist / Text3: Stage 2/3: 23.012, 23.018, 23.116, 29.002
- 378: CP#51 CT6 completed. Triggered by Rel-10 TR 31.828 Study on UICC access to IMS (FS_IMS-UICC) UID_480017. Specify mechanism in UICC and ME to make use of IMS functionality implemented in ME for case a) an ISIM is present b) no ISIM is present in UICC
- 379: CP#51 completed / Text3: 31.102, 31.103, 31.111
- 380: CP#51 exception to 06/11 / Text3: 24.229
- 381: RP#47 completed / Text3: UTRA 25.113, new 25.116, 25.153 (testing)
- 382: RP#50 completed / Text3: UTRA 25.102, 25.105, 25.123, 25.221, 25.222, 25.223, 25.224, 25.225, 25.306, 25.319, 25.321, 25.331, 25.423, 25.427, 25.433
- 383: RP#50 completed. Triggered by FS_RAN-HNBLCRTDD UID_410016 Study on 1.28 Mcps TDD Home NodeB (TR 25.866) / Text3: UTRA
- 384: RP#48 completed / Text3: 25.105
- 385: RP#50 completed. TR 25.968 v100 for Approval / Text3: 25.142, new TR 25.968
- 386: - / Text3: UTRA
- 387: RP#50 completed / Text3: 25.221, 25.222, 25.224, 25.306, 25.308, 25.319, 25.331, 25.423, 25.425, 25.433, 25.435
- 388: RP#50 completion 03/11=>06/11 / Text3: 25.102, 25.105, 25.142
- 389: Triggered by Rel-7 UID_20050 (GNSS in UTRAN) and Rel-8 UID_400051 (Support for Additional NSS). Linked to GERAN Rel-9 UID_38002 (A-GNSS Performances and Testing Procedures) / Text3: UTRA
- 390: RP#50 completed / Text3: new 25.172
- 391: RP#51 completion 03/11=>06/11. TS 34.172 v200 for Approval / Text3: 34.108, 34.109, 34.123-1, 34.123-2, 34.123-3, 36.37.571-5, new 34.172

| ID | WBS | Task | Duration | Start | Finish | Complete | Remaining | Baseline start | Baseline finish | Baseline duration | Total slack | Constraint | Resources | Work | Actual work | Text1 | Text2 | Text4 | Text5 | Text6 | Text7 | Text8 | Text11 | Text9 | Text12 |
| --- | --- | --- | --- | --- | --- | --- | --- | --- | --- | --- | --- | --- | --- | --- | --- | --- | --- | --- | --- | --- | --- | --- | --- | --- | --- |
| 392 | 160 | **Inclusion of RF Pattern Matching Technologies as positioning method in the UTRAN** | 336d? | 2009-12-04 A | 2011-03-18 A | 100% |  | 2009-12-04 | 2011-03-18 | 336d? |  |  | R2,R3 | 5376h | 5376h | LCS_UMTS_RFPMT | PCG-24 | Polaris Wireless | Norman Shaw (nshaw@polariswireless.com) | Rel-10 | RP-46 | Joern | RP-110048 |  |  |
| 393 | 160.1 | Core part: Inclusion of RF Pattern Matching Technologies as positioning method in the UTRAN | 336d? | 2009-12-04 A | 2011-03-18 A | 100% |  | 2009-12-04 | 2011-03-18 | 336d? |  | finish no earlier than 2011-03-18 | R2,R3 | 2688h | 2688h | LCS_UMTS_RFPMT-Core | PCG-24 | Polaris Wireless | Norman Shaw (nshaw@polariswireless.com) | Rel-10 | RP-46 | Joern | RP-110048 |  |  |
| 394 | 161 | **Four carrier HSDPA** | 391d? | 2009-12-04 A | 2011-06-03 | 57% | 168.23d? | 2009-12-04 | 2011-06-03 | 391d? | 465d |  | R1,R2,R3,R4 | 8944h | 5095.74h | 4C_HSDPA | PCG-24 | Qualcomm | Arjun Bharadwaj (arjunb@qualcomm.com) | Rel-10 | RP-46 | Patrick |  |  |  |
| 395 | 161.1 | Core part: Four carrier HSDPA | 336d? | 2009-12-04 A | 2011-03-18 A | 100% |  | 2009-12-04 | 2011-03-18 | 336d? |  | finish no earlier than 2011-03-18 | R1,R2,R3,R4 | 2688h | 2688h | 4C_HSDPA-Core | PCG-24 | Qualcomm | Arjun Bharadwaj (arjunb@qualcomm.com) | Rel-10 | RP-46 | Patrick | RP-110046 |  |  |
| 396 | 161.2 | Perf. part: Four carrier HSDPA | 391d? | 2009-12-04 A | 2011-06-03 | 20% | 312.8d? | 2009-12-04 | 2011-06-03 | 391d? | 465d | finish no earlier than 2011-06-03 | R4 | 3128h | 625.6h | 4C_HSDPA-Perf | PCG-24 | Qualcomm | Arjun Bharadwaj (arjunb@qualcomm.com) | Rel-10 | RP-46 | Issam | RP-110047 |  |  |
| 397 | 162 | **Performance Requirements for two-antenna 1.28Mcps TDD Type 1 and Type 2 UE receiver** | 316d? | 2010-03-19 A | 2011-06-03 | 66% | 107.37d? | 2010-03-19 | 2011-06-03 | 316d? | 465d |  | R4 | 5504h | 3633.82h | 2ant_UE_LCR_TDD | PCG-24 | TD Tech | dafei.wang@td-tech.com | Rel-10 | RP-47 | Issam | Perf. Exception sheet in RP-110207 |  |  |
| 398 | 162.1 | Core part: Performance Requirements for two-antenna 1.28Mcps TDD Type 1 and Type 2 UE receiver | 56d? | 2010-03-19 A | 2010-06-04 A | 100% |  | 2010-03-19 | 2010-06-04 | 56d? |  | finish no earlier than 2010-06-04 | R4 | 448h | 448h | 2ant_UE_LCR_TDD-Core | PCG-24 | TD Tech | dafei.wang@td-tech.com | Rel-10 | RP-47 | Issam | RP-100454 |  |  |
| 399 | 162.2 | Perf. part: Performance Requirements for two-antenna 1.28Mcps TDD Type 1 and Type 2 UE receiver | 316d? | 2010-03-19 A | 2011-06-03 | 60% | 126.4d? | 2010-03-19 | 2011-06-03 | 316d? | 465d | finish no earlier than 2011-06-03 | R4 | 2528h | 1516.8h | 2ant_UE_LCR_TDD-Perf | PCG-24 | TD Tech | dafei.wang@td-tech.com | Rel-10 | RP-47 | Issam | RP-110050 |  |  |
| 400 | 163 | **Automatic Neighbour Relation (ANR) for UTRAN** | 261d? | 2010-06-04 A | 2011-06-03 | 85% | 39.15d? | 2010-06-04 | 2011-06-03 | 261d? | 465d |  | R3,R2 | 4176h | 3549.6h | ANR_UTRAN | PCG-25 | ZTE | Zhai.hengxing@zte.com.cn | Rel-10 | RP-48 | Juha | Exception sheet in RP-110299 |  |  |
| 401 | 163.1 | Core part: Automatic Neighbour Relation (ANR) for UTRAN | 261d? | 2010-06-04 A | 2011-06-03 | 85% | 39.15d? | 2010-06-04 | 2011-06-03 | 261d? | 465d | finish no earlier than 2011-06-03 | R3,R2 | 2088h | 1774.8h | ANR_UTRAN-Core | PCG-25 | ZTE | Zhai.hengxing@zte.com.cn | Rel-10 | RP-48 | Juha | RP-110298 |  |  |
| 402 | 164 | **Support of New Band Combinations for Dual-Band Dual Cell HSDPA** | 261d? | 2010-06-04 A | 2011-06-03 | 96% | 10.11d? | 2010-06-04 | 2011-06-03 | 261d? | 465d |  | R4,R2 | 4784h | 4598.74h | DB_DC_HSDPA | PCG-25 | AT&T | Vince Spatafora (vs5785@att.com) | Rel-10 | RP-48 | Issam | Exception sheet in RP-110399 |  |  |
| 403 | 164.1 | Core part: Support of New Band Combinations for Dual-Band Dual Cell HSDPA | 261d? | 2010-06-04 A | 2011-06-03 | 95% | 13.05d? | 2010-06-04 | 2011-06-03 | 261d? | 465d | finish no earlier than 2011-06-03 | R4,R2 | 2088h | 1983.6h | DB_DC_HSDPA-Core | PCG-25 | AT&T | Vince Spatafora (vs5785@att.com) | Rel-10 | RP-48 | Issam | RP-110051 |  |  |
| 404 | 164.2 | Deleted - Perf. part: Support of New Band Combinations for Dual-Band Dual Cell HSDPA | 76d? | 2010-06-04 A | 2010-09-17 A | 100% |  | 2010-06-04 | 2010-09-17 | 76d? |  | finish no earlier than 2010-09-17 | R4,R2 | 608h | 608h | DB_DC_HSDPA-Perf | PCG-25 | AT&T | Vince Spatafora (vs5785@att.com) | Rel-10 | RP-48 | Issam | RP-100759 | PCG-25 | RP-49 |
| 405 | 165 | **MIMO operation with non-MIMO coexistence in HSDPA** | 466d? | 2010-06-04 A | 2012-03-16 | 49% | 236.75d? | 2010-06-04 | 2012-03-16 | 466d? | 260d |  | R4 | 9392h | 4620.39h | MIMO_HSDPA | PCG-25 | Qualcomm | Heechoon Lee | Rel-10 | RP-48 | Issam | Exception sheet in RP-110304 |  |  |
| 406 | 165.1 | Core part: MIMO operation with non-MIMO coexistence in HSDPA | 186d? | 2010-09-17 A | 2011-06-03 | 75% | 46.5d? | 2010-09-17 | 2011-06-03 | 186d? | 465d | finish no earlier than 2011-06-03 | R4 | 1488h | 1116h | MIMO_HSDPA-Core | PCG-25 | Qualcomm | Heechoon Lee | Rel-10 | RP-49 | Issam | RP-110052 |  |  |
| 407 | 165.2 | Perf. part: MIMO operation with non-MIMO coexistence in HSDPA | 261d? | 2010-06-04 A | 2011-06-03 | 80% | 52.2d? | 2010-06-04 | 2011-06-03 | 261d? | 465d | finish no earlier than 2011-06-03 | R4 | 2088h | 1670.4h | MIMO_HSDPA-Perf | PCG-25 | Qualcomm | Heechoon Lee | Rel-10 | RP-48 | Issam | RP-110053 |  |  |
| 408 | 165.3 | Test part: MIMO operation with non-MIMO coexistence in HSDPA | 261d? | 2011-03-18 | 2012-03-16 |  |  | 2011-03-18 | 2012-03-16 | 261d? | 260d | finish no earlier than 2012-03-16 | R5 | 2088h |  | MIMO_HSDPA-UEConTest | PCG-26 | Qualcomm | Shubhang Vora (svora@qualcomm.com) | Rel-10 | RP-51 | Ingbert |  |  |  |
| 409 | 166 | Interfrequency detected set measurements for UMTS | 61d? | 2010-09-17 A | 2010-12-10 A | 100% |  | 2010-09-17 | 2010-12-10 | 61d? |  | finish no earlier than 2010-12-10 | R2,R4 | 488h | 488h | Interf_dset_meas_UMTS | PCG-25 | Nokia | Chris.callender@nokia.com | Rel-10 | RP-49 | Joern | RP-101093 |  |  |
| 410 | 167 | **Extending 850 MHz Upper Band (814 – 849 MHz)** | 126d? | 2010-12-10 A | 2011-06-03 | 74% | 33.22d? | 2010-12-10 | 2011-06-03 | 126d? | 465d |  | R4,R2,R3,R5 | 3472h | 2374.4h | e850_UB | PCG-26 | Sprint | John.J.Humbert@Sprint.com | Rel-10 | RP-50 | Issam | Exception sheet in RP-110409 |  |  |
| 411 | 167.1 | Core part: Extending 850 MHz Upper Band (814 – 849 MHz) | 126d? | 2010-12-10 A | 2011-06-03 | 90% | 12.6d? | 2010-12-10 | 2011-06-03 | 126d? | 465d | finish no earlier than 2011-06-03 | R4,R2,R3 | 1008h | 907.2h | e850_UB-Core | PCG-26 | Sprint | John.J.Humbert@Sprint.com | Rel-10 | RP-50 | Issam | RP-110064 |  |  |
| 412 | 167.2 | Perf. part: Extending 850 MHz Upper Band (814 – 849 MHz) | 126d? | 2010-12-10 A | 2011-06-03 | 90% | 12.6d? | 2010-12-10 | 2011-06-03 | 126d? | 465d | finish no earlier than 2011-06-03 | R4,R2,R3 | 1008h | 907.2h | e850_UB-Perf | PCG-26 | Sprint | John.J.Humbert@Sprint.com | Rel-10 | RP-50 | Issam | RP-110065 |  |  |
| 413 | 167.3 | Test part: Extending 850 MHz Upper Band (814 – 849 MHz) | 56d? | 2011-03-18 | 2011-06-03 |  |  | 2011-03-18 | 2011-06-03 | 56d? | 465d | finish no earlier than 2011-06-03 | R5 | 448h |  | e850_UB-UEConTest | PCG-26 | Sprint | John.J.Humbert@Sprint.com | Rel-10 | RP-51 | Ingbert |  |  |  |
| 414 | 168 | **Carrier Aggregation for LTE** | 466d? | 2009-12-04 A | 2011-09-16 | 57% | 198.63d? | 2009-12-04 | 2011-09-16 | 466d? | 390d |  | R1,R2,R3,R4 | 10584h | 6072.52h | LTE_CA | PCG-24 | Nokia | Asbjorn.grovlen@nokia.com | Rel-10 | RP-46 | Patrick | Exception sheet in RP-110301 |  |  |
| 415 | 168.1 | Core part: Carrier Aggregation for LTE | 391d? | 2009-12-04 A | 2011-06-03 | 90% | 39.1d? | 2009-12-04 | 2011-06-03 | 391d? | 465d | finish no earlier than 2011-06-03 | R1,R2,R3,R4 | 3128h | 2815.2h | LTE_CA-Core | PCG-24 | Nokia | lars.e.lindh@nokia.com | Rel-10 | RP-46 | Patrick | RP-110387 |  |  |
| 416 | 168.2 | Perf. part: Carrier Aggregation for LTE | 466d? | 2009-12-04 A | 2011-09-16 | 30% | 326.2d? | 2009-12-04 | 2011-09-16 | 466d? | 390d | finish no earlier than 2011-09-16 | R4 | 3728h | 1118.4h | LTE_CA-Perf | PCG-24 | Nokia | lars.e.lindh@nokia.com | Rel-10 | RP-46 | Issam | RP-110072 |  |  |

Notes:
- 392: RP#51 completed. Triggered by Study UID_380079 Evaluation of the inclusion of Path Loss Based Technology in the UTRAN (25.907) / Text3: UTRA
- 393: RP#51 completed / Text3: 25.305, 25.453
- 394: - / Text3: UTRA
- 395: RP#51 completed / Text3: 25.101, 25.104, 25.133, 25.211, 25.212, 25.213, 25.214, 25.215, 25.308, 25.331, 25.423, 25.433, 26.306, new TR 25.864
- 396: - / Text3: 25.101, 25.104, 25.133, 25.141
- 397: Stage 3 / Text3: UTRA
- 398: RP#48 completed / Text3: 25.102
- 399: RP#51 completion 03/11=>06/11 (exception in RP-110207) / Text3: 25.102
- 400: Automatic Neighbour Relation (ANR) function for UTRAN relieves operators from the burden of manually managing the Neighbour cell Relations (NRs) / Text3: UTRA
- 401: RP#51 completion 03/11=>06/11 (exception in RP-110299). TS 25.484 v200 for Approval / Text3: 25.331, 25.413, 25.423, new TS 25.484 (Stage 2)
- 402: Rel-9 Dual-Band Dual-Cell HSDPA (UID_430015 Support for different bands for Dual-Cell HSDPA) has one combination per region in principle. This work adds additional combinations: Band I and XI (Region 3) and Band II and V (Region 2) / Text3: UTRA
- 403: RP#51 completion 03/11=>06/11 (exception in RP-110399) / Text3: 25.101, 25.104, 25.141, 25.317
- 404: RP#49 stopped (Reason: no need for Performance work) / Text3: 25.101, 25.104, 25.141, 25.317
- 405: RP#49 updated WID RP-100687=>RP-100993 (added Core WID, changed WID: Title MIMO Testing in HSDPA => MIMO operation with non-MIMO coexistence in HSDPA) / Text3: UTRA
- 406: RP#51 completion 03/11=>06/11 (extension in RP-110304) / Text3: 25.104
- 407: RP#49 updated WID RP-100687=>RP-100993 (added Core WID, changed WID: Title MIMO Testing in HSDPA => MIMO operation with non-MIMO coexistence in HSDPA) / Text3: 25.101, 25.141
- 408: - / Text3: 34.108, 34.121-1, 34.121-2, 34.123-1, 34.123-2, 34.123-3
- 409: RP#50 completed / Text3: UTRA 25.133, 25.331
- 410: Stage 3 Triggered by R4 Rel-10 LTE TR 37.806 Study on Extending 850 MHz (UID_440016) / Text3: UTRA
- 411: RP#51 completion 03/11=>06/11 (exception in RP-110409) / Text3: 25.101, 25.104, 25.113, 25.133, 25.141, 25.461, 25.466, 36.101, 36.104, 36.113, 36.124, 36.133, 36.141, 36.307, 36.331, 37.104, 37.113, 37.141
- 412: RP#51 completion 03/11=>06/11 / Text3: 25.101, 25.104, 25.113, 25.133, 25.141, 25.461, 25.466, 36.101, 36.104, 36.124, 36.133, 36.141, 36.307, 36.331, 37.104, 37.113, 37.141
- 413: E850 UB band in the E-UTRA and UTRA conformance test specifications / Text3: 34.108, 34.121-1, 34.121-2, 34.123-1, 34.123-2, 34.123-3, 36.508, 36.521-1, 36.521-2, 36.521-3, 36.523-1, 36.523-2, 36.523-3
- 414: Triggered by FS_RAN_LTEA (Study on LTE-Advanced) 36.912, 36. 814 / Text3: LTE
- 415: RP#51 completion 03/11=>06/11 (exception in RP-110301) / Text3: 36.101, 36.104, 36.133, 36.211, 36.212, 36.213, 36.300, 36.302, 36.306, 36.321, 36.331, 36.413, 36.423, 37.104
- 416: RP#50 TR 36.808 v1.0.0 for Information / Text3: 36.101, 36.104, 36.133, 36.141, 37.141, new TR (36.807, 36.808)

| ID | WBS | Task | Duration | Start | Finish | Complete | Remaining | Baseline start | Baseline finish | Baseline duration | Total slack | Constraint | Resources | Work | Actual work | Text1 | Text2 | Text4 | Text5 | Text6 | Text7 | Text8 | Text11 |
| --- | --- | --- | --- | --- | --- | --- | --- | --- | --- | --- | --- | --- | --- | --- | --- | --- | --- | --- | --- | --- | --- | --- | --- |
| 417 | 169 | **Enhanced Downlink Multiple Antenna Transmission for LTE** | 391d? | 2009-12-04 A | 2011-06-03 | 62% | 147.2d? | 2009-12-04 | 2011-06-03 | 391d? | 465d |  | R1,R2,R4 | 8944h | 5576.77h | LTE_eDL_MIMO | PCG-24 | NTT DoCoMo | Hidekazu Taoka (taoka@nttdocomo.com) | Rel-10 | RP-46 | Patrick |  |
| 418 | 169.1 | Core part: Enhanced Downlink Multiple Antenna Transmission for LTE | 336d? | 2009-12-04 A | 2011-03-18 A | 100% |  | 2009-12-04 | 2011-03-18 | 336d? |  | finish no earlier than 2011-03-18 | R1,R2,R4 | 2688h | 2688h | LTE_eDL_MIMO-Core | PCG-24 | NTT DoCoMo | Hidekazu Taoka (taoka@nttdocomo.com) | Rel-10 | RP-46 | Patrick | RP-110067 |
| 419 | 169.2 | Perf. part: Enhanced Downlink Multiple Antenna Transmission for LTE | 391d? | 2009-12-04 A | 2011-06-03 | 30% | 273.7d? | 2009-12-04 | 2011-06-03 | 391d? | 465d | finish no earlier than 2011-06-03 | R4 | 3128h | 938.4h | LTE_eDL_MIMO-Perf | PCG-24 | NTT DoCoMo | Hidekazu Taoka (taoka@nttdocomo.com) | Rel-10 | RP-46 | Issam | RP-110068 |
| 420 | 170 | **Uplink Multiple Antenna Transmission for LTE** | 391d? | 2009-12-04 A | 2011-06-03 | 65% | 136.85d? | 2009-12-04 | 2011-06-03 | 391d? | 465d |  | R1,R2,R4 | 9384h | 6099.6h | LTE_UL_MIMO | PCG-24 | Huawei | Mattias.wennstrom@huawei.com | Rel-10 | RP-46 | Patrick | Exception sheet in RP-110395 |
| 421 | 170.1 | Core part: UL multiple antenna transmission for LTE | 391d? | 2009-12-04 A | 2011-06-03 | 95% | 19.55d? | 2009-12-04 | 2011-06-03 | 391d? | 465d | finish no earlier than 2011-06-03 | R1,R2,R4 | 3128h | 2971.6h | LTE_UL_MIMO-Core | PCG-24 | Huawei | Mattias.wennstrom@huawei.com | Rel-10 | RP-46 | Patrick | RP-110394 |
| 422 | 170.2 | Perf. part: UL multiple antenna transmission for LTE | 391d? | 2009-12-04 A | 2011-06-03 | 35% | 254.15d? | 2009-12-04 | 2011-06-03 | 391d? | 465d | finish no earlier than 2011-06-03 | R4 | 3128h | 1094.8h | LTE_UL_MIMO-Perf | PCG-24 | Huawei | Mattias.wennstrom@huawei.com | Rel-10 | RP-46 | Issam | RP-110413 |
| 423 | 171 | **Fixed Wireless Customer-Premises Equipment (CPE) RF Requirements** | 391d? | 2009-12-04 A | 2011-06-03 | 28% | 283.48d? | 2009-12-04 | 2011-06-03 | 391d? | 465d |  | R4,R5 | 9384h | 2580.6h | FW_CPE_RF | PCG-24 | Verizon Wireless | zheng.zhao@verizonwireless.com | Rel-10 | RP-46 | Issam |  |
| 424 | 171.1 | Core part: Fixed Wireless Customer-Premises Equipment (CPE) RF Requirements | 391d? | 2009-12-04 A | 2011-06-03 | 55% | 175.95d? | 2009-12-04 | 2011-06-03 | 391d? | 465d | finish no earlier than 2011-06-03 | R4 | 3128h | 1720.4h | FW_CPE_RF-Core | PCG-24 | Verizon Wireless | zheng.zhao@verizonwireless.com | Rel-10 | RP-46 | Issam | RP-110066 |
| 425 | 171.2 | Test part: Fixed Wireless Customer-Premises Equipment (CPE) RF Requirements | 391d? | 2009-12-04 | 2011-06-03 |  |  | 2009-12-04 | 2011-06-03 | 391d? | 465d | finish no earlier than 2011-06-03 | R5 | 3128h |  | FW_CPE_RF-UEConTest | PCG-24 | Verizon Wireless | zheng.zhao@verizonwireless.com | Rel-10 | RP-46 | Ingbert | RP-110034 |
| 426 | 172 | **Relays for LTE** | 466d? | 2009-12-04 A | 2011-09-16 | 58% | 193.65d? | 2009-12-04 | 2011-09-16 | 466d? | 390d |  | R1,R2,R4,S3,C4,C6 | 11736h | 4866.64h | LTE_Relay | PCG-24 | Ericsson | christian.hoymann@ericsson.com | Rel-10 | RP-46 | Patrick | Exception sheet in RP-110415 |
| 427 | 172.1 | Core part: Relays for LTE | 391d? | 2009-12-04 A | 2011-06-03 | 83% | 66.47d? | 2009-12-04 | 2011-06-03 | 391d? | 465d | finish no earlier than 2011-06-03 | R1,R2,R4 | 3128h | 2596.24h | LTE_Relay-Core | PCG-24 | Ericsson | christian.hoymann@ericsson.com | Rel-10 | RP-46 | Patrick | RP-110073 |
| 428 | 172.2 | Perf. part: Relays for LTE | 466d? | 2009-12-04 A | 2011-09-16 | 25% | 349.5d? | 2009-12-04 | 2011-09-16 | 466d? | 390d | finish no earlier than 2011-09-16 | R4 | 3728h | 932h | LTE_Relay-Perf | PCG-24 | Ericsson | christian.hoymann@ericsson.com | Rel-10 | RP-46 | Issam | RP-110074 |
| 429 | 172.3 | TR on LTE Relay Nodes Security | 69d? | 2010-12-16 A | 2011-03-23 A | 100% |  | 2010-12-16 | 2011-03-23 | 69d? |  | finish no earlier than 2011-03-23 | S3 | 552h | 552h | LTE_Relay-Sec | PCG-26 | Qualcomm | Adrian Escott (aescott@qualcomm.com) | Rel-10 | SP-50 | Dionisio |  |
| 430 | 172.4 | Security for LTE Relay Nodes (Stage 2) | 69d? | 2010-12-16 A | 2011-03-23 A | 100% |  | 2010-12-16 | 2011-03-23 | 69d? |  | finish no earlier than 2011-03-23 | S3 | 552h | 552h | LTE_Relay-Sec | PCG-26 | Qualcomm | Adrian Escott (aescott@qualcomm.com) | Rel-10 | SP-50 | Dionisio |  |
| 431 | 172.5 | CT6 aspects of LTE Relay Node Security | 3d? | 2011-03-16 A | 2011-03-18 A | 100% |  | 2011-03-16 | 2011-03-18 | 3d? |  | start no earlier than 2011-03-16 | C6 | 24h | 24h | LTE_Relay-Sec | PCG-26 | n/a | n/a | Rel-10 | CP-51 | Xavier |  |
| 432 | 172.6 | Core Network Impacts for Relay Nodes | 3d? | 2011-03-16 A | 2011-03-18 A | 100% |  | 2011-03-16 | 2011-03-18 | 3d? |  | finish no earlier than 2011-03-18 | C4 | 24h | 24h | LTE_Relay-CN | PCG-26 | Vodafone | David.Hutton@vodafone.com | Rel-10 | CP-51 | Kimmo |  |
| 433 | 173 | **Enhanced Inter-Cell Interference Control (ICIC) for non-Carrier Aggregation (CA) based deployments of heterogeneous networks for LTE** | 391d? | 2010-03-19 A | 2011-09-16 | 65% | 138.48d? | 2010-03-19 | 2011-09-16 | 391d? | 390d |  | R1,R2,R3,R4 | 8784h | 5672.95h | eICIC_LTE | PCG-24 | China Mobile | Xiaodong XU (xuxiaodong@chinamobile.com) | Rel-10 | RP-47 | Patrick | Exception sheet in RP-110297 |
| 434 | 173.1 | Core part: Enhanced ICIC for non-CA based deployments of heterogeneous networks for LTE | 316d? | 2010-03-19 A | 2011-06-03 | 95% | 15.8d? | 2010-03-19 | 2011-06-03 | 316d? | 465d | finish no earlier than 2011-06-03 | R1,R2,R3,R4 | 2528h | 2401.6h | eICIC_LTE-Core | PCG-24 | China Mobile | Xiaodong XU (xuxiaodong@chinamobile.com) | Rel-10 | RP-47 | Patrick | RP-110075 |
| 435 | 173.2 | Perf. part: Enhanced ICIC for non-CA based deployments of heterogeneous networks for LTE | 391d? | 2010-03-19 A | 2011-09-16 | 40% | 234.6d? | 2010-03-19 | 2011-09-16 | 391d? | 390d | finish no earlier than 2011-09-16 | R4 | 3128h | 1251.2h | eICIC_LTE-Perf | PCG-24 | China Mobile | Xiaodong XU (xuxiaodong@chinamobile.com) | Rel-10 | RP-47 | Issam | RP-110076 |
| 436 | 174 | **LTE TDD in 2600MHz for US** | 191d? | 2010-03-19 A | 2010-12-10 A | 100% |  | 2010-03-19 | 2010-12-10 | 191d? |  |  | R4,R2,R3,R5 | 4712h | 4712h | LTE_TDD_2600_US | PCG-24 | Clearwire | michael.hart@clearwire.com | Rel-10 | RP-47 | Issam |  |
| 437 | 174.1 | Core part: LTE TDD in 2600MHz for US | 131d? | 2010-03-19 A | 2010-09-17 A | 100% |  | 2010-03-19 | 2010-09-17 | 131d? |  | finish no earlier than 2010-09-17 | R4,R2,R3 | 1048h | 1048h | LTE_TDD_2600_US-Core | PCG-24 | Clearwire | michael.hart@clearwire.com | Rel-10 | RP-47 | Issam | RP-100782 |
| 438 | 174.2 | Perf. part: LTE TDD in 2600MHz for US | 131d? | 2010-03-19 A | 2010-09-17 A | 100% |  | 2010-03-19 | 2010-09-17 | 131d? |  | finish no earlier than 2010-09-17 | R4 | 1048h | 1048h | LTE_TDD_2600_US-Perf | PCG-24 | Clearwire | michael.hart@clearwire.com | Rel-10 | RP-47 | Issam | RP-100783 |
| 439 | 174.3 | UE conformance test part: LTE TDD in 2600MHz for US | 136d? | 2010-06-04 A | 2010-12-10 A | 100% |  | 2010-06-04 | 2010-12-10 | 136d? |  | finish no earlier than 2010-12-10 | R5 | 1088h | 1088h | LTE_TDD_2600_US-UEConTest | PCG-25 | Clearwire | michael.hart@clearwire.com | Rel-10 | RP-48 | Ingbert | RP-101071 |
| 440 | 175 | **Adding 2 GHz band LTE for Ancillary Terrestrial Component (ATC) of Mobile Satellite Service (MSS) in North America** | 391d? | 2010-03-19 A | 2011-09-16 | 66% | 134.33d? | 2010-03-19 | 2011-09-16 | 391d? | 390d |  | R2,R4 | 8784h | 3973.6h | S_Band_LTE_ATC_MSS | PCG-24 | TerreStar, DBSD (formerly ICO) | Rhys.Robinson@terrestar.com, Mariam.Sorond@ico.com | Rel-10 | RP-47 | Joern | Exception sheet in RP-110401 |
| 441 | 175.1 | Core part: Adding 2 GHz band LTE for ATC of MSS in North America | 316d? | 2010-03-19 A | 2011-06-03 | 85% | 47.4d? | 2010-03-19 | 2011-06-03 | 316d? | 465d | finish no earlier than 2011-06-03 | R4,R2 | 2528h | 2148.8h | S_Band_LTE_ATC_MSS-Core | PCG-24 | TerreStar, DBSD (formerly ICO) | Rhys.Robinson@terrestar.com, Mariam.Sorond@ico.com | Rel-10 | RP-47 | Issam | RP-110329 |
| 442 | 175.2 | Perf. part: Adding 2 GHz band LTE for ATC of MSS in North America | 391d? | 2010-03-19 A | 2011-09-16 | 50% | 195.5d? | 2010-03-19 | 2011-09-16 | 391d? | 390d | finish no earlier than 2011-09-16 | R4 | 3128h | 1564h | S_Band_LTE_ATC_MSS-Perf | PCG-24 | TerreStar, DBSD (formerly ICO) | Rhys.Robinson@terrestar.com, Mariam.Sorond@ico.com | Rel-10 | RP-47 | Issam | RP-110330 |

Notes:
- 417: Triggered by FS_RAN_LTEA (Study on LTE-Advanced) 36.912, 36. 814 / Text3: LTE
- 418: RP#51 completed / Text3: 36.101, 36.104, 36.133, 36.201, 36.211, 36.212, 36.213, 36.300, 36.306, 36.321, 36.331
- 419: - / Text3: 36.101, 36.104, 36.133, 36.141
- 420: RP#51 changed Rapp Mattias.Wennstrom=> . Triggered by FS_RAN_LTEA (Study on LTE-Advanced) 36.912, 36. 814 / Text3: LTE
- 421: RP#51 completion 03/11=>06/11 (exception in RP-110395) Changed Rapp Mattias.Wennstrom=> / Text3: 36.101, 36.104, 36.133, 36.201, 36.211, 36.212, 36.213, 36.300, 36.306, 36.321, 36.331, new RAN4 TR 36.817
- 422: RP#51 changed Rapp Mattias.Wennstrom=> / Text3: 36.101, 36.104, 36.133, 36.141, 36.817
- 423: RP#51 work on HOLD. New companies invited to make proposals on way forward at RP#52. Add new power classes in E-UTRAN UL to allow CPE type applications to be operated at higher max output power / Text3: LTE
- 424: RP#51 work on HOLD. New companies invited to make proposals on way forward at RP#52 / Text3: 36.101
- 425: RP#51 work on HOLD. New companies invited to make proposals on way forward at RP#52 / Text3: 36.521-1
- 426: Triggered by FS_RAN_LTEA (Study on LTE-Advanced) 36.912, 36. 814. SP#51 SA3 Security completed / Text3: LTE
- 427: RP#51 exception in RP-110415 / Text3: 36.133, 36.201, 36.211, 36.212, 36.213, 36.300, 36.321, 36.323, 36.331, new RAN1 TS 36.216, new RAN4 (36.116, 36.826)
- 428: RP#50 completion 03/11=>09/11 / Text3: 36.133, new TS 36.117 (E-UTRA Relay conformance testing)
- 429: SP#51 completed / Text3: 33.816
- 430: SP#51 completed (impacting Stage 3 in CT and RAN) / Text3: 33.401 (CR#0437,0438), CT1 24.301, CT4 (29.272, 29.274), CT6 31.102, RAN2 (36.331, 36.323), RAN3 36.413
- 431: CP#51 completed / Text3: 31.101, 31.102
- 432: CP#51 completed / Text3: 23.003, 23.008, 29.303, 29.230, 29.272
- 433: Stage 3 Triggered by FS_RAN_LTEA (Study on LTE-Advanced) 36.912, 36.814 / Text3: LTE
- 434: RP#51 completion 03/11=>06/11 (exception in RP-110297) / Text3: 36.101, 36.133, 36.201, 36.211, 36.212, 36.213, 36.214, 36.300, 36.321, 36.331, 36.413, 36.423
- 435: - / Text3: 36.101, 36.133
- 436: RP#50 Testing completed. RP#49 Core+Perf completed / Text3: LTE
- 437: RP#49 completed / Text3: 25.461, 25.466, 36.101, 36.104, 36.113, 36.124, 36.133, 36.141, 36.307, 36.331, 37.104, 37.113, 37.141, new TR 36.812
- 438: RP#49 completed / Text3: 36.101, 36.104, 36.133, 36.141, 36.307, 37.104, 37.141, new TR 36.812
- 439: RP#50 completed / Text3: 36.508, 36.521-1, 36.521-2, 36.521-3, 36.523-1, 36.523-2, 36.523-3
- 440: Stage 3 / Text3: LTE
- 441: RP#51 completion 03/11=>06/11 (exception in RP-110401) / Text3: 25.101, 25.104, 25.141, 25.461, 25.466, 36.101, 36.104, 36.113, 36.124, 36.133, 36.307, 37.104, 37.141, new TR 36.811
- 442: RP#51 completion 06/11=>09/11 / Text3: 36.101, 36.104, 36.113, 36.124, 36.133, 36.141, 36.307, new 36.811

| ID | WBS | Task | Duration | Start | Finish | Complete | Remaining | Baseline start | Baseline finish | Baseline duration | Total slack | Constraint | Resources | Work | Actual work | Text1 | Text2 | Text4 | Text5 | Text6 | Text7 | Text8 | Text11 |
| --- | --- | --- | --- | --- | --- | --- | --- | --- | --- | --- | --- | --- | --- | --- | --- | --- | --- | --- | --- | --- | --- | --- | --- |
| 443 | 176 | **Adding L-Band (Band 24) LTE for Ancillary Terrestrial Component (ATC) of Mobile Satellite Service (MSS) in North America** | 391d? | 2010-03-19 A | 2011-09-16 | 44% | 219.85d? | 2010-03-19 | 2011-09-16 | 391d? | 390d |  | R4,R2 | 8792h | 3848.36h | L_Band_LTE_ATC_MSS | PCG-24 | LightSquared | Eric.Jacks@lightsquared.com, Maqbool.Aliani@lightsquared.com | Rel-10 | RP-47 | Issam |  |
| 444 | 176.1 | Core part: Adding L-Band (Band 24) LTE for ATC of MSS in North America | 261d? | 2010-03-19 A | 2011-03-18 A | 100% |  | 2010-03-19 | 2011-03-18 | 261d? |  | finish no earlier than 2010-12-10 | R4,R2 | 2088h | 2088h | L_Band_LTE_ATC_MSS-Core | PCG-24 | LightSquared | Eric.Jacks@lightsquared.com, Maqbool.Aliani@lightsquared.com | Rel-10 | RP-47 | Issam | RP-101117 |
| 445 | 176.2 | Perf. part: Adding L-Band (Band 24) LTE for ATC of MSS in North America | 316d? | 2010-03-19 A | 2011-06-03 | 15% | 267.1d? | 2010-03-19 | 2011-06-03 | 316d? | 465d | finish no earlier than 2011-06-03 | R4 | 2528h | 391.2h | L_Band_LTE_ATC_MSS-Perf | PCG-24 | LightSquared | Eric.Jacks@lightsquared.com, Maqbool.Aliani@lightsquared.com | Rel-10 | RP-47 | Issam | RP-110079 |
| 446 | 176.3 | Test part: Adding L-Band (Band 24) LTE for ATC of MSS in North America | 131d? | 2011-03-18 | 2011-09-16 |  |  | 2011-03-18 | 2011-09-16 | 131d? | 390d | finish no earlier than 2011-09-16 | R5 | 1048h |  | L_Band_LTE_ATC_MSS-UEConTest | PCG-26 | LightSquared | Masoud.olfat@LightSquared.com | Rel-10 | RP-51 | Ingbert |  |
| 447 | 177 | **LTE Self Optimizing Networks (SON) enhancements** | 316d? | 2010-03-19 A | 2011-06-03 | 85% | 47.4d? | 2010-03-19 | 2011-06-03 | 316d? | 465d |  | R3,R2,R4 | 5056h | 4297.6h | SONenh_LTE | PCG-24 | Nokia Siemens Networks | krzysztof.kordybach@nsn.com | Rel-10 | RP-47 | Juha | Exception sheet in RP-110195 |
| 448 | 177.1 | Core part: LTE Self Optimizing Networks (SON) enhancements | 316d? | 2010-03-19 A | 2011-06-03 | 85% | 47.4d? | 2010-03-19 | 2011-06-03 | 316d? | 465d | finish no earlier than 2011-06-03 | R3,R2,R4 | 2528h | 2148.8h | SONenh_LTE-Core | PCG-24 | Nokia Siemens Networks | krzysztof.kordybach@nsn.com | Rel-10 | RP-47 | Juha | RP-110080 |
| 449 | 178 | **Further enhancements to MBMS for LTE** | 206d? | 2010-06-04 A | 2011-03-18 A | 100% |  | 2010-06-04 | 2011-03-18 | 206d? |  |  | R2,R3 | 3296h | 3296h | MBMS_LTE_enh | PCG-25 | Huawei | Ms Zhao Junhui (zhaojh@huawei.com) | Rel-10 | RP-48 | Joern |  |
| 450 | 178.1 | Core part: Further enhancements to MBMS for LTE | 206d? | 2010-06-04 A | 2011-03-18 A | 100% |  | 2010-06-04 | 2011-03-18 | 206d? |  | finish no earlier than 2011-03-18 | R2,R3 | 1648h | 1648h | MBMS_LTE_enh-Core | PCG-25 | Huawei | Ms Zhao Junhui (zhaojh@huawei.com) | Rel-10 | RP-48 | Joern | RP-110083 |
| 451 | 179 | **UMTS/LTE 3500 MHz** | 992d? | 2007-11-30 A | 2011-09-16 | 41% | 580.54d? | 2007-11-30 | 2011-09-16 | 992d? | 390d |  | R4,R2,R3,R5 | 23874h | 9902.3h | RInImp8-UMTSLTE3500 | PCG-21 | Ericsson | johan.skold@ericsson.com | Rel-10 | RP-38 | Issam | Exception sheet in RP-110111 |
| 452 | 179.1 | UMTS/LTE 3500 MHz | 905d? | 2007-11-30 A | 2011-06-03 | 80% | 181d? | 2007-11-30 | 2011-06-03 | 905d? | 465d | finish no earlier than 2011-06-03 | R4,R2,R3 | 7240h | 5792h | RInImp8-UMTSLTE3500 | PCG-21 | Ericsson | johan.skold@ericsson.com | Rel-10 | RP-38 | Issam | RP-110056 |
| 453 | 179.2 | Conformance Test Aspects – LTE 3500 | 727d? | 2008-12-05 A | 2011-09-16 | 30% | 508.9d? | 2008-12-05 | 2011-09-16 | 727d? | 390d | finish no earlier than 2011-09-16 | R5 | 5816h | 1744.8h | LTE-UEConTest_LTE3500 | PCG-22 | Ericsson | fredrik.sundstrom@ericsson.com | Rel-10 | RP-42 | Ingbert | RP-110032 |
| 454 | 179.3 | Conformance Test Aspects – UMTS 3500 | 727d? | 2008-12-05 A | 2011-09-16 | 5% | 690.65d? | 2008-12-05 | 2011-09-16 | 727d? | 390d | finish no earlier than 2011-09-16 | R5 | 5816h | 290.8h | RInImp-UEConTest_UMTS3500 | PCG-22 | Ericsson | fredrik.sundstrom@ericsson.com | Rel-10 | RP-42 | Ingbert | RP-110033 |
| 455 | 180 | **Minimization of Drive Tests for E-UTRAN and UTRAN** | 391d? | 2009-12-04 A | 2011-06-03 | 90% | 39.1d? | 2009-12-04 | 2011-06-03 | 391d? | 465d |  | R2,R4,R3 | 6256h | 5630.4h | MDT_UMTSLTE | PCG-24 | Nokia Siemens Networks | malgorzata.tomala@nsn.com | Rel-10 | RP-46 | Joern | Exception sheet in RP-110194 |
| 456 | 180.1 | Core part: Minimization of Drive Tests for E-UTRAN and UTRAN | 391d? | 2009-12-04 A | 2011-06-03 | 90% | 39.1d? | 2009-12-04 | 2011-06-03 | 391d? | 465d | finish no earlier than 2011-06-03 | R2,R4,R3 | 3128h | 2815.2h | MDT_UMTSLTE-Core | PCG-24 | Nokia Siemens Networks | malgorzata.tomala@nsn.com | Rel-10 | RP-46 | Joern | RP-110057 |
| 457 | 181 | **HNB and HeNB Mobility Enhancements** | 261d? | 2010-03-19 A | 2011-03-18 A | 100% |  | 2010-03-19 | 2011-03-18 | 261d? |  |  | R3,R2 | 4176h | 4176h | HNB_HENB_mob_enh | PCG-24 | Alcatel-Lucent | Martin,Warner@alcatel-lucent.com | Rel-10 | RP-47 | Juha |  |
| 458 | 181.1 | Core part: HNB and HeNB Mobility Enhancements | 261d? | 2010-03-19 A | 2011-03-18 A | 100% |  | 2010-03-19 | 2011-03-18 | 261d? |  | start no earlier than 2010-03-19 | R3,R2 | 2088h | 2088h | HNB_HENB_mob_enh-Core | PCG-24 | Alcatel-Lucent | Martin.Warner@alcatel-lucent.com | Rel-10 | RP-47 | Juha | RP-110058 |
| 459 | 182 | **Expanded 1900 MHz Band for UTRA and LTE** | 261d? | 2010-06-04 A | 2011-06-03 | 90% | 26.1d? | 2010-06-04 | 2011-06-03 | 261d? | 465d |  | R4,R2 | 6264h | 5637.6h | E1900 | PCG-25 | Sprint | nick.j.baustert@sprint.com | Rel-10 | RP-48 | Issam | Exception sheet in RP-110400 |
| 460 | 182.1 | Core part: Expanded 1900 MHz Band for UTRA and LTE | 261d? | 2010-06-04 A | 2011-06-03 | 90% | 26.1d? | 2010-06-04 | 2011-06-03 | 261d? | 465d | finish no earlier than 2011-06-03 | R4,R2 | 2088h | 1879.2h | E1900-Core | PCG-25 | Sprint | nick.j.baustert@sprint.com | Rel-10 | RP-48 | Issam | RP-110059 |
| 461 | 182.2 | Perf. part: Expanded 1900 MHz Band for UTRA and LTE | 261d? | 2010-06-04 A | 2011-06-03 | 90% | 26.1d? | 2010-06-04 | 2011-06-03 | 261d? | 465d | finish no earlier than 2011-06-03 | R4,R2 | 2088h | 1879.2h | E1900-Perf | PCG-25 | Sprint | nick.j.baustert@sprint.com | Rel-10 | RP-48 | Issam | RP-110060 |
| 462 | 183 | **Multi-standard radio Base Station RF requirements for non-contiguous spectrum deployments** | 336d? | 2010-06-04 A | 2011-09-16 | 52% | 162.95d? | 2010-06-04 | 2011-09-16 | 336d? | 390d |  | R4,G1 | 9552h | 4919.61h | MSR_NC | PCG-25 | Ericsson | johan.skold@ericsson.com | Rel-10 | RP-48 | Issam |  |
| 463 | 183.1 | Core part: Multi-standard radio Base Station RF requirements for non-contiguous spectrum deployments | 261d? | 2010-06-04 A | 2011-06-03 | 90% | 26.1d? | 2010-06-04 | 2011-06-03 | 261d? | 465d | finish no earlier than 2011-06-03 | R4 | 2088h | 1879.2h | MSR_NC-Core | PCG-25 | Ericsson | johan.skold@ericsson.com | Rel-10 | RP-48 | Issam | RP-110061 |
| 464 | 183.2 | Perf. part: Multi-standard radio Base Station RF requirements for non-contiguous spectrum deployments | 336d? | 2010-06-04 A | 2011-09-16 | 15% | 285.6d? | 2010-06-04 | 2011-09-16 | 336d? | 390d | finish no earlier than 2011-09-16 | R4 | 2688h | 403.2h | MSR_NC-Perf | PCG-25 | Ericsson | johan.skold@ericsson.com | Rel-10 | RP-48 | Issam | RP-110062 |
| 465 | 183.3 | GERAN part: Multi-standard radio Base Station RF requirements for non-contiguous spectrum deployments | 261d? | 2010-09-03 A | 2011-09-02 | 60% | 104.4d? | 2010-09-03 | 2011-09-02 | 261d? | 400d | finish no earlier than 2011-09-02 | G1 | 2088h | 1252.8h | MSR_NC-GERAN | PCG-25 | Ericsson | mats.y.samuelsson@ericsson.com | Rel-10 | GP-47 | Paolo | No exception sheet |
| 466 | 184 | Local Call Local Switch | 1055.8d? | 2007-05-07 A | 2011-05-20 | 85% | 158.37d? | 2007-05-07 | 2011-05-20 | 1055.8d? | 475d |  | GP,G2 | 8446.4h | 7179.44h | LCLS | PCG-22 | Huawei | wang_zhixi@huawei.com | Rel-10 | GP-41 | Paolo | Exception sheet in GP-110399 |

Notes:
- 443: - / Text3: LTE
- 444: RP#51 completed / Text3: 25.101, 25.104, 25.141, 25.461, 25.466, 34.124, 36.101, 36.104, 36.113, 36.124, 36.133, 36.307, 37.104, 37.141, new RAN4 TR 36.813
- 445: - / Text3: 34.121-1, 36.101, 36.104, 36.113, 36.124, 36.133, 36.141, 36.307, 36.521-1, 36.813
- 446: - / Text3: 36.508, 36.521-1, 36.521-2, 36.521-3, 36.523-2
- 447: RP#50 completion 12/10=>03/11. Stage 1,2,3 / Text3: LTE
- 448: RP#51 completion 03/11=>06/11 (exception in RP-110195) / Text3: 36.300, 36.331, 36.413, 36.423
- 449: RP#51 completed. SA2 decided not to support MBR>GBR in Rel-10 MBMS. For SA2, MBR=GBR in Rel-10 MBMS. Hence RAN removed enabling statistical multiplexing gains for variable bit rate services in Objectives / Text3: LTE
- 450: RP#51 completed / Text3: 25.446, 36.300, 36.321, 36.322, 36.323, 36.331, 36.440, 36.441, 36.442, 36.443, 36.444, 36.445
- 451: - / Text3: UTRA, LTE
- 452: RP#51 completion 03/11=>06/11 (exception in RP-110111) / Text3: 25.101, 25.104, 25.113, 25.133, 25.141, 25.307, 25.307, 25.331, 25.461, 25.463, 34.124, 36.101, 36.104, 36.113, 36.141, 36.331, new 37.801
- 453: RP#50 completion 12/10=>09/11 / Text3: 36.508, 36.521-1, 36.521-2, 36.521-3
- 454: RP#51 updated WID RP-080870=>RP-110386. Changed Rapp Nokia=>Ericsson / Text3: 34.108, 34.121-1, 34.121-2
- 455: Triggered by UID_430021 TR 36.805 (Study on Minimization of drive-tests in NGN) / Text3: UTRA, LTE
- 456: RP#51 completion 03/11=>06/11 (exception in RP-110194) / Text3: 25.133, 25.215, 25.304, 25.331, 25.423, 36.133, 36.214, 36.300, 36.304, 36.331, 36.413, 36.423, new 37.320 (Stage 2)
- 457: RP#51 completed. Common UTRA and E-UTRA Work Item to ensure that divergence between the systems is minimized / Text3: UTRA, LTE
- 458: RP#51 completed. WID updated RP-101426=>RP-110183 / Text3: 25.413, 25.467, 25.469, 36.300, 36.413, 36.423, new 25.471
- 459: Create a new band that expands UTRA and E-UTRA band 2 to include frequencies between 1910 1915 MHz and 1990-1995 MHz (US FCC allocation) / Text3: UTRA, LTE
- 460: RP#51 completion 03/11=>06/11 (exception in RP-110400) / Text3: 25.101, 25.104, 25.113, 25.133, 25.141, 25.461, 25.466, 36.101, 36.104, 36.113, 36.124, 36.133, 36.141, 36.307, 36.331, new TR 36.818
- 461: RP#51 completion 03/11=>06/11 / Text3: 25.101, 25.104, 25.113, 25.133, 25.141, 25.461, 25.466, 36.101, 36.104, 36.113, 36.124, 36.133, 36.141, 36.307, 36.331, new TR 36.818
- 462: Exception sheet in RP-110110 / Text3: UTRA, LTE, GERAN
- 463: RP#51 completion 03/11=>06/11 (exception in RP-110110) / Text3: 25.104, 36.104, 37.104, new TR 37.802
- 464: - / Text3: 25.141, 36.141, 37.141, 37.802
- 465: GP#49 completion 03/11=>09/11. GP#47 approved WID / Text3: 45.005, 51.021
- 466: GP#49 completion 03/11=>05/11 (exception in GP-110399). GP#41 WID approved / Text3: GERAN Stage 3: 48.008, 48.103

| ID | WBS | Task | Duration | Start | Finish | Complete | Remaining | Baseline start | Baseline finish | Baseline duration | Total slack | Constraint | Resources | Work | Actual work | Text1 | Text2 | Text4 | Text6 | Text7 | Text8 | Text9 | Text12 | Text11 |
| --- | --- | --- | --- | --- | --- | --- | --- | --- | --- | --- | --- | --- | --- | --- | --- | --- | --- | --- | --- | --- | --- | --- | --- | --- |
| 467 | 185 | **CN aspects of Local Call Local Switch** | 472d? | 2009-05-29 A | 2011-03-18 A | 100% |  | 2009-05-29 | 2011-03-18 | 472d? |  |  | C4 | 13008h | 13008h | LCLS-CN | PCG-23 | Vodafone | Rel-10 | CP-44 | Kimmo |  |  |  |
| 468 | 185.1 | TR on CN aspects of Local Call Local Switch | 341d? | 2009-05-29 A | 2010-09-17 A | 100% |  | 2009-05-29 | 2010-09-17 | 341d? |  | finish no earlier than 2010-09-17 | C4 | 2728h | 2728h | LCLS-CN | PCG-23 | Vodafone | Rel-10 | CP-44 | Kimmo |  |  |  |
| 469 | 185.2 | CN aspects of Local Call Local Switch | 131d? | 2010-09-17 A | 2011-03-18 A | 100% |  | 2010-09-17 | 2011-03-18 | 131d? |  | finish no earlier than 2011-03-18 | C4 | 1048h | 1048h | LCLS-CN | PCG-25 | Vodafone | Rel-10 | CP-49 | Kimmo |  |  |  |
| 470 | 185.3 | Deleted - CT3 aspects of Local Call Local Switch | 341d? | 2009-05-29 A | 2010-09-17 A | 100% |  | 2009-05-29 | 2010-09-17 | 341d? |  | finish no earlier than 2010-09-17 | C3 | 2728h | 2728h | LCLS-CN | PCG-23 | Vodafone | Rel-10 | CP-44 | Jiwan | PCG-25 | CP-49 |  |
| 471 | 185.4 | Deleted - CT1 aspects of Local Call Local Switch | 341d? | 2009-05-29 A | 2010-09-17 A | 100% |  | 2009-05-29 | 2010-09-17 | 341d? |  | finish no earlier than 2010-09-17 | C1 | 2728h | 2728h | LCLS-CN | PCG-23 | Vodafone | Rel-10 | CP-44 | Frederic | PCG-25 | CP-49 |  |
| 472 | 186 | **Tightened Link Level Performance Requirements for Single Antenna MS** | 261d? | 2010-09-03 A | 2011-09-02 | 22% | 204.38d? | 2010-09-03 | 2011-09-02 | 261d? | 400d |  | G1,G2,C1,G3new | 7232h | 1568.99h | TIGHTER | PCG-25 | Renesas | Rel-10 | GP-46 | Paolo |  |  | Exception sheet in GP-110495 |
| 473 | 186.1 | CT1 part for TIGHTER | 196d? | 2010-09-03 | 2011-06-03 |  |  | 2010-09-03 | 2011-06-03 | 196d? | 465d | finish no earlier than 2011-06-03 | C1 | 1568h |  | TIGHTER | PCG-25 | Renesas | Rel-10 | GP-46 | Frederic |  |  | Exception sheet in CP-110157 |
| 474 | 186.2 | TIGHTER Performance Requirements | 186d? | 2010-09-03 A | 2011-05-20 | 75% | 46.5d? | 2010-09-03 | 2011-05-20 | 186d? | 475d | finish no earlier than 2011-05-20 | G1,G2 | 1488h | 1116h | TIGHTER | PCG-25 | Renesas | Rel-10 | GP-46 | Paolo |  |  | Exception sheet in GP-110495 |
| 475 | 186.3 | TIGHTER Testing | 261d? | 2010-09-03 | 2011-09-02 |  |  | 2010-09-03 | 2011-09-02 | 261d? | 400d | finish no earlier than 2011-09-02 | G3new,G1,G2 | 2088h |  | TIGHTER | PCG-25 | Renesas | Rel-10 | GP-46 | Ingbert |  |  |  |
| 476 | 187 | **Support of Multi-Operator Core Network by GERAN** | 206d? | 2010-05-21 A | 2011-03-04 A | 100% |  | 2010-05-21 | 2011-03-04 | 206d? |  |  | G2,S2,C1 | 5096h | 5096h | MOCN-GERAN | PCG-25 | Alcatel-Lucent | Rel-10 | GP-47 | Gert |  |  |  |
| 477 | 187.1 | Stage 2 for Support of Multi-Operator Core Network by GERAN | 150d? | 2010-05-21 A | 2010-12-16 A | 100% |  | 2010-05-21 | 2010-12-16 | 150d? |  | finish no earlier than 2010-12-15 | S2 | 1200h | 1200h | MOCN-GERAN | PCG-25 | Alcatel-Lucent | Rel-10 | GP-47 | Maurice |  |  |  |
| 478 | 187.2 | CT1 part of Stage 3 for Support of Multi-Operator Core Network by GERAN | 146d? | 2010-05-21 A | 2010-12-10 A | 100% |  | 2010-05-21 | 2010-12-10 | 146d? |  | finish no earlier than 2010-12-10 | C1 | 1168h | 1168h | MOCN-GERAN | PCG-25 | Alcatel-Lucent | Rel-10 | GP-47 | Frederic |  |  |  |
| 479 | 187.3 | GERAN2 part of Stage 3 for Support of Multi-Operator Core Network by GERAN | 135d? | 2010-08-30 A | 2011-03-04 A | 100% |  | 2010-08-30 | 2011-03-04 | 135d? |  | finish no earlier than 2011-03-04 | G2 | 1080h | 1080h | MOCN-GERAN | PCG-25 | Alcatel-Lucent | Rel-10 | GP-47 | Gert |  |  |  |
| 480 | 188 | **Enhancements of Iur-g interface** | 196d? | 2010-09-03 A | 2011-06-03 | 58% | 82.24d? | 2010-09-03 | 2011-06-03 | 196d? | 465d |  | G2,R3 | 4184h | 2428.51h | eIurg | PCG-25 | China Mobile, ZTE | Rel-10 | GP-47 | Gert |  |  | Exception sheet in RP-110300 |
| 481 | 188.1 | GERAN part for Enhancements of Iur-g interface (Stage 2/3) | 131d? | 2010-09-03 A | 2011-03-04 A | 100% |  | 2010-09-03 | 2011-03-04 | 131d? |  | finish no earlier than 2011-03-04 | G2 | 1048h | 1048h | eIurg-GERAN | PCG-25 | China Mobile, ZTE | Rel-10 | GP-47 | Gert |  |  |  |
| 482 | 188.2 | Core part: Enhancements of Iur-g interface (Stage 2/3) | 196d? | 2010-09-03 A | 2011-06-03 | 30% | 137.2d? | 2010-09-03 | 2011-06-03 | 196d? | 465d | finish no earlier than 2011-06-03 | R3 | 1568h | 470.4h | eIurg-RAN | PCG-25 | ZTE | Rel-10 | RP-49 | Juha |  |  | RP-110055 |
| 483 | 189 | (Small) Technical Enhancements and Improvements for Rel-10 | 470d? | 2009-06-04 A | 2011-03-23 A | 100% |  | 2009-06-04 | 2011-03-23 | 470d? |  | finish no earlier than 2011-03-23 | All | 3760h | 3760h | TEI10 | PCG-23 |  | Rel-10 | SP-44 |  |  |  |  |
| 484 | 190 | **Deleted - Registration in Densely-populated area (RED)** | 665d? | 2007-03-12 A | 2009-09-24 A | 100% |  | 2007-03-12 | 2009-09-24 | 665d? |  |  | S1 | 9544h | 9544h | RED |  | NTT DoCoMo | Rel-10 | SP-35 | Alain | PCG-24 | SP-46 |  |
| 485 | 190.1 | Deleted - Stage 1 for RED | 4d? | 2007-03-12 A | 2007-03-15 A | 100% |  | 2007-03-12 | 2007-03-15 | 4d? |  | start no earlier than 2007-03-12 | S1 | 32h | 32h | RED |  | NTT DoCoMo | Rel-10 | SP-35 | Alain | PCG-24 | SP-46 |  |
| 486 | 190.2 | Deleted - Stage 2 for RED | 524d? | 2007-09-25 A | 2009-09-24 A | 100% |  | 2007-09-25 | 2009-09-24 | 524d? |  | finish no earlier than 2009-09-24 | S2 | 4192h | 4192h | RED |  | NTT DoCoMo | Rel-10 | SP-37 | Maurice | PCG-23 | SP-45 |  |
| 487 | 191 | **Deleted - Network Selection for non-3GPP Access** | 471d? | 2007-12-07 A | 2009-09-24 A | 100% |  | 2007-12-07 | 2009-09-24 | 471d? |  |  | S1,C6 | 10452.8h | 10452.8h | N3GtoNSP | PCG-21 | Telefónica O2 | Rel-10 | SP-38 | Alain | PCG-23 | SP-45 |  |
| 488 | 191.1 | Deleted - Stage 1 for N3GtoNSP | 471d? | 2007-12-07 A | 2009-09-24 A | 100% |  | 2007-12-07 | 2009-09-24 | 471d? |  | finish no earlier than 2009-12-10 | S1 | 3768h | 3768h | N3GtoNSP | PCG-21 | Telefónica O2 | Rel-10 | SP-38 | Alain | PCG-23 | SP-45 |  |
| 489 | 191.2 | Deleted - CT6 issues for N3GtoNSP | 471d? | 2007-12-07 A | 2009-09-24 A | 100% |  | 2007-12-07 | 2009-09-24 | 471d? |  | finish no earlier than 2009-12-04 | C6 | 3768h | 3768h | N3GtoNSP | PCG-21 | Telefónica O2 | Rel-10 | CP-38 | Xavier | PCG-23 | CP-45 |  |
| 490 | 192 | **Deleted - GTP-based S8 chaining** | 337d? | 2008-12-11 A | 2010-03-25 A | 100% |  | 2008-12-11 | 2010-03-25 | 337d? |  |  | S2 | 5392h | 5392h | GTPchaining | PCG-22 | Huawei | Rel-10 | SP-42 | Maurice | PCG-24 | SP-47 |  |
| 491 | 192.1 | Deleted - Stage 2 for GTPchaining | 337d? | 2008-12-11 A | 2010-03-25 A | 100% |  | 2008-12-11 | 2010-03-25 | 337d? |  | finish no earlier than 2010-03-25 | S2 | 2696h | 2696h | GTPchaining | PCG-22 | Huawei | Rel-10 | SP-42 | Maurice | PCG-24 | SP-47 |  |
| 492 | 193 | Deleted - UTRAN 2 ms TTI uplink range improvement | 272d? | 2009-03-06 A | 2010-03-19 A | 100% |  | 2009-03-06 | 2010-03-19 | 272d? |  | finish no earlier than 2010-03-19 | R1,R2,R3,R4 | 2176h | 2176h | RANimp-2mTTI_ULimp | PCG-22 | Nokia Siemens Networks | Rel-10 | RP-43 | Patrick | PCG-24 | RP-47 | RP-100040 |
| 493 | 194 | Deleted - Enhanced Home NodeB / eNodeB continuation of Rel-9 | 337d? | 2008-12-11 A | 2010-03-25 A | 100% |  | 2008-12-11 | 2010-03-25 | 337d? |  |  | S2 | 2696h | 2696h | eEHNB | PCG-23 | Alcatel-Lucent | Rel-10 | SP-44 | Maurice | PCG-24 | SP-47 |  |

Notes:
- 467: CP#51 completed / Text3: GERAN Stage 2/3 / Text5: David.Hutton@vodafone.com
- 468: CT#49 completed / Text3: new TR 23.889 / Text5: David.Hutton@vodafone.com
- 469: CP#51 completed / Text3: 23.003, 23.009, 23.205, 23.231, 29.002, 29.205, 29.232, new TS 23.284 / Text5: David.Hutton@vodafone.com
- 470: CP#49 stopped. Result of study TR 23.889: no CT3 specification impact / Text5: David.Hutton@vodafone.com
- 471: CP#49 stopped. Result of study TR 23.889: no CT1 specification impact / Text5: David.Hutton@vodafone.com
- 472: GP#49 completion 03/11=>05/11 (exception in GP-110495). GP#46 approved WID / Text3: GERAN / Text5: carsten.juncker@renesasmobile.com
- 473: CP#51 completion 03/11=>06/11 (exception in CP-110157) / Text3: 24.008 / Text5: marko.niemi@renesasmobile.com
- 474: GP#49 completion 03/11=>05/11 (exception in GP-110495). Changed Rapp Nokia=>Renesas / Text3: 45.005, 45.015 / Text5: carsten.juncker@renesasmobile.com
- 475: GP#49 changed Rapp Nokia=>Renesas / Text3: 51.010 / Text5: carsten.juncker@renesasmobile.com
- 476: GP#49 completed. SP/CP#50 completed. GP#47 approved WID. 900 MHz spectrum re-farming to other RATs lead operators to reduce GSM capacity and therefore share their GSM networks. Hence the need for the most suitable (GE)RAN sharing method / Text3: GERAN / Text5: michel.robert@alcatel-lucent.com
- 477: SP#50 completed / Text3: 23.251 / Text5: michel.robert@alcatel-lucent.com
- 478: CP#50 completed / Text3: 24.008 CR#1644 / Text5: michel.robert@alcatel-lucent.com
- 479: GP#49 completed / Text3: 48.008 CR#0325, 48.018 CR#0303 / Text5: michel.robert@alcatel-lucent.com
- 480: GP#49 completed. RP#51 exception sheet in RP-110126. GP#47 approved WID / Text3: GERAN,UTRA / Text5: Ms Juan Deng (dengjuan@chinamobile.com), Xinhui Wang (wangxinhui@zte.com.cn)
- 481: GP#49 completed. GP#48 updated WID GP-101659=>GP-101758 (restricting the scope to GERAN BSC and TD-SCDMA RNC only). GP#47 approved WID / Text3: 43.130, 48.008 / Text5: Ms Juan Deng (dengjuan@chinamobile.com), Xinhui Wang (wangxinhui@zte.com.cn)
- 482: RP#51 completion 03/11=>06/11 (exception in RP-110300) / Text3: UTRA Stage 2 (25.401, 25.420), Stage 3 (25.423) / Text5: Liu Junqiang (liu.junqiang@zte.com.cn)
- 483: -
- 484: SP#35 Stage 1 completed. SP#45 Stage 2 work stopped. SP#46 work stopped/abandoned / Text3: WID identifies also impacted CT1 24.008, RAN2 25.331 / Text5: tanakai@nttdocomo.co.jp
- 485: SP#35 completed. SP#46 work stopped/abandoned / Text3: 22.101 CR#0207 / Text5: takakurat@s1.nttdocomo.co.jp
- 486: SP#45 Stage 2 work stopped / Text3: draft TR 23.880 withdrawn, 23.002, 23.060, 23.221, 23.236 / Text5: tanakai@nttdocomo.co.jp
- 487: SP#45 work stopped/abandoned / Text5: chris.friel@O2.com
- 488: SP#45 work stopped/abandoned / Text3: 22.011 / Text5: chris.friel@O2.com
- 489: SP#45 work stopped/abandoned / Text3: 36.300 / Text5: chris.friel@O2.com
- 490: SP#47 work stopped (depending on ongoing related CT4 work). Stage 1 in UID_320022 Rel-8 Requirements for evolution of the 3GPP system architecture (AIPN-SAE): 22.278, 22.011, 22.246 / Text5: Haining Wang (wanghaining@huawei.com)
- 491: SP#47 work stopped / Text3: 23.402 / Text5: Haining Wang (wanghaining@huawei.com)
- 492: RP#47 work stopped/abandoned (no CR approved). Cell sets the TTI (Transmission Time Interval) to 2 ms / Text3: 25.133, 25.212, 25.214, 25.321, 25.331 / Text5: Karri Ranta-aho (karri.ranta-aho@nsn.com)
- 493: SP#47 deleted (SA2 work moved under SA1 UID_450053). SP#44 Umbrella Feature created to host WIs moved out of Rel-9 (SA2 UID_420034 on IMS aspects of Architecture for Home NodeB) / Text5: Nicolas Drevon

| ID | WBS | Task | Type | Duration | Start | Finish | Complete | Baseline start | Baseline finish | Baseline duration | Constraint | Resources | Work | Actual work | Text1 | Text2 | Text3 | Text4 | Text6 | Text7 | Text8 | Text9 | Text11 | Text12 |
| --- | --- | --- | --- | --- | --- | --- | --- | --- | --- | --- | --- | --- | --- | --- | --- | --- | --- | --- | --- | --- | --- | --- | --- | --- |
| 494 | 195 | **Deleted - Enhanced Interference Management for Home NodeBs** |  | 131d? | 2010-03-19 A | 2010-09-17 A | 100% | 2010-03-19 | 2010-09-17 | 131d? |  | R3 | 2096h | 2096h | HNB_IM | PCG-24 | UTRA | Qualcomm | Rel-10 | RP-47 | Juha | PCG-25 | RP-100754 | RP-49 |
| 495 | 195.1 | Deleted - Core part: Enhanced Interference Management for Home NodeBs |  | 131d? | 2010-03-19 A | 2010-09-17 A | 100% | 2010-03-19 | 2010-09-17 | 131d? | finish no earlier than 2010-09-17 | R3 | 1048h | 1048h | HNB_IM-Core | PCG-24 | 25.413, 25.467, 25.469 | Qualcomm | Rel-10 | RP-47 | Juha | PCG-25 | RP-100754 | RP-49 |
| 496 | 196 | **Deleted - Latency reductions for LTE** |  | 266d? | 2009-12-04 A | 2010-12-10 A | 100% | 2009-12-04 | 2010-12-10 | 266d? |  | R2,R1 | 4256h | 4256h | LTE_LATRED | PCG-24 | LTE | Ericsson | Rel-10 | RP-46 | Joern | PCG-26 |  | RP-50 |
| 497 | 196.1 | Deleted - Core part: Latency reductions for LTE |  | 266d? | 2009-12-04 A | 2010-12-10 A | 100% | 2009-12-04 | 2010-12-10 | 266d? | finish no earlier than 2010-12-10 | R2,R1 | 2128h | 2128h | LTE_LATRED-Core | PCG-24 | 36.213, 36.300, 36.306, 36.321, 36.331 | Ericsson | Rel-10 | RP-46 | Joern | PCG-26 | RP-101112 | RP-50 |
| 498 | 197 | Release 10 Studies |  | 531d? | 2009-03-12 A | 2011-03-23 A | 100% | 2009-03-12 | 2011-03-23 | 531d? | finish no earlier than 2011-03-23 | CP,GP,RP,SP | 4248h | 4248h |  |  |  |  | Rel-10 |  |  |  |  |  |
| 499 | 198 | **Study on enhanced voice service requirements for the Evolved Packet System (EPS)** |  | 670d? | 2007-09-03 A | 2010-03-25 A | 100% | 2007-09-03 | 2010-03-25 | 670d? |  | S1,S4 | 13384h | 13384h | FS_EV_EPS |  | 22.813 | France Telecom | Rel-10 | SP-37 | Alain |  |  |  |
| 500 | 198.1 | Use cases definition and service and system requirements |  | 334d? | 2007-09-03 A | 2008-12-11 A | 100% | 2007-09-03 | 2008-12-11 | 334d? | finish no earlier than 2008-12-11 | S1 | 2672h | 2672h | FS_EV_EPS-S1 |  | 22.813 | France Telecom | Rel-10 | SP-37 | Alain |  |  |  |
| 501 | 198.2 | Codec specific part of FS_EV_EPS |  | 669d? | 2007-09-03 A | 2010-03-25 A | 100% | 2007-09-03 | 2010-03-25 | 669d? | finish no earlier than 2010-03-25 | S4 | 5352h | 5352h | FS_EV_EPS-S4 |  | 22.813 | Ericsson | Rel-10 | SP-37 | Paolo |  |  |  |
| 502 | 199 | Study on advanced requirements for IP interconnect |  | 528d? | 2007-12-04 A | 2009-12-10 A | 100% | 2007-12-04 | 2009-12-10 | 528d? | finish no earlier than 2009-12-10 | S1 | 4224h | 4224h | FS_IPXS | PCG-21 | 22.893 | Telefónica O2 | Rel-10 | SP-38 | Alain |  |  |  |
| 503 | 200 | Study on Personal Broadcast Service |  | 397d? | 2008-09-18 A | 2010-03-25 A | 100% | 2008-09-18 | 2010-03-25 | 397d? | finish no earlier than 2010-03-25 | S1 | 3168h | 3168h | FS_PBS | PCG-21 | 22.947 | ETRI | Rel-10 | SP-41 | Alain |  |  |  |
| 504 | 201 | Study on LCS support in SAE for non-3GPP accesses |  | 397d? | 2008-09-18 A | 2010-03-25 A | 100% | 2008-09-18 | 2010-03-25 | 397d? | finish no earlier than 2010-03-25 | S1 | 3168h | 3168h | FS_LCS_n3GPP | PCG-21 | 22.814 | SK Telecom | Rel-10 | SP-41 | Alain |  |  |  |
| 505 | 202 | Study on Haptic Services |  | 272d? | 2009-03-12 A | 2010-03-25 A | 100% | 2009-03-12 | 2010-03-25 | 272d? | finish no earlier than 2010-03-25 | S1 | 2168h | 2168h | FS_Haptics | PCG-22 | 22.987 | SK Telecom | Rel-10 | SP-43 | Alain |  |  |  |
| 506 | 203 | Study on System enhancements for the use of IMS services in Local BreakOut and Optimal Routing of Media |  | 575d? | 2007-10-01 A | 2009-12-10 A | 100% | 2007-10-01 | 2009-12-10 | 575d? | finish no earlier than 2009-12-10 | S2 | 4600h | 4600h | FS_IMS_LBO_ORM |  | 23.894 | Telecom Italia, BT | Rel-10 | SP-37 | Maurice |  |  |  |
| 507 | 204 | Study on Intra Domain Connection of RAN Nodes to Multiple CN Nodes |  | 533d? | 2008-03-12 A | 2010-03-25 A | 100% | 2008-03-12 | 2010-03-25 | 533d? | finish no earlier than 2010-03-25 | S2 | 4264h | 4264h | FS_IDC | PCG-21 | 23.924 (was 23.823) | China Mobile | Rel-10 | SP-39 | Maurice |  |  |  |
| 508 | 205 | Study on Single Radio Voice Call Continuity enhancements |  | 341d? | 2009-06-04 A | 2010-09-23 A | 100% | 2009-06-04 | 2010-09-23 | 341d? | finish no earlier than 2010-09-23 | S2 | 2728h | 2728h | FS_eSRVCC | PCG-23 | 23.856 | China Mobile | Rel-10 | SP-44 | Maurice |  |  |  |
| 509 | 206 | Study on Single Radio Video Call Continuity for 3G-CS |  | 131d? | 2010-03-25 A | 2010-09-23 A | 100% | 2010-03-25 | 2010-09-23 | 131d? | finish no earlier than 2010-09-23 | S2 | 1048h | 1048h | FS_vSRVCC | PCG-24 | 23.886 | Samsung | Rel-10 | SP-47 | Maurice |  |  |  |
| 510 | 207 | Study on S2b Mobility based on GTP |  | 56d? | 2010-03-25 A | 2010-06-10 A | 100% | 2010-03-25 | 2010-06-10 | 56d? | finish no earlier than 2010-06-07 | S2 | 448h | 448h | FS_SMOG | PCG-24 | 23.834 | Alcatel-Lucent | Rel-10 | SP-47 | Maurice |  |  |  |
| 511 | 208 | Study on Surround Sound codec extension for PSS and MBMS |  | 530d? | 2009-03-12 A | 2011-03-23 A | 100% | 2009-03-12 | 2011-03-23 | 530d? | finish no earlier than 2011-03-23 | S4 | 4240h | 4240h | FS_SS_PSS_MBMS | PCG-22 | 26.950 | Fraunhofer Gesellschaft | Rel-10 | SP-43 | Paolo |  |  |  |
| 512 | 209 | Study on Improved Video Coding Support |  | 205d? | 2010-06-10 A | 2011-03-23 A | 100% | 2010-06-10 | 2011-03-23 | 205d? | finish no earlier than 2011-03-23 | S4 | 1640h | 1640h | FS_IVCS | PCG-25 | 26.904 | Nokia, ETRI | Rel-10 | SP-48 | Paolo |  |  |  |
| 513 | 210 | Study on Rc Reference Point Functionalities and Message Flows |  | 397d? | 2008-09-18 A | 2010-03-25 A | 100% | 2008-09-18 | 2010-03-25 | 397d? | finish no earlier than 2010-03-23 | S5 | 3170.08h | 3170.08h | FS_OAM_Rc | PCG-21 | 32.825 | Huawei | Rel-10 | SP-41 | Dionisio |  |  |  |
| 514 | 211 | Study on Telecommunication Management; Energy Savings Management |  | 271d? | 2009-03-12 A | 2010-03-25 A | 100% | 2009-03-12 | 2010-03-25 | 271d? | finish no earlier than 2010-03-25 | S5 | 2168h | 2168h | FS_OAM_ESM | PCG-22 | 32.826 | Orange, Vodafone | Rel-10 | SP-43 | Dionisio |  |  |  |
| 515 | 212 | Study on Integration of Device Management Information with Itf-N |  | 211d? | 2009-06-04 A | 2010-03-25 A | 100% | 2009-06-04 | 2010-03-25 | 211d? | finish no earlier than 2010-03-25 | S5 | 1688h | 1688h | FS_IDMI_Itf-N | PCG-23 | 32.827 | Motorola | Rel-10 | SP-44 | Dionisio |  |  |  |
| 516 | 213 | Study on Alignment of 3GPP Generic NRM IRP and TMF Shared Information Data (SID) model |  | 335d? | 2009-12-10 A | 2011-03-23 A | 100% | 2009-12-10 | 2011-03-23 | 335d? | finish no earlier than 2011-03-23 | S5 | 2680h | 2680h | FS_3GNRM_TMFSID | PCG-24 | 32.828 | Nokia Siemens Networks | Rel-10 | SP-46 | Dionisio |  |  |  |
| 517 | 214 | Study on Harmonization of 3GPP Alarm IRP and TMF Interface Program (TIP) Fault Management |  | 335d? | 2009-12-10 A | 2011-03-23 A | 100% | 2009-12-10 | 2011-03-23 | 335d? | finish no earlier than 2011-03-23 | S5 | 2680h | 2680h | FS_3G_TMF_FM | PCG-24 | 32.829 | Nokia Siemens Networks, Alcatel-Lucent | Rel-10 | SP-46 | Dionisio |  |  |  |
| 518 | 215 | Study on Alarm Correlation and Alarm Root Cause Analysis |  | 205d? | 2010-06-10 A | 2011-03-23 A | 100% | 2010-06-10 | 2011-03-23 | 205d? | finish no earlier than 2011-03-23 | S5 | 1640h | 1640h | FS_AC_ARCA | PCG-25 | 32.832 | Ericsson | Rel-10 | SP-48 | Dionisio |  |  |  |
| 519 | 216 | Study on Alignment of 3GPP PM IRP and TMF Interface Program (TIP) PM |  | 205d? | 2010-06-10 A | 2011-03-23 A | 100% | 2010-06-10 | 2011-03-23 | 205d? | finish no earlier than 2011-03-23 | S5 | 1640h | 1640h | FS_3G_TMF_PM | PCG-25 | 32.831 | Alcatel-Lucent | Rel-10 | SP-48 | Dionisio |  |  |  |
| 520 | 217 | Study on Policy and Charging Rules Function (PCRF) failure and restoration |  | 261d? | 2009-08-18 A | 2010-09-17 A | 100% | 2009-08-18 | 2010-09-17 | 261d? | finish no earlier than 2010-09-17 | C3 | 2088h | 2088h | FS_PCRF-FR | PCG-23 | 29.816 | NEC | Rel-10 | CP-45 | Jiwan |  |  |  |
| 521 | 218 | Study on User Data Convergence (UDC) evolution |  | 206d? | 2010-06-04 A | 2011-03-18 A | 100% | 2010-06-04 | 2011-03-18 | 206d? | finish no earlier than 2011-03-18 | C4 | 1648h | 1648h | FS_UDCe | PCG-25 | 23.845 | Alcatel-Lucent | Rel-10 | CP-48 | Kimmo |  |  |  |
| 522 | 219 | Study on UICC access to IMS |  | 206d? | 2010-06-04 A | 2011-03-18 A | 100% | 2010-06-04 | 2011-03-18 | 206d? | finish no earlier than 2011-03-18 | C6 | 1648h | 1648h | FS_IMS-UICC | PCG-25 | 31.828 | Gemalto | Rel-10 | CP-48 | Xavier |  |  |  |
| 523 | 220 | Study on Uplink Tx Diversity for HSPA |  | 208.4d? | 2009-08-18 A | 2010-06-04 A | 100% | 2009-08-18 | 2010-06-04 | 208.4d? | finish no earlier than 2010-06-04 | R4 | 1667.2h | 1667.2h | FS_UL-TxDiv-HSPA | PCG-23 | UTRA 25.863 | Qualcomm | Rel-10 | RP-45 | Issam |  | RP-100499 |  |
| 524 | 221 | Study on Solutions for Energy Saving within UTRA Node B |  | 206d? | 2009-12-04 A | 2010-09-17 A | 100% | 2009-12-04 | 2010-09-17 | 206d? | finish no earlier than 2010-09-17 | R1,R3 | 1648h | 1648h | FS_Energy_UMTS | PCG-24 | UTRA 25.927 | Vodafone | Rel-10 | RP-46 | Patrick |  | RP-100796 |  |
| 525 | 222 | Study on Improvements of distributed antenna for 1.28Mcps TDD |  | 191d? | 2010-03-05 A | 2010-12-10 A | 100% | 2010-03-05 | 2010-12-10 | 191d? | finish no earlier than 2010-12-10 | R1,R2,R3 | 1528h | 1528h | FS_distr_ant_LCR_TDD | PCG-24 | UTRA 25.865 | ZTE | Rel-10 | RP-47 | Patrick |  | RP-101287 |  |
| 526 | 223 | Deleted - Study on Unauthenticated PS Emergency Calls |  | 471d? | 2008-06-05 A | 2010-03-25 A | 100% | 2008-06-05 | 2010-03-25 | 471d? | finish no earlier than 2010-03-25 | S1 | 3768h | 3768h | FS_UAPSEC | PCG-21 | 22.984 | Nokia Siemens Networks | Rel-10 | SP-40 | Alain | PCG-24 |  | SP-47 |
| 527 | 224 | Deleted - Study on enhancements to IMS border functions for IMS Interconnection of services |  | 586d? | 2008-09-18 A | 2010-12-15 A | 100% | 2008-09-18 | 2010-12-15 | 586d? | finish no earlier than 2010-12-15 | S2 | 4688h | 4688h | FS_eIMS_IBCF | PCG-21 | 23.848 | Starent Networks | Rel-10 | SP-41 | Maurice | PCG-26 |  | SP-50 |
| 528 | 225 | Deleted - Study on EPC Charging enhancement |  | 211d? | 2009-06-04 A | 2010-03-25 A | 100% | 2009-06-04 | 2010-03-25 | 211d? | finish no earlier than 2010-03-25 | S5 | 1688h | 1688h | FS_EPCcharg | PCG-23 |  | Nokia Siemens Networks | Rel-10 | SP-44 | Dionisio | PCG-24 |  | SP-47 |
| 529 | 226 | Deleted - Study on Interworking Proxy between GTP based and PMIP based interfaces |  | 186d? | 2009-09-18 A | 2010-06-04 A | 100% | 2009-09-18 | 2010-06-04 | 186d? | finish no earlier than 2010-06-04 | C4 | 1488h | 1488h | FS_GTP-MIP-IW | PCG-23 | 29.875 | NTT DoCoMo | Rel-10 | CP-45 | Kimmo | PCG-25 |  | CP-48 |
| 530 | 227 | Release 9 Features | milestone | 0d? | 2008-06-05 A | 2008-06-05 A | 100% | 2008-06-05 | 2008-06-05 | 0d? |  | CP,GP,RP,SP |  |  |  |  |  |  | Rel-9 |  |  |  |  |  |

Notes:
- 494: RP#49 stopped (no further standardization needed). Ensure that Enhanced Interference Management methods identified in Rel-9 for HNBs do not fail in deployments with a large penetration of CSG-aware UEs / Text5: Andrei Radulescu (aradules@qualcomm.com)
- 495: RP#49 stopped (no further standardization needed) / Text5: Andrei Radulescu (aradules@qualcomm.com)
- 496: RP#50 work stopped (RP-101266) / Text5: henrik.enbuske@ericsson.com
- 497: RP#50 work stopped (RP-101266) / Text5: henrik.enbuske@ericsson.com
- 498: -
- 499: SP#47 completed. TR 22.813-100 for Approval. Spin-off Feature UID_470030 Codec for Enhanced Voice Services / Text5: LOTTIN, Philippe
- 500: SP#47 completed. TR 22.813-100 for Approval / Text5: LOTTIN, Philippe
- 501: SP#47 completed. TR 22.813-100 for Approval / Text5: stefan.bruhn@ericson.com
- 502: SP#46 completed. Linked to Rel-8 Feature UID_380060 IP Interconnection of Services (IPinterc). Spin-off Feature Rel-11 UID_470051 Advanced IP Interconnection of Services / Text5: chris.friel@O2.com
- 503: SP#47 completed / Text5: Jaihyung Cho
- 504: SP#47 completed / Text5: jinhan.song@sktelecom.com
- 505: SP#47 completed. Covers Mobile/Fixed/Cordless/etc terminals. Haptic (human-machine tactile communication) extend service offering & richness of user experience beyond current visual & auditory senses / Text5: jinhan.song@sktelecom.com
- 506: SP#46 completed. Spin-off Feature UID_460028 Optimal Media Routeing (OMR). Linked to Study on Multimedia Session Continuity UID_350051, Study on Centralized IMS Service Control UID_330012, IMS inter-operator service interconnection interface UID_360011 / Text5: mario.madella@telecomitalia.it, victor.kueh@bt.com
- 507: SP#47 completed. Concluded no further normative work expected. Linked to 23.236 / Text5: LIU HONG (liuhongyfw@chinamobile.com)
- 508: SP#49 completed (Conclusion: select the SIP anchoring based solution for normative work CR (TEI10) introducing and completing stage-2). Analyzed performance of Rel-8 SRVCC solution from E-UTRAN/HSPA to UTRAN/GERAN / Text5: Hou zhiqiang (houzhiqiang@chinamobile.com), Jiang Yi (jiangyi@chinamobile.com)
- 509: SP#49 completed. TR 23.886v100 for Approval. Related to Rel-8 UID_350030 Single Radio Voice Call Continuity for 3GPP (SAES-SRVCC). Study how to provide Video Call seamless service continuity for 3G/LTE terminal user / Text5: Haris Zisimopoulos (haris.z@samsung.com)
- 510: SP#48 completed. Triggered by Rel-8 UID_350027 SAE for support for non-3GPP accesses. Nature of relationship: S2b one of the interfaces defined for non-3GPP accesses support in EPS. Stage 1 in Rel-8 UID_320022 (AIPN-SAE) 22.278,22.101 / Text5: bruno.landais@alcatel-lucent.com
- 511: SP#51 completed. Extend Rel-8 UID_34043 (Extending PSS and MBMS User Services for optimized Mobile TV) / Text5: jan.plogsties@iis.franhofer.de
- 512: SP#51 completed. Extends Rel-9 Improved Video Support for PSS and MBMS (UID_430039) / Text5: imed.bouazizi@nokia.com, jaihyung@etri.re.kr
- 513: SP#47 completed / Text5: shan.mingjun@huawei.com
- 514: SP#47 completed. Study result might impact Feature UID_420011 Self Organising Networks (SON) / Text5: Jean-Michel Cornilly (Orange)
- 515: SP#47 completed. TR 32.827 v100 for Information + Approval. WID updated SP-090462=>SP-100088. Study the missing Itf-N part in the Framework. Study changes to Itf-N to utilize UE based measurements / Text5: Yizhi Yao (yzyao@motorola.com)
- 516: SP#51 completed / Text5: olaf.pollakowski@nsn.com
- 517: SP#51 completed / Text5: olaf.pollakowski@nsn.com, Padma.Sudarsan@alcatel-lucent.com
- 518: SP#51 completed / Text5: edwin.tse@ericsson.com
- 519: SP#51 completed / Text5: Padma.Sudarsan@alcatel-lucent.com
- 520: CP#49 completed (the solution will be chosen during a separate implementation work) / Text5: gottfried.punz@nw.neclab.eu
- 521: CP#51 completed. Study UDC evolution from Features in Rel-9 UID_400034 and Rel-10 UID_480011 UDC Data Model / Text5: jean-jacques.trottin@alcatel-lucent.com
- 522: CP#51 completed / Text5: Denis.Lheriteau@gemalto.com
- 523: RP#48 completed / Text5: Heechoon Lee (heechoon@qualcomm.com)
- 524: RP#49 completed. Based on ETSI EE TS 102 706. / Text5: Prakash.bhat@vodafone.com
- 525: RP#50 completed. TR 25.865 v101 for Approval / Text5: huang.he4@zte.com.cn
- 526: SP#47 work stopped/abandoned / Text5: Juergen Merkel
- 527: SP#50 work stopped. Additional work may be addressed as part of the Rel-11 Feature UID_470051 Advanced IP Interconnection of Services (IPXS) / Text5: Rajat Ghai (rghai@starentnetworks.com)
- 528: SP#47 work stopped. Issue covered by Rel-10 UID_460039 Charging for LIPA_SIPTO and UID_4700xy Charging for IFOM / Text5: Gerald.Goermer@nsn.com
- 529: CP#48 work stopped/abandoned / Text5: takaaki.matsuura.sp@s1.nttdocomo.com
- 530: -

| ID | WBS | Task | Duration | Start | Finish | Complete | Remaining | Baseline start | Baseline finish | Baseline duration | Total slack | Constraint | Resources | Work | Actual work | Text1 | Text2 | Text4 | Text5 | Text6 | Text7 | Text8 | Text11 |
| --- | --- | --- | --- | --- | --- | --- | --- | --- | --- | --- | --- | --- | --- | --- | --- | --- | --- | --- | --- | --- | --- | --- | --- |
| 531 | 228 | **Enhanced Home NodeB / eNodeB** | 923d? | 2008-06-05 A | 2011-12-16 | 92% | 74.4d? | 2008-06-05 | 2011-12-16 | 923d? | 325d |  | S1,S2,S3,S5,C1,C6,R2,R3,R4,GP | 37416h | 29537.6h | EHNB | PCG-21 | T-Mobile | michael.kurz@t-mobile.at | Rel-9 | SP-40 | Alain |  |
| 532 | 228.1 | Stage 1 for EHNB | 261d? | 2008-06-05 A | 2009-06-04 A | 100% |  | 2008-06-05 | 2009-06-04 | 261d? |  | finish no earlier than 2009-06-04 | S1 | 2088h | 2088h | EHNB | PCG-21 | T-Mobile | michael.kurz@t-mobile.at | Rel-9 | SP-40 | Alain |  |
| 533 | 228.2 | Architecture aspects of EHNB | 266d? | 2008-09-18 A | 2009-09-24 A | 100% |  | 2008-09-18 | 2009-09-24 | 266d? |  | finish no earlier than 2009-09-22 | S2 | 2128h | 2128h | EHNB | PCG-21 | T-Mobile | sebastian.speicher@telekom.de | Rel-9 | SP-41 | Maurice |  |
| 534 | 228.3 | Security aspects of Enhanced Home NodeB / eNodeB | 262d? | 2008-12-11 A | 2009-12-10 A | 100% |  | 2008-12-11 | 2009-12-10 | 262d? |  | finish no earlier than 2009-12-10 | S3 | 2096h | 2096h | EHNB-Sec | PCG-22 | Huawei | Marcus Wong (mwong@huawei.com) | Rel-9 | SP-42 | Dionisio |  |
| 535 | 228.4 | CT1 aspects - Support of Home NB and Home eNB enhancements | 321d? | 2009-09-18 A | 2010-12-10 A | 100% |  | 2009-09-18 | 2010-12-10 | 321d? |  | finish no earlier than 2010-12-10 | C1 | 2568h | 2568h | EHNB-CT1 | PCG-23 | Qualcomm | Ramachandran Subramanian (rsubrama@qualcomm.com) | Rel-9 | CP-45 | Frederic |  |
| 536 | 228.5 | CT6 aspects - Support of Home NB and Home eNB enhancements | 131d? | 2009-09-18 A | 2010-03-19 A | 100% |  | 2009-09-18 | 2010-03-19 | 131d? |  | finish no earlier than 2010-03-19 | C6 | 1048h | 1048h | EHNB-CT6 | PCG-23 | Qualcomm | Ramachandran Subramanian (rsubrama@qualcomm.com) | Rel-9 | CP-45 | Xavier |  |
| 537 | 228.6 | 3G HNB Gateway and LTE HeNB Gateway OAM&P | 336d? | 2008-12-11 A | 2010-03-25 A | 100% |  | 2008-12-11 | 2010-03-25 | 336d? |  | finish no earlier than 2010-03-25 | S5 | 2688h | 2688h | HNB-OAM_GW | PCG-22 | China Mobile | GangChen (chengang@chinamobile.com) | Rel-9 | SP-42 | Dionisio |  |
| 538 | 228.7 | 3G HNB and LTE HeNB OAM&P Type 1 Interface | 272d? | 2009-03-12 A | 2010-03-25 A | 100% |  | 2009-03-12 | 2010-03-25 | 272d? |  | finish no earlier than 2010-03-25 | S5 | 2168h | 2168h | HNB_eHNB-OAM_Type1 | PCG-22 | Huawei | Zou Lan (zlan@huawei.com) | Rel-9 | SP-43 | Dionisio |  |
| 539 | 228.8 | 3G HNB and LTE HeNB OAM&P Type 2 Interface | 225d? | 2009-05-15 A | 2010-03-25 A | 100% |  | 2009-05-15 | 2010-03-25 | 225d? |  | finish no earlier than 2010-03-25 | S5 | 1800h | 1800h | HNB_eHNB-OAM_Type2 | PCG-23 | Ericsson | edwin.tse@ericsson.com | Rel-9 | SP-44 | Dionisio |  |
| 540 | 228.9 | LTE FDD Home eNodeB RF Requirements | 336d? | 2008-12-05 A | 2010-03-19 A | 100% |  | 2008-12-05 | 2010-03-19 | 336d? |  | finish no earlier than 2010-03-19 | R4 | 2688h | 2688h | HeNB-RF_FDD | PCG-22 | Motorola | Ying Cai (yingcai@motorola.com) | Rel-9 | RP-42 | Issam | RP-100035 |
| 541 | 228.10 | LTE TDD Home eNodeB RF Requirements | 271d? | 2009-03-06 A | 2010-03-19 A | 100% |  | 2009-03-06 | 2010-03-19 | 271d? |  | finish no earlier than 2010-03-19 | R4 | 2168h | 2168h | HeNB-RF_TDD | PCG-22 | China Mobile | Nan Li (linan@chinamobile.com) | Rel-9 | RP-43 | Issam | RP-100036 |
| 542 | 228.11 | Home NB and Home eNB enhancements - RAN3 aspects | 197d? | 2009-03-06 A | 2009-12-04 A | 100% |  | 2009-03-06 | 2009-12-04 | 197d? |  | finish no earlier than 2009-12-04 | R3 | 1576h | 1576h | EHNB-RAN3 | PCG-22 | Alcatel-Lucent | Martin Warner (mw15@alcatel-lucent.com) | Rel-9 | RP-43 | Juha | RP-091050 |
| 543 | 228.12 | Home NB and Home eNB enhancements - RAN2 aspects | 271d? | 2009-03-06 A | 2010-03-19 A | 100% |  | 2009-03-06 | 2010-03-19 | 271d? |  | finish no earlier than 2010-03-19 | R2 | 2168h | 2168h | EHNB-RAN2 | PCG-22 | Huawei | Yang Xudong (yangxudong@huawei.com) | Rel-9 | RP-43 | Joern | RP-100037 |
| 544 | 228.13 | Conformance Test Aspects – Home NB enhancements for FDD | 326d? | 2010-09-17 A | 2011-12-16 | 50% | 163d? | 2010-09-17 | 2011-12-16 | 326d? | 325d | finish no earlier than 2011-12-16 | R5 | 2608h | 1304h | EHNB-UTRA_FDD_UEConTest | PCG-25 | Huawei | trica_li@huawei.com | Rel-9 | RP-49 | Ingbert | RP-110041 |
| 545 | 228.14 | Conformance Test Aspects – Home eNB enhancements | 201d? | 2010-12-10 A | 2011-09-16 | 20% | 160.8d? | 2010-12-10 | 2011-09-16 | 201d? | 390d | finish no earlier than 2011-09-16 | R5 | 1608h | 321.6h | EHNB-LTE_UEConTest | PCG-26 | Qualcomm | Mrs Lena Chaponniere (lchaponn@qualcomm.com) | Rel-9 | RP-50 | Ingbert | RP-110042 |
| 546 | 228.15 | Home NB and Home eNB enhancements - GERAN aspects | 341d? | 2009-05-18 A | 2010-09-03 A | 100% |  | 2009-05-18 | 2010-09-03 | 341d? |  | finish no earlier than 2010-09-03 | GP | 2728h | 2728h | EHNB-GERAN | PCG-23 | Nokia Siemens Networks | leonardo.provvedi@roke.co.uk | Rel-9 | GP-42 | Paolo |  |
| 547 | 229 | **Value-Added Services for Short Message Service** | 586d? | 2007-09-10 A | 2009-12-04 A | 100% |  | 2007-09-10 | 2009-12-04 | 586d? |  |  | S1,C4,C1 | 10888h | 10888h | VAS4SMS |  | China Mobile | Wu Bin (wubin@chinamobile.com) | Rel-9 | SP-37 | Alain |  |
| 548 | 229.1 | Stage 1 for VAS4SMS | 133d? | 2007-09-10 A | 2008-03-12 A | 100% |  | 2007-09-10 | 2008-03-12 | 133d? |  | finish no earlier than 2008-03-21 | S1 | 1064h | 1064h | VAS4SMS |  | China Mobile | Wu Bin (wubin@chinamobile.com) | Rel-9 | SP-37 | Alain |  |
| 549 | 229.2 | CT4 aspects of VAS4SMS Interface and Signalling Flow | 322d? | 2008-09-12 A | 2009-12-04 A | 100% |  | 2008-09-12 | 2009-12-04 | 322d? |  | finish no earlier than 2009-12-04 | C4 | 2568h | 2568h | VAS4SMS | PCG-21 | China Mobile | Wu Bin (wubin@chinamobile.com) | Rel-9 | CP-41 | Kimmo |  |
| 550 | 229.3 | CT1 aspects of VAS4SMS Interface and Signalling Flow | 321d? | 2008-09-09 A | 2009-12-04 A | 100% |  | 2008-09-09 | 2009-12-04 | 321d? |  | finish no earlier than 2009-12-04 | C1 | 2568h | 2568h | VAS4SMS | PCG-21 | China Mobile | Wu Bin (wubin@chinamobile.com) | Rel-9 | CP-41 | Frederic |  |
| 551 | 230 | **Definition of End-User Identity** | 334d? | 2007-09-03 A | 2008-12-11 A | 100% |  | 2007-09-03 | 2008-12-11 | 334d? |  |  | S1 | 5344h | 5344h | EUI |  | Nokia Siemens Networks | Juergen.Merkel@nsn.com | Rel-9 | SP-38 | Alain |  |
| 552 | 230.1 | Definition of End-User Identity | 334d? | 2007-09-03 A | 2008-12-11 A | 100% |  | 2007-09-03 | 2008-12-11 | 334d? |  | finish no earlier than 2008-12-11 | S1 | 2672h | 2672h | EUI | PCG-21 | Nokia Siemens Networks | Juergen.Merkel@NSN.com | Rel-9 | SP-38 | Alain |  |
| 553 | 231 | **Customized Ringing Signal** | 653d? | 2007-12-06 A | 2010-06-04 A | 100% |  | 2007-12-06 | 2010-06-04 | 653d? |  |  | S1,C1 | 8168h | 8168h | CRS | PCG-21 | SK Telecom, China Mobile | Donghee Shim (SK Telecom), Jianping Zheng (China Mobile) | Rel-9 | SP-38 | Alain |  |
| 554 | 231.1 | Stage 1 for Customized Ringing Signal | 266d? | 2007-12-06 A | 2008-12-11 A | 100% |  | 2007-12-06 | 2008-12-11 | 266d? |  | finish no earlier than 2008-12-11 | S1 | 2128h | 2128h | CRS | PCG-21 | SK Telecom, China Mobile | Donghee Shim (SK Telecom), Jianping Zheng (China Mobile) | Rel-9 | SP-38 | Alain |  |
| 555 | 231.2 | Stage 3 for IMS Customized Ringing Signal (CRS) Service | 267d? | 2009-05-29 A | 2010-06-04 A | 100% |  | 2009-05-29 | 2010-06-04 | 267d? |  | finish no earlier than 2010-06-04 | C1 | 816h | 816h | CRS | PCG-23 | China Mobile | wangzhao | Rel-9 | CP-44 | Frederic |  |

Notes:
- 531: CP#50 Core specification completed. Testing ongoing / Text3: UTRA, LTE
- 532: CP#49 the SA1-reqs are moving. CT1 will align when the work in SA1 is clear. (was SP#44 completed.) / Text3: 22.220, 22.011
- 533: SP#45 completed / Text3: 23.401, 23.402, 23.060, new 23.830
- 534: SP#46 completed / Text3: new 33.320
- 535: CP#50 completed (Roaming aspects for manual CSG selection, Support of temporary users and CSG membership changes, Support of user controlled and operator controlled lists) / Text3: 23.122, 24.008, 24.285, 24.301
- 536: CP#47 completed. Storing of CSG related data items on the USIM / Text3: 31.102
- 537: SP#47 completed / Text3: 32.632, 32.633, 32.635, new (32.771, 32.772, 32.773, 32.775, 32.781, 32.782, 32.783, 32.785)
- 538: SP#47 completed / Text3: 32.581, 32.582, 32.583, 32.584, new (32.591, 32.592, 32.593, 32.594)
- 539: SP#47 completed / Text3: new (32.571, 32.572)
- 540: RP#47 completed / Text3: 36.104, 36.141, new TR 36.921
- 541: RP#47 completed / Text3: 36.104, 36.141, 36.300, 36.331, 36.413, new TR 36.922
- 542: RP#46 completed (based on high priority items specified in RP-090995) / Text3: 25.413, 25.467, 25.467, 25.468, 25.469, 25.469, 36.401, 36.413, new 25.444
- 543: RP#47 completed / Text3: 25.304, 25.331, 25.367, 36.300, 36.304, 36.331
- 544: UTRA. Testing for UID_430026 Support of Home NB and Home eNB enhancements RAN2 aspects (25.304, 25.331, 25.367) / Text3: 34.108, 34.123-1, 34.123-2, 34.123-3
- 545: - / Text3: 36.508, 36.523-1, 36.523-2, 36.523-3
- 546: GP#47 completed. GP#42 WID approved / Text3: 43.055, 43.129, 44.018, 44.060, 45.008, 48.008, 48.018
- 547: CP#46 completed
- 548: SP#39 completed. SP#43 Feature moved to Rel-9 / Text3: 22.142
- 549: CP#46 completed / Text3: new 23.142
- 550: CP#46 completed / Text3: 23.040
- 551: SP#42 closed. Stage 1 work closed at 5% completion due to lack of input (added only the EUI definition in 21.905)
- 552: SP#42 closed. Stage 1 work closed at 5% completion due to lack of input (added only the EUI definition in 21.905) / Text3: 21.905
- 553: CP#48 completed
- 554: SP#42 completed. / Text3: 22.173, new 22.183
- 555: CP#48 completed / Text3: 24.173, new 24.183

| ID | WBS | Task | Type | Duration | Start | Finish | Complete | Baseline start | Baseline finish | Baseline duration | Constraint | Resources | Work | Actual work | Text1 | Text2 | Text3 | Text4 | Text6 | Text7 | Text8 | Text11 |
| --- | --- | --- | --- | --- | --- | --- | --- | --- | --- | --- | --- | --- | --- | --- | --- | --- | --- | --- | --- | --- | --- | --- |
| 556 | 232 | **Public Warning System** |  | 523d? | 2007-12-06 A | 2009-12-04 A | 100% | 2007-12-06 | 2009-12-04 | 523d? |  | S1,C1,C4,R2 | 10232h | 10232h | PWS | PCG-21 | GERAN, UTRA, LTE | T-Mobile | Rel-9 | SP-38 | Alain |  |
| 557 | 232.1 | Stage 1 for Public Warning System |  | 266d? | 2007-12-06 A | 2008-12-11 A | 100% | 2007-12-06 | 2008-12-11 | 266d? | finish no earlier than 2008-12-11 | S1 | 2128h | 2128h | PWS | PCG-21 | 22.268 | T-Mobile | Rel-9 | SP-38 | Alain |  |
| 558 | 232.2 | **Stage 3 for Public Warning System** |  | 137d? | 2009-05-29 A | 2009-12-04 A | 100% | 2009-05-29 | 2009-12-04 | 137d? |  | C1,C4 | 3272h | 3272h | PWS-St3 | PCG-23 |  | Qualcomm | Rel-9 | CP-44 | Frederic |  |
| 559 | 232.2.1 | CT1 aspects of Stage 3 for Public Warning System |  | 137d? | 2009-05-29 A | 2009-12-04 A | 100% | 2009-05-29 | 2009-12-04 | 137d? | finish no earlier than 2009-12-04 | C1 | 1088h | 1088h | PWS-St3 | PCG-23 | 23.041 | Qualcomm | Rel-9 | CP-44 | Frederic |  |
| 560 | 232.2.2 | CT4 aspects of Stage 3 for Public Warning System |  | 136d? | 2009-05-30 A | 2009-12-04 A | 100% | 2009-05-30 | 2009-12-04 | 136d? | finish no earlier than 2009-12-04 | C4 | 1088h | 1088h | PWS-St3 | PCG-23 | 29.168 | Qualcomm | Rel-9 | CP-44 | Kimmo |  |
| 561 | 232.3 | Public Warning System (PWS) – RAN aspects |  | 81d? | 2009-05-30 A | 2009-12-04 A | 100% | 2009-05-30 | 2009-12-04 | 81d? | finish no earlier than 2009-12-04 | R2,R3 | 648h | 648h | PWS-RAN | PCG-23 | LTE 36.300, 36.302, 36.331, 36.413 | AT&T | Rel-9 | RP-44 | Joern | RP-091052 |
| 562 | 233 | **Support of Personal Area Networks and Enhancements to Personal Network Management** |  | 523d? | 2008-06-05 A | 2010-06-04 A | 100% | 2008-06-05 | 2010-06-04 | 523d? |  | S1,C1 | 8360h | 8360h | PAN_EPNM | PCG-21 |  | Vodafone | Rel-9 | SP-40 | Alain |  |
| 563 | 233.1 | Stage 1 for PAN_EPNM | milestone | 0d? | 2008-06-05 A | 2008-06-05 A | 100% | 2008-06-05 | 2008-06-05 | 0d? | finish no earlier than 2008-06-05 | S1 |  |  | PAN_EPNM | PCG-21 | 22.259 | Vodafone | Rel-9 | SP-40 | Alain |  |
| 564 | 233.2 | Stage 2 for Support of Personal Area Networks and Enhancements to Personal Network Managemen |  | 196d? | 2009-03-06 A | 2009-12-04 A | 100% | 2009-03-06 | 2009-12-04 | 196d? | finish no earlier than 2009-12-04 | C1 | 1568h | 1568h | PAN_EPNM | PCG-22 | 23.259 | Huawei | Rel-9 | CP-43 | Frederic |  |
| 565 | 233.3 | Stage 3 for Support of Personal Area Networks and Enhancements to Personal Network Managemen |  | 326d? | 2009-03-09 A | 2010-06-04 A | 100% | 2009-03-09 | 2010-06-04 | 326d? | finish no earlier than 2010-06-04 | C1 | 2608h | 2608h | PAN_EPNM | PCG-22 | 24.259 | Huawei | Rel-9 | CP-43 | Frederic |  |
| 566 | 234 | **Multi-Media Telephony Service enhancements** |  | 472d? | 2008-06-05 A | 2010-03-25 A | 100% | 2008-06-05 | 2010-03-25 | 472d? |  | S1,S5,C1 | 10288h | 10288h | eMMTel | PCG-21 |  | France Telecom | Rel-9 | SP-40 | Alain |  |
| 567 | 234.1 | Stage 1 for eMMTel |  | 136d? | 2008-06-05 A | 2008-12-11 A | 100% | 2008-06-05 | 2008-12-11 | 136d? | start no earlier than 2008-06-05 | S1 | 1088h | 1088h | eMMTel | PCG-21 | 22.173 | France Telecom | Rel-9 | SP-40 | Alain |  |
| 568 | 234.2 | Multimedia Telephony (MMTel) Service and Supplementary Services - Online Charging and completion for Offline Charging (all supplementary services) |  | 272d? | 2009-03-12 A | 2010-03-25 A | 100% | 2009-03-12 | 2010-03-25 | 272d? | finish no earlier than 2010-03-25 | S5 | 2168h | 2168h | eMMTel-SS-CH | PCG-22 | 32.275, 32.298, 32.299 | Alcatel-Lucent | Rel-9 | SP-43 | Dionisio |  |
| 569 | 234.3 | Support of Real-time Transfer of Tariff Information (RTTI) in IMS charging |  | 271d? | 2009-03-12 A | 2010-03-25 A | 100% | 2009-03-12 | 2010-03-25 | 271d? | finish no earlier than 2010-03-25 | S5 | 2168h | 2168h | IMSTSS-RTTI-CH | PCG-22 | 32.240, 32.280, 32.298, 32.299 | Orange | Rel-9 | SP-43 | Dionisio |  |
| 570 | 234.4 | Stage 3 - Enhancements for Completion of Communications Supplementary service |  | 136d? | 2009-05-30 A | 2009-12-04 A | 100% | 2009-05-30 | 2009-12-04 | 136d? | finish no earlier than 2009-12-04 | C1 | 1088h | 1088h | eMMTel-CC | PCG-23 | 24.642 | France Telecom | Rel-9 | CP-44 | Frederic |  |
| 571 | 235 | **User Data Convergence (UDC)** |  | 527d? | 2008-06-05 A | 2010-06-10 A | 100% | 2008-06-05 | 2010-06-10 | 527d? |  | S1,S5,C4 | 14456h | 14456h | UDC | PCG-21 |  | Nokia Siemens Networks | Rel-9 | SP-40 | Alain |  |
| 572 | 235.1 | Stage 1 for User Data Convergence (UDC) |  | 136d? | 2008-06-05 A | 2008-12-11 A | 100% | 2008-06-05 | 2008-12-11 | 136d? | start no earlier than 2008-06-05 | S1 | 1088h | 1088h | UDC | PCG-21 | 22.985, 22.101 | Nokia Siemens Networks | Rel-9 | SP-40 | Alain |  |
| 573 | 235.2 | User Data Convergence (UDC) Technical Realization (Stage 2) |  | 271d? | 2009-03-06 A | 2010-03-19 A | 100% | 2009-03-06 | 2010-03-19 | 271d? | finish no earlier than 2010-03-19 | C4 | 2168h | 2168h | UDC-CN | PCG-22 | new 23.335 | Ericsson | Rel-9 | CP-43 | Kimmo |  |
| 574 | 235.3 | User Data Convergence (UDC) Protocol Description |  | 130d? | 2009-09-18 A | 2010-03-19 A | 100% | 2009-09-18 | 2010-03-19 | 130d? | finish no earlier than 2010-03-19 | C4 | 1040h | 1040h | UDC-CN | PCG-23 | new 29.335 | China Mobile, Ericsson | Rel-9 | CP-45 | Kimmo |  |
| 575 | 235.4 | **User Data Convergence (UDC) Modelling and Management** |  | 266d? | 2009-06-04 A | 2010-06-10 A | 100% | 2009-06-04 | 2010-06-10 | 266d? |  | S5 | 5944h | 5944h | UDC-MMAN | PCG-23 |  | T-Mobile, China Mobile, Ericsson | Rel-9 | SP-44 | Dionisio |  |
| 576 | 235.4.1 | UDC – Framework for Model Handling and Management |  | 266d? | 2009-06-04 A | 2010-06-10 A | 100% | 2009-06-04 | 2010-06-10 | 266d? | finish no earlier than 2010-06-10 | S5 | 2128h | 2128h | UDC-MMAN-MFRM | PCG-23 | 32.172, new 32.181 | T-Mobile | Rel-9 | SP-44 | Dionisio |  |
| 577 | 235.4.2 | UDC – Common Baseline Information Model |  | 211d? | 2009-06-04 A | 2010-03-25 A | 100% | 2009-06-04 | 2010-03-25 | 211d? | finish no earlier than 2010-03-25 | S5 | 1688h | 1688h | UDC-MMAN-CBIM | PCG-23 | 32.172, new 32.182 | China Mobile, Ericsson | Rel-9 | SP-44 | Dionisio |  |
| 578 | 236 | **IMS Services Centralization and Continuity** |  | 393d? | 2008-09-18 A | 2010-03-19 A | 100% | 2008-09-18 | 2010-03-19 | 393d? |  | S1,S2,C1 | 12160h | 12160h | IMS_SCC | PCG-21 |  | NEC | Rel-9 | SP-41 | Alain |  |
| 579 | 236.1 | Stage 1 - Inter-Device Transfer – Requirements |  | 61d? | 2008-09-18 A | 2008-12-11 A | 100% | 2008-09-18 | 2008-12-11 | 61d? | finish no earlier than 2009-06-18 | S1 | 488h | 488h | IMS_SCC-IDT | PCG-21 | 22.101, 22.228 | NEC | Rel-9 | SP-41 | Alain |  |
| 580 | 236.2 | Stage 2 - IMS Service Continuity Enhancements: Service, Policy and Interactions |  | 186d? | 2008-09-18 A | 2009-06-04 A | 100% | 2008-09-18 | 2009-06-04 | 186d? | finish no earlier than 2009-06-04 | S2 | 1488h | 1488h | IMS_SCC-SPI | PCG-21 | 23.838, 23.237, 23.292, 23.216 | Huawei | Rel-9 | SP-41 | Maurice |  |
| 581 | 236.3 | Stage 3 - IMS Service Continuity Enhancements: Service, Policy, Interactions and Inter UE Transfer |  | 212d? | 2009-05-29 A | 2010-03-19 A | 100% | 2009-05-29 | 2010-03-19 | 212d? | finish no earlier than 2010-03-19 | C1 | 1696h | 1696h | IMS_SCC-SPI | PCG-23 | 24.216, 24.229, 24.237 | Qualcomm | Rel-9 | CP-44 | Frederic |  |
| 582 | 236.4 | Stage 2 - IMS Centralized Services |  | 186d? | 2008-09-18 A | 2009-06-04 A | 100% | 2008-09-18 | 2009-06-04 | 186d? | finish no earlier than 2009-06-04 | S2 | 1488h | 1488h | IMS_SCC-ICS | PCG-21 | 23.292, new 23.883 | Alcatel-Lucent | Rel-9 | SP-41 | Maurice |  |
| 583 | 236.5 | Stage 3 - Enhancements to IMS Centralized Services |  | 212d? | 2009-05-29 A | 2010-03-19 A | 100% | 2009-05-29 | 2010-03-19 | 212d? | finish no earlier than 2010-03-19 | C1 | 1688h | 1688h | IMS_SCC-ICS | PCG-23 | 24.292, 24.604, 24.607, 24.608, 24.611, 24.623 | Nokia Siemens Networks | Rel-9 | CP-44 | Frederic |  |
| 584 | 236.6 | Stage 3 - IMS Centralized Services support via I1 interface |  | 271d? | 2009-03-06 A | 2010-03-19 A | 100% | 2009-03-06 | 2010-03-19 | 271d? | finish no earlier than 2010-03-19 | C1 | 2168h | 2168h | IMS_SCC-ICS_I1 | PCG-22 | 24.237, 24.292, new 24.294 | Huawei | Rel-9 | CP-43 | Frederic |  |

Notes:
- 556: TSG#46 completed. Larger scope than Rel-8 Feature UID_370051 (ETWS). Triggered by TR 22.968 Study UID_320025 (FS_PWS) / Text5: Mark.Younge@t-mobile.com
- 557: SP#42 completed / Text5: Mark.Younge@t-mobile.com
- 558: RP#46 completed / Text5: Ramachandran Subramanian (rsubrama@qualcomm.com)
- 559: CP#46 completed / Text5: Ramachandran Subramanian (rsubrama@qualcomm.com)
- 560: CP#46 completed / Text5: Ramachandran Subramanian (rsubrama@qualcomm.com)
- 561: RP#46 completed / Text5: don.zelmer@att.com
- 562: CP#48 completed / Text5: armin.toepfer@vodafone.com
- 563: SP#40 completed / Text5: armin.toepfer@vodafone.com
- 564: CP#46 completed / Text5: Lili Yang (kadyyang@huawei.com)
- 565: CP#48 completed / Text5: Lili Yang (kadyyang@huawei.com)
- 566: SP#47 completed / Text5: Philippe Lottin
- 567: SP#42 completed / Text5: Philippe Lottin
- 568: SA#47 completed / Text5: maryse.gardella@alcatel-lucent.com
- 569: SA#47 completed. Linked to SA5 Rel-8 UID_380042 AoC support in IMS Charging (IMSTSS) / Text5: Jean-Luc Garcia (jl.garcia@orange-ftgroup.com)
- 570: CP#46 completed / Text5: Youssef.chadli@orange-ftgroup.com
- 571: SP#48 completed. Triggered by Rel-8 SA5 Study of Common Profile Storage Framework of User Data for network services and management (UID_320006) TR 32.808 / Text5: juergen.merkel@nsn.com
- 572: SP#42 completed / Text5: juergen.merkel@nsn.com
- 573: CP#47 completed / Text5: emiliano.merino@ericsson.com
- 574: CP#47 completed / Text5: Lan Si Zhong (lansizhong@chinamobile.com), emiliano.merino@ericsson.com
- 575: SP#48 completed / Text5: istvan.aba@t-mobile.at, lansizhong@chinamobile.com, miguel.a.garcia@ericsson.com
- 576: SP#48 completed / Text5: istvan.aba@t-mobile.at
- 577: SP#47 completed / Text5: Lan Si Zhong, Miguel Garcia
- 578: CP#47 completed / Text5: Joerg Swetina (joerg.swetina@nw.neclab.eu)
- 579: SP#42 completed / Text5: Joerg Swetina (joerg.swetina@nw.neclab.eu)
- 580: SP#44 completed. TR 23.838 for Approval / Text5: HengLiang Zhang (hl_zhang@huawei.com)
- 581: CP#47 completed / Text5: Roozbeh Atarius (ratarius@qualcomm.com)
- 582: SP#44 completed. TR 23.883 for Information + Approval / Text5: andy.bennett@alcatel-lucent.com
- 583: CP#47 completed / Text5: Peter.Leis@nsn.com
- 584: CP#47 completed / Text5: Lili Yang(kadyyang@huawei.com)

| ID | WBS | Task | Duration | Start | Finish | Complete | Remaining | Baseline start | Baseline finish | Baseline duration | Total slack | Constraint | Resources | Work | Actual work | Text1 | Text2 | Text4 | Text5 | Text6 | Text7 | Text8 | Text11 |
| --- | --- | --- | --- | --- | --- | --- | --- | --- | --- | --- | --- | --- | --- | --- | --- | --- | --- | --- | --- | --- | --- | --- | --- |
| 585 | 237 | **Service Specific Access Control in EPS** | 333d? | 2008-12-11 A | 2010-03-19 A | 100% |  | 2008-12-11 | 2010-03-19 | 333d? |  |  | S1,C1 | 4368h | 4368h | SSAC | PCG-22 | NTT DoCoMo | Frederic Thepot (thepot@docomolab-euro.com) | Rel-9 | SP-42 | Alain |  |
| 586 | 237.1 | Stage 1 for Service Specific Access Control in EPS | 1d? | 2008-12-11 A | 2008-12-11 A | 100% |  | 2008-12-11 | 2008-12-11 | 1d? |  | start no earlier than 2008-12-11 | S1 | 8h | 8h | SSAC | PCG-22 | NTT DoCoMo | Frederic Thepot (thepot@docomolab-euro.com) | Rel-9 | SP-42 | Alain |  |
| 587 | 237.2 | Stage 3 for Service Specific Access Control in EPS | 212d? | 2009-05-29 A | 2010-03-19 A | 100% |  | 2009-05-29 | 2010-03-19 | 212d? |  | finish no earlier than 2010-03-19 | C1 | 1696h | 1696h | SSAC | PCG-23 | NTT DoCoMo | Hideyuki Yamashita (yamashitahi@s1.nttdocomo.co.jp) | Rel-9 | CP-44 | Frederic |  |
| 588 | 238 | **Support for IMS Emergency Calls over GPRS and EPS** | 1021d? | 2008-01-14 A | 2011-12-09 | 93% | 71.92d? | 2008-01-14 | 2011-12-09 | 1021d? | 330d |  | S1,S2,S3,C1,C3,C4,R2,R3,R5 | 37043.7h | 24563.7h | IMS_EMER_GPRS_EPS | PCG-21 | Alcatel-Lucent | Deborah Barclay | Rel-9 | SP-38 | Maurice |  |
| 589 | 238.1 | Stage 1 for IMS Emergency Calls over GPRS and EPS | 239d? | 2008-01-14 A | 2008-12-11 A | 100% |  | 2008-01-14 | 2008-12-11 | 239d? |  | finish no earlier than 2008-12-11 | S1 | 1912h | 1912h | IMS_EMER_GPRS_EPS | PCG-21 | Alcatel-Lucent | Deborah Barclay | Rel-9 | SP-38 | Alain |  |
| 590 | 238.2 | Stage 2 for IMS Emergency Calls over GPRS and EPS | 364d? | 2008-01-14 A | 2009-06-04 A | 100% |  | 2008-01-14 | 2009-06-04 | 364d? |  | finish no earlier than 2009-06-04 | S2 | 2912h | 2912h | IMS_EMER_GPRS_EPS | PCG-21 | Alcatel-Lucent | Deborah Barclay | Rel-9 | SP-38 | Maurice |  |
| 591 | 238.3 | Security aspects for IMS Emergency Calls over GPRS and EPS | 391d? | 2008-12-12 A | 2010-06-10 A | 100% |  | 2008-12-12 | 2010-06-10 | 391d? |  | finish no earlier than 2010-03-25 | S3 | 3128h | 3128h | IMS_EMER_GPRS_EPS-Sec | PCG-22 | Alcatel-Lucent | Deborah Barclay | Rel-9 | SP-42 | Dionisio |  |
| 592 | 238.4 | **Stage 3 for IMS Emergency Calls over GPRS and EPS** | 662d? | 2009-05-29 A | 2011-12-09 | 76% | 158.5d? | 2009-05-29 | 2011-12-09 | 662d? | 330d |  | C1,C3,C4,R5 | 11907.7h | 5683.68h | IMS_EMER_GPRS_EPS | PCG-23 | Alcatel-Lucent | Frank Alfano (falfano@alcatel-lucent.com) | Rel-9 | CP-44 | Frederic |  |
| 593 | 238.4.1 | CT1 aspects - Stage 3 for IMS Emergency Calls over GPRS and EPS | 212d? | 2009-05-29 A | 2010-03-19 A | 100% |  | 2009-05-29 | 2010-03-19 | 212d? |  | finish no earlier than 2010-03-19 | C1 | 1696h | 1696h | IMS_EMER_GPRS_EPS | PCG-23 | Alcatel-Lucent | Frank Alfano (falfano@alcatel-lucent.com) | Rel-9 | CP-44 | Frederic |  |
| 594 | 238.4.2 | Conformance Test Aspects - CT1 aspects for IMS Emergency Calls over GPRS and EPS | 396d? | 2010-06-04 A | 2011-12-09 | 50% | 198d? | 2010-06-04 | 2011-12-09 | 396d? | 330d | finish no earlier than 2011-12-09 | R5 | 3168h | 1584h | IMS_EMER_GPRS_EPS_UEConTest | PCG-25 | Samsung | stoyan.baev@partner.samsung.com | Rel-9 | RP-48 | Ingbert | RP-110037 |
| 595 | 238.4.3 | CT3 aspects - Stage 3 for IMS Emergency Calls over GPRS and EPS | 82d? | 2009-05-29 A | 2009-09-18 A | 100% |  | 2009-05-29 | 2009-09-18 | 82d? |  | start no earlier than 2009-05-29 | C3 | 651.68h | 651.68h | IMS_EMER_GPRS_EPS | PCG-23 | Alcatel-Lucent | Frank Alfano (falfano@alcatel-lucent.com) | Rel-9 | CP-44 | Jiwan |  |
| 596 | 238.4.4 | CT4 aspects - Stage 3 for IMS Emergency Calls over GPRS and EPS | 137d? | 2009-05-29 A | 2009-12-04 A | 100% |  | 2009-05-29 | 2009-12-04 | 137d? |  | finish no earlier than 2009-12-04 | C4 | 1096h | 1096h | IMS_EMER_GPRS_EPS | PCG-23 | Alcatel-Lucent | Frank Alfano (falfano@alcatel-lucent.com) | Rel-9 | CP-44 | Kimmo |  |
| 597 | 238.5 | Support for IMS Emergency Calls over LTE | 206d? | 2008-12-05 A | 2009-09-18 A | 100% |  | 2008-12-05 | 2009-09-18 | 206d? |  |  | R2,R3 | 1648h | 1648h | IMS_EMER_LTE | PCG-22 | Alcatel-Lucent | Sudeep Palat (spalat@alcatel-lucent.com) | Rel-9 | RP-42 | Joern |  |
| 598 | 238.6 | Conformance Test Aspects – Support for IMS Emergency Calls over LTE | 187d? | 2010-03-25 A | 2010-12-10 A | 100% |  | 2010-03-25 | 2010-12-10 | 187d? |  | finish no earlier than 2010-12-10 | R5 | 1496h | 1496h | IMS_EMER_LTE_UEConTest | PCG-24 | Ericsson | leif.mattisson@ericsson.com | Rel-9 | RP-47 | Ingbert | RP-101068 |
| 599 | 238.7 | **SRVCC support for IMS Emergency Calls** | 322d? | 2008-09-18 A | 2009-12-10 A | 100% |  | 2008-09-18 | 2009-12-10 | 322d? |  |  | S2,C1,C4,C3 | 5872h | 5872h | IMS_EMER_GPRS_EPS-SRVCC | PCG-21 | China Mobile | Yu Qing (Yuqing@chinamobile.com) | Rel-9 | SP-41 | Maurice |  |
| 600 | 238.7.1 | SRVCC support for IMS Emergency Calls | 322d? | 2008-09-18 A | 2009-12-10 A | 100% |  | 2008-09-18 | 2009-12-10 | 322d? |  | finish no earlier than 2009-12-10 | S2 | 2576h | 2576h | IMS_EMER_GPRS_EPS-SRVCC | PCG-21 | China Mobile | Yu Qing (Yuqing@chinamobile.com) | Rel-9 | SP-41 | Maurice |  |
| 601 | 238.7.2 | **CT aspects of SRVCC support for IMS Emergency Calls** | 137d? | 2009-05-29 A | 2009-12-04 A | 100% |  | 2009-05-29 | 2009-12-04 | 137d? |  |  | C1,C4,C3 | 3296h | 3296h | IMS_EMER_GPRS_EPS-SRVCC | PCG-24 | China Mobile | jiangyi@chinamobile.com | Rel-9 | CP-46 | Frederic |  |
| 602 | 238.7.2.1 | CT1 aspects of SRVCC support for IMS Emergency Calls | 137d? | 2009-05-29 A | 2009-12-04 A | 100% |  | 2009-05-29 | 2009-12-04 | 137d? |  | finish no earlier than 2009-12-04 | C1 | 1096h | 1096h | IMS_EMER_GPRS_EPS-SRVCC | PCG-23 | China Mobile | jiangyi@chinamobile.com | Rel-9 | CP-44 | Frederic |  |
| 603 | 238.7.2.2 | CT4 aspects of SRVCC support for IMS Emergency Calls | 137d? | 2009-05-29 A | 2009-12-04 A | 100% |  | 2009-05-29 | 2009-12-04 | 137d? |  | finish no earlier than 2009-12-04 | C4 | 1096h | 1096h | IMS_EMER_GPRS_EPS-SRVCC | PCG-23 | China Mobile | jiangyi@chinamobile.com | Rel-9 | CP-44 | Kimmo |  |
| 604 | 238.7.2.3 | CT3 aspects of SRVCC support for IMS Emergency Calls | 1d? | 2009-12-04 A | 2009-12-04 A | 100% |  | 2009-12-04 | 2009-12-04 | 1d? |  | finish no earlier than 2009-12-04 | C3 | 8h | 8h | IMS_EMER_GPRS_EPS-SRVCC | PCG-24 | China Mobile | jiangyi@chinamobile.com | Rel-9 | CP-46 | Kimmo |  |
| 605 | 239 | **LCS for LTE and EPS** | 858d? | 2008-06-05 A | 2011-09-16 | 87% | 114.26d? | 2008-06-05 | 2011-09-16 | 858d? | 390d |  | S2,C1,C4,R2,R1,R3,R4,R5 | 22352h | 16020h | LCS_LTE_EPS | PCG-22 |  |  | Rel-9 | SP-43 | Maurice |  |
| 606 | 239.1 | **LCS Control Plane Solution for EPS** | 468d? | 2008-06-05 A | 2010-03-19 A | 100% |  | 2008-06-05 | 2010-03-19 | 468d? |  |  | S2,C4,C1 | 9224h | 9224h | LCS_EPS-CPS | PCG-21 | Polaris Wireless | Robert Gross (rgross@polariswireless.com) | Rel-9 | SP-40 | Maurice |  |
| 607 | 239.1.1 | Stage 2 for LCS Control Plane Solution for EPS | 261d? | 2008-06-05 A | 2009-06-04 A | 100% |  | 2008-06-05 | 2009-06-04 | 261d? |  | finish no earlier than 2009-06-04 | S2 | 2088h | 2088h | LCS_EPS-CPS | PCG-21 | Polaris Wireless | Robert Gross (rgross@polariswireless.com) | Rel-9 | SP-40 | Maurice |  |
| 608 | 239.1.2 | CT4 aspects of Control Plane LCS in the EPC | 212d? | 2009-05-29 A | 2010-03-19 A | 100% |  | 2009-05-29 | 2010-03-19 | 212d? |  | finish no earlier than 2010-03-19 | C4 | 1696h | 1696h | LCS_EPS-CPS | PCG-23 | Polaris Wireless | Robert Gross (rgross@polariswireless.com) | Rel-9 | CP-44 | Kimmo |  |
| 609 | 239.1.3 | CT1 aspects of Control Plane LCS in the EPC | 212d? | 2009-05-29 A | 2010-03-19 A | 100% |  | 2009-05-29 | 2010-03-19 | 212d? |  | finish no earlier than 2010-03-19 | C1 | 1696h | 1696h | LCS_EPS-CPS | PCG-23 | Polaris Wireless | Robert Gross (rgross@polariswireless.com) | Rel-9 | CP-44 | Frederic |  |
| 610 | 239.2 | Positioning Support for LTE | 392d? | 2008-12-05 A | 2010-06-04 A | 100% |  | 2008-12-05 | 2010-06-04 | 392d? |  | finish no earlier than 2010-06-04 | R2,R1,R3,R4 | 3136h | 3136h | LCS_LTE | PCG-22 | Qualcomm | Nathan Tenny (ntenny@qualcomm.com) | Rel-9 | RP-42 | Joern | RP-100442 |
| 611 | 239.3 | Conformance Test Aspects – Positioning Support for LTE | 391d? | 2010-03-19 A | 2011-09-16 | 50% | 195.5d? | 2010-03-19 | 2011-09-16 | 391d? | 390d | finish no earlier than 2011-09-16 | R5 | 3128h | 1564h | LCS_LTE_UEConTest | PCG-24 | Alcatel-Lucent | nidal.khrais@alcatel-lucent.com | Rel-9 | RP-47 | Ingbert | RP-110035 |

Notes:
- 585: CP#47 completed. Triggered by Study UID_400036 on Service Specific Access Control in EPS (FS_SSAC)
- 586: SP#42 completed / Text3: 22.011 CR0136
- 587: CP#47 completed / Text3: 24.173, 27.007
- 588: SP#48 completed / Text3: GERAN, LTE
- 589: SP#42 completed / Text3: 22.101
- 590: SP#44 completed / Text3: 23.869, 23.060, 23.167, 23.203, 23.221, 23.228, 23.271, 23.401, 23.402
- 591: SP#48 completed / Text3: 33.401, 33.402
- 592: CP#47 completed / Text3: GERAN, LTE
- 593: CP#47 completed / Text3: 23.122, 24.008, 24.229, 24.301, 24.302
- 594: RP#51 completion 03/11=>12/11. Testing for UID_440036 CT1 aspects - Stage 3 of Support for IMS Emergency Calls over GPRS and EPS / Text3: 34.108, 34.123-1, 34.123-2, 34.123-3, 34.229-1, 34.229-2, 34.229-3, 36.508, 36.523-1, 36.523-2, 36.523-3
- 595: CP#45 completed / Text3: 29.212, 29.213, 29.214, 29.215
- 596: CP#46 completed / Text3: 23.003, 23.008, 29.060, 29.272, 29.273, 29.274, 29.275, 29.276
- 597: RP#45 completed / Text3: 36.331, 36.413
- 598: RP#50 completed. Testing for UID_420041 Support for IMS Emergency Calls over LTE / Text3: 36.508, 36.523-1, 36.523-2, 36.523-3
- 599: CP/SP#46 completed
- 600: SP#46 completed. SP#43 WID updated SP-080562=>SP-090099 (added location continuity aspects) / Text3: 23.870, 23.216, 23.237
- 601: CP#46 completed. WID updated CP-090436=>CP-090882 (added CT3 part)
- 602: CP#46 completed / Text3: 24.229, 24.237
- 603: CP#46 completed / Text3: 29.205, 29.280
- 604: CP#46 completed / Text3: 29.163
- 605: RP#48 Core completed/Test ongoing / Text3: LTE
- 606: Triggered by abandoned Study UID_380068 (FS_LCS_EPS). Linked to Feature UID_380064 Support for IMS Emergency Calls over GPRS and EPS
- 607: SP#44 completed / Text3: 23.891, 23.271, 23.401, 23.402
- 608: CP#47 completed (IANA registrations outstanding). Stage 3 SLs and SLg interfaces & transport of positioning messages between E-SMLC and MME in the scope of UID_420006 (Positioning Support for LTE) / Text3: 24.080, 29.002, 29.272, 29.230, new 24.171, 29.171, 29.172, 29.173
- 609: CP#47 completed / Text3: 24.301
- 610: RP#48 completed. UID_400038 (LCS Control Plane Solution for EPS) depends on this WI / Text3: 34.213, 36.133, 36.211, 36.214, 36.300, 36.305, 36.331, 36.355, 36.410, 36.413, 36.455, new 36.171
- 611: RP#50 completion 03/11=>09/11. TS 37.571-5 v100 for Information / Text3: 36.508, 36.509, 36.521-3, new (36.571-1/2/3/4, 37.571-5)

| ID | WBS | Task | Duration | Start | Finish | Complete | Remaining | Baseline start | Baseline finish | Baseline duration | Total slack | Constraint | Resources | Work | Actual work | Text1 | Text2 | Text4 | Text5 | Text6 | Text7 | Text8 | Text11 |
| --- | --- | --- | --- | --- | --- | --- | --- | --- | --- | --- | --- | --- | --- | --- | --- | --- | --- | --- | --- | --- | --- | --- | --- |
| 612 | 240 | **MBMS support in EPS** | 918d? | 2008-06-05 A | 2011-12-09 | 84% | 148.87d? | 2008-06-05 | 2011-12-09 | 918d? | 330d |  | S2,S3,S5,C3,C4,R2,R3,R4 | 19568h | 16393.5h | MBMS_EPS | PCG-21 | China Mobile | Liu Hong (liuhongyfw@chinamobile.com) | Rel-9 | SP-40 | Maurice |  |
| 613 | 240.1 | Stage 2 for MBMS support in EPS | 261d? | 2008-06-05 A | 2009-06-04 A | 100% |  | 2008-06-05 | 2009-06-04 | 261d? |  | finish no earlier than 2009-06-04 | S2 | 2088h | 2088h | MBMS_EPS | PCG-21 | China Mobile | Liu Hong (liuhongyfw@chinamobile.com) | Rel-9 | SP-40 | Maurice |  |
| 614 | 240.2 | Security for MBMS support in EPS | 261d? | 2008-12-11 A | 2009-12-10 A | 100% |  | 2008-12-11 | 2009-12-10 | 261d? |  | finish no earlier than 2009-12-10 | S3 | 2088h | 2088h | MBMS_EPS | PCG-22 | China Mobile | Liu Hong (liuhongyfw@chinamobile.com) | Rel-9 | SP-42 | Dionisio |  |
| 615 | 240.3 | MBMS Charging in EPS | 201d? | 2009-03-06 A | 2009-12-10 A | 100% |  | 2009-03-06 | 2009-12-10 | 201d? |  | finish no earlier than 2009-12-10 | S5 | 1600h | 1600h | MBMS_EPS | PCG-22 | ZTE | guo.wenjie1@zte.com.cn | Rel-9 | SP-43 | Dionisio |  |
| 616 | 240.4 | CT4 aspects of MBMS support in EPS (Stage 3) | 137d? | 2009-05-29 A | 2009-12-04 A | 100% |  | 2009-05-29 | 2009-12-04 | 137d? |  | finish no earlier than 2009-12-04 | C4 | 1096h | 1096h | MBMS_EPS | PCG-23 | China Mobile, ZTE | wangjingyf@chinamobile.com, lu.fei1@zte.com.cn | Rel-9 | CP-44 | Kimmo |  |
| 617 | 240.5 | CT3 aspects of MBMS support in EPS (Stage 3) | 137d? | 2009-05-29 A | 2009-12-04 A | 100% |  | 2009-05-29 | 2009-12-04 | 137d? |  | start no earlier than 2009-05-29 | C3 | 1096h | 1096h | MBMS_EPS | PCG-23 | ZTE, China Mobile | zhou.xiaoyun@zte.com.cn, wangjingyf@chinamobile.com | Rel-9 | CP-44 | Jiwan |  |
| 618 | 240.6 | MBMS support in LTE | 271d? | 2009-03-06 A | 2010-03-19 A | 100% |  | 2009-03-06 | 2010-03-19 | 271d? |  | finish no earlier than 2010-03-19 | R2,R3,R4 | 2168h | 2168h | MBMS_LTE | PCG-22 | Huawei | arnaud.meylan@huawei.com | Rel-9 | RP-43 | Joern | RP-100033 |
| 619 | 240.7 | Conformance Test Aspects – MBMS support in LTE | 261d? | 2010-12-10 A | 2011-12-09 | 5% | 247.95d? | 2010-12-10 | 2011-12-09 | 261d? | 330d | finish no earlier than 2011-12-09 | R5 | 2088h | 104.4h | MBMS_LTE-UEConTest | PCG-26 | Huawei | Zhang Xin (zhangxin0208@huawei.com) | Rel-9 | RP-50 | Ingbert | RP-110325 |
| 620 | 241 | **Access Network Discovery and Selection Function enhancements** | 333d? | 2008-12-11 A | 2010-03-19 A | 100% |  | 2008-12-11 | 2010-03-19 | 333d? |  |  | S2,C1 | 4720h | 4720h | eANDSF | PCG-22 | Motorola | Apostolis Salkintzis (salki@motorola.com) | Rel-9 | SP-42 | Maurice |  |
| 621 | 241.1 | Stage 2 for Access Network Discovery and Selection Function enhancements | 126d? | 2008-12-11 A | 2009-06-04 A | 100% |  | 2008-12-11 | 2009-06-04 | 126d? |  | finish no earlier than 2009-06-04 | S2 | 1008h | 1008h | eANDSF | PCG-22 | Motorola | Apostolis Salkintzis (salki@motorola.com) | Rel-9 | SP-42 | Maurice |  |
| 622 | 241.2 | CT1 aspects of Access Network Discovery and Selection Function enhancements | 131d? | 2009-09-18 A | 2010-03-19 A | 100% |  | 2009-09-18 | 2010-03-19 | 131d? |  | finish no earlier than 2010-03-19 | C1 | 1048h | 1048h | eANDSF | PCG-23 | Panasonic | benjamin.limck@sg.panasonic.com | Rel-9 | CP-45 | Frederic |  |
| 623 | 242 | **Multiple PDN Connection to the Same APN for PMIP-based Interfaces** | 267d? | 2009-03-13 A | 2010-03-19 A | 100% |  | 2009-03-13 | 2010-03-19 | 267d? |  |  | S2,C4,C1 | 4120h | 4120h | MUPSAP | PCG-22 | Samsung | erik.guttman@partner.samsung.com | Rel-9 | SP-43 | Maurice |  |
| 624 | 242.1 | Stage 2 for Multiple PDN Connection to the Same APN for PMIP-based Interfaces | 61d? | 2009-03-13 A | 2009-06-04 A | 100% |  | 2009-03-13 | 2009-06-04 | 61d? |  | finish no earlier than 2009-06-04 | S2 | 488h | 488h | MUPSAP | PCG-22 | Samsung | erik.guttman@partner.samsung.com | Rel-9 | SP-43 | Maurice |  |
| 625 | 242.2 | CT4 aspects of Multiple PDN Connection to the Same APN for PMIP-based Interfaces | 56d? | 2009-09-18 A | 2009-12-04 A | 100% |  | 2009-09-18 | 2009-12-04 | 56d? |  | finish no earlier than 2009-12-04 | C4 | 448h | 448h | MUPSAP | PCG-23 | Samsung | Surjyakanta Mohapatra (surjya.kanta@samsung.com) | Rel-9 | CP-45 | Kimmo |  |
| 626 | 242.3 | CT1 aspects of Multiple PDN Connection to the Same APN for PMIP-based Interfaces | 131d? | 2009-09-18 A | 2010-03-19 A | 100% |  | 2009-09-18 | 2010-03-19 | 131d? |  | finish no earlier than 2010-03-19 | C1 | 1048h | 1048h | MUPSAP | PCG-23 | Samsung | Surjyakanta Mohapatra (surjya.kanta@samsung.com) | Rel-9 | CP-45 | Frederic |  |
| 627 | 243 | **System aspects of vocoder rate adaptation for LTE** | 140d? | 2009-05-30 A | 2009-12-10 A | 100% |  | 2009-05-30 | 2009-12-10 | 140d? |  |  | S2,S4,R2 | 3504h | 3504h | LTEimp-Vocoder | PCG-23 | Qualcomm | AC Mahendran (ac@qualcomm.com) | Rel-9 | SP-45 | Maurice |  |
| 628 | 243.1 | SA2 system aspects of vocoder rate adaptation for LTE | 81d? | 2009-06-04 A | 2009-09-24 A | 100% |  | 2009-06-04 | 2009-09-24 | 81d? |  | start no earlier than 2009-06-04 | S2 | 648h | 648h | LTEimp-Vocoder | PCG-23 | Qualcomm | AC Mahendran (ac@qualcomm.com) | Rel-9 | SP-45 | Maurice |  |
| 629 | 243.2 | SA4 system aspects of vocoder rate adaptation for LTE | 136d? | 2009-06-04 A | 2009-12-10 A | 100% |  | 2009-06-04 | 2009-12-10 | 136d? |  | finish no earlier than 2009-12-07 | S4 | 1088h | 1088h | LTEimp-Vocoder | PCG-23 | Qualcomm | Nikolai Leung | Rel-9 | SP-45 | Paolo |  |
| 630 | 243.3 | Vocoder rate adaptation for LTE | 81d? | 2009-05-30 A | 2009-09-18 A | 100% |  | 2009-05-30 | 2009-09-18 | 81d? |  | finish no earlier than 2009-09-18 | R2 | 648h | 648h | LTEimp-Vocoder | PCG-23 | Alcatel-Lucent | Sudeep Palat (spalat@alcatel-lucent.com) | Rel-9 | RP-44 | Joern | RP-090704 |
| 631 | 244 | Access Security Enhancements | 505d? | 2007-07-02 A | 2009-06-04 A | 100% |  | 2007-07-02 | 2009-06-04 | 505d? |  | finish no earlier than 2009-06-03 | S3 | 4040h | 4040h | ACCSEC2 |  | Ericsson | Bengt.Sahlin@ericsson.com | Rel-9 | SP-26 | Dionisio |  |
| 632 | 245 | **Protection against Unsolicited Communication for IMS (PUCI)** | 322d? | 2008-09-18 A | 2009-12-10 A | 100% |  | 2008-09-18 | 2009-12-10 | 322d? |  |  | S3,S1 | 5640h | 5640h | PUCI | PCG-21 | NEC | Anand R. Prasad (anand@bq.jp.nec.com) | Rel-9 | SP-41 | Alain |  |
| 633 | 245.1 | Stage 1 for PUCI | 61d? | 2008-09-18 A | 2008-12-11 A | 100% |  | 2008-09-18 | 2008-12-11 | 61d? |  | finish no earlier than 2009-06-18 | S1 | 488h | 488h | PUCI | PCG-21 | NEC | Anand R. Prasad (anand@bq.jp.nec.com) | Rel-9 | SP-41 | Alain |  |
| 634 | 245.2 | SA3 work on PUCI | 322d? | 2008-09-18 A | 2009-12-10 A | 100% |  | 2008-09-18 | 2009-12-10 | 322d? |  | finish no earlier than 2009-12-10 | S3 | 2576h | 2576h | PUCI | PCG-21 | NEC | Anand R. Prasad (anand@bq.jp.nec.com) | Rel-9 | SP-41 | Dionisio |  |
| 635 | 246 | **IMS Media Plane Security** | 322d? | 2009-03-13 A | 2010-06-04 A | 100% |  | 2009-03-13 | 2010-06-04 | 322d? |  |  | S3,C1,C4,C3 | 7755.2h | 7755.2h | MEDIASEC | PCG-22 | Vodafone | Peter.Howard@vodafone.com | Rel-9 | SP-43 | Dionisio |  |
| 636 | 246.1 | SA3 aspects of IMS Media Plane Security | 271d? | 2009-03-13 A | 2010-03-25 A | 100% |  | 2009-03-13 | 2010-03-25 | 271d? |  | finish no earlier than 2010-03-25 | S3 | 2168h | 2168h | MEDIASEC | PCG-22 | Vodafone | Peter.Howard@vodafone.com | Rel-9 | SP-43 | Dionisio |  |

Notes:
- 612: RP#47 completed. SP#46, CP#46 completed / Text3: LTE
- 613: SP#44 completed / Text3: 23.246
- 614: SP#46 completed / Text3: 33.246
- 615: SP#46 completed / Text3: 32.273, 32.251, 32.298, 32.299
- 616: CP#46 completed / Text3: 29.274, 29.281, 23.007, 23.008
- 617: CP#46 completed / Text3: 29.061
- 618: RP#47 completed / Text3: 25.446, 36.101, 36.104, 36.141, 36.300, 36.304, 36.321, 36.322, 36.323, 36.331, 36.440, 36.441, 36.442, 36.444, 36.445
- 619: RP#51 completion 03/12=>12/11 / Text3: 36.508, 36.521-1, 36.521-2, 36.523-1, 36.523-2, 36.523-3
- 620: CP#47 completed. No new Rel-9 use cases defined. Implement service requirements not covered in Rel-8 / Text3: 22.278, SA3 33.402 CR#0055
- 621: SP#44 completed / Text3: 23.402, 23.002
- 622: CP#47 completed / Text3: 24.302, 24.312
- 623: CP#47 completed. Continues Rel-8 SAES Stage 2 UID_320005. Stage 1 in 22.278 (EPS Service requirements)
- 624: SP#44 completed / Text3: 23.060, 23.203, 23.401, 23.402
- 625: CP#46 completed / Text3: 29.275, 23.008, 29.282
- 626: CP#47 completed / Text3: 24.302
- 627: SP#46 completed. Triggered by RAN2 UID_440013 Vocoder rate adaptation for LTE / Text3: LTE
- 628: SP#45 completed (CR adding support for Explicit Congestion Notification) / Text3: 23.401 CR#1103r3
- 629: SP#46 completed / Text3: 26.114
- 630: RP#45 completed / Text3: 36.300 CR#0114
- 631: SP#44 completed. Stopped TR 33.801. CRs 33.102,43.020 on A5/2 removal done long time ago. A5/4 introduction CRs will be done under UID_440057 128 bit encryption for GSM and GPRS. SP#26 approved WID (improved GERAN security) / Text3: 33.102, 43.020
- 632: SP#46 TR 33.937 completed but no specification work done in Rel-9. Related work in OMA Categorization Based Content Screening
- 633: SP#42 completed / Text3: 22.228
- 634: SP#46 completed. No normative work done in Rel-9 / Text3: new 33.937
- 635: CP#48 completed
- 636: SP#47 completed / Text3: new 33.828, 33.328

| ID | WBS | Task | Duration | Start | Finish | Complete | Baseline start | Baseline finish | Baseline duration | Constraint | Resources | Work | Actual work | Text1 | Text2 | Text4 | Text5 | Text6 | Text7 | Text8 | Text3 | Text9 | Text12 |
| --- | --- | --- | --- | --- | --- | --- | --- | --- | --- | --- | --- | --- | --- | --- | --- | --- | --- | --- | --- | --- | --- | --- | --- |
| 637 | 246.2 | **CN aspects of IMS Media Plane Security** | 186d? | 2009-09-18 A | 2010-06-04 A | 100% | 2009-09-18 | 2010-06-04 | 186d? |  | C1,C4,C3 | 3011.2h | 3011.2h | MEDIASEC_CORE | PCG-23 | Vodafone | peter.dawes@vodafone.com | Rel-9 | CP-45 | Frederic |  |  |  |
| 638 | 246.2.1 | CT1 aspects of IMS Media Plane Security | 33d? | 2009-09-18 A | 2010-03-19 A | 100% | 2009-09-18 | 2010-03-19 | 33d? | finish no earlier than 2010-03-19 | C1 | 264h | 264h | MEDIASEC_CORE | PCG-23 | Vodafone | peter.dawes@vodafone.com | Rel-9 | CP-45 | Frederic | 23.218, 24.229 |  |  |
| 639 | 246.2.2 | CT4 aspects of IMS Media Plane Security | 131d? | 2009-09-18 A | 2010-03-19 A | 100% | 2009-09-18 | 2010-03-19 | 131d? | finish no earlier than 2010-03-19 | C4 | 1048h | 1048h | MEDIASEC_CORE | PCG-23 | Vodafone | peter.dawes@vodafone.com | Rel-9 | CP-45 | Kimmo | 29.238, 23.334, 29.334 |  |  |
| 640 | 246.2.3 | CT3 aspects of IMS Media Plane Security | 131d? | 2009-12-04 A | 2010-06-04 A | 100% | 2009-12-04 | 2010-06-04 | 131d? | finish no earlier than 2010-06-04 | C3 | 1048h | 1048h | MEDIASEC_CORE | PCG-24 | Vodafone | peter.dawes@vodafone.com | Rel-9 | CP-46 | Jiwan | 29.162 |  |  |
| 641 | 247 | **GBAPush enhancements (Generic push layer)** | 533d? | 2008-03-12 A | 2010-03-25 A | 100% | 2008-03-12 | 2010-03-25 | 533d? |  | S3 | 8528h | 8528h | eGBAPush | PCG-23 | Ericsson | Rolf Blom | Rel-9 | SP-44 | Dionisio | new 33.224 |  |  |
| 642 | 247.1 | SA3 part of eGBAPush (Generic push layer) | 533d? | 2008-03-12 A | 2010-03-25 A | 100% | 2008-03-12 | 2010-03-25 | 533d? | finish no earlier than 2010-03-25 | S3 | 4264h | 4264h | eGBAPush | PCG-21 | Ericsson | Rolf Blom | Rel-9 | SP-39 | Dionisio | new 33.224 |  |  |
| 643 | 248 | Extended Identity Management | 136d? | 2009-06-04 A | 2009-12-10 A | 100% | 2009-06-04 | 2009-12-10 | 136d? | finish no earlier than 2009-12-10 | S3 | 1088h | 1088h | GBA-IdM | PCG-23 | Nokia | Silke.Holtmanns@nokia.com | Rel-9 | SP-44 | Dionisio | new 33.924, CT4 29.109 (added service code) |  |  |
| 644 | 249 | **Network Domain Security (NDS) enhancements to support backhaul security** | 211d? | 2009-06-04 A | 2010-03-25 A | 100% | 2009-06-04 | 2010-03-25 | 211d? |  | S3,C4 | 4432h | 4432h | NDS_Backhaul | PCG-23 | Vodafone | Peter.Howard@vodafone.com | Rel-9 | SP-44 | Dionisio |  |  |  |
| 645 | 249.1 | SA3 part of Network Domain Security (NDS) enhancements to support backhaul security | 211d? | 2009-06-04 A | 2010-03-25 A | 100% | 2009-06-04 | 2010-03-25 | 211d? | finish no earlier than 2010-03-25 | S3 | 1688h | 1688h | NDS_Backhaul | PCG-23 | Vodafone | Peter.Howard@vodafone.com | Rel-9 | SP-44 | Dionisio | 33.102, 33.210, 33.310, 33.401, 33.402 |  |  |
| 646 | 249.2 | CT4 part of Network Domain Security (NDS) enhancements to support backhaul security | 132d? | 2009-06-04 A | 2009-12-04 A | 100% | 2009-06-04 | 2009-12-04 | 132d? | finish no earlier than 2009-12-04 | C4 | 1056h | 1056h | NDS_Backhaul | PCG-23 | Vodafone | Peter.Howard@vodafone.com | Rel-9 | SP-44 | Kimmo |  |  |  |
| 647 | 250 | **128 bit encryption for GSM and GPRS** | 136d? | 2009-06-04 A | 2009-12-10 A | 100% | 2009-06-04 | 2009-12-10 | 136d? |  | S3,C1,C4,G2,G3new | 6040h | 6040h | A5/4-GEA4 | PCG-23 | Ericsson | Karl Norrman | Rel-9 | SP-44 | Dionisio |  |  |  |
| 648 | 250.1 | SA3 part of 128 bit encryption for GSM and GPRS | 136d? | 2009-06-04 A | 2009-12-10 A | 100% | 2009-06-04 | 2009-12-10 | 136d? | finish no earlier than 2010-01-06 | S3 | 1088h | 1088h | A5/4-GEA4 | PCG-23 | Ericsson | Karl Norrman | Rel-9 | SP-44 | Dionisio | 33.102,43.020, new 55.226 |  |  |
| 649 | 250.2 | CT1 part of 128 bit encryption for GSM and GPRS | 77d? | 2009-06-04 A | 2009-09-18 A | 100% | 2009-06-04 | 2009-09-18 | 77d? | start no earlier than 2009-06-04 | C1 | 616h | 616h | A5/4-GEA4 | PCG-23 | Ericsson | Karl Norrman | Rel-9 | SP-44 | Frederic | 24.008,44.064 |  |  |
| 650 | 250.3 | CT4 part of 128 bit encryption for GSM and GPRS | 136d? | 2009-06-04 A | 2009-12-10 A | 100% | 2009-06-04 | 2009-12-10 | 136d? | start no earlier than 2009-06-04 | C4 | 1088h | 1088h | A5/4-GEA4 | PCG-23 | Ericsson | Karl Norrman | Rel-9 | SP-44 | Kimmo |  |  |  |
| 651 | 250.4 | GERAN2 part of 128 bit encryption for GSM and GPRS | 67d? | 2009-06-04 A | 2009-09-04 A | 100% | 2009-06-04 | 2009-09-04 | 67d? | finish no earlier than 2009-09-04 | G2 | 536h | 536h | A5/4-GEA4 | PCG-23 | Ericsson | Karl Norrman | Rel-9 | SP-44 | Gert | 44.018,48.008,48.018,48.058 |  |  |
| 652 | 250.5 | GERAN3new (testing) part of 128 bit encryption for GSM and GPRS | 122d? | 2009-06-04 A | 2009-11-20 A | 100% | 2009-06-04 | 2009-11-20 | 122d? | finish no earlier than 2009-11-20 | G3new | 976h | 976h | A5/4-GEA4 | PCG-23 | Ericsson | Karl Norrman | Rel-9 | SP-44 | Ingbert | 51.010 |  |  |
| 653 | 250.6 | Deleted - SA2 part of 128 bit encryption for GSM and GPRS | 81d? | 2009-06-04 A | 2009-09-24 A | 100% | 2009-06-04 | 2009-09-24 | 81d? | finish no earlier than 2009-09-24 | S2 | 648h | 648h | A5/4-GEA4 | PCG-23 | Ericsson | Karl Norrman | Rel-9 | SP-44 | Maurice | 23.060 | PCG-23 | SP-45 |
| 654 | 251 | Timed Graphics | 337d? | 2008-12-11 A | 2010-03-25 A | 100% | 2008-12-11 | 2010-03-25 | 337d? | finish no earlier than 2010-03-25 | S4 | 2696h | 2696h | TG | PCG-22 | Ericsson | clinton.priddle@ericsson.com | Rel-9 | SP-42 | Paolo | 26.114, 26.140, 26.234, 26.244, 26.245, 26.346, new 26.430 |  |  |
| 655 | 252 | Managing MTSI Media Adaptation | 272d? | 2009-03-12 A | 2010-03-25 A | 100% | 2009-03-12 | 2010-03-25 | 272d? | finish no earlier than 2009-12-10 | S4 | 1568h | 1568h | M3A | PCG-22 | Samsung | kyunghun.jung@samsung.com | Rel-9 | SP-43 | Paolo | 26.114 |  |  |
| 656 | 253 | **PSS and MBMS Aspects** | 272d? | 2009-03-12 A | 2010-03-25 A | 100% | 2009-03-12 | 2010-03-25 | 272d? |  | S4 | 6512h | 6512h | PMA | PCG-23 | Ericsson, Nokia | Clinton.Priddle@ericsson.com, imed.bouazizi@nokia.com | Rel-9 | SP-44 | Paolo |  |  |  |
| 657 | 253.1 | PSS and MBMS extensions | 271d? | 2009-03-12 A | 2010-03-25 A | 100% | 2009-03-12 | 2010-03-25 | 271d? | finish no earlier than 2010-03-25 | S4 | 2168h | 2168h | PMA-MBS_Ext | PCG-22 | Ericsson | Clinton.Priddle@ericsson.com | Rel-9 | SP-43 | Paolo | 26.234, 26.346 |  |  |
| 658 | 253.2 | Improved Video Support for PSS and MBMS | 271d? | 2009-03-12 A | 2010-03-25 A | 100% | 2009-03-12 | 2010-03-25 | 271d? | finish no earlier than 2010-03-25 | S4 | 2168h | 2168h | PMA-IVS | PCG-22 | Nokia | imed.bouazizi@nokia.com | Rel-9 | SP-43 | Paolo | 26.234, 26.244, 26.346, new 26.903 |  |  |
| 659 | 254 | IMS based PSS and MBMS User Service extensions | 197d? | 2009-03-12 A | 2009-12-10 A | 100% | 2009-03-12 | 2009-12-10 | 197d? | finish no earlier than 2009-12-10 | S4 | 1576h | 1576h | IMS_PSS_MBMS_US_EXT | PCG-22 | Ericsson | Markus Kampmann | Rel-9 | SP-43 | Paolo | 26.237 |  |  |
| 660 | 255 | Syndicated Feed Reception within 3GPP environments | 136d? | 2009-06-04 A | 2009-12-10 A | 100% | 2009-06-04 | 2009-12-10 | 136d? | start no earlier than 2009-06-04 | S4 | 1088h | 1088h | SFR | PCG-23 | Ericsson | Thorsten.Lohmar@ericsson.com | Rel-9 | SP-44 | Paolo | 26.150 |  |  |
| 661 | 256 | Distortion Measurement Test Methods and Requirements | 131d? | 2009-09-24 A | 2010-03-25 A | 100% | 2009-09-24 | 2010-03-25 | 131d? | finish no earlier than 2010-03-25 | S4 | 1048h | 1048h | DTMR | PCG-23 | Motorola | Stephen Kendall (wcsk01@motorola.com) | Rel-9 | SP-45 | Paolo | 26.131, 26.132 |  |  |

Notes:
- 637: CP#48 completed
- 638: CP#47 completed
- 639: CP#47 completed
- 640: CP#48 completed
- 641: SP#43 umbrella to host 33.224, moved from Rel-8 to Rel-9. SP#47 completed
- 642: SP#47 completed
- 643: SP#46 completed. Stage 1 not identified (GBA Liberty Interworking has been outlined and GBAOpenID interworking is analogous)
- 644: SP#47 completed. Continuation of Rel-8 UID_390044 SAE security architecture. Covers gaps in backhaul security in SAE (also applicable to UTRAN and GERAN backhaul)
- 645: SP#47 completed
- 646: CP#46 completed. No impact on CT4 specs
- 647: Allow 128 as an alternative to 64 bit keys (Stage 2/3 + Test spec)
- 648: SP#46 completed
- 649: CP#45 completed
- 650: CP#46 completed. Kc128 enhancements are carried as UMTS keys => no impact on CT4 29.002, 29.060
- 651: GP#43 WID approved + completed
- 652: GP#44 completed. GP#43 WID approved
- 653: SP#45 work stopped/abandoned
- 654: SP#47 completed. Provide graphics in parallel to a video stream (without requiring an umbrella scene descriptor such as 3GPP DIMS in TS 26.142)
- 655: SP#46 completed. Work extending Rel-8 UID_34041 MTSI Video - Dynamic Rate Adaptation/Signalling of Image Size. Update speech/video adaptation algorithms used by network to control MTSI client terminal in congestion or poor transmission conditions.
- 656: Umbrella WI
- 657: SP#47 completed. Extends Rel-8 UID_34043 (PSS_MBMS_OMTV) & ensures compatibility with UID_34046 (IMS_PSS_MBMS_US)
- 658: SP#47 completed
- 659: SP#46 completed. Work extending Rel-8 UID_34046 (IMS_PSS_MBMS_US), SA2 UID_410034 IMSSCC-SPI (IMS Service Continuity Enhancements: Service, Policy and Interactions)
- 660: SP#46 completed. TS 26.150v100 for Approval. RSS optimized for mobile use. Reuse/reference OMA's enabler DCD.
- 661: SP#47 completed

| ID | WBS | Task | Duration | Start | Finish | Complete | Baseline start | Baseline finish | Baseline duration | Constraint | Resources | Work | Actual work | Text1 | Text2 | Text6 | Text7 | Text8 | Text4 | Text9 | Text12 |
| --- | --- | --- | --- | --- | --- | --- | --- | --- | --- | --- | --- | --- | --- | --- | --- | --- | --- | --- | --- | --- | --- |
| 662 | 257 | **OAM&P 9** | 601d? | 2008-02-22 A | 2010-06-10 A | 100% | 2008-02-22 | 2010-06-10 | 601d? |  | S5 | 36890.4h | 36890.4h | OAM9 | PCG-22 | Rel-9 | SP-42 | Dionisio |  |  |  |
| 663 | 257.1 | **Network Infrastructure Management** | 337d? | 2008-12-11 A | 2010-03-25 A | 100% | 2008-12-11 | 2010-03-25 | 337d? |  | S5 | 8760h | 8760h | OAM9-NIM | PCG-22 | Rel-9 | SP-42 | Dionisio |  |  |  |
| 664 | 257.1.1 | Software Management for Network Elements | 336d? | 2008-12-11 A | 2010-03-25 A | 100% | 2008-12-11 | 2010-03-25 | 336d? | finish no earlier than 2010-03-25 | S5 | 2688h | 2688h | OAM9-NE_SWM | PCG-22 | Rel-9 | SP-42 | Dionisio | Huawei, Nokia Siemens Networks |  |  |
| 665 | 257.1.2 | Service Oriented Architecture (SOA) for IRP | 211d? | 2009-06-04 A | 2010-03-25 A | 100% | 2009-06-04 | 2010-03-25 | 211d? | finish no earlier than 2010-03-25 | S5 | 1688h | 1688h | OAM9 | PCG-23 | Rel-9 | SP-44 | Dionisio | Ericsson, Nokia Siemens Networks |  |  |
| 666 | 257.1.3 | IRP SOAP Solution Sets continuation from Rel-8 | 211d? | 2009-06-04 A | 2010-03-25 A | 100% | 2009-06-04 | 2010-03-25 | 211d? | finish no earlier than 2010-03-25 | S5 | 1688h | 1688h | OAM9 | PCG-23 | Rel-9 | SP-44 | Dionisio | Ericsson |  |  |
| 667 | 257.2 | **Performance Management** | 327d? | 2009-03-12 A | 2010-06-10 A | 100% | 2009-03-12 | 2010-06-10 | 327d? |  | S5 | 7890.41h | 7890.41h | OAM9-PM | PCG-22 | Rel-9 | SP-42 | Dionisio |  |  |  |
| 668 | 257.2.1 | Enhancement of UTRAN Performance Measurements | 136d? | 2009-06-04 A | 2009-12-10 A | 100% | 2009-06-04 | 2009-12-10 | 136d? | start no earlier than 2009-06-04 | S5 | 1088h | 1088h | OAM9 | PCG-23 | Rel-9 | SP-44 | Dionisio | China Mobile |  |  |
| 669 | 257.2.2 | Enhancement of E-UTRAN Performance Measurements | 327d? | 2009-03-12 A | 2010-06-10 A | 100% | 2009-03-12 | 2010-06-10 | 327d? | finish no earlier than 2010-06-10 | S5 | 2616h | 2616h | OAM9 | PCG-22 | Rel-9 | SP-43 | Dionisio | Motorola, Huawei |  |  |
| 670 | 257.2.3 | Enhancement of EPC Performance Measurements | 197d? | 2009-03-12 A | 2009-12-10 A | 100% | 2009-03-12 | 2009-12-10 | 197d? | finish no earlier than 2010-03-25 | S5 | 1570.41h | 1570.41h | OAM9 | PCG-22 | Rel-9 | SP-43 | Dionisio | China Mobile |  |  |
| 671 | 257.3 | **Self-Organizing Networks (SON) - OAM aspects** | 601d? | 2008-02-22 A | 2010-06-10 A | 100% | 2008-02-22 | 2010-06-10 | 601d? |  | S5 | 11736h | 11736h | OAM9-SON | PCG-22 | Rel-9 | SP-43 | Dionisio |  |  |  |
| 672 | 257.3.1 | SON self-optimization management | 600d? | 2008-02-22 A | 2010-06-10 A | 100% | 2008-02-22 | 2010-06-10 | 600d? | finish no earlier than 2010-06-10 | S5 | 4800h | 4800h | LTE_SON-OAM | PCG-21 | Rel-9 | SP-39 | Dionisio | Huawei |  |  |
| 673 | 257.3.2 | Automatic Radio Network Configuration Data Preparation | 266d? | 2009-06-04 A | 2010-06-10 A | 100% | 2009-06-04 | 2010-06-10 | 266d? | finish no earlier than 2010-06-10 | S5 | 2128h | 2128h | OAM9 | PCG-23 | Rel-9 | SP-44 | Dionisio | Nokia Siemens Networks |  |  |
| 674 | 257.4 | Subscription Management (SuM) evolution | 266d? | 2009-06-04 A | 2010-06-10 A | 100% | 2009-06-04 | 2010-06-10 | 266d? | finish no earlier than 2010-06-10 | S5 | 2128h | 2128h | OAM9-SuM | PCG-23 | Rel-9 | SP-44 | Dionisio | Ericsson |  |  |
| 675 | 257.5 | Deleted - Trace | 196d? | 2009-03-13 A | 2009-12-10 A | 100% | 2009-03-13 | 2009-12-10 | 196d? | finish no earlier than 2009-12-10 | S5 | 1568h | 1568h | OAM9-Trace | PCG-22 | Rel-9 | SP-42 | Dionisio |  | PCG-24 | SP-46 |
| 676 | 258 | Charging Management small Enhancements | 211d? | 2009-06-04 A | 2010-03-25 A | 100% | 2009-06-04 | 2010-03-25 | 211d? |  | S5 | 1688h | 1688h | CH9 | PCG-23 | Rel-9 | SP-44 | Dionisio |  |  |  |
| 677 | 259 | **CS-IBCF and CS-TrGW definition in 3GPP specifications** | 472d? | 2008-05-30 A | 2010-03-19 A | 100% | 2008-05-30 | 2010-03-19 | 472d? |  | C3,C4 | 10714.3h | 10714.3h | CS-IBCF | PCG-21 | Rel-9 | CP-40 | Jiwan | Telecom Italia |  |  |
| 678 | 259.1 | CT3 aspects of CS-IBCF and CS-TrGW definition in 3GPP specifications | 472d? | 2008-05-30 A | 2010-03-19 A | 100% | 2008-05-30 | 2010-03-19 | 472d? | finish no earlier than 2009-12-04 | C3 | 3770.34h | 3770.34h | CS-IBCF | PCG-21 | Rel-9 | CP-40 | Jiwan | Telecom Italia |  |  |
| 679 | 259.2 | CT4 aspects of CS-IBCF and CS-TrGW definition in 3GPP specifications | 396d? | 2008-05-30 A | 2009-12-04 A | 100% | 2008-05-30 | 2009-12-04 | 396d? | finish no earlier than 2009-12-04 | C4 | 3168h | 3168h | CS-IBCF | PCG-21 | Rel-9 | CP-40 | Kimmo | Telecom Italia |  |  |
| 680 | 260 | **IMS – Interconnection Border Control Function (IBCF) – Transition Gateway (TrGW); Ix Interface; Stage 3** | 322d? | 2008-09-12 A | 2009-12-04 A | 100% | 2008-09-12 | 2009-12-04 | 322d? |  | C4,C3 | 6858.4h | 6858.4h | IMS_IBCF | PCG-21 | Rel-9 | CP-41 | Kimmo | Alcatel-Lucent |  |  |
| 681 | 260.1 | CT4 part of IMS – Interconnection Border Control Function (IBCF) – Transition Gateway (TrGW); Ix Interface; Stage 3 | 321d? | 2008-09-12 A | 2009-12-04 A | 100% | 2008-09-12 | 2009-12-04 | 321d? | finish no earlier than 2009-12-04 | C4 | 2568h | 2568h | IMS_IBCF | PCG-21 | Rel-9 | CP-41 | Kimmo | Alcatel-Lucent |  |  |
| 682 | 260.2 | CT3 part of IMS – Interconnection Border Control Function (IBCF) – Transition Gateway (TrGW); Ix Interface; Stage 3 | 295.8d? | 2008-09-12 A | 2009-12-04 A | 100% | 2008-09-12 | 2009-12-04 | 295.8d? | finish no earlier than 2010-03-19 | C3 | 2366.4h | 2366.4h | IMS_IBCF | PCG-21 | Rel-9 | CP-41 | Jiwan | Alcatel-Lucent |  |  |
| 683 | 261 | IMS Application Level Gateway Control Function (ALGCF) – IMS Access Media Gateway (IMA-MGW); Iq Interface; Stage 2 and Stage 3 | 321d? | 2008-09-12 A | 2009-12-04 A | 100% | 2008-09-12 | 2009-12-04 | 321d? | finish no earlier than 2009-12-04 | C4 | 2568h | 2568h | IMS_AGCF | PCG-21 | Rel-9 | CP-41 | Kimmo | Alcatel-Lucent |  |  |
| 684 | 262 | **Enhancements of IMS Customized Alerting Tone (CAT) Service** | 392d? | 2008-12-05 A | 2010-06-04 A | 100% | 2008-12-05 | 2010-06-04 | 392d? |  | C1 | 5846.4h | 5846.4h | eCAT | PCG-22 | Rel-9 | CP-42 | Frederic | China Mobile |  |  |
| 685 | 262.1 | Stage 3 for Enhancements of IMS Customized Alerting Tone (CAT) Service | 391d? | 2008-12-05 A | 2010-06-04 A | 100% | 2008-12-05 | 2010-06-04 | 391d? | finish no earlier than 2010-06-04 | C1 | 3128h | 3128h | eCAT-SS | PCG-22 | Rel-9 | CP-42 | Frederic | China Mobile |  |  |

Notes:
- 662: SP#42 umbrella Feature created to host OAM WIs / Text3: TR 30.819
- 663: SP#42 umbrella BB created to host OAM WIs
- 664: SP#47 completed / Text3: 32.531, 32.532, 32.533, new 32.537 / Text5: Bidipta Das (bidipta@huawei.com), Clemens Suerbaum (clemens.suerbaum@nsn.com)
- 665: SP#47 completed (covering SOA Architecture & SOA-supporting Solution Set). Triggered by UID_400029 Study on Service Oriented Architecture (SOA) for IRP (TR 32.824) / Text3: 32.101, 32.102, 32.150 / Text5: edwin.tse@ericsson.com, Jörg Schmidt (joerg@cox.net)
- 666: SP#47 completed. Continuation of Rel-8 UID_400030 IRP SOAP Solution Sets / Text3: New (32.127/ 327/ 337/ 357/ 387/ 397/ 447/ 397/ 447/ 507/ 537), 32.121,32.122,32.123,32,32.321,32.322,32.323,32.325,32.331,32.332,32.333,32.335,32.351,32.352,32.353,32.381,32.382,32.383,32.385,32.391,32.392,32.393,32.395,32.441,32.442,32.443 / Text5: John Power
- 667: SP#42 umbrella BB created to host OAM WIs
- 668: SP#46 completed / Text3: 32.405 / Text5: Liang Shuangchun (liangshuangchun@cmdi.chinamobile.com), Li Jian (lijian@chinamobile.com), Bao Haitao
- 669: SP#48 completed / Text3: 32.425 / Text5: Yizhi Yao (yzyao@motorola.com),Lan Zou (zlan@huawei.com)
- 670: SP#46 completed / Text3: 32.426 / Text5: Li Jian (lijian@chinamobile.com), Liang Shuangchun (liangshuangchun@cmdi.chinamobile.com)
- 671: SP#43 umbrella BB created to host OAM WIs
- 672: SP#48 completed / Text3: 32.425, new (32.521, 32.522, 32.523, 32.525) / Text5: Lan Zou (zlan@huawei.com)
- 673: SP#48 completed / Text3: 32.501, 32.502, 32.503, 32.505, new 32.507 / Text5: clemens.suerbaum@nsn.com
- 674: SP#48 completed / Text3: 32.140, 32.141, 32.152, 32.172, 32.175 / Text5: frode.nergard@ericsson.com
- 675: SP#46 stopped (no work in Rel-9)
- 676: SP#47 completed / Text3: TR 30.819
- 677: CP#47 completed. Rel-8 UID_380061 (Ipinterc) covers Stage 1 in SA1 22.101, 22.228 / Text5: mauro.ficaccio@telecomitalia.it
- 678: CP#47 completed / Text3: 29.235 / Text5: mauro.ficaccio@telecomitalia.it
- 679: CP#46 completed / Text3: 23.231, 29.232, new 29.238 / Text5: mauro.ficaccio@telecomitalia.it
- 680: CP#46 completed / Text5: bruno.landais@alcatel-lucent.fr
- 681: CP#46 completed / Text3: new 29.238 / Text5: bruno.landais@alcatel-lucent.fr
- 682: CP#46 completed / Text3: 29.162, 29.235 / Text5: bruno.landais@alcatel-lucent.fr
- 683: CP#46 completed / Text3: new 23.334, 29.334 / Text5: bruno.landais@alcatel-lucent.fr
- 684: CP#48 completed. Stage 1 in 22.182 / Text5: Jiang Yi
- 685: CP#48 completed / Text3: 24.182 / Text5: Jiang Yi

| ID | WBS | Task | Duration | Start | Finish | Complete | Baseline start | Baseline finish | Baseline duration | Constraint | Resources | Work | Actual work | Text1 | Text2 | Text4 | Text5 | Text6 | Text7 | Text8 | Text11 |
| --- | --- | --- | --- | --- | --- | --- | --- | --- | --- | --- | --- | --- | --- | --- | --- | --- | --- | --- | --- | --- | --- |
| 686 | 263 | **Completion of IMS Restoration Procedures** | 212d? | 2009-05-29 A | 2010-03-19 A | 100% | 2009-05-29 | 2010-03-19 | 212d? |  | C3, C4,C1 | 6784h | 6784h | eIMS_RP | PCG-23 | Ericsson | Emiliano Merino (emiliano.merino@ericsson.com) | Rel-9 | CP-44 | Kimmo |  |
| 687 | 263.1 | CT4 aspects of Completion of IMS Restoration Procedures | 212d? | 2009-05-29 A | 2010-03-19 A | 100% | 2009-05-29 | 2010-03-19 | 212d? | finish no earlier than 2010-03-19 | C4 | 1696h | 1696h | eIMS_RP | PCG-23 | Ericsson | Emiliano Merino (emiliano.merino@ericsson.com) | Rel-9 | CP-44 | Kimmo |  |
| 688 | 263.2 | CT1 aspects of Completion of IMS Restoration Procedures | 212d? | 2009-05-29 A | 2010-03-19 A | 100% | 2009-05-29 | 2010-03-19 | 212d? | finish no earlier than 2010-03-19 | C1 | 1696h | 1696h | eIMS_RP | PCG-23 | Ericsson | Emiliano Merino (emiliano.merino@ericsson.com) | Rel-9 | CP-44 | Kimmo |  |
| 689 | 263.3 | CT3 aspects of Completion of IMS Restoration Procedures | 212d? | 2009-05-29 A | 2010-03-19 A | 100% | 2009-05-29 | 2010-03-19 | 212d? | finish no earlier than 2010-03-19 | C3 | 1696h | 1696h | eIMS_RP | PCG-24 | Ericsson | Emiliano Merino (emiliano.merino@ericsson.com) | Rel-9 | CP-46 | Kimmo |  |
| 690 | 264 | IMS Stage 3 - IETF Protocol Alignment | 212d? | 2009-05-29 A | 2010-03-19 A | 100% | 2009-05-29 | 2010-03-19 | 212d? | finish no earlier than 2010-03-19 | C1 | 1696h | 1696h | IMSProtoc3 | PCG-23 | Alcatel-Lucent | Keith Drage (drage@alcatel-lucent.com) | Rel-9 | CP-44 | Frederic |  |
| 691 | 265 | Operational description of the Inter-IMS Network to Network Interface (II-NNI) | 267d? | 2009-05-29 A | 2010-06-04 A | 100% | 2009-05-29 | 2010-06-04 | 267d? | finish no earlier than 2010-06-04 | C3 | 2136h | 2136h | II-NNI | PCG-23 | Orange | sebastien.daudet@orange-ftgroup.com | Rel-9 | CP-44 | Jiwan |  |
| 692 | 266 | Definition of Ml interface for Control Plane LCS (Stage 3) | 131d? | 2009-09-18 A | 2010-03-19 A | 100% | 2009-09-18 | 2010-03-19 | 131d? | finish no earlier than 2010-03-19 | C1 | 1048h | 1048h | EMC2 | PCG-23 | Alcatel-Lucent | Keith Drage (drage@alcatel-lucent.com) | Rel-9 | CP-45 | Frederic |  |
| 693 | 267 | PCC enhancements | 56d? | 2009-09-18 A | 2009-12-04 A | 100% | 2009-09-18 | 2009-12-04 | 56d? | finish no earlier than 2009-12-04 | C3 | 448h | 448h | PCC-Enh | PCG-23 | Huawei | Wei Weihua (weiwh@huawei.com) | Rel-9 | CP-45 | Jiwan |  |
| 694 | 268 | 3GPP IMS Conferencing Management Object (MO) | 2d? | 2009-12-03 A | 2009-12-04 A | 100% | 2009-12-03 | 2009-12-04 | 2d? | start no earlier than 2009-12-03 | C1 | 16h | 16h | IMS_ConfMO | PCG-24 |  |  | Rel-9 | CP-46 | Frederic |  |
| 695 | 269 | In Case of Emergency (ICE) Graphics | 3d? | 2010-03-17 A | 2010-03-19 A | 100% | 2010-03-17 | 2010-03-19 | 3d? | finish no earlier than 2010-03-19 | C6 | 24h | 24h | ICE_Graphics | PCG-24 | Sagem-Orga | heiko.kruse@sagem-orga.com | Rel-9 | CP-47 | Xavier |  |
| 696 | 270 | **Rel-9 Improvements of the Radio Interface** | 397d? | 2008-09-12 A | 2010-03-19 A | 100% | 2008-09-12 | 2010-03-19 | 397d? |  | RP,GP | 19147.6h | 19147.6h | RInImp9 | PCG-21 |  |  | Rel-9 | RP-41 | Issam |  |
| 697 | 270.1 | LCR TDD UE OTA Performance Requirements | 186d? | 2008-09-12 A | 2009-05-29 A | 100% | 2008-09-12 | 2009-05-29 | 186d? | finish no earlier than 2009-05-29 | R4 | 1488h | 1488h | RInImp9-RFLCROTA | PCG-21 | RITT | Wu Xiang (wuxiang@chinattl.com) | Rel-9 | RP-41 | Issam | RP-090389 |
| 698 | 270.2 | **RF requirements for Multicarrier and Multi-RAT BS** | 347d? | 2008-11-21 A | 2010-03-19 A | 100% | 2008-11-21 | 2010-03-19 | 347d? |  | R4,G1 | 7403.6h | 7403.6h | RInImp9-RFmulti | PCG-21 | Ericsson | Johan.skold@ericsson.com | Rel-9 | RP-41 | Issam |  |
| 699 | 270.2.1 | RAN4 part of RF requirements for Multicarrier and Multi RAT BS | 337d? | 2008-12-05 A | 2010-03-19 A | 100% | 2008-12-05 | 2010-03-19 | 337d? | finish no earlier than 2010-03-19 | R4 | 2696h | 2696h | RInImp9-Rfmulti | PCG-22 | Ericsson | Johan.skold@ericsson.com | Rel-9 | RP-42 | Issam | RP-100027 |
| 700 | 270.2.2 | GERAN part of RF requirements for Multicarrier and Multi RAT BS | 261d? | 2008-11-21 A | 2009-11-20 A | 100% | 2008-11-21 | 2009-11-20 | 261d? | finish no earlier than 2009-11-20 | G1 | 2088h | 2088h | RInImp9-RFmulti-GERAN | PCG-22 | Ericsson | mats.y.samuelsson@ericsson.com | Rel-9 | GP-40 | Paolo |  |
| 701 | 270.3 | Extended UMTS/LTE 800 MHz | 207d? | 2008-12-05 A | 2009-09-18 A | 100% | 2008-12-05 | 2009-09-18 | 207d? |  | R4,R2,R3 | 1648h | 1648h | RInImp9-UMTSLTE800 | PCG-22 | NTT DoCoMo | Shingo Suwa (suwas@nttdocomo.co.jp) | Rel-9 | RP-42 | Issam | RP-090687 |
| 702 | 270.4 | UMTS/LTE 800 MHz for Europe | 272d? | 2009-03-06 A | 2010-03-19 A | 100% | 2009-03-06 | 2010-03-19 | 272d? | finish no earlier than 2010-03-19 | R4,R2,R3 | 2176h | 2176h | RInImp9-UMTSLTE800EU | PCG-22 | Ericsson | olav.queseth@ericsson.com | Rel-9 | RP-43 | Issam | RP-100028 |
| 703 | 270.5 | Performance requirement for LCR TDD with UE speeds up to 350 km/h | 196d? | 2009-03-06 A | 2009-12-04 A | 100% | 2009-03-06 | 2009-12-04 | 196d? | finish no earlier than 2009-12-04 | R4 | 1568h | 1568h | RInImp9-LCRTDD350 | PCG-22 | CATT | Yuexia Song (songyuexia@datangmobile.cn) | Rel-9 | RP-43 | Issam | RP-091035 |
| 704 | 270.6 | Extended UMTS/LTE 1500 MHz | 211d? | 2009-05-30 A | 2010-03-19 A | 100% | 2009-05-30 | 2010-03-19 | 211d? | finish no earlier than 2010-03-19 | R4,R2,R3 | 1688h | 1688h | UMTSLTE1500 | PCG-23 | NTT DoCoMo | Shingo Suwa (suwas@nttdocomo.co.jp) | Rel-9 | RP-44 | Issam | RP-100029 |
| 705 | 271 | **Rel-9 Improvements of the Radio Interface - UE Conformance Testing** | 350d? | 2009-05-19 A | 2010-09-17 A | 100% | 2009-05-19 | 2010-09-17 | 350d? |  | R5 | 8184h | 8184h | RInImp-UEConTest | PCG-23 |  |  | Rel-9 | RP-44 | Ingbert |  |
| 706 | 271.1 | Conformance Test Aspects – UMTS/LTE in 800 MHz for Europe | 350d? | 2009-05-19 A | 2010-09-17 A | 100% | 2009-05-19 | 2010-09-17 | 350d? | finish no earlier than 2010-09-17 | R5 | 2800h | 2800h | RInImp-UEConTest-UMTSLTE800EU | PCG-23 | Ericsson | fredrik.sundstrom@ericsson.com | Rel-9 | RP-44 | Ingbert | RP-100736 |
| 707 | 271.2 | Conformance Test Aspects – Extended UMTS/LTE 1500 MHz | 186d? | 2009-09-18 A | 2010-06-04 A | 100% | 2009-09-18 | 2010-06-04 | 186d? | finish no earlier than 2010-06-04 | R5 | 1488h | 1488h | UMTSLTE1500_UEConTest | PCG-23 | NTT DoCoMo | Nguyen Dung Dao (dao@nttdocomo.co.jp) | Rel-9 | RP-45 | Ingbert | RP-100487 |
| 708 | 271.3 | TDD UE Over The Air (Antenna) conformance testing methodology | 81d? | 2009-05-30 A | 2009-09-18 A | 100% | 2009-05-30 | 2009-09-18 | 81d? | finish no earlier than 2009-09-18 | R5 | 648h | 648h | UEAnt_TDDTest | PCG-23 | CATR | Qu Yan (quyan@emcite.com) | Rel-9 | RP-44 | Ingbert | RP-090727 |
| 709 | 271.4 | Conformance Test Aspects – Performance requirement for LCR TDD with UE speeds up to 350 km/h | 56d? | 2010-03-19 A | 2010-06-04 A | 100% | 2010-03-19 | 2010-06-04 | 56d? | finish no earlier than 2010-06-04 | R5 | 448h | 448h | RInImp9-LCRTDD350_UEConTest | PCG-24 | CATT | Xiaozhong Chen (chexiaozhong@datangmobile.cn) | Rel-9 | RP-47 | Ingbert | RP-100496 |
| 710 | 272 | Conformance Test Aspects – SMS over IMS in E-UTRAN | 131d? | 2009-09-18 A | 2010-03-19 A | 100% | 2009-09-18 | 2010-03-19 | 131d? | finish no earlier than 2010-06-18 | R5 | 1048h | 1048h | SMSoverIMS_UEConTest | PCG-23 | Alcatel-Lucent | Nidal Khrais (khrais@alcatel-lucent.com) | Rel-9 | RP-45 | Ingbert | RP-100072 |

Notes:
- 686: CP#47 completed. Continuation of Rel-8 Feature UID_400012 IMS Restoration Procedures
- 687: CP#47 completed / Text3: 23.380, 23.820
- 688: CP#47 completed / Text3: 24.229
- 689: CP#47 completed / Text3: 29.061, 29.212, 29.213, 29.214, 29.215
- 690: CP#47 completed / Text3: 23.218, 24.229, 24.930
- 691: CP#48 completed / Text3: 29.165
- 692: CP#47 completed [Stage 3 for Rel-7 Emergency Calls (EMC1)]. Related to Rel-9 UID_400038 LCS Control Plane Solution for EPS. Stage 2 in Rel-9 UID_400038 (23.271), UID_410037 (23.167) / Text3: 24.229
- 693: CP#46 completed / Text3: 29.212, 29.213, 29.215
- 694: CP#46 completed. Linked to Rel-6 UID_11051 (IMS Management objects) under the Feature UID_32021 (IMS Phase 2). MO compatible with OMA DM v1.2 & upwards and defined using OMA DM Device Description Framework (OMA-ERELD _DM-V1_2) / Text3: new 24.166
- 695: CP#47 approved WID and completed. Added capability to store ICE graphical information (picture). Linked to CT6 Rel-8 ICE Feature UID_380059 In Case of Emergency numbers storage and easy access on UICC / Text3: 31.102 CR#0433
- 696: RP#41 umbrella Feature created to host Rel-9 WIs / Text3: GERAN, UTRA, LTE
- 697: RP#44 completed technical work (RAN4 internal TR abandoned) / Text3: UTRA (no TR 25.8xy produced)
- 698: RP#47 completed. RF requirements specification applicable to Multi-Standard Radio (MSR) Base Station with multiple carriers and/or multiple 3GPP Radio Access Technologies (RAT) / Text3: GERAN, UTRA, LTE
- 699: RP#48 completed / Text3: UTRA, LTE 25.104, 25.105, 36.104, new 37.104, 37.113, 37.141, 37.900
- 700: GP#44 Core spec completed (ongoing BS conformance spec). GP#40 WID approved / Text3: GERAN 45.005, 51.021
- 701: RP#45 completed / Text3: UTRA, LTE 25.101, 25.104, 25.113, 25.133, 34.124, 36.101, 36.104, 36.113, 36.124, 36.133, 36.141, 25.306, 25.307, 25.331, 36.331, 25.461, 25.466, new 36.800
- 702: RP#47 completed / Text3: UTRA, LTE 25.101, 25.104, 25.113, 25.133, 25.141, 34.124, 36.101, 36.104, 36.113, 36.124, 36.133, 36.141, new 36.810, 25.306, 25.307, 25.331, 36.331, 25.461, 25.466
- 703: RP#46 completed / Text3: UTRA 25.102, 25.105, 25.142
- 704: RP#47 completed. For potential deployment in Japan / Text3: UTRA, LTE 25.101, 25.104, 25.113, 25.133, 25.141, 25.306, 25.307, 25.331, 25.461, 25.466, 34.124, 36.101, 36.104, 36.113, 36.124, 36.133, 36.141, 36.331, new (36.821, 36.307)
- 705: - / Text3: UTRA, LTE
- 706: RP#49 completed. Testing for UID_430009 UMTS/LTE 800 MHz for Europe / Text3: UTRA, LTE 34.108, 34.121-1, 34.121-2, 36.508, 36.521-1, 36.521-2, 36.521-3
- 707: RP#48 completed / Text3: UTRA, LTE 34.108, 34.121-1, 34.121-2, 34.123-1, 34.123-2, 36.508, 36.521-1, 36.521-2, 36.521-3, 36.523-1, 36.523-2, 36.523-3
- 708: RP#45 completed. Finalized TDD UE test methodology based on R4 TR 25.914 (UE and MS antenna performance evaluation method) and TS 25.144 Over the Air (Antenna) minimum performance requirements for the speech mode (terminal close to head) / Text3: UTRA 34.114
- 709: RP#48 completed. Testing for UID_430010 Performance requirement for LCR TDD with UE speeds up to 350 km/h / Text3: UTRA 34.122
- 710: RP#47 completed / Text3: LTE 34.229-1, 34.229-2, 34.229-3

| ID | WBS | Task | Duration | Start | Finish | Complete | Remaining | Baseline start | Baseline finish | Baseline duration | Total slack | Constraint | Resources | Work | Actual work | Text1 | Text2 | Text6 | Text7 | Text8 | Text4 | Text5 | Text11 |
| --- | --- | --- | --- | --- | --- | --- | --- | --- | --- | --- | --- | --- | --- | --- | --- | --- | --- | --- | --- | --- | --- | --- | --- |
| 711 | 273 | **Rel-9 RAN improvements** | 272d? | 2009-03-06 A | 2010-03-19 A | 100% |  | 2009-03-06 | 2010-03-19 | 272d? |  |  | RP | 9536h | 9536h | RANimp | PCG-22 | Rel-9 | RP-43 | Issam |  |  |  |
| 712 | 273.1 | Dual-Cell HSUPA | 272d? | 2009-03-06 A | 2010-03-19 A | 100% |  | 2009-03-06 | 2010-03-19 | 272d? |  | finish no earlier than 2010-03-19 | R1,R2,R3,R4 | 1568h | 1568h | RANimp-DC_HSUPA | PCG-22 | Rel-9 | RP-43 | Patrick | Nokia Siemens Networks | Karri Ranta-aho (karri.ranta-aho@nsn.com) | RP-100030 |
| 713 | 273.2 | Support for different bands for Dual-Cell HSDPA | 197d? | 2009-03-06 A | 2009-12-04 A | 100% |  | 2009-03-06 | 2009-12-04 | 197d? |  |  | R4,R2,R3 | 1568h | 1568h | RANimp-MultiBand_DC_HSDPA | PCG-22 | Rel-9 | RP-43 | Issam | Nokia Siemens Networks | Tuomo Säynäjäkangas (tuomo.saynajakangas@nsn.com) | RP-091038 |
| 714 | 273.3 | Combination of DC-HSDPA with MIMO | 197d? | 2009-03-06 A | 2009-12-04 A | 100% |  | 2009-03-06 | 2009-12-04 | 197d? |  |  | R1,R2,R3,R4 | 1568h | 1568h | RANimp-DC_MIMO | PCG-22 | Rel-9 | RP-43 | Patrick | Ericsson | johan.bergman@ericsson.com | RP-091039 |
| 715 | 273.4 | Transmit Antenna Array (TxAA) extension for non-MIMO UEs | 197d? | 2009-03-06 A | 2009-12-04 A | 100% |  | 2009-03-06 | 2009-12-04 | 197d? |  |  | R1,R2,R3,R4 | 1568h | 1568h | RANimp-TxAA_nonMIMO | PCG-22 | Rel-9 | RP-43 | Patrick | Nokia | Arto Lehti (arto.lehti@nokia.com) | RP-091040 |
| 716 | 273.5 | Cell Portion for 1.28 Mcps TDD | 136d? | 2009-05-30 A | 2009-12-04 A | 100% |  | 2009-05-30 | 2009-12-04 | 136d? |  |  | R3,R1,R4 | 1088h | 1088h | CP_LCRTDD | PCG-23 | Rel-9 | RP-44 | Juha | CATT | Ying Zhang (zhangying2@datangmobile.cn) | RP-091041 |
| 717 | 274 | **Rel-9 RAN improvements - UE Conformance Testing** | 321d? | 2010-09-17 A | 2011-12-09 | 29% | 226.97d? | 2010-09-17 | 2011-12-09 | 321d? | 330d |  | R5 | 6632h | 1942.6h |  | PCG-25 | Rel-9 | RP-49 | Ingbert |  |  |  |
| 718 | 274.1 | Conformance Test Aspects – Combination of DC-HSDPA with MIMO | 186d? | 2010-09-17 A | 2011-06-03 | 80% | 37.2d? | 2010-09-17 | 2011-06-03 | 186d? | 465d | finish no earlier than 2011-06-03 | R5 | 1488h | 1190.4h | RANimp-DC_MIMO_UEConTest | PCG-25 | Rel-9 | RP-49 | Ingbert | Ericsson | leif.mattisson@ericsson.com | RP-110040 |
| 719 | 274.2 | Conformance Test Aspects – Dual-Cell HSUPA | 191d? | 2011-03-18 | 2011-12-09 |  |  | 2011-03-18 | 2011-12-09 | 191d? | 330d | finish no earlier than 2011-12-09 | R5 | 1528h |  | RANimp-DC_HSUPA_UEConTest | PCG-26 | Rel-9 | RP-51 | Ingbert | Ericsson | leif.mattisson@ericsson.com |  |
| 720 | 274.3 | Conformance Test Aspects – Support for different bands for Dual-Cell HSDPA | 131d? | 2011-03-18 | 2011-09-16 |  |  | 2011-03-18 | 2011-09-16 | 131d? | 390d | finish no earlier than 2011-09-16 | R5 | 1048h |  | RANimp-MultiBand_DC_HSDPA_UEConTest | PCG-26 | Rel-9 | RP-51 | Ingbert | Ericsson | leif.mattisson@ericsson.com |  |
| 721 | 275 | **LTE improvements** | 587d? | 2009-03-06 A | 2011-06-03 | 91% | 50.08d? | 2009-03-06 | 2011-06-03 | 587d? | 465d |  | RP | 9928h | 7994.74h | LTEimp | PCG-22 | Rel-9 | RP-42 | Patrick |  |  |  |
| 722 | 275.1 | LTE Pico NodeB RF Requirements | 196d? | 2009-03-06 A | 2009-12-04 A | 100% |  | 2009-03-06 | 2009-12-04 | 196d? |  | finish no earlier than 2010-03-05 | R4 | 1568h | 1568h | LTEimp-Pico_eNB-RF | PCG-22 | Rel-9 | RP-43 | Issam | Huawei | Liyan Yin (yinliyan@huawei.com) | RP-091045 |
| 723 | 275.2 | Enhanced Dual-Layer transmission for LTE | 272d? | 2009-03-06 A | 2010-03-19 A | 100% |  | 2009-03-06 | 2010-03-19 | 272d? |  | finish no earlier than 2010-03-18 | R1,R2,R4 | 2176h | 2176h | LTEimp-eDL | PCG-22 | Rel-9 | RP-43 | Patrick | China Mobile | Xu Xiaodong (xuxiaodong@chinamobile.com) | RP-100034 |
| 724 | 275.3 | UE Conformance Test Aspects – Enhanced Dual-layer transmission for LTE TDD | 186d? | 2010-09-17 A | 2011-06-03 | 70% | 55.8d? | 2010-09-17 | 2011-06-03 | 186d? | 465d | finish no earlier than 2011-06-03 | R5 | 1488h | 1041.6h | LTEimp-eDL_UEConTest | PCG-25 | Rel-9 | RP-49 | Ingbert | China Mobile | Shanpeng Xiao (xiaoshanpeng@chinamobile.com) | RP-110039 |
| 725 | 276 | Self-Organizing Networks (SON) | 272d? | 2009-03-06 A | 2010-03-19 A | 100% |  | 2009-03-06 | 2010-03-19 | 272d? |  | finish no earlier than 2010-03-19 | R3,R2 | 2176h | 2176h | SON | PCG-22 | Rel-9 | SP-42 | Juha | Nokia Siemens Networks | krzysztof.kordybach@nsn.com | RP-100038 |
| 726 | 277 | **A-GNSS Performances and Testing Procedures** | 787d? | 2008-05-16 A | 2011-05-20 | 94% | 49.2d? | 2008-05-16 | 2011-05-20 | 787d? | 475d |  | GP | 16368h | 9760h | AGNSSPTP |  | Rel-9 |  | Paolo | Thales | Michel.monnerat@thalesaleniaspace.com |  |
| 727 | 277.1 | A-GNSS Minimum Performances | 472d? | 2008-05-16 A | 2010-03-05 A | 100% |  | 2008-05-16 | 2010-03-05 | 472d? |  | finish no earlier than 2010-03-05 | G1 | 3776h | 3776h | AGNSSPTP- Perfreq |  | Rel-9 |  | Paolo | Thales | Michel.monnerat@thalesaleniaspace.com |  |
| 728 | 277.2 | A-GNSS Testing Procedures | 787d? | 2008-05-16 A | 2011-05-20 | 90% | 78.7d? | 2008-05-16 | 2011-05-20 | 787d? | 475d | finish no earlier than 2011-05-20 | G3new | 6296h | 5666.4h | AGNSSPTP-MStest |  | Rel-9 |  | Ingbert | Thales | Michel.monnerat@thalesaleniaspace.com |  |
| 729 | 278 | **Voice services over Adaptive Multi-user channels on One Slot** | 857d? | 2008-11-21 A | 2012-03-02 | 83% | 144.69d? | 2008-11-21 | 2012-03-02 | 857d? | 270d |  | GP,G1,G2,G3new | 24104h | 17472h | VAMOS | PCG-22 | Rel-9 | SP-42 | Paolo | Nokia Siemens Networks, China Mobile | juergen.hofmann@nsn.com, liuxiaoyu@chinamobile.com |  |
| 730 | 278.1 | Stage 2 for Voice services over Adaptive Multi-user channels on One Slot | 392d? | 2008-11-21 A | 2010-05-21 A | 100% |  | 2008-11-21 | 2010-05-21 | 392d? |  | finish no earlier than 2010-05-21 | GP,G1,G2 | 3136h | 3136h | VAMOS | PCG-22 | Rel-9 | GP-40 | Paolo | Nokia Siemens Networks, China Mobile | juergen.hofmann@nsn.com, liuxiaoyu@chinamobile.com |  |
| 731 | 278.2 | Stage 3 for Voice services over Adaptive Multi-user channels on One Slot | 596d? | 2008-11-24 A | 2011-03-04 A | 100% |  | 2008-11-24 | 2011-03-04 | 596d? |  | finish no earlier than 2011-03-04 | GP,G1,G2 | 4768h | 4768h | VAMOS | PCG-22 | Rel-9 | GP-40 | Paolo | Nokia Siemens Networks, China Mobile | juergen.hofmann@nsn.com, liuxiaoyu@chinamobile.com |  |
| 732 | 278.3 | VAMOS Radio Performance Requirements | 651d? | 2008-11-24 A | 2011-05-20 | 90% | 65.1d? | 2008-11-24 | 2011-05-20 | 651d? | 475d | finish no earlier than 2011-05-20 | GP,G1,G2 | 5208h | 4687.2h | VAMOS | PCG-22 | Rel-9 | GP-40 | Paolo | Nokia Siemens Networks, China Mobile | juergen.hofmann@nsn.com, liuxiaoyu@chinamobile.com |  |
| 733 | 278.4 | VAMOS - MS conformance testing | 391d? | 2010-09-03 A | 2012-03-02 | 30% | 273.7d? | 2010-09-03 | 2012-03-02 | 391d? | 270d | finish no earlier than 2012-03-02 | G3new | 3128h | 938.4h | VAMOS_MStest | PCG-25 | Rel-9 | GP-47 | Ingbert | Research In Motion | Raveendra Seetharam (rseetharam@rim.com) |  |
| 734 | 278.5 | VAMOS - BTS conformance testing | 126d? | 2010-11-26 A | 2011-05-20 | 80% | 25.2d? | 2010-11-26 | 2011-05-20 | 126d? | 475d | finish no earlier than 2011-05-20 | G1 | 1008h | 806.4h | VAMOS_BTStest | PCG-26 | Rel-9 | GP-48 | Paolo | Nokia Siemens Networks | eddie.riddington@nsn.com |  |

Notes:
- 711: RP#47 completed / Text3: UTRA
- 712: RP#47 completed / Text3: 25.101, 25.104, 25.133, 25.211, 25.212, 25.213, 25.214, 25.215, 25.319, 25.306, 25.321, 25.331, 25.423, 25.433
- 713: RP#46 completed / Text3: 25.101, 25.104, 25.133, 25.306, 25.308, 25.331, 25.423, 25.433, new 25.317 (Requirements on Ues supporting a release-independent frequency band combination)
- 714: RP#46 completed / Text3: 25.101, 25.104, 25.133, 25.211, 25.212, 25.213, 25.214, 25.215, 25.308, 25.321, 25.331, 26.306, 25.423, 25.433
- 715: RP#46 completed / Text3: 25.101, 25.104, 25.211, 25.212, 25.213, 25.214, 25.215, 25.308, 25.306, 25.321, 25.331, 25.423, 25.433
- 716: RP#46 completed / Text3: 25.102, 25.105, 25.123, 25.225, 25.423, 25.433
- 717: -
- 718: UTRA. Testing for Rel-9 UID_430016 Combination of DC-HSDPA with MIMO / Text3: UTRA 34.108, 34.121-1, 34.121-2, 34.123-1, 34.123-2, 34.123-3
- 719: UTRA. Testing for Rel-9 UID_430014 Dual-Cell HSUPA / Text3: UTRA 34.108, 34.121-1, 34.121-2, 34.123-1, 34.123-2, 34.123-3
- 720: UTRA. Testing for Rel-9 UID_430015 Support for different bands for Dual-Cell HSDPA / Text3: UTRA 34.108, 34.121-1, 34.121-2, 34.123-1, 34.123-2, 34.123-3
- 721: - / Text3: LTE
- 722: RP#46 completed / Text3: 36.104, 36.141, new 36.931
- 723: RP#47 completed / Text3: 36.101, 36.211, 36.212, 36.213, 36.331
- 724: RP#51 completion 03/11=>06/11. Testing for UID_430029 (Enhanced Dual-Layer transmission for LTE) / Text3: 36.508, 36.521-1, 36.521-2
- 725: RP#47 completed / Text3: LTE 25.413, 36.300, 36.413, 36.423, 48.018, new 36.902
- 726: GP#46 still ongoing MS testing. Linked to Rel-10 RAN4 UID_450027 (A-GNSS Minimum Performance for UTRAN)
- 727: GP#45 completed (open performance requirements alignment GPS/Galileo) / Text3: 45.005
- 728: GP#49 completion 03/11=>05/11 / Text3: 51.010-1, new 51.010-7
- 729: GP#46 completion 05/10=>09/10. GP#44 exception to 05/10 in GP-092470. GP#40 WID approved. Triggered by UID_50590 (MUROS) Study on Multi-User Reusing-One-Slot
- 730: GP#46 completed / Text3: 45.001
- 731: GP#49 completed / Text3: 24.008, 44.018, 45.002, 45.003, 45.004, 45.008, 48.008, 48.058
- 732: GP#49 completion 03/11=>05/11 / Text3: 45.005
- 733: GP#47 WID approved. / Text3: 51.010-1, 51.010-2
- 734: GP#49 completion 03/11=>05/11. GP#48 WID approved / Text3: 51.021

| ID | WBS | Task | Type | Duration | Start | Finish | Complete | Baseline start | Baseline finish | Baseline duration | Constraint | Resources | Work | Actual work | Text1 | Text2 | Text4 | Text5 | Text6 | Text7 | Text8 | Text9 | Text12 | Text11 |
| --- | --- | --- | --- | --- | --- | --- | --- | --- | --- | --- | --- | --- | --- | --- | --- | --- | --- | --- | --- | --- | --- | --- | --- | --- |
| 735 | 279 | **Cell Broadcast protocol Base Station Controller – Cell Broadcast Centre (BSC-CBC)** |  | 222d? | 2009-05-15 A | 2010-03-19 A | 100% | 2009-05-15 | 2010-03-19 | 222d? |  | GP,C1 | 5248h | 5248h | CEBRO | PCG-23 | Ericsson | claes-goran.persson@ericsson.com | Rel-9 | GP-42 | Paolo |  |  |  |
| 736 | 279.1 | GERAN part of Cell Broadcast protocol Base Station Controller – Cell Broadcast Centre |  | 212d? | 2009-05-15 A | 2010-03-05 A | 100% | 2009-05-15 | 2010-03-05 | 212d? | finish no earlier than 2010-03-05 | GP | 1696h | 1696h | CEBRO | PCG-23 | Ericsson | claes-goran.persson@ericsson.com | Rel-9 | GP-42 | Paolo |  |  |  |
| 737 | 279.2 | CT1 part of Cell Broadcast protocol Base Station Controller – Cell Broadcast Centre |  | 222d? | 2009-05-15 A | 2010-03-19 A | 100% | 2009-05-15 | 2010-03-19 | 222d? | finish no earlier than 2010-03-19 | C1 | 1776h | 1776h | CEBRO | PCG-23 | Ericsson | claes-goran.persson@ericsson.com | Rel-9 | GP-42 | Frederic |  |  |  |
| 738 | 280 | Hybrid Location |  | 136d? | 2009-05-18 A | 2009-11-20 A | 100% | 2009-05-18 | 2009-11-20 | 136d? | finish no earlier than 2009-11-20 | GP | 1088h | 1088h | HILT | PCG-23 | TruePosition | Matt Ward (mward@trueposition.com) | Rel-9 | GP-42 | Paolo |  |  |  |
| 739 | 281 | (Small) Technical Enhancements and Improvements for Rel-9 |  | 325d? | 2008-09-15 A | 2009-12-10 A | 100% | 2008-09-15 | 2009-12-10 | 325d? | finish no earlier than 2009-12-10 | All | 2600h | 2600h | TEI9 | PCG-22 |  |  | Rel-9 | SP-42 | All |  |  |  |
| 740 | 282 | Test - (Small) Technical Enhancements and Improvements for Rel-9 |  | 286d? | 2009-11-20 A | 2010-12-24 A | 100% | 2009-11-20 | 2010-12-24 | 286d? | finish no earlier than 2010-12-24 | R5,G3new | 2288h | 2288h | TEI9_Test | PCG-24 |  |  | Rel-9 | GP-44 | Ingbert |  |  |  |
| 741 | 283 | **Deleted - Services Alignment and Migration** |  | 467d? | 2006-12-06 A | 2008-09-18 A | 100% | 2006-12-06 | 2008-09-18 | 467d? |  | S1 | 7472h | 7472h | ServAl |  | Telefónica O2 | chris.friel@O2.com | Rel-9 | SP-33 | Alain |  |  |  |
| 742 | 283.1 | Deleted - Stage 1 for ServAl |  | 467d? | 2006-12-06 A | 2008-09-18 A | 100% | 2006-12-06 | 2008-09-18 | 467d? | finish no earlier than 2008-12-11 | S1 | 3736h | 3736h | ServAl | PCG-21 | Telefónica O2 | chris.friel@O2.com | Rel-9 | SP-33 | Alain |  |  |  |
| 743 | 284 | Deleted - Harmonization of Gq'/Rx for Common IMS |  | 304d? | 2008-01-14 A | 2009-03-12 A | 100% | 2008-01-14 | 2009-03-12 | 304d? | finish no earlier than 2009-03-12 | S2 | 2432h | 2432h | IMS_Comm_GqRx_Harm | PCG-21 | Alcatel-Lucent | geoffrey.cristallo@alcatel-lucent.be | Rel-9 | SP-38 | Maurice | PCG-22 | SP-43 |  |
| 744 | 285 | Deleted - Support of WiMAX - LTE Mobility |  | 407d? | 2008-06-06 A | 2009-12-25 A | 100% | 2008-06-06 | 2009-12-25 | 407d? | start no earlier than 2008-06-06 | R2 | 3248h | 3248h | WiMAX_LTE_Mobility | PCG-21 | Samsung |  | Rel-9 | RP-38 | Joern | PCG-21 | SP-39 |  |
| 745 | 286 | Deleted - Support of WiMAX - UMTS Mobility |  | 407d? | 2008-06-06 A | 2009-12-25 A | 100% | 2008-06-06 | 2009-12-25 | 407d? | start no earlier than 2008-06-06 | R2 | 3248h | 3248h | WiMAX_UMTS_Mobility | PCG-21 | Intel |  | Rel-9 | RP-38 | Joern | PCG-21 | SP-39 |  |
| 746 | 287 | Deleted - Definition of 3GPP UICC services over the new high-speed interface | milestone | 0d? | 2010-03-19 A | 2010-03-19 A | 100% | 2010-03-19 | 2010-03-19 | 0d? |  | C6 |  |  | UICCHS | PCG-21 | Gemalto | Denis.Lheriteau@gemalto.com | Rel-9 | CP-38 | Xavier | PCG-24 | CP-47 |  |
| 747 | 288 | **Deleted - SAES Enhancements (non RAN aspects)** |  | 381d? | 2007-06-25 A | 2008-12-08 A | 100% | 2007-06-25 | 2008-12-08 | 381d? |  | S2 | 11664h | 11664h | SAES_Ph2 | PCG-21 | Nokia Siemens Networks |  | Rel-9 | SP-39 | Maurice | PCG-21 | SP-39 |  |
| 748 | 288.1 | Deleted - Functions and procedures for SAE to support LTE MBMS |  | 381d? | 2007-06-25 A | 2008-12-08 A | 100% | 2007-06-25 | 2008-12-08 | 381d? | finish no earlier than 2008-12-08 | S2 | 3048h | 3048h | SAES_Ph2 |  |  |  | Rel-9 | SP-35 | Maurice | PCG-21 | SP-39 |  |
| 749 | 288.2 | Deleted - CS over EPS |  | 194d? | 2008-03-12 A | 2008-12-08 A | 100% | 2008-03-12 | 2008-12-08 | 194d? | finish no earlier than 2008-12-08 | S2 | 1552h | 1552h | SAES_Ph2 | PCG-21 |  |  | Rel-9 | SP-39 | Maurice | PCG-21 | SP-39 |  |
| 750 | 288.3 | **Deleted - SAE for generic support for non-3GPP accesses** |  | 251d? | 2007-06-25 A | 2008-06-09 A | 100% | 2007-06-25 | 2008-06-09 | 251d? |  | S2 | 4016h | 4016h | SAES_Ph2 | PCG-21 |  |  | Rel-9 | SP-39 | Maurice | PCG-21 | SP-39 |  |
| 751 | 288.3.1 | Deleted - Single Radio Aspects of SAE for Optimized Handover with WiMAX |  | 251d? | 2007-06-25 A | 2008-06-09 A | 100% | 2007-06-25 | 2008-06-09 | 251d? | finish no earlier than 2008-06-09 | S2 | 2008h | 2008h | SAES_Ph2 | PCG-21 |  |  | Rel-9 | SP-39 | Maurice | PCG-21 | SP-39 |  |
| 752 | 289 | Deleted - Lawful Interception in the 3GPP Rel-9 |  | 211d? | 2009-06-04 A | 2010-03-25 A | 100% | 2009-06-04 | 2010-03-25 | 211d? | finish no earlier than 2010-03-25 | S3 | 1688h | 1688h | LI9 | PCG-23 | PIDS, Nortel | Koen Jaspers, Ronald Ryan | Rel-9 | SP-44 | Dionisio | PCG-24 | SP-47 |  |
| 753 | 290 | Release 9 Studies |  | 468d? | 2008-06-05 A | 2010-03-19 A | 100% | 2008-06-05 | 2010-03-19 | 468d? |  | CP,RP,SP | 3744h | 3744h |  |  |  |  | Rel-9 |  |  |  |  |  |
| 754 | 291 | Study on Service Specific Access Control in EPS |  | 136d? | 2008-06-05 A | 2008-12-11 A | 100% | 2008-06-05 | 2008-12-11 | 136d? | start no earlier than 2008-06-05 | S1 | 1088h | 1088h | FS_SSAC | PCG-21 | NTT DoCoMo | Shin-ichi Isobe (isobes@nttdocomo.co.jp) | Rel-9 | SP-40 | Alain |  |  |  |
| 755 | 292 | Study on CS Domain Services over EPS access |  | 492d? | 2007-04-25 A | 2009-03-12 A | 100% | 2007-04-25 | 2009-03-12 | 492d? | finish no earlier than 2009-03-12 | S2 | 3936h | 3936h | FS_CSoPS |  | T-Mobile | Karl-Heinz.Nenner@T-Mobile.net | Rel-9 | SP-35 | Maurice |  |  |  |
| 756 | 293 | Study on Extended Support of IMS Emergency Calls |  | 319d? | 2007-09-24 A | 2008-12-11 A | 100% | 2007-09-24 | 2008-12-11 | 319d? | finish no earlier than 2009-06-18 | S2 | 2552h | 2552h | FS_IMS-eCall |  | Qualcomm | Stephen Edge | Rel-9 | SP-37 | Maurice |  |  |  |
| 757 | 294 | Study on Service Continuity for Emergency Voice Calls |  | 721d? | 2006-06-08 A | 2009-03-12 A | 100% | 2006-06-08 | 2009-03-12 | 721d? | finish no earlier than 2009-03-12 | S2 | 5768h | 5768h | FS_VCCEm |  | Nortel | Ricky Kaura (rkaura@nortel.com) | Rel-9 | SP-32 | Maurice |  |  |  |
| 758 | 295 | Study on Security Aspects of Remote Provisioning and Change of Subscription for M2M Equipment |  | 582d? | 2004-04-06 A | 2009-12-10 A | 100% | 2004-04-06 | 2009-12-10 | 582d? | finish no earlier than 2009-12-10 | S3,C6 | 4656h | 4656h | FS_UM2M |  | Ericsson | vesa.lehtovirta@ericsson.com | Rel-9 | SP-37 | Dionisio |  |  |  |
| 759 | 296 | Study on System Maintenance over Itf-N |  | 602d? | 2007-06-07 A | 2009-09-24 A | 100% | 2007-06-07 | 2009-09-24 | 602d? | finish no earlier than 2009-09-24 | S5 | 4808h | 4808h | FS_OAM-Maint-Itf-N |  | ZTE | Shuqiang Huang (huangsq@zte.com.cn) | Rel-9 | SP-36 | Dionisio |  |  |  |
| 760 | 297 | Study on Self-Organizing Networks (SON) related OAM interfaces for Home NodeB |  | 522d? | 2007-06-07 A | 2009-06-04 A | 100% | 2007-06-07 | 2009-06-04 | 522d? | finish no earlier than 2009-12-10 | S5 | 4168h | 4168h | FS_OAM-SON-HNB |  | Huawei | Zou Lan (zlan@huawei.com) | Rel-9 | SP-36 | Dionisio |  |  |  |
| 761 | 298 | Study on Self-healing of Self-Organizing Networks (SON) |  | 416d? | 2008-02-22 A | 2009-09-24 A | 100% | 2008-02-22 | 2009-09-24 | 416d? | finish no earlier than 2009-09-24 | S5 | 3320.15h | 3320.15h | FS_OAM-SON-SH | PCG-21 | ZTE | zhu.weihong@zte.com.cn | Rel-9 | SP-39 | Dionisio |  |  |  |
| 762 | 299 | Study on Service Oriented Architecture (SOA) for IRP |  | 262d? | 2008-06-05 A | 2009-06-04 A | 100% | 2008-06-05 | 2009-06-04 | 262d? | finish no earlier than 2009-05-20 | S5 | 2088h | 2088h | FS_OAM_SOA_IRP | PCG-21 | Ericsson | edwin.tse@ericsson.com | Rel-9 | SP-40 | Dionisio |  |  |  |
| 763 | 300 | Study on Evaluation of the inclusion of Path Loss Based Technology in the UTRAN |  | 516d? | 2007-12-17 A | 2009-12-04 A | 100% | 2007-12-17 | 2009-12-04 | 516d? | finish no earlier than 2009-09-18 | R4 | 4120h | 4120h | FS_RAN-Pathloss | PCG-21 | Polaris Wireless | Norman Shaw (nshaw@polariswireless.com) | Rel-9 | RP-38 | Issam |  |  | RP-091080 |
| 764 | 301 | Study on LTE-Advanced |  | 461d? | 2007-03-23 A | 2010-03-19 A | 100% | 2007-03-23 | 2010-03-19 | 461d? | finish no earlier than 2010-03-19 | R1,R2,R3,R4 | 3688h | 3688h | FS_RAN_LTEA | PCG-21 | NTT DoCoMo | Tetsushi Abe | Rel-9 | RP-39 | Patrick |  |  | RP-100080 |
| 765 | 302 | Study on 1.28 Mcps TDD Home NodeB |  | 387d? | 2008-02-20 A | 2009-12-04 A | 100% | 2008-02-20 | 2009-12-04 | 387d? | finish no earlier than 2009-12-04 | R4 | 3096h | 3096h | FS_RAN-HNBLCRTDD | PCG-21 | TD Tech | Li Rong (lirong@td-tech.com) | Rel-9 | RP-41 | Issam |  |  | RP-091081 |
| 766 | 303 | Study on E-UTRAN Mobility Evaluation and Enhancement |  | 126d? | 2008-12-05 A | 2009-05-29 A | 100% | 2008-12-05 | 2009-05-29 | 126d? | finish no earlier than 2009-05-29 | R1 | 1008h | 1008h | FS_EUTRAN_mob | PCG-22 | Qualcomm | Rajat Prakash (rprakash@qualcomm.com) | Rel-9 | RP-42 | Patrick |  |  | RP-090426 |
| 767 | 304 | Study on Minimization of drive-tests in Next Generation Networks |  | 196d? | 2009-03-06 A | 2009-12-04 A | 100% | 2009-03-06 | 2009-12-04 | 196d? | finish no earlier than 2009-12-04 | R2 | 1568h | 1568h | FS_NGN_min_drive-tests | PCG-22 | Qualcomm | Masato Kitazoe (mkitazoe@qualcomm.com) | Rel-9 | RP-43 | Joern |  |  | RP-091084 |
| 768 | 305 | Study on Enhanced Interference Management for HNBs |  | 61d? | 2009-03-06 A | 2009-05-29 A | 100% | 2009-03-06 | 2009-05-29 | 61d? | start no earlier than 2009-03-06 | R4 | 488h | 488h | FS_eInterfMgmt_HNB | PCG-22 | Qualcomm | Farhad Meshkati (fmeshkat@qualcomm.com) | Rel-9 | RP-43 | Issam |  |  | RP-090429 |
| 769 | 306 | Study on Enhanced Interference Management Mechanisms for HNBs |  | 81d? | 2009-05-30 A | 2009-09-18 A | 100% | 2009-05-30 | 2009-09-18 | 81d? | finish no earlier than 2009-09-18 | R3 | 648h | 648h | FS_eInterfMgmtMchsm_HNB | PCG-23 | Qualcomm | Farhad Meshkati (fmeshkat@qualcomm.com) | Rel-9 | RP-44 | Juha |  |  | RP-090733 |
| 770 | 307 | Deleted - Study on Protection against SMS and MMS spam |  | 862d? | 2006-06-08 A | 2009-09-24 A | 100% | 2006-06-08 | 2009-09-24 | 862d? | finish no earlier than 2009-09-24 | S3 | 6896h | 6896h | FS_CPSMal |  | Orange | eric.gauthier@orange.ch | Rel-9 | SP-32 | Dionisio | PCG-23 | SP-45 |  |
| 771 | 308 | Release 8 Features |  | 914.3d? | 2006-09-19 A | 2010-03-19 A | 100% | 2006-09-19 | 2010-03-19 | 914.3d? | start no earlier than 2000-01-03 | CP,GP,RP,SP | 7314.4h | 7314.4h |  |  |  |  | Rel-8 |  |  |  |  |  |

Notes:
- 735: CP#47 completed. GP#45 completed. GP#42 WID approved
- 736: GP#45 completed. GP#42 WID approved / Text3: new 48.049
- 737: CP#47 completed / Text3: 23.041
- 738: GP#44 completed. GP#42 WID approved (Hybrid Integrated Location Technology=HILT) / Text3: 43.059, 48.071
- 739: SP#46 completed
- 740: GP#44 created
- 741: SP#41 closed (no tangible result of this work; no CR against TR 22.983). Triggered by Study UID_370086 (FSServAl)
- 742: SP#41 closed (no tangible result of this work; no CR against TR 22.983) / Text3: 22.983
- 743: SP#43 stopped. LS_out to TISPAN informs about stopping this activity / Text3: 23.822, 23.203
- 744: RP#39: No agreed WID / Text3: 36.306, 36.331, 36.413, 36.300, 36.214, 36.133, 36.304
- 745: RP#39: No agreed WID / Text3: 25.306, 25.331, 25.413
- 746: CP#47 work stopped/abandoned / Text3: 31.xyz
- 747: SP#39 created to host Rel-9 Wis. BUT no agreed WID
- 748: SP#39 SAE functionality moved to Rel-9. WID returned to SA2 for re-consideration & remove MBMS for EPS from Rel 8
- 749: SP#39 SAE functionality moved to Rel-9. BUT no agreed WID
- 750: SP#39 SAE functionality moved to Rel-9. BUT no agreed WID
- 751: SP#39 SAE functionality moved to Rel-9. BUT no agreed WID
- 752: SP#47 stopped. WI + new topics moved to Rel-10 / Text3: 33.106, 33.107, 33.108
- 753: -
- 754: SP#42 completed. Spin-off Feature UID_420020 (SSAC) / Text3: 22.986
- 755: SP#43 completed. Linked to Combinational Services UID_31064, Services Alignment and Migration (ServAl) UID_330017 and 3GPP System Architecture Evolution (SAES) UID_3208 / Text3: 23.879
- 756: SP#42 completed / Text3: 23.868
- 757: SP#43 completed / Text3: 23.826
- 758: SP#46 completed. Triggered by the SA1 Rel-8 Study on Facilitating Machine to Machine Communication in GSM and UMTS (FS_M2M) UID_7027 in TR 22.868. / Text3: 33.812
- 759: SP#45 completed / Text3: 32.822
- 760: SP#44 completed. Linked to SA5 TR 32.816 Study of Management for LTE and SAE (UID_340036) / Text3: 32.821
- 761: SP#45 completed. Linked to SA5 TR 32.816 Study of Management for LTE and SAE (UID_340036) / Text3: 32.823
- 762: SP#44 completed. Spin-off implementation WI UID_440064 Service Oriented Architecture (SOA) for IRP / Text3: 32.824
- 763: RP#46 completed / Text3: 25.907
- 764: RP#47 completed / Text3: 36.913 , new 36.814, 36.912, R2 36.806 (Relay architectures for E-UTRA), R4 36.815 (LTE-Advanced feasibility studies in RAN4)
- 765: RP#46 completed / Text3: 25.866
- 766: RP#44 closed (RP-090452 R1 LS to RAN on Conclusions for LTE Mobility Study Item - no further Rel-9 action / no TR needed) / Text3: none
- 767: RP#46 completed / Text3: 36.805
- 768: RP#44 completed. Linked to UID_420008 LTE FDD Home eNodeB RF Requirements. Spin-off RAN3 UID_440015 Study on Enhanced Interference Management Mechanisms for HNBs / Text3: 25.967
- 769: RP#45 completed. Triggered by RAN4 UID_430027 Study on Enhanced Interference Management for HNBs / Text3: 25.967
- 770: SP#45 work stopped/abandoned / Text3: 33.9xx
- 771: -

| ID | WBS | Task | Duration | Start | Finish | Complete | Remaining | Baseline start | Baseline finish | Baseline duration | Total slack | Constraint | Resources | Work | Actual work | Text1 | Text4 | Text5 | Text6 | Text8 | Text7 | Text2 |
| --- | --- | --- | --- | --- | --- | --- | --- | --- | --- | --- | --- | --- | --- | --- | --- | --- | --- | --- | --- | --- | --- | --- |
| 772 | 309 | **3GPP System Architecture Evolution Specification - Evolved Packet System (non RAN aspects)** | 1344d? | 2006-04-12 A | 2011-06-03 | 99% | 0.46d? | 2006-04-12 | 2011-06-03 | 1344d? | 465d |  | SP,CP | 268148h | 265426h | SAES | T-Mobile | michael.kurz@t-mobile.at | Rel-8 | Alain |  |  |
| 773 | 309.1 | Requirements for evolution of the 3GPP system architecture | 395d? | 2006-06-08 A | 2007-12-12 A | 100% |  | 2006-06-08 | 2007-12-12 | 395d? |  | finish no earlier than 2007-11-30 | S1 | 3160h | 3160h | AIPN-SAE | T-Mobile | michael.kurz@t-mobile.at | Rel-8 | Alain |  |  |
| 774 | 309.2 | **High level and common (for all accesses) functions** | 629d? | 2007-01-02 A | 2009-05-29 A | 100% |  | 2007-01-02 | 2009-05-29 | 629d? |  |  | SP,CP | 42536h | 42536h | EPS-ComF | Nokia Siemens Networks | balazs.bertenyi@nsn.com | Rel-8 | Maurice | SP-37 |  |
| 775 | 309.2.1 | Stage 2 for High level functions | 370d? | 2007-01-02 A | 2008-06-02 A | 100% |  | 2007-01-02 | 2008-06-02 | 370d? |  | finish no earlier than 2008-06-02 | S2 | 2960h | 2960h | SAES-SA-HLF | Motorola | Irfan.Ali@motorola.com | Rel-8 | Maurice |  |  |
| 776 | 309.2.2 | Stage 2 Security Architecture | 197d? | 2008-03-12 A | 2008-12-11 A | 100% |  | 2008-03-12 | 2008-12-11 | 197d? |  | finish no earlier than 2008-12-11 | S3 | 1576h | 1576h | SAES | Nokia Siemens Networks | marc.blommaert.ext@nsn.com | Rel-8 | Dionisio | SP-39 | PCG-21 |
| 777 | 309.2.3 | Stage 3 (CT1) for SAE impact on services, network functions and capabilities | 545d? | 2007-02-05 A | 2009-03-06 A | 100% |  | 2007-02-05 | 2009-03-06 | 545d? |  | finish no earlier than 2009-03-06 | C1 | 4360h | 4360h | SAES | Nokia Siemens Networks | robert.zaus@nsn.com | Rel-8 | Frederic |  |  |
| 778 | 309.2.4 | Stage 3 SAE impact on existing capabilities | 480d? | 2007-02-05 A | 2008-12-05 A | 100% |  | 2007-02-05 | 2008-12-05 | 480d? |  | finish no earlier than 2008-12-12 | C3 | 3840h | 3840h | SAES | Huawei | Wei Weihua (weiwh@huawei.com) | Rel-8 | Jiwan |  |  |
| 779 | 309.2.5 | Stage 3 (CT4) of SAE impact on existing capabilities | 545d? | 2007-02-05 A | 2009-03-06 A | 100% |  | 2007-02-05 | 2009-03-06 | 545d? |  | finish no earlier than 2009-03-06 | C4 | 4360h | 4360h | SAES | Huawei | shahab.lavasani@huawei.com | Rel-8 | Kimmo |  |  |
| 780 | 309.2.6 | Stage 2/3 for Network selection procedures | 480d? | 2007-02-05 A | 2008-12-05 A | 100% |  | 2007-02-05 | 2008-12-05 | 480d? |  | finish no earlier than 2009-03-06 | C1 | 3840h | 3840h | SAES | Nokia Siemens Networks | robert.zaus@nsn.com | Rel-8 | Frederic |  |  |
| 781 | 309.2.7 | Stage 3 EPC interworking with external PDNs (SGi) | 605d? | 2007-02-05 A | 2009-05-29 A | 100% |  | 2007-02-05 | 2009-05-29 | 605d? |  | finish no earlier than 2009-05-29 | C3 | 4840h | 4840h | SAES-St3-intwk | Huawei | Wei Weihua (weiwh@huawei.com) | Rel-8 | Jiwan |  |  |
| 782 | 309.2.8 | Stage 3 PCC within SAE | 605d? | 2007-02-05 A | 2009-05-29 A | 100% |  | 2007-02-05 | 2009-05-29 | 605d? |  | finish no earlier than 2009-05-29 | C3 | 4840h | 4840h | SAES-St3-PCC | Ericsson | j.javier.pastor@ericsson.com | Rel-8 | Jiwan |  |  |
| 783 | 309.2.9 | Stage 3 for SAE / LTE identities | 545d? | 2007-02-05 A | 2009-03-06 A | 100% |  | 2007-02-05 | 2009-03-06 | 545d? |  | finish no earlier than 2009-03-06 | C4 | 4360h | 4360h | SAES | Huawei | shahab.lavasani@huawei.com | Rel-8 | Kimmo |  |  |
| 784 | 309.2.10 | Unified guidelines for Diameter usage within 3GPP | 316d? | 2007-09-21 A | 2008-12-05 A | 100% |  | 2007-09-21 | 2008-12-05 | 316d? |  | finish no earlier than 2008-12-05 | C3 | 2528h | 2528h | SAES-DIAM | Huawei | Javier Gonzalez Gallego | Rel-8 | Jiwan | CP-37 |  |
| 785 | 309.3 | **SAE for LTE access** | 569d? | 2007-01-02 A | 2009-03-06 A | 100% |  | 2007-01-02 | 2009-03-06 | 569d? |  |  | S2,C1,C3,C4 | 57824h | 57824h | SAES-LTE | Motorola | Irfan.Ali@motorola.com | Rel-8 | Maurice |  |  |
| 786 | 309.3.1 | CT4 Stage 3 for protocol between EPCs | 545d? | 2007-02-05 A | 2009-03-06 A | 100% |  | 2007-02-05 | 2009-03-06 | 545d? |  | finish no earlier than 2009-03-06 | C4 | 4360h | 4360h | SAES | Huawei | shahab.lavasani@huawei.com | Rel-8 | Kimmo |  |  |
| 787 | 7.2.2.1 | **SAES-SA-FP_LTE with GTP variant** | 569d? | 2007-01-02 A | 2009-03-06 A | 100% |  | 2007-01-02 | 2009-03-06 | 569d? |  |  | S2,C4 | 11896h | 11896h | SAES-SA-FP_LTE-GTP | Nokia Siemens Networks | balazs.bertenyi@nsn.com | Rel-8 | Maurice |  |  |
| 788 | 309.3.2.1 | Stage 2 for SAES-SA-FP_LTE with GTP variant | 373d? | 2007-01-02 A | 2008-06-05 A | 100% |  | 2007-01-02 | 2008-06-05 | 373d? |  | finish no earlier than 2008-06-02 | S2 | 2984h | 2984h | SAES-SA-FP_LTE-GTP-St2 | Nokia Siemens Networks | balazs.bertenyi@nsn.com | Rel-8 | Maurice |  |  |
| 789 | 309.3.2.2 | CT4 Stage 3 for GTP v2 protocol | 545d? | 2007-02-05 A | 2009-03-06 A | 100% |  | 2007-02-05 | 2009-03-06 | 545d? |  | finish no earlier than 2009-03-06 | C4 | 4360h | 4360h | SAES | Huawei | shahab.lavasani@huawei.com | Rel-8 | Kimmo |  |  |
| 790 | 7.2.2.2 | **SAES-SA-FP_LTE with PMIP variant** | 569d? | 2007-01-02 A | 2009-03-06 A | 100% |  | 2007-01-02 | 2009-03-06 | 569d? |  |  | S2,C4 | 15736h | 15736h | SAES-SA-FP_LTE-IETF | Nokia Siemens Networks | balazs.bertenyi@nsn.com | Rel-8 | Maurice |  |  |
| 791 | 309.3.3.1 | Stage 2 for SAES-SA-FP_LTE with PMIP variant | 373d? | 2007-01-02 A | 2008-06-05 A | 100% |  | 2007-01-02 | 2008-06-05 | 373d? |  | finish no earlier than 2008-06-02 | S2 | 2984h | 2984h | SAES-SA-FP_LTE-IETF-St2 | Nokia Siemens Networks | balazs.bertenyi@nsn.com | Rel-8 | Maurice |  |  |
| 792 | 309.3.3.2 | CT4 Stage 3 for PMIP protocol within EPC | 545d? | 2007-02-05 A | 2009-03-06 A | 100% |  | 2007-02-05 | 2009-03-06 | 545d? |  | finish no earlier than 2009-03-06 | C4 | 4360h | 4360h | SAES | Huawei | shahab.lavasani@huawei.com | Rel-8 | Kimmo | CP-37 |  |
| 793 | 309.3.3.3 | Mobile IPv4 (MIPv4) based Mobility protocols | 480d? | 2007-02-05 A | 2008-12-05 A | 100% |  | 2007-02-05 | 2008-12-05 | 480d? |  | finish no earlier than 2008-12-05 | C4 | 3840h | 3840h | SAES | Motorola | Lewis Milton | Rel-8 | Kimmo | CP-41 |  |
| 794 | 309.3.4 | Stage 3 for UE NAS mobility procedures in idle and active mode | 545d? | 2007-02-05 A | 2009-03-06 A | 100% |  | 2007-02-05 | 2009-03-06 | 545d? |  | finish no earlier than 2009-03-06 | C1 | 4360h | 4360h | SAES | Nokia Siemens Networks | robert.zaus@nsn.com | Rel-8 | Frederic |  |  |
| 795 | 309.3.5 | Stage 3 for Session management, bearer control and QoS aspects | 545d? | 2007-02-05 A | 2009-03-06 A | 100% |  | 2007-02-05 | 2009-03-06 | 545d? |  | finish no earlier than 2009-03-06 | C1 | 4360h | 4360h | SAES | Nokia Siemens Networks | robert.zaus@nsn.com | Rel-8 | Frederic |  |  |
| 796 | 309.3.6 | Stage 3 for security aspects of LTE Access | 545d? | 2007-02-05 A | 2009-03-06 A | 100% |  | 2007-02-05 | 2009-03-06 | 545d? |  | finish no earlier than 2009-03-06 | C1 | 4360h | 4360h | SAES | Nokia Siemens Networks | robert.zaus@nsn.com | Rel-8 | Frederic |  |  |
| 797 | 309.3.7 | Stage 3 for QoS mechanisms | 480d? | 2007-02-05 A | 2008-12-05 A | 100% |  | 2007-02-05 | 2008-12-05 | 480d? |  | finish no earlier than 2008-12-12 | C3 | 3840h | 3840h | SAES | Ericsson | j.javier.pastor@ericsson.com | Rel-8 | Jiwan |  |  |
| 798 | 309.3.8 | Stage 3 for EPC - HSS interface | 545d? | 2007-02-05 A | 2009-03-06 A | 100% |  | 2007-02-05 | 2009-03-06 | 545d? |  | finish no earlier than 2009-03-06 | C4 | 4360h | 4360h | SAES | Huawei | shahab.lavasani@huawei.com | Rel-8 | Kimmo |  |  |

Notes:
- 772: SP#39 WID updated SP-070933=>SP-080132. Role model for SAE/LTE system wide project management by SA2 in SP-060166
- 773: SP#38 completed / Text3: 22.011, 22.246, new 22.278
- 774: CP#44 completed
- 775: SP#40 completed / Text3: new 23.402
- 776: SP#42 completed / Text3: 33.210, 33.310, new 33.401
- 777: CP#43 completed / Text3: 24.229, 27.007, new 24.305
- 778: CP#42 completed / Text3: 29.061
- 779: CP#43 completed / Text3: new (29.274, 29.275)
- 780: CP#42 completed / Text3: 23.122, new 24.302
- 781: CP#44 completed / Text3: 29.061
- 782: CP#44 completed / Text3: 29.212, 29.213, 29.214, new 29.215
- 783: CP#43 completed / Text3: 23.003
- 784: CP#42 completed / Text3: new 29.909
- 785: CP#43 completed
- 786: CP#43 completed / Text3: 29.274, 29.275
- 787: CP#43 completed
- 788: SP#40 completed / Text3: 23.401, 23.060, 23.002, 23.246, 23.203, 23.107, 23.234, 23.271
- 789: CP#43 completed / Text3: 29.274
- 790: CP#43 completed
- 791: SP#40 completed
- 792: CP#43 completed / Text3: 29.275, 29.282
- 793: CP#42 completed / Text3: 29.279
- 794: CP#43 completed / Text3: 24.007, 24.301
- 795: CP#43 completed / Text3: 24.007, 24.301
- 796: CP#43 completed / Text3: 24.008, 24.301
- 797: CP#42 completed / Text3: 29.213
- 798: CP#43 completed / Text3: 29.272

| ID | WBS | Task | Type | Duration | Start | Finish | Complete | Baseline start | Baseline finish | Baseline duration | Constraint | Resources | Work | Actual work | Text1 | Text4 | Text5 | Text6 | Text8 | Text3 | Text7 | Text2 | Text12 |
| --- | --- | --- | --- | --- | --- | --- | --- | --- | --- | --- | --- | --- | --- | --- | --- | --- | --- | --- | --- | --- | --- | --- | --- |
| 799 | 309.4 | **SAE for Interoperation between LTE and legacy cellular PS accesses** |  | 545d? | 2007-02-05 A | 2009-03-06 A | 100% | 2007-02-05 | 2009-03-06 | 545d? |  | S2,C1,C4 | 40152h | 40152h | SAES-SA-FP_3GPP | Motorola | Irfan.Ali@motorola.com | Rel-8 | Maurice |  |  |  |  |
| 800 | 309.4.1 | Stage 2 for Interoperation between LTE and 2G/3G |  | 424d? | 2007-02-05 A | 2008-09-18 A | 100% | 2007-02-05 | 2008-09-18 | 424d? | finish no earlier than 2008-09-11 | S2 | 3392h | 3392h | EPSto2_3G | Motorola | Irfan.Ali@motorola.com | Rel-8 | Maurice | 23.401, 23.402 | SP-37 |  |  |
| 801 | 309.4.2 | Stage 3 for Inter-system mobility between E-UTRAN and 2G/3G |  | 545d? | 2007-02-05 A | 2009-03-06 A | 100% | 2007-02-05 | 2009-03-06 | 545d? | finish no earlier than 2009-03-06 | C1 | 4360h | 4360h | SAES | Nokia Siemens Networks | robert.zaus@nsn.com | Rel-8 | Frederic | 24.008, 24.301 | CP-38 | PCG-21 |  |
| 802 | 309.4.3 | Stage 2 GPRS enhancements for LTE access |  | 272d? | 2007-09-04 A | 2008-09-18 A | 100% | 2007-09-04 | 2008-09-18 | 272d? | start no earlier than 2007-09-04 | S2 | 2176h | 2176h | SAES-GPRS_LTE | Vodafone | chris.pudney@vodafone.com | Rel-8 | Maurice | 23.401 |  |  |  |
| 803 | 309.4.4 | Stage 2 GPRS for EPC (23.060, etc.) |  | 179d? | 2008-01-14 A | 2008-09-18 A | 100% | 2008-01-14 | 2008-09-18 | 179d? | finish no earlier than 2008-09-18 | S2 | 1432h | 1432h | SAES | Nokia Siemens Networks | balazs.bertenyi@nsn.com | Rel-8 | Maurice | 23.060 | SP-39 | PCG-21 |  |
| 804 | 309.4.5 | Stage 3 for EPC - GPRS |  | 545d? | 2007-02-05 A | 2009-03-06 A | 100% | 2007-02-05 | 2009-03-06 | 545d? | finish no earlier than 2009-03-06 | C4 | 4360h | 4360h | SAES | Huawei | shahab.lavasani@huawei.com | Rel-8 | Kimmo | 29.274, 29.275, 29.281 |  |  |  |
| 805 | 309.4.6 | Stage 3 for EPC to UTRAN |  | 545d? | 2007-02-05 A | 2009-03-06 A | 100% | 2007-02-05 | 2009-03-06 | 545d? | finish no earlier than 2009-03-06 | C4 | 4360h | 4360h | SAES | Huawei | shahab.lavasani@huawei.com | Rel-8 | Kimmo | 29.274, 29.275, 29.281 | CP-38 | PCG-21 |  |
| 806 | 309.4.7 | Stage 3 for EPC to 3GPP2 |  | 545d? | 2007-02-05 A | 2009-03-06 A | 100% | 2007-02-05 | 2009-03-06 | 545d? | finish no earlier than 2009-03-06 | C4 | 4360h | 4360h | SAES | Huawei | shahab.lavasani@huawei.com | Rel-8 | Kimmo | 29.277, 29.276 | CP-38 | PCG-21 |  |
| 807 | 309.4.8 | Stage 2 for Interoperation between LTE and CDMA2000 |  | 329d? | 2007-06-18 A | 2008-09-18 A | 100% | 2007-06-18 | 2008-09-18 | 329d? | finish no earlier than 2008-04-25 | S2 | 2632h | 2632h | EPStoC2k | Motorola, Vodafone | Irfan.Ali@motorola.com, chris.pudney@vodafone.com | Rel-8 | Maurice | 23.401, 23.402 | CP-37 |  |  |
| 808 | 309.4.9 | Stage 3 for Inter-system mobility between E-UTRAN and CDMA2000 |  | 545d? | 2007-02-05 A | 2009-03-06 A | 100% | 2007-02-05 | 2009-03-06 | 545d? | finish no earlier than 2009-03-06 | C1 | 4360h | 4360h | SAES | Nokia Siemens Networks | robert.zaus@nsn.com | Rel-8 | Frederic | 24.301, 24.302 |  |  |  |
| 809 | 309.4.10 | Stage 3 for MME - SGSN signalling free protocol |  | 545d? | 2007-02-05 A | 2009-03-06 A | 100% | 2007-02-05 | 2009-03-06 | 545d? | finish no earlier than 2009-03-06 | C4 | 4360h | 4360h | SAES | Huawei | shahab.lavasani@huawei.com | Rel-8 | Kimmo | 29.272, 29.274 |  |  |  |
| 810 | 309.5 | **SAE for support for non-3GPP accesses** |  | 569d? | 2007-01-02 A | 2009-03-06 A | 100% | 2007-01-02 | 2009-03-06 | 569d? |  | S2,S3,C1,C4 | 53872h | 53872h | SAES-SA-FP_n3GPP | Motorola | Irfan.Ali@motorola.com | Rel-8 | Maurice |  |  |  |  |
| 811 | 7.2.4.1 | Stage 2 for Host-based Mobility aspects |  | 373d? | 2007-01-02 A | 2008-06-05 A | 100% | 2007-01-02 | 2008-06-05 | 373d? | finish no earlier than 2008-04-11 | S2 | 2984h | 2984h | SAES-SA-FP_n3GPP-HBMob | Motorola | Irfan.Ali@motorola.com | Rel-8 | Maurice | 23.402 |  |  |  |
| 812 | 7.2.4.2 | Stage 2 for Network-based Mobility aspects |  | 448d? | 2007-01-02 A | 2008-09-18 A | 100% | 2007-01-02 | 2008-09-18 | 448d? | finish no earlier than 2008-09-18 | S2 | 3584h | 3584h | SAES-SA-FP_n3GPP-NBMob | Motorola | Irfan.Ali@motorola.com | Rel-8 | Maurice | 23.402 |  |  |  |
| 813 | 309.5.3 | Stage 3 for Mobility management based on DSMIPv6 |  | 480d? | 2007-02-05 A | 2008-12-05 A | 100% | 2007-02-05 | 2008-12-05 | 480d? | finish no earlier than 2008-12-05 | C1 | 3840h | 3840h | SAES | Nokia Siemens Networks | robert.zaus@nsn.com | Rel-8 | Frederic | 24.303 |  |  |  |
| 814 | 309.5.4 | Stage 3 for Mobility management based on MIP v4 |  | 480d? | 2007-02-05 A | 2008-12-05 A | 100% | 2007-02-05 | 2008-12-05 | 480d? | start no earlier than 2007-02-05 | C1 | 3840h | 3840h | SAES | Nokia Siemens Networks | robert.zaus@nsn.com | Rel-8 | Frederic | 24.304 | CP-39 | PCG-21 |  |
| 815 | 309.5.5 | Stage 3 for Inter-system mobility between E-UTRAN and non 3GPP accesses |  | 545d? | 2007-02-05 A | 2009-03-06 A | 100% | 2007-02-05 | 2009-03-06 | 545d? | finish no earlier than 2009-03-06 | C1 | 4360h | 4360h | SAES | Nokia Siemens Networks | robert.zaus@nsn.com | Rel-8 | Frederic | 24.008, 24.301 | CP-38 | PCG-21 |  |
| 816 | 309.5.6 | Stage 2 for Optimized Dual-Radio Handover with WiMAX |  | 249d? | 2007-06-25 A | 2008-06-05 A | 100% | 2007-06-25 | 2008-06-05 | 249d? | finish no earlier than 2008-06-09 | S2 | 1992h | 1992h | SAES-SA-FP_n3GPP-OptWIMAX | Motorola | Irfan.Ali@motorola.com | Rel-8 | Maurice | 23.402 |  |  |  |
| 817 | 309.5.7 | Stage 2 Security aspects for non-3GPP Access |  | 197d? | 2008-03-12 A | 2008-12-11 A | 100% | 2008-03-12 | 2008-12-11 | 197d? | finish no earlier than 2008-12-11 | S3 | 1576h | 1576h | SAES | Nokia Siemens Networks | marc.blommaert.ext@nsn.com | Rel-8 | Dionisio | 33.402, 33.210, 33.310 | SP-39 | PCG-21 |  |
| 818 | 309.5.8 | Stage 3 security aspects for DSMIPv6 Access |  | 480d? | 2007-02-05 A | 2008-12-05 A | 100% | 2007-02-05 | 2008-12-05 | 480d? | finish no earlier than 2008-12-05 | C1 | 3840h | 3840h | SAES | Nokia Siemens Networks | robert.zaus@nsn.com | Rel-8 | Frederic | 24.303 | CP-37 |  |  |
| 819 | 309.5.9 | Stage 3 security aspects for MIPv4 Access |  | 480d? | 2007-02-05 A | 2008-12-05 A | 100% | 2007-02-05 | 2008-12-05 | 480d? | finish no earlier than 2008-12-05 | C1 | 3840h | 3840h | SAES | Nokia Siemens Networks | robert.zaus@nsn.com | Rel-8 | Frederic | 24.304 | CP-39 | PCG-21 |  |
| 820 | 309.5.10 | Stage 3 for Access to the EPC via non-3GPP access networks |  | 545d? | 2007-02-05 A | 2009-03-06 A | 100% | 2007-02-05 | 2009-03-06 | 545d? | finish no earlier than 2009-03-06 | C1 | 4360h | 4360h | SAES | Nokia Siemens Networks | robert.zaus@nsn.com | Rel-8 | Frederic | 24.302, 24.312 |  |  |  |
| 821 | 309.5.11 | Stage 3 for interfaces within EPC |  | 383d? | 2007-09-19 A | 2009-03-06 A | 100% | 2007-09-19 | 2009-03-06 | 383d? | finish no earlier than 2009-03-06 | C4 | 3064h | 3064h | SAES | Huawei | shahab.lavasani@huawei.com | Rel-8 | Kimmo | 29.274, 29.281 | CP-37 |  |  |
| 822 | 309.5.12 | Stage 3 for Interfaces EPC - non-3GPP IP access |  | 545d? | 2007-02-05 A | 2009-03-06 A | 100% | 2007-02-05 | 2009-03-06 | 545d? | finish no earlier than 2009-03-06 | C4 | 4360h | 4360h | SAES | Huawei | shahab.lavasani@huawei.com | Rel-8 | Kimmo | 29.273, 29.275 |  |  |  |
| 823 | 309.5.13 | Stage 3 for AAA/HSS related |  | 480d? | 2007-02-05 A | 2008-12-05 A | 100% | 2007-02-05 | 2008-12-05 | 480d? | finish no earlier than 2008-12-05 | C4 | 3840h | 3840h | SAES | Huawei | shahab.lavasani@huawei.com | Rel-8 | Kimmo | 29.273 |  |  |  |
| 824 | 309.5.14 | Stage 3 for EPC - AAA interface |  | 480d? | 2007-02-05 A | 2008-12-05 A | 100% | 2007-02-05 | 2008-12-05 | 480d? | finish no earlier than 2008-12-05 | C4 | 3840h | 3840h | SAES | Huawei | shahab.lavasani@huawei.com | Rel-8 | Kimmo | 29.273 |  |  |  |
| 825 | 309.5.15 | Deleted (already covered) SAES-SA-FP_n3GPP Optimized Handover with CDMA | milestone | 0d? | 2007-06-25 A | 2007-06-25 A | 100% | 2007-06-25 | 2007-06-25 | 0d? | finish no earlier than 2007-06-25 | S2 |  |  | SAES-SA-FP_n3GPP-OptCDMA | Nokia Siemens Networks |  | Rel-8 | Maurice |  |  |  | SP-37 |

Notes:
- 799: CP#43 completed
- 800: SP#41 completed
- 801: CP#43 completed
- 802: SP#41 completed
- 803: SP#41 completed
- 804: CP#43 completed
- 805: CP#43 completed
- 806: CP#43 completed
- 807: SP#41 completed (except: Handover of multiple PDNs=>Rel-9)
- 808: CP#43 completed
- 809: CP#43 completed
- 810: CP#43 completed. SP#39 retained in Rel-8 (in addition to the essential functionality defined in SP-070699). Replaces UID_340037
- 811: SP#40 completed
- 812: SP#41 completed
- 813: CP#42 completed
- 814: CP#42 completed
- 815: CP#43 completed
- 816: SP#40 completed
- 817: SP#42 completed
- 818: CP#42 completed
- 819: CP#42 completed
- 820: CP#43 completed
- 821: CP#43 completed
- 822: CP#43 completed
- 823: CP#42 completed
- 824: CP#42 completed
- 825: SP#37 stopped

| ID | WBS | Task | Type | Duration | Start | Finish | Complete | Remaining | Baseline start | Baseline finish | Baseline duration | Total slack | Constraint | Resources | Work | Actual work | Text1 | Text4 | Text6 | Text8 | Text2 | Text7 | Text9 | Text12 | Text11 |
| --- | --- | --- | --- | --- | --- | --- | --- | --- | --- | --- | --- | --- | --- | --- | --- | --- | --- | --- | --- | --- | --- | --- | --- | --- | --- |
| 826 | 309.6 | **Single Radio Voice Call Continuity for 3GPP (SRVCC)** |  | 569d? | 2007-01-02 A | 2009-03-06 A | 100% |  | 2007-01-02 | 2009-03-06 | 569d? |  |  | S2,C1,C4 | 10752h | 10752h | SAES-SRVCC | Nokia Siemens Networks | Rel-8 | Maurice |  |  |  |  |  |
| 827 | 309.6.1 | Stage 2 for 2G/3G SRVCC |  | 448d? | 2007-01-02 A | 2008-09-18 A | 100% |  | 2007-01-02 | 2008-09-18 | 448d? |  | finish no earlier than 2008-09-15 | S2 | 3584h | 3584h | SAES-SRVCC | Nokia Siemens Networks | Rel-8 | Maurice |  |  |  |  |  |
| 828 | 309.6.2 | Stage 3 for SRVCC in EPS |  | 201d? | 2008-05-30 A | 2009-03-06 A | 100% |  | 2008-05-30 | 2009-03-06 | 201d? |  | finish no earlier than 2009-03-06 | C1 | 1608h | 1608h | SAES-SRVCC | Nokia Siemens Networks | Rel-8 | Frederic | PCG-21 | CP-41 |  |  |  |
| 829 | 309.6.3 | MME to MSC interface for SRVCC |  | 126d? | 2008-09-12 A | 2009-03-06 A | 100% |  | 2008-09-12 | 2009-03-06 | 126d? |  | finish no earlier than 2009-03-06 | C4 | 1008h | 1008h | SAES-SRVCC | Nokia Siemens Networks | Rel-8 | Kimmo | PCG-21 | CP-41 |  |  |  |
| 830 | 309.7 | Voice Call Continuity for CDMA2000 1X |  | 249d? | 2007-06-25 A | 2008-06-05 A | 100% |  | 2007-06-25 | 2008-06-05 | 249d? |  | finish no earlier than 2008-06-13 | S2 | 1992h | 1992h | SAES-VCC_1X | Nokia Siemens Networks | Rel-8 | Maurice |  |  |  |  |  |
| 831 | 309.8 | SAE impacts on IMS |  | 373d? | 2007-01-02 A | 2008-06-05 A | 100% |  | 2007-01-02 | 2008-06-05 | 373d? |  | finish no earlier than 2008-06-13 | S2 | 2984h | 2984h | SAES-SA_IMS | Nokia Siemens Networks | Rel-8 | Maurice |  |  |  |  |  |
| 832 | 309.9 | **CS Fallback in EPS** |  | 258d? | 2008-03-12 A | 2009-03-06 A | 100% |  | 2008-03-12 | 2009-03-06 | 258d? |  |  | S2,C1,C4 | 4800h | 4800h | SAES-CSFB | T-Mobile, Vodafone | Rel-8 | Maurice | PCG-21 | SP-39 |  |  |  |
| 833 | 309.9.1 | Stage 2 for CS Fallback in EPS |  | 62d? | 2008-03-12 A | 2008-06-05 A | 100% |  | 2008-03-12 | 2008-06-05 | 62d? |  | finish no earlier than 2008-12-05 | S2 | 496h | 496h | SAES-CSFB | T-Mobile, Vodafone | Rel-8 | Maurice | PCG-21 | SP-40 |  |  |  |
| 834 | 309.9.2 | Stage 3 for CS Fallback in EPS |  | 201d? | 2008-05-30 A | 2009-03-06 A | 100% |  | 2008-05-30 | 2009-03-06 | 201d? |  | finish no earlier than 2009-03-06 | C1 | 1608h | 1608h | SAES-CSFB | NEC | Rel-8 | Frederic | PCG-21 | CP-40 |  |  |  |
| 835 | 309.9.3 | Stage 3 for CS Fallback in EPS |  | 136d? | 2008-05-30 A | 2008-12-05 A | 100% |  | 2008-05-30 | 2008-12-05 | 136d? |  | finish no earlier than 2008-12-05 | C4 | 1088h | 1088h | SAES-CSFB | NEC | Rel-8 | Kimmo | PCG-21 | CP-40 |  |  |  |
| 836 | 309.10 | System enhancements for the use of IMS services in local breakout |  | 62d? | 2008-03-12 A | 2008-06-05 A | 100% |  | 2008-03-12 | 2008-06-05 | 62d? |  | finish no earlier than 2008-06-05 | S2 | 496h | 496h | SAES-IMS_LBO | Telecom Italia | Rel-8 | Maurice | PCG-21 | SP-39 |  |  |  |
| 837 | 309.11 | **EPC Data Definitions** |  | 309d? | 2008-01-07 A | 2009-03-12 A | 100% |  | 2008-01-07 | 2009-03-12 | 309d? |  |  | S5 | 7144h | 7144h | EPC-OAM |  | Rel-8 | Dionisio | PCG-21 | SP-39 |  |  |  |
| 838 | 309.11.1 | EPC Network Resource Model (NRM) Integration Reference Point (IRP) |  | 309d? | 2008-01-07 A | 2009-03-12 A | 100% |  | 2008-01-07 | 2009-03-12 | 309d? |  | finish no earlier than 2009-03-12 | S5 | 2472h | 2472h | EPC-OAM | Huawei | Rel-8 | Dionisio | PCG-21 | SP-38 |  |  |  |
| 839 | 309.11.2 | Performance measurements for EPC |  | 275d? | 2008-02-22 A | 2009-03-12 A | 100% |  | 2008-02-22 | 2009-03-12 | 275d? |  | finish no earlier than 2009-03-12 | S5 | 2200h | 2200h | EPC-OAM | China Mobile | Rel-8 | Dionisio | PCG-21 | SP-39 |  |  |  |
| 840 | 309.12 | EPC Charging |  | 309d? | 2008-01-07 A | 2009-03-12 A | 100% |  | 2008-01-07 | 2009-03-12 | 309d? |  | finish no earlier than 2009-03-12 | S5 | 2472h | 2472h | EPC-CH | Nokia Siemens Networks | Rel-8 | Dionisio | PCG-21 | SP-38 |  |  |  |
| 841 | 309.13 | Domain Name System Procedures for Evolved Packet System (DEPS) |  | 179.75d? | 2008-05-30 A | 2009-03-06 A | 100% |  | 2008-05-30 | 2009-03-06 | 179.75d? |  | finish no earlier than 2009-03-06 | C4 | 1438h | 1438h | SAES-DEPS | TeliaSonera | Rel-8 | Kimmo | PCG-21 | CP-40 |  |  |  |
| 842 | 309.14 | InterWorking Function (IWF) between MAP based and Diameter based interfaces |  | 126d? | 2008-09-12 A | 2009-03-06 A | 100% |  | 2008-09-12 | 2009-03-06 | 126d? |  | finish no earlier than 2009-03-06 | C4 | 1008h | 1008h | SAES-MAP2Diam | Huawei | Rel-8 | Kimmo | PCG-21 | CP-41 |  |  |  |
| 843 | 309.15 | **CT6 aspects of SAE** |  | 847d? | 2008-03-07 A | 2011-06-03 | 99% | 7.63d? | 2008-03-07 | 2011-06-03 | 847d? | 465d |  | C6 | 13480h | 13358.6h | SAES | Nokia | Rel-8 | Xavier | PCG-21 | SP-39 |  |  |  |
| 844 | 309.15.1 | CT6 aspects of SAE |  | 321d? | 2008-03-07 A | 2009-05-29 A | 100% |  | 2008-03-07 | 2009-05-29 | 321d? |  | finish no earlier than 2009-05-29 | C6 | 2568h | 2568h | SAES | Nokia | Rel-8 | Xavier | PCG-21 | CP-39 |  |  |  |
| 845 | 309.15.2 | Test interworking of LTE Terminals with the USIM |  | 526d? | 2008-12-05 A | 2010-12-10 A | 100% |  | 2008-12-05 | 2010-12-10 | 526d? |  | finish no earlier than 2010-12-10 | C6 | 4208h | 4208h | SAES-USIM_LTE-Test | Comprion | Rel-8 | Xavier | PCG-22 | CP-42 |  |  |  |
| 846 | 309.15.3 | Test interworking of IP Multimedia Services Identity Module (ISIM) terminals with IP Multimedia Subsystem (IMS) |  | 186d? | 2010-09-17 A | 2011-06-03 | 95% | 9.3d? | 2010-09-17 | 2011-06-03 | 186d? | 465d | finish no earlier than 2011-06-03 | C6 | 1488h | 1413.6h | SAES-ISIM_IMS_Test | Comprion | Rel-8 | Xavier | PCG-25 | CP-49 |  |  |  |
| 847 | 309.16 | Issues for CT1 TR 24.801 |  | 420d? | 2007-01-04 A | 2008-12-05 A | 100% |  | 2007-01-04 | 2008-12-05 | 420d? |  | finish no earlier than 2008-12-05 | C1 | 3360h | 3360h | SAES | Nokia Siemens Networks | Rel-8 | Frederic | PCG-21 | CP-39 |  |  |  |
| 848 | 309.17 | Issues for CT3 TR 29.804 |  | 420d? | 2007-02-05 A | 2008-09-12 A | 100% |  | 2007-02-05 | 2008-09-12 | 420d? |  | finish no earlier than 2008-12-12 | C3 | 3360h | 3360h | SAES | Ericsson | Rel-8 | Jiwan | PCG-21 | CP-39 |  |  |  |
| 849 | 309.18 | Deleted - Issues for CT4 TR 29.803 |  | 420d? | 2007-01-04 A | 2008-09-12 A | 100% |  | 2007-01-04 | 2008-09-12 | 420d? |  | finish no earlier than 2008-12-11 | C4 | 3360h | 3360h | SAES | Huawei | Rel-8 | Kimmo | PCG-21 | CP-39 | PCG-21 | CP-41 |  |
| 850 | 309.19 | Deleted (covered by 380068): Functions and procedures for SAE to support LCS | milestone | 0d? | 2008-03-03 A | 2008-03-03 A | 100% |  | 2008-03-03 | 2008-03-03 | 0d? |  | finish no earlier than 2008-03-03 | S2 |  |  | SAES-SA-FP_LCS | Nokia Siemens Networks | Rel-8 | Maurice |  |  |  | SP-37 |  |
| 851 | 309.20 | Deleted (covered by 380064): SAE aspects of Emergency Calls | milestone | 0d? | 2008-03-03 A | 2008-03-03 A | 100% |  | 2008-03-03 | 2008-03-03 | 0d? |  | start no earlier than 2008-03-03 | S2 |  |  | SAES-SA-EmCall | Nokia Siemens Networks | Rel-8 | Maurice |  |  |  | SP-37 |  |
| 852 | 309.21 | Deleted - CT1 aspects of SAES |  | 16.7d? | 2007-09-04 A | 2007-09-27 A | 100% |  | 2007-09-04 | 2007-09-27 | 16.7d? |  | start no earlier than 2007-09-04 | CP,C1 | 133.62h | 133.62h | SAES-St3 |  | Rel-8 | Frederic |  |  |  | SP-37 |  |
| 853 | 309.22 | Deleted - CT1 aspects of SAES | milestone | 0d? | 2007-09-04 A | 2007-09-04 A | 100% |  | 2007-09-04 | 2007-09-04 | 0d? |  | start no earlier than 2007-09-04 | C1 |  |  | SAES-St3 |  | Rel-8 | Frederic |  |  |  | SP-37 |  |
| 854 | 309.23 | Deleted - Interoperability | milestone | 0d? | 2008-03-14 A | 2008-03-14 A | 100% |  | 2008-03-14 | 2008-03-14 | 0d? |  | start no earlier than 2008-03-14 | C1 |  |  | SAES-St3-interop |  | Rel-8 | Frederic |  |  |  | SP-37 |  |
| 855 | 309.24 | Deleted - CT3 aspects of SAES | milestone | 0d? | 2007-09-04 A | 2007-09-04 A | 100% |  | 2007-09-04 | 2007-09-04 | 0d? |  | start no earlier than 2007-09-04 | C3 |  |  | SAES-St3 |  | Rel-8 | Jiwan |  |  |  | SP-37 |  |
| 856 | 309.25 | Deleted - CT4 aspects of SAES | milestone | 0d? | 2007-09-04 A | 2007-09-04 A | 100% |  | 2007-09-04 | 2007-09-04 | 0d? |  | start no earlier than 2007-09-04 | C4 |  |  | SAES-St3 |  | Rel-8 | Kimmo |  |  |  | SP-37 |  |
| 857 | 309.26 | Deleted - UE to EPC NAS signalling (incl. MBMS and QoS aspects) | milestone | 0d? | 2008-03-14 A | 2008-03-14 A | 100% |  | 2008-03-14 | 2008-03-14 | 0d? |  | start no earlier than 2008-03-14 | C1 |  |  | SAES-St3-sig |  | Rel-8 | Frederic |  |  |  | SP-37 |  |
| 858 | 309.27 | Deleted - User and Control plane protocols | milestone | 0d? | 2007-09-21 A | 2007-09-21 A | 100% |  | 2007-09-21 | 2007-09-21 | 0d? |  | start no earlier than 2007-09-21 | C4 |  |  | SAES-St3-prot |  | Rel-8 | Kimmo |  |  |  | SP-37 |  |
| 859 | 309.28 | Deleted - Architecture enhancements for non-3GPP accesses | milestone | 0d? | 2007-09-04 A | 2007-09-04 A | 100% |  | 2007-09-04 | 2007-09-04 | 0d? |  | start no earlier than 2007-09-04 | S2 |  |  | SAES-non_3GPP | Motorola | Rel-8 | Maurice |  |  |  | SP-34 |  |
| 860 | 309.29 | Deleted - Stage 2 of architecture for the 3GPP System Architecture Evolution | milestone | 0d? | 2007-10-02 A | 2007-10-02 A | 100% |  | 2007-10-02 | 2007-10-02 | 0d? |  | start no earlier than 2007-10-02 | S2 |  |  | SAES-St2 | Vodafone | Rel-8 | Maurice |  |  |  | SP-34 |  |
| 861 | 309.30 | Deleted - SA aspects of System Architecture Evolution |  | 384d? | 2006-04-12 A | 2007-10-01 A | 100% |  | 2006-04-12 | 2007-10-01 | 384d? |  | finish no earlier than 2007-10-02 | S2 | 3072h | 3072h | SAES-SA |  | Rel-8 | Maurice |  |  |  | SP-34 |  |
| 862 | 310 | Conformance Test Aspects – Mobility management based on DSMIPv6 (Dual-Stack Mobile IPv6) |  | 261d? | 2009-09-18 A | 2010-09-17 A | 100% |  | 2009-09-18 | 2010-09-17 | 261d? |  | finish no earlier than 2010-09-17 | R5 | 2088h | 2088h | DSMIPv6_UEConTest | Qualcomm | Rel-8 | Ingbert | PCG-23 | RP-45 |  |  | RP-100738 |

Notes:
- 826: CP#43 completed. SP#38 WID approved (extract from SAE WID SP-070817). / Text5: curt.c.wong@nokia.com
- 827: SP#41 completed. SP#38 WID approved / Text3: new 23.216 / Text5: curt.c.wong@nokia.com
- 828: CP#43 completed / Text3: 23.009, 24.008, new 24.301 / Text5: robert.zaus@nsn.com
- 829: CP#43 completed / Text3: 23.003, 23.008, new (29.274, 29.277, 29.280) / Text5: Giorgi Gulbani
- 830: SP#40 completed / Text5: balazs.bertenyi@nsn.com
- 831: SP#40 completed / Text5: balazs.bertenyi@nsn.com
- 832: CP#43 completed / Text5: sabine.demel@t-mobile.at, chris.pudney@vodafone.com
- 833: SP#40 completed / Text3: new (23.272, 23.401) / Text5: sabine.demel@t-mobile.at, chris.pudney@vodafone.com
- 834: CP#43 completed / Text3: 24.007, 24.008, 24.011, 29.018, new (24.301, 24.801, 29.118) / Text5: yannick.lair@nectech.fr
- 835: CP#42 completed / Text3: 23.007, 23.008, 29.274, new 29.277 / Text5: yannick.lair@nectech.fr
- 836: SP#40 completed / Text3: 23.228, 23.221, 23.203 / Text5: mario.madella@telecomitalia.it
- 837: SP#43 completed
- 838: SP#43 completed / Text3: new (32.751, 32.752, 32.753, 32.755) / Text5: WANG, Xuelong
- 839: SP#43 completed / Text3: new 32.426 / Text5: Li Jian (lijian@chinamobile.com), Liang Shuangchun (liangshuangchun@cmdi.chinamobile.com)
- 840: SP#43 completed / Text3: 32.240, 32.296, 32.251, 32.252, 32.298, 32.299 / Text5: Gerald.Goermer@nsn.com
- 841: CP#43 completed / Text3: 23.003, new 29.303 / Text5: jouni.korhonen@teliasonera.com
- 842: CP#43 completed. Triggered by UID_380023 (FS_MAP2Diam) / Text3: new 29.305 / Text5: liming49985@huawei.com
- 843: CP#44 completed core specification / Text5: Rune Lindholm
- 844: CP#44 completed (specified Network Measurement Results collection via USAT) / Text3: 31.102, 31.111 / Text5: Rune Lindholm
- 845: CP#50 completed. Steering of Roaming test cases have been introduced. Remaining issues CSG display testing (Provide Local Information, Call Control for EPS/PDN, Event Download (Access Technology Change - Multiple Access Technologies) / Text3: 31.121, 31.124 / Text5: Udo Willenbrink (uwillenbrink@comprion.com )
- 846: Linked to Rel-5 UID_1273 Provisioning of IP-based multimedia services (24.229, 31.103), Rel-8 UID_390021 CT6 aspects of SAE, UID_420018 Test interworking of LTE Terminals with the USIM, Rel-9 UID_450018 Testing SMS over IMS in E-UTRAN (34.229). / Text3: 31.121, 31.124, new TS 31.134 / Text5: Udo Willenbrink (uwillenbrink@comprion.com )
- 847: CP#43 completed / Text3: 24.801 / Text5: robert.zaus@nsn.com
- 848: CP#41 completed / Text3: 29.804 / Text5: j.javier.pastor@ericsson.com
- 849: CP#41 Work stopped and continued in Normative specifications / Text3: 29.803
- 850: SP#37 stopped
- 851: SP#37 stopped
- 852: SP#37 stopped
- 853: SP#37 stopped
- 854: SP#37 stopped
- 855: SP#37 stopped
- 856: SP#37 stopped / Text3: 29.803
- 857: SP#37 stopped
- 858: SP#37 stopped
- 859: SP#34 stopped. Replaced by UID_350027 and its children / Text3: 23.402 / Text5: Irfan.Ali@motorola.com
- 860: SP#34 stopped. Replaced by UIDs 340018 and 340037. (SP#34 report discussion of SP-060917.) / Text3: 23.002, 23.060, 23.107, 23.203, 23.228, 23.234, 23.246, 23.271, 23.279 / Text5: chris.pudney@vodafone.com
- 861: SP#34 stopped
- 862: RP#49 completed. Testing for CT1's UID_360022 (24.303) under Rel-8 Feature SAES / Text3: 36.508, 36.523-1, 36.523-2, 36.523-3 / Text5: Lena Chaponniere (lchaponn@qualcomm.com)

| ID | WBS | Task | Duration | Start | Finish | Complete | Baseline start | Baseline finish | Baseline duration | Constraint | Resources | Work | Actual work | Text1 | Text4 | Text5 | Text6 | Text7 | Text8 | Text2 | Text9 | Text12 |
| --- | --- | --- | --- | --- | --- | --- | --- | --- | --- | --- | --- | --- | --- | --- | --- | --- | --- | --- | --- | --- | --- | --- |
| 863 | 311 | **IMS Centralized Service Control (ICSRA)** | 395d? | 2007-09-03 A | 2009-03-06 A | 100% | 2007-09-03 | 2009-03-06 | 395d? |  | S1,S2,C1,C3,C4 | 10680h | 10680h | ICSRA | AT&T | Randolph Wohlert (rwohlert@tri.sbc.com) | Rel-8 | SP-37 | Alain |  |  |  |
| 864 | 311.1 | Stage 1 for ICSRA | 138d? | 2007-09-03 A | 2008-03-12 A | 100% | 2007-09-03 | 2008-03-12 | 138d? | finish no earlier than 2007-12-14 | S1 | 1104h | 1104h | ICSRA | AT&T | Randolph Wohlert (rwohlert@tri.sbc.com) | Rel-8 | SP-38 | Alain | PCG-21 |  |  |
| 865 | 311.2 | Stage 2 for ICSRA | 125d? | 2007-12-14 A | 2008-06-05 A | 100% | 2007-12-14 | 2008-06-05 | 125d? | start no earlier than 2007-12-14 | S2 | 1000h | 1000h | ICSRA-St2 | Alcatel-Lucent |  | Rel-8 | SP-38 | Maurice | PCG-21 |  |  |
| 866 | 311.3 | **Stage 3 for ICSRA – Protocol, Addressing, Subscriber Data** | 201d? | 2008-05-30 A | 2009-03-06 A | 100% | 2008-05-30 | 2009-03-06 | 201d? |  | C1,C3,C4 | 6520h | 6520h | ICSRA | Ericsson | sean.schneyer@ericsson.com | Rel-8 |  | Frederic |  |  |  |
| 867 | 311.3.1 | CT1 aspects - Stage 3 for ICSRA | 201d? | 2008-05-30 A | 2009-03-06 A | 100% | 2008-05-30 | 2009-03-06 | 201d? | finish no earlier than 2009-03-06 | C1 | 1608h | 1608h | ICSRA | Ericsson | Sean Schneyer | Rel-8 | CP-40 | Frederic | PCG-21 |  |  |
| 868 | 311.3.2 | CT3 aspects - Stage 3 for ICSRA | 201d? | 2008-05-30 A | 2009-03-06 A | 100% | 2008-05-30 | 2009-03-06 | 201d? | finish no earlier than 2009-03-06 | C3 | 1608h | 1608h | ICSRA | Mavenir | Brett Wallis ( brett@mavenir.com) | Rel-8 | CP-40 | Jiwan | PCG-21 |  |  |
| 869 | 311.3.3 | CT4 aspects - Stage 3 for ICSRA | 136d? | 2008-05-30 A | 2008-12-05 A | 100% | 2008-05-30 | 2008-12-05 | 136d? | start no earlier than 2008-05-30 | C4 | 1088h | 1088h | ICSRA | Ericsson | Sean Schneyer | Rel-8 | CP-40 | Kimmo | PCG-21 |  |  |
| 870 | 311.3.4 | Deleted - Stage 3 for ICSRA – I1 interface | 76d? | 2008-05-30 A | 2008-09-12 A | 100% | 2008-05-30 | 2008-09-12 | 76d? | finish no earlier than 2008-09-12 | C1 | 608h | 608h | ICSRA | Huawei | xupeili@huawei.com | Rel-8 | CP-40 | Frederic | PCG-21 | PCG-21 | CP-41 |
| 871 | 312 | **IMS Multimedia Telephony and Supplementary Services** | 487d? | 2007-05-02 A | 2009-03-12 A | 100% | 2007-05-02 | 2009-03-12 | 487d? |  | S1,S5,C1,C3,C4 | 46006.4h | 46006.4h | IMSTSS |  |  | Rel-8 | SP-37 | Alain |  |  |  |
| 872 | 312.1 | **General aspects of IMS Sup Services** | 395d? | 2007-09-03 A | 2009-03-06 A | 100% | 2007-09-03 | 2009-03-06 | 395d? |  | S1,C1,C3,C4 | 9752h | 9752h | IMSSS-Gal | Ericsson | Susana Sabater | Rel-8 | SP-37 | Alain |  |  |  |
| 873 | 312.1.1 | Service and Capability for Core IMS - inclusion of TISPAN requirements | 75d? | 2007-09-03 A | 2007-12-14 A | 100% | 2007-09-03 | 2007-12-14 | 75d? | finish no earlier than 2007-12-14 | S1 | 600h | 600h | TISCAPR8 | Ericsson | Susana Sabater | Rel-8 | SP-37 | Alain |  |  |  |
| 874 | 312.1.2 | Documentation of TISPAN R1 and R2 in CT1 | 208d? | 2007-11-28 A | 2008-09-12 A | 100% | 2007-11-28 | 2008-09-12 | 208d? | finish no earlier than 2008-09-12 | C1 | 1664h | 1664h | REDOC_TIS-C1 | Nokia Siemens Networks | peter.leis@nsn.com | Rel-8 | CP-38 | Frederic | PCG-21 |  |  |
| 875 | 312.1.3 | Documentation of TISPAN R1 and R2 in CT3 | 333d? | 2007-11-28 A | 2009-03-06 A | 100% | 2007-11-28 | 2009-03-06 | 333d? | finish no earlier than 2009-03-06 | C3 | 2664h | 2664h | REDOC_TIS-C3 | Nokia Siemens Networks | peter.leis@nsn.com | Rel-8 | CP-38 | Jiwan | PCG-21 |  |  |
| 876 | 312.1.4 | Documentation of TISPAN R1 and R2 in CT4 | 208d? | 2007-11-28 A | 2008-09-12 A | 100% | 2007-11-28 | 2008-09-12 | 208d? | finish no earlier than 2008-09-12 | C4 | 1664h | 1664h | REDOC_TIS-C4 | Nokia Siemens Networks | peter.leis@nsn.com | Rel-8 | CP-38 | Kimmo | PCG-21 |  |  |
| 877 | 312.2 | **IMS Multimedia Telephony Service** | 394d? | 2007-09-10 A | 2009-03-12 A | 100% | 2007-09-10 | 2009-03-12 | 394d? |  | S1,S5 | 5096h | 5096h | IMS-MMTel |  |  | Rel-8 | SP-37 | Alain |  |  |  |
| 878 | 312.2.1 | Merging TISPAN MMTel [requirements] for Common IMS | 65d? | 2007-09-10 A | 2007-12-07 A | 100% | 2007-09-10 | 2007-12-07 | 65d? | finish no earlier than 2007-12-07 | S1 | 520h | 520h | TMMTEL | Nokia Siemens Networks |  | Rel-8 | SP-37 | Alain |  |  |  |
| 879 | 312.2.2 | Multimedia Telephony Service and Supplementary Services (MMTel) offline Charging | 309d? | 2008-01-07 A | 2009-03-12 A | 100% | 2008-01-07 | 2009-03-12 | 309d? | finish no earlier than 2009-03-12 | S5 | 2472h | 2472h | MMTel-CH | Alcatel-Lucent | Maryse.Gardella@alcatel.fr | Rel-8 | SP-38 | Dionisio | PCG-21 |  |  |
| 880 | 312.3 | **Call Completion on Busy Subscriber (CCBS)/Call Completion on Non-Reachable (CCNR) on IMS** | 483d? | 2007-05-02 A | 2009-03-06 A | 100% | 2007-05-02 | 2009-03-06 | 483d? |  | C1,C3 | 11072h | 11072h | CCBS_CCNR | Deutsche Telekom | martin.huelsemann@telekom.de | Rel-8 | SP-38 | Frederic | PCG-21 |  |  |
| 881 | 312.3.1 | Stage 3 CCBS_CCNR | 483d? | 2007-05-02 A | 2009-03-06 A | 100% | 2007-05-02 | 2009-03-06 | 483d? | finish no earlier than 2009-03-06 | C1 | 3864h | 3864h | CCBS_CCNR | Deutsche Telekom | martin.huelsemann@telekom.de | Rel-8 | CP-38 | Frederic | PCG-21 |  |  |
| 882 | 312.3.2 | Stage 3 CCBS_CCNR | 418d? | 2007-05-02 A | 2008-12-05 A | 100% | 2007-05-02 | 2008-12-05 | 418d? | finish no earlier than 2008-12-05 | C3 | 3344h | 3344h | CCBS_CCNR | Deutsche Telekom | martin.huelsemann@telekom.de | Rel-8 | CP-38 | Jiwan | PCG-21 |  |  |
| 883 | 312.4 | **Flexible Alerting** | 288d? | 2008-01-30 A | 2009-03-06 A | 100% | 2008-01-30 | 2009-03-06 | 288d? |  | S1,C1 | 5278.4h | 5278.4h | FA | Nortel | milanpa@nortel.com | Rel-8 | SP-39 | Alain | PCG-21 |  |  |
| 884 | 312.4.1 | Stage 1 FA | 92d? | 2008-01-30 A | 2008-06-05 A | 100% | 2008-01-30 | 2008-06-05 | 92d? |  | S1 | 670.4h | 670.4h | FA | Telecom Italia |  | Rel-8 | SP-39 | Alain | PCG-21 |  |  |
| 885 | 312.4.2 | Stage 3 FA | 288d? | 2008-01-30 A | 2009-03-06 A | 100% | 2008-01-30 | 2009-03-06 | 288d? | finish no earlier than 2009-03-06 | C1 | 2304h | 2304h | FA | Nortel | milanpa@nortel.com | Rel-8 | CP-39 | Frederic | PCG-21 |  |  |
| 886 | 312.5 | **Communication Wait on IMS** | 331d? | 2007-11-30 A | 2009-03-06 A | 100% | 2007-11-30 | 2009-03-06 | 331d? |  | C1,C3 | 7416h | 7416h | CW_IMS | Deutsche Telekom | martin.huelsemann@telekom.de | Rel-8 | SP-38 | Frederic | PCG-21 |  |  |
| 887 | 312.5.1 | Stage 3 CW-IMS | 331d? | 2007-11-30 A | 2009-03-06 A | 100% | 2007-11-30 | 2009-03-06 | 331d? | finish no earlier than 2009-03-06 | C1 | 2648h | 2648h | CW_IMS | Deutsche Telekom | martin.huelsemann@telekom.de | Rel-8 | CP-38 | Frederic | PCG-21 |  |  |
| 888 | 312.5.2 | Stage 3 CW-IMS | 265d? | 2007-11-30 A | 2008-12-04 A | 100% | 2007-11-30 | 2008-12-04 | 265d? | finish no earlier than 2008-12-05 | C3 | 2120h | 2120h | CW_IMS | Deutsche Telekom | martin.huelsemann@telekom.de | Rel-8 | CP-38 | Jiwan | PCG-21 |  |  |
| 889 | 312.6 | Advice of Charge (AoC) support in IMS Charging | 309d? | 2008-01-07 A | 2009-03-12 A | 100% | 2008-01-07 | 2009-03-12 | 309d? | finish no earlier than 2009-03-12 | S5 | 2472h | 2472h | IMSTSS | Nokia Siemens Networks | Gerald.Goermer@nsn.com | Rel-8 | SP-38 | Dionisio | PCG-21 |  |  |
| 890 | 312.7 | Add Interconnection Border Control Function (IBCF) to IMS Charging | 128d? | 2007-09-17 A | 2008-03-12 A | 100% | 2007-09-17 | 2008-03-12 | 128d? | finish no earlier than 2008-03-12 | S5 | 1024h | 1024h | IMSTSS | Alcatel-Lucent | Maryse.Gardella@alcatel.fr | Rel-8 | SP-37 | Dionisio |  |  |  |

Notes:
- 863: CP#46 completed
- 864: SP#39 completed / Text3: 22.101
- 865: SP#40 completed / Text3: 23.292, 23.206
- 866: CP#46 completed
- 867: CP#46 completed / Text3: 24.229, new (24.292, 24.286)
- 868: CP#43 completed / Text3: new 29.292
- 869: CP#42 completed / Text3: 23.003, 29.232, 23.018, 29.002
- 870: CP#41 work stopped / Text3: 24.293
- 871: SP#43 completed
- 872: CP#43 completed
- 873: SP#39 completed / Text3: 22.228, 22.115, 22.101
- 874: CP#41 completed / Text3: 24.141, 24.147, 24.173, 24.229, 24.247, 24.341, 24.604, 24.605, 24.606, 24.607, 24.608, 24.610, 24.611, 24.616, 24.623, 24.628, 24.629, 24.647, 24.654
- 875: CP#43 completed / Text3: 29.162, 29.163, 29.658
- 876: CP#41 completed / Text3: 29.228, 29.229
- 877: SP#43 completed
- 878: SP#38 completed / Text3: 22.173
- 879: CP#43 completed / Text3: 32.275, 32.298/299
- 880: CP#43 completed
- 881: CP#43 completed / Text3: 24.642, 24.229, 24.173
- 882: CP#42 completed / Text3: 29.163
- 883: CP#43 completed
- 884: SP#40 completed / Text3: 22.173
- 885: CP#43 completed / Text3: 24.239, 24.173
- 886: CP#43 completed
- 887: CP#43 completed / Text3: 24.615, 24.229, 24.173
- 888: CP#42 completed / Text3: 29.163
- 889: SP#43 completed / Text3: 32.240, 32.260, 32.296, 32.298, 32.299, new 32.280
- 890: SP#39 completed / Text3: 32.260, 32.298

| ID | WBS | Task | Duration | Start | Finish | Complete | Baseline start | Baseline finish | Baseline duration | Constraint | Resources | Work | Actual work | Text1 | Text2 | Text4 | Text5 | Text6 | Text7 | Text8 |
| --- | --- | --- | --- | --- | --- | --- | --- | --- | --- | --- | --- | --- | --- | --- | --- | --- | --- | --- | --- | --- |
| 891 | 313 | **3GPP2 Input to Common IMS** | 200d? | 2008-03-07 A | 2008-12-11 A | 100% | 2008-03-07 | 2008-12-11 | 200d? |  | S1,S2,S3,C1,C3,C4 | 8653.2h | 8653.2h | CIMS_3GPP2 | PCG-21 | Nortel | Amar Deol (deola@nortelnetworks.com) | Rel-8 | SP-39 | Alain |
| 892 | 313.1 | Stage 1 CIMS_3GPP2 (SA1) | 30.65d? | 2008-03-12 A | 2008-06-05 A | 100% | 2008-03-12 | 2008-06-05 | 30.65d? | finish no earlier than 2008-06-12 | S1 | 245.2h | 245.2h | CIMS_3GPP2 | PCG-21 | Nortel | Amar Deol (deola@nortelnetworks.com) | Rel-8 | SP-39 | Alain |
| 893 | 313.2 | Stage 2 CIMS_3GPP2 (SA2) | 62d? | 2008-03-12 A | 2008-06-05 A | 100% | 2008-03-12 | 2008-06-05 | 62d? | finish no earlier than 2008-09-11 | S2 | 496h | 496h | IMS_Common | PCG-21 | Nortel | Amar Deol (deola@nortelnetworks.com) | Rel-8 | SP-39 | Maurice |
| 894 | 313.3 | Security CIMS_3GPP2 (SA3) | 197d? | 2008-03-12 A | 2008-12-11 A | 100% | 2008-03-12 | 2008-12-11 | 197d? | finish no earlier than 2008-12-11 | S3 | 1576h | 1576h | IMS_Common | PCG-21 | Nortel | Amar Deol (deola@nortelnetworks.com) | Rel-8 | SP-39 | Dionisio |
| 895 | 313.4 | Stage 3 CIMS_3GPP2 (CT1) | 196d? | 2008-03-07 A | 2008-12-05 A | 100% | 2008-03-07 | 2008-12-05 | 196d? | finish no earlier than 2008-12-11 | C1 | 1568h | 1568h | REDOC_3GPP2 | PCG-21 | Alcatel-Lucent | orsic@alcatel-lucent.com | Rel-8 | CP-39 | Frederic |
| 896 | 313.5 | Stage 3 CIMS_3GPP2 (CT3) | 196d? | 2008-03-07 A | 2008-12-05 A | 100% | 2008-03-07 | 2008-12-05 | 196d? | finish no earlier than 2008-12-05 | C3 | 1568h | 1568h | REDOC_3GPP2 | PCG-21 | Alcatel-Lucent | orsic@alcatel-lucent.com | Rel-8 | CP-39 | Jiwan |
| 897 | 313.6 | Stage 3 CIMS_3GPP2 (CT4) | 200d? | 2008-03-07 A | 2008-12-11 A | 100% | 2008-03-07 | 2008-12-11 | 200d? | finish no earlier than 2008-12-11 | C4 | 1600h | 1600h | REDOC_3GPP2 | PCG-21 | Alcatel-Lucent | orsic@alcatel-lucent.com | Rel-8 | CP-39 | Kimmo |
| 898 | 314 | **IMS Enhancements for support of Packet Cable access** | 388d? | 2006-12-06 A | 2008-05-30 A | 100% | 2006-12-06 | 2008-05-30 | 388d? |  | S2,S3,C1,C3,C4 | 27448h | 27448h | PktCbl |  | Cablelabs | Bernie McKibben (b.mckibben@cablelabs.com) | Rel-8 |  | Maurice |
| 899 | 314.1 | **IMS Enhancements for Cable Client Types and Deployment Models** | 345d? | 2007-02-05 A | 2008-05-30 A | 100% | 2007-02-05 | 2008-05-30 | 345d? |  | S2,C1 | 6992h | 6992h | PktCbl-Deploy |  | Cablelabs | Bernie McKibben (b.mckibben@cablelabs.com) | Rel-8 |  | Maurice |
| 900 | 314.1.1 | Architecture aspects of PktCbl-Deploy | 219d? | 2007-02-05 A | 2007-12-06 A | 100% | 2007-02-05 | 2007-12-06 | 219d? | finish no earlier than 2007-12-03 | S2 | 1752h | 1752h | PktCbl-Deploy |  | Cablelabs | Bernie McKibben (b.mckibben@cablelabs.com) | Rel-8 |  | Maurice |
| 901 | 314.1.2 | CT1 aspects of PktCbl-Deploy | 310d? | 2007-03-26 A | 2008-05-30 A | 100% | 2007-03-26 | 2008-05-30 | 310d? | finish no earlier than 2008-06-15 | C1 | 2480h | 2480h | PktCbl-Deploy |  | Cablelabs | D.Hancock@CableLabs.com | Rel-8 |  | Frederic |
| 902 | 314.2 | **IMS Inter-working aspects in Support of Cable Regulatory requirements** | 290d? | 2007-02-05 A | 2008-03-14 A | 100% | 2007-02-05 | 2008-03-14 | 290d? |  | S2,C1,C3 | 5640h | 5640h | PktCbl-Intw |  | Cablelabs | B.McKibben@CableLabs.com | Rel-8 |  | Maurice |
| 903 | 314.2.1 | Architecture aspects of PktCbl-Interwork | 160d? | 2007-02-05 A | 2007-09-14 A | 100% | 2007-02-05 | 2007-09-14 | 160d? | start no earlier than 2007-02-05 | S2 | 1280h | 1280h | PktCbl-Intw |  | Cablelabs | B.McKibben@CableLabs.com | Rel-8 |  | Maurice |
| 904 | 314.2.2 | CT1,CT3 aspects of PktCbl-Interwork | 255d? | 2007-03-26 A | 2008-03-14 A | 100% | 2007-03-26 | 2008-03-14 | 255d? | finish no earlier than 2008-03-15 | C1,C3 | 2040h | 2040h | PktCbl-Intw |  | Cablelabs | D.Hancock@CableLabs.com | Rel-8 |  | Frederic |
| 905 | 314.3 | **IMS Enhancements for Security Requirements in Support of Cable Deployments** | 388d? | 2006-12-06 A | 2008-05-30 A | 100% | 2006-12-06 | 2008-05-30 | 388d? |  | S3,C1,C3,C4 | 11712h | 11712h | PktCbl-Sec |  | Cablelabs | s.dotson@cablelabs.com | Rel-8 |  | Dionisio |
| 906 | 314.3.1 | SA3 aspects of PktCbl-Sec | 331d? | 2006-12-06 A | 2008-03-12 A | 100% | 2006-12-06 | 2008-03-12 | 331d? | finish no earlier than 2007-12-20 | S3 | 2648h | 2648h | PktCbl-Sec |  | Cablelabs | s.dotson@cablelabs.com | Rel-8 |  | Dionisio |
| 907 | 314.3.2 | CT1 aspects of PktCbl-Sec | 310d? | 2007-03-26 A | 2008-05-30 A | 100% | 2007-03-26 | 2008-05-30 | 310d? | finish no earlier than 2008-06-06 | C1 | 2480h | 2480h | PktCbl-Sec |  | Cablelabs | D.Hancock@CableLabs.com | Rel-8 |  | Frederic |
| 908 | 314.3.3 | CT3 aspects of PktCbl-Sec | 180d? | 2007-03-26 A | 2007-11-30 A | 100% | 2007-03-26 | 2007-11-30 | 180d? | finish no earlier than 2008-03-15 | C3 | 1440h | 1440h | PktCbl-Intw | PCG-21 | Cablelabs | D.Hancock@CableLabs.com | Rel-8 | CP-38 | Jiwan |
| 909 | 314.3.4 | CT4 aspects of PktCbl-Sec | 255d? | 2007-03-26 A | 2008-03-14 A | 100% | 2007-03-26 | 2008-03-14 | 255d? | finish no earlier than 2008-03-14 | C4 | 2040h | 2040h | PktCbl-Sec |  | Cablelabs | D.Hancock@CableLabs.com | Rel-8 |  | Kimmo |
| 910 | 315 | **IMS System enhancements for corporate network access** | 717d? | 2007-06-22 A | 2010-03-19 A | 100% | 2007-06-22 | 2010-03-19 | 717d? |  | S2,S1,C1,C4 | 14336.9h | 14336.9h | IMS_Corp |  | Orange | Delphin Barankanira | Rel-8 |  | Maurice |
| 911 | 315.1 | SA1 aspects of IMS_Corp | 23.6d? | 2008-03-12 A | 2008-06-05 A | 100% | 2008-03-12 | 2008-06-05 | 23.6d? | finish no earlier than 2008-06-05 | S1 | 188.8h | 188.8h | IMS_Corp | PCG-21 | Telecom Italia |  | Rel-8 | SP-39 | Alain |
| 912 | 315.2 | SA2 aspects of IMS_Corp | 325d? | 2007-06-22 A | 2008-09-18 A | 100% | 2007-06-22 | 2008-09-18 | 325d? | finish no earlier than 2008-12-25 | S2 | 2600h | 2600h | IMS_Corp |  | Orange | Delphin Barankanira | Rel-8 |  | Maurice |
| 913 | 315.3 | CT1 aspects of IMS_Corp | 532d? | 2008-03-07 A | 2010-03-19 A | 100% | 2008-03-07 | 2010-03-19 | 532d? | finish no earlier than 2010-03-19 | C1 | 4244.09h | 4244.09h | IMS_Corp | PCG-21 | Alcatel-Lucent | Keith Drage (drage@alcatel-lucent.com) | Rel-8 | CP-39 | Frederic |
| 914 | 315.4 | CT4 aspects of IMS_Corp | 196d? | 2008-02-26 A | 2008-12-05 A | 100% | 2008-02-26 | 2008-12-05 | 196d? | finish no earlier than 2008-12-11 | C4 | 1568h | 1568h | IMS_Corp | PCG-21 | Alcatel-Lucent | Keith Drage (drage@alcatel-lucent.com) | Rel-8 | CP-39 | Kimmo |

Notes:
- 891: TSG#42 completed
- 892: SP#40 completed / Text3: 22.228, 22.173, 22.101, 22.153
- 893: SP#40 completed / Text3: 23.002, 23.141, 23.203, 23.167, 23.228
- 894: SP#42 completed [issues addressed under UID_370078 (IMS-Sec)] / Text3: 33.141, 33.203, 33.210
- 895: CP#42 completed / Text3: 23.218, 24.141, 24.147, 24.173, 24.229, 24.238, 24.247, 24.604, 24.605, 24.606, 24.607, 24.608, 24.610, 24.611, 24.629, 24.930
- 896: CP#42 completed / Text3: 29.163, 29.212, 29.213, 29.214
- 897: CP#42 completed / Text3: 29.228, 29.229, 29.328, 29.329
- 898: CP#40 completed
- 899: CP#40 completed
- 900: SP#38 completed / Text3: 23.228
- 901: CP#40 completed
- 902: CP#39 completed
- 903: SP#37 completed / Text3: 23.228
- 904: CP#39 completed / Text3: 24.229
- 905: CP#40 completed
- 906: SP#39 completed / Text3: 33.203, 33.210, 33.220
- 907: CP#40 completed / Text3: 24.229
- 908: CP#38 completed / Text3: 29.163
- 909: CP#39 completed / Text3: 29.228, 29.229, 23.008
- 910: CP#47 completed
- 911: SP#40 completed
- 912: no Stage 2 impacts / Text3: 23.228
- 913: CP#47 completed / Text3: 24.229, 24.503
- 914: CP#42 completed / Text3: 29.228, 29.229, 23.003, 23.008, 29.433

| ID | WBS | Task | Duration | Start | Finish | Complete | Baseline start | Baseline finish | Baseline duration | Constraint | Resources | Work | Actual work | Text1 | Text2 | Text6 | Text7 | Text8 | Text4 | Text5 |
| --- | --- | --- | --- | --- | --- | --- | --- | --- | --- | --- | --- | --- | --- | --- | --- | --- | --- | --- | --- | --- |
| 915 | 316 | **Maintenance of TISPAN documentation** | 244d? | 2007-07-02 A | 2008-06-05 A | 100% | 2007-07-02 | 2008-06-05 | 244d? |  | S2,C1,C3,C4 | 5984h | 5984h | MAINTISP | PCG-21 | Rel-8 | SP-38 | Maurice |  |  |
| 916 | 316.1 | Maintenance of TISPAN R1 | 86d? | 2007-11-09 A | 2008-03-07 A | 100% | 2007-11-09 | 2008-03-07 | 86d? | start no earlier than 2007-11-09 | C1,C3,C4 | 688h | 688h | MAINT_R1 | PCG-21 | Rel-7 | CP-38 | Frederic | Alcatel-Lucent | Keith Drage (drage@alcatel-lucent.com) |
| 917 | 316.2 | Maintenance of TISPAN R2 | 86d? | 2007-11-09 A | 2008-03-07 A | 100% | 2007-11-09 | 2008-03-07 | 86d? | start no earlier than 2007-11-09 | C1,C3,C4 | 688h | 688h | MAINT_R2 | PCG-21 | Rel-8 | CP-38 | Frederic | Alcatel-Lucent | Keith Drage (drage@alcatel-lucent.com) |
| 918 | 316.3 | Documentation of TISPAN NGN R1 and R2 in 3GPP SA2 | 104d? | 2008-01-14 A | 2008-06-05 A | 100% | 2008-01-14 | 2008-06-05 | 104d? | finish no earlier than 2008-06-20 | S2 | 832h | 832h | IMS_Comm_Doc | PCG-21 | Rel-8 | SP-38 | Maurice | Nokia Siemens Networks | jozsef.varga@nsn.com |
| 919 | 316.4 | Maintenance of TISPAN release 1 common IMS | 114d? | 2007-07-02 A | 2007-12-06 A | 100% | 2007-07-02 | 2007-12-06 | 114d? | finish no earlier than 2007-12-06 | S2,S1 | 912h | 912h | IMS_Comm_Mtce7 | PCG-21 | Rel-7 | SP-38 | Maurice | BT, Ericsson | Dick Knight, Raymond Forbes |
| 920 | 316.5 | Maintenance of TISPAN release 2 common IMS | 114d? | 2007-07-02 A | 2007-12-06 A | 100% | 2007-07-02 | 2007-12-06 | 114d? | finish no earlier than 2007-12-06 | S2 | 912h | 912h | IMS_Comm_Mtce8 | PCG-21 | Rel-8 | SP-38 | Maurice | Telecom Italia | antonio.ascolese@telecomitalia.it |
| 921 | 317 | **IMS Service Continuity** | 318d? | 2008-03-12 A | 2009-05-29 A | 100% | 2008-03-12 | 2009-05-29 | 318d? |  | S2,S1,C1 | 5624h | 5624h | IMS-Cont | PCG-21 | Rel-8 | SP-39 | Maurice | LG Electronics | JaeSeung SONG (anthonys@lge.com) |
| 922 | 317.1 | Stage 1 IMS Service Continuity | 62d? | 2008-03-12 A | 2008-06-05 A | 100% | 2008-03-12 | 2008-06-05 | 62d? | start no earlier than 2008-03-12 | S1 | 496h | 496h | IMS-Cont | PCG-21 | Rel-8 | SP-39 | Alain | LG Electronics | JaeSeung SONG (anthonys@lge.com) |
| 923 | 317.2 | Stage 2 IMS Service Continuity | 62d? | 2008-03-12 A | 2008-06-05 A | 100% | 2008-03-12 | 2008-06-05 | 62d? | finish no earlier than 2008-06-05 | S2 | 496h | 496h | IMS-Cont | PCG-21 | Rel-8 | SP-39 | Maurice | LG Electronics | JaeSeung SONG (anthonys@lge.com) |
| 924 | 317.3 | Stage 3 IMS Service Continuity | 261d? | 2008-05-30 A | 2009-05-29 A | 100% | 2008-05-30 | 2009-05-29 | 261d? | finish no earlier than 2009-05-29 | C1 | 2088h | 2088h | IMS-Cont | PCG-21 | Rel-8 | CP-40 | Frederic | Huawei | Lili Yang (kadyyang@huawei.com) |
| 925 | 318 | **Security Enhancements for IMS** | 643.3d? | 2006-09-19 A | 2009-03-06 A | 100% | 2006-09-19 | 2009-03-06 | 643.3d? |  | S3,C1,C4 | 18624h | 18624h | IMS-Sec |  | Rel-8 | SP-37 | Dionisio | Ericsson | Bengt.Sahlin@ericsson.com |
| 926 | 318.1 | Stage 2 for IMS-Sec | 466d? | 2007-03-01 A | 2008-12-11 A | 100% | 2007-03-01 | 2008-12-11 | 466d? | finish no earlier than 2008-12-11 | S3 | 3728h | 3728h | IMS-Sec |  | Rel-8 |  | Dionisio | Ericsson | Bengt.Sahlin@ericsson.com |
| 927 | 318.2 | CT1 part of Stage 3 for IMS-Sec | 392d? | 2006-09-19 A | 2008-12-05 A | 100% | 2006-09-19 | 2008-12-05 | 392d? | finish no earlier than 2008-12-05 | C1 | 3136h | 3136h | IMS-Sec | PCG-21 | Rel-8 | CP-39 | Frederic | Ericsson |  |
| 928 | 318.3 | CT4 part of Stage 3 for IMS-Sec | 457d? | 2007-06-07 A | 2009-03-06 A | 100% | 2007-06-07 | 2009-03-06 | 457d? | finish no earlier than 2009-03-06 | C4 | 3656h | 3656h | IMS-Sec | PCG-21 | Rel-8 | CP-39 | Kimmo | Ericsson |  |
| 929 | 318.4 | CT1 part of NASS Bundled Authentication | 343d? | 2007-11-14 A | 2009-03-06 A | 100% | 2007-11-14 | 2009-03-06 | 343d? | finish no earlier than 2009-03-06 | C1 | 2744h | 2744h | NBA | PCG-21 | Rel-8 | CP-39 | Frederic | Alcatel-Lucent | Keith Drage (drage@alcatel-lucent.com) |
| 930 | 318.5 | CT4 part of NASS Bundled Authentication | 143d? | 2007-11-14 A | 2008-05-30 A | 100% | 2007-11-14 | 2008-05-30 | 143d? | start no earlier than 2007-11-14 | C4 | 1144h | 1144h | NBA-CT4 | PCG-21 | Rel-8 | CP-39 | Kimmo | Alcatel-Lucent |  |
| 931 | 319 | IMS initiated and controlled PSS and MBMS User Service | 262d? | 2008-03-12 A | 2009-03-12 A | 100% | 2008-03-12 | 2009-03-12 | 262d? | finish no earlier than 2009-03-12 | S2,C3,C4 |  |  | IMS_PSS_MBMS_US |  | Rel-8 |  | Paolo | FT, Ericsson | olle.franceschi@ericsson.com |
| 932 | 320 | **Multimedia interworking between IMS and CS networks** | 836d? | 2005-09-23 A | 2008-12-05 A | 100% | 2005-09-23 | 2008-12-05 | 836d? |  | C3,C4 | 16112h | 16112h | MIW-IMS |  | Rel-8 |  | Jiwan | Vodafone | nico.gabriele@vodafone.com |
| 933 | 320.1 | Note: Stages 1 and 2 defined in earlier Release | 49d? | 2005-09-23 A | 2005-11-30 A | 100% | 2005-09-23 | 2005-11-30 | 49d? | start no earlier than 2005-09-23 | S2 | 392h | 392h | MIW-IMS |  | Rel-8 |  | Maurice | Vodafone | nico.gabriele@vodafone.com |
| 934 | 320.2 | Stage 3 of MW-IMS | 571d? | 2005-09-23 A | 2007-11-30 A | 100% | 2005-09-23 | 2007-11-30 | 571d? | finish no earlier than 2007-09-14 | C3 | 4568h | 4568h | MIW-IMS-St3 |  | Rel-8 |  | Jiwan | Vodafone | nico.gabriele@vodafone.com |
| 935 | 320.3 | Stage 3 for MW-IMS, MONA extension | 285d? | 2007-11-05 A | 2008-12-05 A | 100% | 2007-11-05 | 2008-12-05 | 285d? | finish no earlier than 2008-12-05 | C3 | 2280h | 2280h | MIW-IMS | PCG-21 | Rel-8 | CP-38 | Jiwan | Vodafone | Christer.Holmberg@ericsson.com |
| 936 | 320.4 | Mn interface (MGCF – IM MGW) | 273d? | 2007-11-21 A | 2008-12-05 A | 100% | 2007-11-21 | 2008-12-05 | 273d? | finish no earlier than 2008-12-19 | C4 | 2184h | 2184h | MIW-IMS | PCG-21 | Rel-8 | CP-38 | Kimmo | Vodafone | Christer.Holmberg@ericsson.com |
| 937 | 321 | IMS Stage 3 IETF Protocol Alignment | 446d? | 2007-06-22 A | 2009-03-06 A | 100% | 2007-06-22 | 2009-03-06 | 446d? | finish no earlier than 2009-03-06 | C1 | 3568h | 3568h | IMSProtoc2 |  | Rel-8 |  | Frederic | Alcatel-Lucent | Keith Drage (drage@alcatel-lucent.com) |
| 938 | 322 | **Interworking between User-to-User Signalling (UUS) and SIP** | 335d? | 2007-11-30 A | 2009-03-12 A | 100% | 2007-11-30 | 2009-03-12 | 335d? |  | C1,C3 | 7488h | 7488h | UUSIW | PCG-21 | Rel-8 | CP-38 | Kimmo | Huawei | Lili Yang (kadyyang@huawei.com) |
| 939 | 322.1 | Stage 3 MGCF UUSIW | 266d? | 2007-11-30 A | 2008-12-05 A | 100% | 2007-11-30 | 2008-12-05 | 266d? | finish no earlier than 2008-12-05 | C1 | 2128h | 2128h | UUSIW | PCG-21 | Rel-8 | CP-38 | Frederic | Huawei | Lili Yang (kadyyang@huawei.com) |
| 940 | 322.2 | Stage 3 MGCF UUSIW | 335d? | 2007-11-30 A | 2009-03-12 A | 100% | 2007-11-30 | 2009-03-12 | 335d? | finish no earlier than 2009-03-12 | C3 | 2680h | 2680h | UUSIW | PCG-21 | Rel-8 | CP-38 | Jiwan | Huawei | Lili Yang (kadyyang@huawei.com) |

Notes:
- 915: SP#40 completed
- 916: CP#39 completed / Text3: 24.404, 24.405, 24.406, 24.407, 24.408, 24.410, 24.411, 24.416, 29.421, 24.423, 24.428, 24.429, 29.433, 24.441, 24.403, 29.427, 24.430, 29.412
- 917: CP#39 completed / Text3: 24.406, 24.407, 24.410, 24.411, 24.423, 24.430, 24.447, 24.451, 24.454, 24.503, 24.505, 24.508, 24.516, 24.528, 24.529, 29.412, 29.421, 29.433, 29.458, 29.527, 29.624
- 918: SP#40 completed / Text3: 23.228, 23.204, 23.167
- 919: SP#38 completed / Text3: 22.273, 22.401, 23.406, 23.417, 23.508, 23.509, 23.511, 22.401, 22.173
- 920: SP#38 completed / Text3: 23.506, 23.507,23.517, 23.521
- 921: CP#44 completed
- 922: SP#40 completed
- 923: SP#40 completed / Text3: 23.237, 23.292
- 924: CP#44 completed / Text3: 24.237, 24.229, 24.216
- 925: CP#43 completed
- 926: SP#42 completed. SP#46 withdrawn draft 33.178-100 and 33.978 from Rel-8 onwards / Text3: 33.203, 33.141, 33.803
- 927: CP#42 completed
- 928: CP#43 completed
- 929: CP#43 completed / Text3: 24.229
- 930: CP#40 completed / Text3: 29.229, 29.228, 23.008
- 931: SP#43 completed. SP#39 WID approved / Text3: 26.237, 26.234, 26.346, 33.246
- 932: CP#42 completed
- 933: SP#31 Moved from FS section Feb 2006
- 934: Moved from Rel-7. Feature extended in Rel-8 by including Stage 3 covering MONA UID_380021 / Text3: 29.863, 29.163
- 935: CP#42 completed / Text3: 29.863, 29.163
- 936: CP#42 completed / Text3: 29.332
- 937: CP#43 completed / Text3: 23.218, 24.229, 24.930
- 938: CP#43 completed
- 939: CP#42 completed / Text3: 24.279, 24.229
- 940: CP#43 completed / Text3: 29.163

| ID | WBS | Task | Type | Duration | Start | Finish | Complete | Baseline start | Baseline finish | Baseline duration | Constraint | Resources | Work | Actual work | Text1 | Text2 | Text4 | Text5 | Text6 | Text7 | Text8 | Text3 | Text11 |
| --- | --- | --- | --- | --- | --- | --- | --- | --- | --- | --- | --- | --- | --- | --- | --- | --- | --- | --- | --- | --- | --- | --- | --- |
| 941 | 323 | **Support of Overlap signalling** |  | 331d? | 2007-11-30 A | 2009-03-06 A | 100% | 2007-11-30 | 2009-03-06 | 331d? |  | C3,C1,C4 | 10008.2h | 10008.2h | Overlap | PCG-21 | Deutsche Telekom | r.jesske@telekom.de | Rel-8 | CP-38 | Jiwan |  |  |
| 942 | 323.1 | Stage 3 Overlap (CT1) |  | 331d? | 2007-11-30 A | 2009-03-06 A | 100% | 2007-11-30 | 2009-03-06 | 331d? | finish no earlier than 2009-03-06 | C1 | 2648h | 2648h | Overlap | PCG-21 | Deutsche Telekom | r.jesske@telekom.de | Rel-8 | CP-38 | Frederic | 24.229 |  |
| 943 | 323.2 | Stage 3 Overlap (CT3) |  | 331d? | 2007-11-30 A | 2009-03-06 A | 100% | 2007-11-30 | 2009-03-06 | 331d? | finish no earlier than 2009-03-06 | C3 | 2648h | 2648h | Overlap | PCG-21 | Deutsche Telekom | r.jesske@telekom.de | Rel-8 | CP-38 | Jiwan | 29.163 |  |
| 944 | 323.3 | Stage 3 Overlap (CT4) |  | 258.02d? | 2007-11-30 A | 2008-12-05 A | 100% | 2007-11-30 | 2008-12-05 | 258.02d? | start no earlier than 2007-11-30 | C4 | 2064.16h | 2064.16h | Overlap | PCG-21 | Deutsche Telekom | r.jesske@telekom.de | Rel-8 | CP-38 | Kimmo | 29.228, 29.229 |  |
| 945 | 324 | AS/MRFC Stage 2 and 3 |  | 278d? | 2007-11-14 A | 2008-12-05 A | 100% | 2007-11-14 | 2008-12-05 | 278d? | finish no earlier than 2008-12-05 | C1 | 2224h | 2224h | MRFC_TS | PCG-21 | Hewlett-Packard | mark.syrett@hp.com | Rel-8 | CP-38 | Frederic | 23.218, 24.229, 24.147, 24.247 |  |
| 946 | 325 | **IMS Restoration Procedures** |  | 201d? | 2008-05-30 A | 2009-03-06 A | 100% | 2008-05-30 | 2009-03-06 | 201d? |  | C4,C1 | 4824h | 4824h | IMS_RP | PCG-21 | Ericsson | german.blanco@ericsson.com | Rel-8 | SP-40 | Kimmo |  |  |
| 947 | 325.1 | IMS Restoration Procedures (CT4) |  | 201d? | 2008-05-30 A | 2009-03-06 A | 100% | 2008-05-30 | 2009-03-06 | 201d? | finish no earlier than 2009-03-06 | C4 | 1608h | 1608h | IMS_RP | PCG-21 | Ericsson | german.blanco@ericsson.com | Rel-8 | SP-40 | Kimmo | 23.380, 29.228, 29.229, 29.230, 23.008 |  |
| 948 | 325.2 | IMS Restoration Procedures (CT1) |  | 201d? | 2008-05-30 A | 2009-03-06 A | 100% | 2008-05-30 | 2009-03-06 | 201d? | finish no earlier than 2009-03-06 | C1 | 1608h | 1608h | IMS_RP | PCG-21 | Ericsson | german.blanco@ericsson.com | Rel-8 | SP-40 | Frederic | 24.229 |  |
| 949 | 326 | IMS Application Server Service Data Descriptions for AS interoperability |  | 125d? | 2008-09-12 A | 2009-03-06 A | 100% | 2008-09-12 | 2009-03-06 | 125d? | finish no earlier than 2009-03-06 | C4 | 1000h | 1000h | IMS_ASIO | PCG-21 | Alcatel-Lucent | nhberry@alcatel-lucent.com | Rel-8 | CP-41 | Kimmo | 29.328, 29.329, 29.364 |  |
| 950 | 327 | **I-WLAN Network Selection Principle (NSP)** |  | 451d? | 2007-06-14 A | 2009-03-06 A | 100% | 2007-06-14 | 2009-03-06 | 451d? |  | S1,C1,C6 | 6643.2h | 6643.2h | IWLANNSP |  | Telefónica O2 | chris.friel@O2.com | Rel-8 |  | Alain |  |  |
| 951 | 327.1 | Stage 1 for I-WLAN NSP | milestone | 0d? | 2007-06-14 A | 2007-06-14 A | 100% | 2007-06-14 | 2007-06-14 | 0d? |  | S1 |  |  | IWLANNSP | PCG-21 | Telefónica O2 | chris.friel@O2.com | Rel-8 | SP-39 | Alain | 22.234 |  |
| 952 | 327.2 | Stage 3 for I-WLAN NSP |  | 261d? | 2008-03-07 A | 2009-03-06 A | 100% | 2008-03-07 | 2009-03-06 | 261d? | finish no earlier than 2008-12-05 | C1 | 2088h | 2088h | IWLANNSP | PCG-21 | Research In Motion | Adrian Buckley (abuckley@rim.com) | Rel-8 | CP-39 | Frederic | 24.234 |  |
| 953 | 327.3 | Stage 3 for I-WLAN NSP |  | 118.4d? | 2008-03-07 A | 2008-12-11 A | 100% | 2008-03-07 | 2008-12-11 | 118.4d? | finish no earlier than 2008-12-11 | C6 | 947.2h | 947.2h | IWLANNSP | PCG-21 | Research In Motion | Adrian Buckley (abuckley@rim.com) | Rel-8 | CP-39 | Xavier | 31.102, 31.111 |  |
| 954 | 328 | **Mobility between 3GPP-WLAN Interworking and 3GPP Systems** |  | 386d? | 2007-09-14 A | 2009-03-06 A | 100% | 2007-09-14 | 2009-03-06 | 386d? |  | S2,C1 | 6216h | 6216h | IWLAN_Mob |  | Orange | xiaobao.chen@orange-ftgroup.com | Rel-8 | SP-37 | Maurice |  |  |
| 955 | 328.1 | Stage 2: I-WLAN Mobility |  | 190d? | 2007-09-14 A | 2008-06-05 A | 100% | 2007-09-14 | 2008-06-05 | 190d? | finish no earlier than 2008-09-08 | S2 | 1520h | 1520h | IWLAN_Mob | PCG-21 | Orange | xiaobao.chen@orange-ftgroup.com | Rel-8 | SP-38 | Maurice | new 23.327 |  |
| 956 | 328.2 | CT1 aspects of I-WLAN Mobility |  | 201d? | 2008-05-30 A | 2009-03-06 A | 100% | 2008-05-30 | 2009-03-06 | 201d? | finish no earlier than 2009-03-06 | C1 | 1608h | 1608h | IWLAN_Mob | PCG-21 | Orange | reina.nader@orange-ftgroup.com | Rel-8 | CP-40 | Frederic | 24.303, new 24.327 |  |
| 957 | 329 | Conformance Test Aspects – Mobility between 3GPP WLAN Interworking and 3GPP Systems |  | 206d? | 2009-12-04 A | 2010-09-17 A | 100% | 2009-12-04 | 2010-09-17 | 206d? | finish no earlier than 2010-09-17 | R5 | 1648h | 1648h | IWLAN_Mob_UEConTest | PCG-24 | Qualcomm | Patrick Stupar (pstupar@qualcomm.com) | Rel-8 | RP-46 | Ingbert | 34.108, 34.123-1, 34.123-2, 34.123-3 | RP-100740 |
| 958 | 330 | **Enhancements for Voice Group Call Service (VGCS) Applications (EVA)** |  | 919d? | 2006-03-15 A | 2009-09-18 A | 100% | 2006-03-15 | 2009-09-18 | 919d? |  | S1,C1,C4,G2 | 23503.5h | 23503.5h | EVA |  | Nortel | Amar Deol (deola@nortelnetworks.com) | Rel-8 |  | Alain |  |  |
| 959 | 330.1 | SA1 aspects of EVA |  | 191d? | 2006-03-15 A | 2006-12-06 A | 100% | 2006-03-15 | 2006-12-06 | 191d? | finish no earlier than 2006-12-06 | S1 | 1528h | 1528h | EVA |  | Nortel | Amar Deol (deola@nortelnetworks.com) | Rel-8 |  | Alain | 42.068 |  |
| 960 | 330.2 | VGCS/VBS and GPRS Interactions |  | 145d? | 2007-09-03 A | 2008-03-21 A | 100% | 2007-09-03 | 2008-03-21 | 145d? | finish no earlier than 2008-03-21 | S1 | 1160h | 1160h | EVA |  | Huawei | Ling Liu | Rel-8 | SP-37 | Alain | 42.068, 42.069 |  |
| 961 | 330.3 | CT1 aspects of EVA |  | 862d? | 2006-06-02 A | 2009-09-18 A | 100% | 2006-06-02 | 2009-09-18 | 862d? | finish no earlier than 2009-12-04 | C1 | 6887.53h | 6887.53h | EVA |  | Nortel | milanpa@nortel.com | Rel-8 |  | Frederic | 43.068, 44.068 |  |
| 962 | 330.4 | CT4 aspects of EVA |  | 391d? | 2006-06-02 A | 2007-11-30 A | 100% | 2006-06-02 | 2007-11-30 | 391d? | finish no earlier than 2007-06-01 | C4 | 3128h | 3128h | EVA |  | Nortel |  | Rel-8 |  | Kimmo | 29.002 |  |
| 963 | 330.5 | GERAN2 aspects of EVA |  | 431d? | 2006-06-30 A | 2008-02-22 A | 100% | 2006-06-30 | 2008-02-22 | 431d? | finish no earlier than 2008-02-22 | G2 | 3448h | 3448h | EVA |  | Nortel | frank.billenkamp@nortel.com | Rel-8 |  | Gert | 44.018, 48.008 |  |
| 964 | 331 | **Personal Network Management** |  | 955d? | 2005-07-11 A | 2009-03-06 A | 100% | 2005-07-11 | 2009-03-06 | 955d? |  | S1,C1,S3 | 27008h | 27008h | PNM |  | Vodafone | armin.toepfer@vodafone.com | Rel-8 |  | Alain |  |  |
| 965 | 331.1 | Stage 1 for PNM |  | 276d? | 2005-07-11 A | 2006-07-31 A | 100% | 2005-07-11 | 2006-07-31 | 276d? | start no earlier than 2005-07-11 | S1 | 2208h | 2208h | PNM |  | Vodafone | armin.toepfer@vodafone.com | Rel-8 |  | Alain | 22.259 |  |
| 966 | 331.2 | Stage 2 for PNM |  | 445d? | 2007-03-26 A | 2008-12-05 A | 100% | 2007-03-26 | 2008-12-05 | 445d? | finish no earlier than 2008-12-05 | C1 | 3560h | 3560h | PNM |  | Vodafone | yang.lu@vodafone.com | Rel-8 |  | Frederic | 23.259 |  |

Notes:
- 941: CP#43 completed
- 942: CP#43 completed
- 943: CP#43 completed
- 944: CP#42 completed
- 945: CP#42 completed. Triggered by Study UID_7048 (MRFC)
- 946: CP#43 completed. Triggered by Study TR 23.820 (FS_IMS_RP) UID_350018
- 947: CP#43 completed
- 948: CP#43 completed
- 949: CP#43 completed. Triggered by UID_360030 (FS_IMS_ASIO)
- 950: CP#43 completed
- 951: SP#36 completed
- 952: CP#43 completed
- 953: CP#42 completed
- 954: CP#43 completed
- 955: SP#40 completed
- 956: CP#43 completed
- 957: RP#49 completed. Testing for Rel-8 UID_400013 CT1 aspects of mobility between 3GPP WLAN Interworking and 3GPP Systems (24.327)
- 958: CP#45 completed
- 959: SP#38 completed
- 960: SP#39 completed
- 961: CP#45 completed
- 962: CP#38 completed
- 963: GP#37 completed
- 964: CP#43 completed
- 965: SP#31 completed
- 966: CP#42 completed

| ID | WBS | Task | Type | Duration | Start | Finish | Complete | Baseline start | Baseline finish | Baseline duration | Constraint | Resources | Work | Actual work | Text1 | Text4 | Text5 | Text6 | Text8 | Text3 | Text12 | Text7 | Text2 | Text11 |
| --- | --- | --- | --- | --- | --- | --- | --- | --- | --- | --- | --- | --- | --- | --- | --- | --- | --- | --- | --- | --- | --- | --- | --- | --- |
| 967 | 331.3 | **Stage 3 for PNM** |  | 510d? | 2007-03-26 A | 2009-03-06 A | 100% | 2007-03-26 | 2009-03-06 | 510d? |  | C1,C4 | 11720h | 11720h | PNM | Vodafone | yang.lu@vodafone.com | Rel-8 | Frederic |  |  |  |  |  |
| 968 | 331.3.1 | CT1 aspects of Stage 3 PNM |  | 510d? | 2007-03-26 A | 2009-03-06 A | 100% | 2007-03-26 | 2009-03-06 | 510d? | finish no earlier than 2008-12-05 | C1 | 4080h | 4080h | PNM | Vodafone | yang.lu@vodafone.com | Rel-8 | Frederic | 24.259, 24.229 |  |  |  |  |
| 969 | 331.3.2 | Deleted - CT4 aspects of Stage 3 PNM |  | 445d? | 2007-03-26 A | 2008-12-05 A | 100% | 2007-03-26 | 2008-12-05 | 445d? | finish no earlier than 2008-12-11 | C4 | 3560h | 3560h | PNM | Vodafone | yang.lu@vodafone.com | Rel-8 | Kimmo |  | CP-42 |  |  |  |
| 970 | 331.4 | Key establishment between a UICC hosting device and a remote device |  | 235d? | 2006-12-06 A | 2007-10-30 A | 100% | 2006-12-06 | 2007-10-30 | 235d? | finish no earlier than 2007-10-30 | S3 | 1880h | 1880h | PNM | Ericsson | Vesa.Lehtovirta@ericsson.com | Rel-8 | Dionisio | 33.259 |  |  |  |  |
| 971 | 331.5 | Deleted - Actual Requirements of PNM | milestone | 0d? | 2007-03-26 A | 2007-03-26 A | 100% | 2007-03-26 | 2007-03-26 | 0d? | finish no earlier than 2007-03-26 | C1 |  |  | PNM | Ericsson |  | Rel-8 | Frederic |  | SP-37 |  |  |  |
| 972 | 332 | **eCall Data Transfer** |  | 637d? | 2006-09-28 A | 2009-03-06 A | 100% | 2006-09-28 | 2009-03-06 | 637d? |  | S1,C1 | 9744h | 9744h | EData | Airbiquity | rrobinson@airbiquity.com | Rel-8 | Alain |  |  |  |  |  |
| 973 | 332.1 | eData Requirements |  | 380d? | 2006-09-28 A | 2008-03-12 A | 100% | 2006-09-28 | 2008-03-12 | 380d? | finish no earlier than 2006-12-07 | S1 | 3040h | 3040h | EData | Airbiquity | rrobinson@airbiquity.com | Rel-8 | Alain | 22.101, 22.105 |  | SP-37 |  |  |
| 974 | 332.2 | Transfer of data during an emergency call |  | 201d? | 2008-05-30 A | 2009-03-06 A | 100% | 2008-05-30 | 2009-03-06 | 201d? | finish no earlier than 2009-03-06 | C1 | 1608h | 1608h | EData | T-Mobile | Dieter Jacobsohn | Rel-8 | Frederic | 24.008 |  | SP-40 | PCG-21 |  |
| 975 | 333 | eCall data transfer Phase 2: Comparison of alternative in-band modem solutions and standardization of one in-band modem solution |  | 472d? | 2007-12-06 A | 2009-09-24 A | 100% | 2007-12-06 | 2009-09-24 | 472d? | finish no earlier than 2009-09-24 | S4 | 3768.09h | 3768.09h | eCall_Phase2 | Airbiquity | lhong@airbiquity.com & rrobinson@airbiquity.com | Rel-8 | Paolo | 26.267, 26.268, 26.269, 26.967, 26.969 |  |  |  |  |
| 976 | 334 | eCall Conformance Testing |  | 261d? | 2009-09-04 A | 2010-09-03 A | 100% | 2009-09-04 | 2010-09-03 | 261d? | finish no earlier than 2010-09-03 | G3new | 2088h | 2088h | eCall_MSTest | Ericsson, Qualcomm | Vikrant Jain (vikrantj@qualcomm.com) | Rel-8 | Ingbert | 51.010-1, 51.010-2 |  | GP-45 | PCG-23 |  |
| 977 | 335 | Conformance Test Aspects – non-modem procedures of eCall sessions in UTRA |  | 186d? | 2009-09-18 A | 2010-06-04 A | 100% | 2009-09-18 | 2010-06-04 | 186d? | finish no earlier than 2010-06-04 | R5 | 1488h | 1488h | UMTS_eCall_UEConTest | Ericsson, Qualcomm | Shubhang Vora (svora@qualcomm.com) | Rel-8 | Ingbert | 34.108, 34.123-1, 34.123-2, 34.123-3 |  | RP-45 | PCG-23 | RP-100489 |
| 978 | 336 | **IP Interconnection of Services** |  | 668d? | 2006-08-16 A | 2009-03-06 A | 100% | 2006-08-16 | 2009-03-06 | 668d? |  | S1,S2,S5,C3 | 17520h | 17520h | IPinterc | Telefónica O2 | chris.friel@O2.com | Rel-8 | Alain |  |  | SP-38 | PCG-21 |  |
| 979 | 336.1 | Stage 1 for IPinterc |  | 70d? | 2007-12-06 A | 2008-03-12 A | 100% | 2007-12-06 | 2008-03-12 | 70d? | start no earlier than 2007-12-06 | S1 | 560h | 560h | IPinterc | Telefónica O2 | chris.friel@O2.com | Rel-8 | Alain | 22.101, 22.228 |  | SP-38 | PCG-21 |  |
| 980 | 336.2 | **System enhancements for interconnection interfaces between two IMSs** |  | 668d? | 2006-08-16 A | 2009-03-06 A | 100% | 2006-08-16 | 2009-03-06 | 668d? |  | S2,S5,C3 | 11616h | 11616h | IMS_NNI | Telecom Italia | Mario Madella (mario.madella@telecomitalia.it) | Rel-8 | Maurice |  |  |  |  |  |
| 981 | 336.2.1 | Stage 2 for IMS_NNI |  | 120d? | 2007-06-22 A | 2007-12-06 A | 100% | 2007-06-22 | 2007-12-06 | 120d? | finish no earlier than 2007-12-21 | S2 | 960h | 960h | IMS_NNI | Telecom Italia | Mario Madella (mario.madella@telecomitalia.it) | Rel-8 | Maurice | 23.002, 23.228 |  |  |  |  |
| 982 | 336.2.2 | IMS inter-operator service interconnection interface |  | 461d? | 2007-06-01 A | 2009-03-06 A | 100% | 2007-06-01 | 2009-03-06 | 461d? | finish no earlier than 2009-03-06 | C3 | 3688h | 3688h | FBI2-IOPSI | Telecom Italia | antonio.ascolese@telecomitalia.it | Rel-8 | Jiwan | 29.865, 29.165 |  |  |  |  |
| 983 | 336.2.3 | Charging harmonization for NGN between 3GPP and ATIS-TMOC |  | 51d? | 2006-09-28 A | 2006-12-07 A | 100% | 2006-09-28 | 2006-12-07 | 51d? | finish no earlier than 2006-12-07 | S5 | 408h | 408h | FBI2-TISP2-CH | Amdocs | yishai.brown@amdocs.com | Rel-8 | Dionisio | 32.297 |  |  |  |  |
| 984 | 336.2.4 | Deleted - Protocol impact of FBI for TISPAN R2 |  | 152d? | 2006-08-16 A | 2007-03-15 A | 100% | 2006-08-16 | 2007-03-15 | 152d? | finish no earlier than 2007-03-15 | C1 | 1216h | 1216h | FBI2-TISP2-c1 | Ericsson |  | Rel-8 | Frederic |  | SP-38 |  |  |  |
| 985 | 336.2.5 | Deleted (never approved) - Stage 2 of FBI for TISPAN R2 - Rel 8 | milestone | 0d? | 2007-11-30 A | 2007-11-30 A | 100% | 2007-11-30 | 2007-11-30 | 0d? | finish no earlier than 2007-11-30 | S2 |  |  | FBI2-TISP2-s2 | Nokia Siemens Networks |  | Rel-8 | Maurice |  | SP-36 |  |  |  |
| 986 | 337 | **Support of (G)MSC-S – (G)MSC-S Nc Interface based on the SIP-I protocol** |  | 386d? | 2007-09-14 A | 2009-03-06 A | 100% | 2007-09-14 | 2009-03-06 | 386d? |  | C4,C3 | 11872h | 11872h | SIP_Nc | Vodafone | David.Hutton@vodafone.com | Rel-8 | Kimmo |  |  |  |  |  |
| 987 | 337.1 | Stage 1 for SIP_Nc (covered by Feature IPinterc) |  | 70d? | 2007-12-06 A | 2008-03-12 A | 100% | 2007-12-06 | 2008-03-12 | 70d? | start no earlier than 2007-12-06 | S1 | 560h | 560h | IPinterc | Telefónica O2 | chris.friel@O2.com | Rel-8 | Alain | 22.101, 22.228 |  | CP-41 | PCG-21 |  |
| 988 | 337.2 | SIP-I based circuit-switched core network; Stage 2 |  | 321d? | 2007-09-14 A | 2008-12-05 A | 100% | 2007-09-14 | 2008-12-05 | 321d? | finish no earlier than 2008-12-11 | C4 | 2568h | 2568h | SIP_Nc-St2 | Vodafone | David.Hutton@vodafone.com | Rel-8 | Kimmo | 23.231, 23.153, 23.205 |  |  |  |  |
| 989 | 337.3 | Application of SIP-I Protocols to Circuit Switched (CS) core network architecture; Stage 3 |  | 321d? | 2007-09-14 A | 2008-12-05 A | 100% | 2007-09-14 | 2008-12-05 | 321d? | finish no earlier than 2008-12-11 | C4 | 2568h | 2568h | SIP_Nc-St3 | Vodafone | David.Hutton@vodafone.com | Rel-8 | Kimmo | 29.231, 29.232, 29.332 |  |  |  |  |
| 990 | 337.4 | Interworking between the 3GPP CS domain with SIP-I as signalling protocol and other networks |  | 386d? | 2007-09-14 A | 2009-03-06 A | 100% | 2007-09-14 | 2009-03-06 | 386d? | finish no earlier than 2009-03-06 | C3 | 3088h | 3088h | SIP_Nc | Nokia Siemens Networks | Thomas.Belling@nsn.com | Rel-8 | Jiwan | 29.235, 23.172, 23.202, 29.007, 29.163, 29.414 |  |  |  |  |

Notes:
- 967: CP#43 completed
- 968: CP#43 completed
- 969: CP#42 no impact on CT4 specs
- 970: SP#37 completed
- 971: SP#37 stopped
- 972: SP#39 completed. Linked to SA4 Feature UID_34042 (eCall_Phase2)
- 973: SP#39 completed
- 974: CP#43 completed
- 975: SP#45 completed. Triggered by Study UID_360015 (eCALLIBMS). Linked to SA1 Feature UID_330005 (EData)
- 976: GP#47 completed. GP#43 WID approved. Testing for Rel-8 eCall_Phase2 (UID_34042) and EData (UID_330005)
- 977: RP#48 completed. Testing for Rel-8 eCall_Phase2 (UID_34042) and Edata (UID_330005)
- 978: SP#43 completed
- 979: SP#39 completed.
- 980: CP#43 completed
- 981: SP#38 completed
- 982: CP#43 completed
- 983: SP#34 completed
- 984: SP#38 stopped
- 985: SP#36 stopped
- 986: CP#43 completed. Stage 1 in Feature UID_380060 (IPinterc). CP#40 updated WID CP-070517=>CP-080282
- 987: 22/07/08 Created. Stage 1 for SIP_Nc (covered by SA1 Feature UID_380060 Ipinterc)
- 988: CP#42 completed
- 989: CP#42 completed
- 990: CP#43 completed. CP#42 target 12/08=>03/09

| ID | WBS | Task | Type | Duration | Start | Finish | Complete | Baseline start | Baseline finish | Baseline duration | Constraint | Resources | Work | Actual work | Text1 | Text4 | Text5 | Text6 | Text7 | Text8 | Text3 | Text2 | Text11 | Text9 | Text12 |
| --- | --- | --- | --- | --- | --- | --- | --- | --- | --- | --- | --- | --- | --- | --- | --- | --- | --- | --- | --- | --- | --- | --- | --- | --- | --- |
| 991 | 338 | **Earthquake and Tsunami Warning System** |  | 440d? | 2007-09-10 A | 2009-05-15 A | 100% | 2007-09-10 | 2009-05-15 | 440d? |  | S1,S2,C1,C4,G2 | 7200h | 7200h | ETWS | NTT DoCoMo | kitaharar@nttdocomo.co.jp | Rel-8 | SP-37 | Alain |  |  |  |  |  |
| 992 | 338.1 | Stage 1 for ETWS |  | 133d? | 2007-09-10 A | 2008-03-12 A | 100% | 2007-09-10 | 2008-03-12 | 133d? | finish no earlier than 2008-03-12 | S1 | 1064h | 1064h | ETWS | NTT DoCoMo | kitaharar@nttdocomo.co.jp | Rel-8 | SP-37 | Alain | 22.168 |  |  |  |  |
| 993 | 338.2 | SA2 aspects of ETWS |  | 179d? | 2008-01-14 A | 2008-09-18 A | 100% | 2008-01-14 | 2008-09-18 | 179d? | finish no earlier than 2008-09-08 | S2 | 1432h | 1432h | ETWS | NTT DoCoMo | tanakai@nttdocomo.co.jp | Rel-8 | SP-38 | Maurice | 23.828, 23.401 | PCG-21 |  |  |  |
| 994 | 338.3 | CT1 aspects of ETWS |  | 50.5d? | 2008-05-30 A | 2008-12-05 A | 100% | 2008-05-30 | 2008-12-05 | 50.5d? | finish no earlier than 2008-12-05 | C1 | 404h | 404h | ETWS | NTT DoCoMo | yamashitahi@s1.nttdocomo.co.jp | Rel-8 | CP-40 | Frederic | 23.041 | PCG-21 |  |  |  |
| 995 | 338.4 | CT4 aspects of ETWS |  | 50.5d? | 2008-09-26 A | 2008-12-05 A | 100% | 2008-09-26 | 2008-12-05 | 50.5d? | finish no earlier than 2008-12-05 | C4 | 404h | 404h | ETWS | NTT DoCoMo | yamashitahi@s1.nttdocomo.co.jp | Rel-8 | CP-40 | Kimmo | 29.168 | PCG-21 |  |  |  |
| 996 | 338.5 | ETWS primary notification message definition in GERAN |  | 47d? | 2009-03-12 A | 2009-05-15 A | 100% | 2009-03-12 | 2009-05-15 | 47d? | finish no earlier than 2009-05-15 | G2 | 376h | 376h | ETWS | Ericsson | claes-goran.persson@ericsson.com | Rel-8 | SP-43 | Gert | 44.018, 44.060 | PCG-22 |  |  |  |
| 997 | 339 | Conformance Test Aspects – UMTS Earthquake and Tsunami Warning System (ETWS) FDD |  | 207d? | 2009-05-29 A | 2010-03-12 A | 100% | 2009-05-29 | 2010-03-12 | 207d? | finish no earlier than 2010-03-12 | R5 | 1656h | 1656h | ETWS_UMTS_UEConTestFDD | NTT DoCoMo | Makoto Ito (itohm@nttdocomo.co.jp) | Rel-8 | RP-44 | Ingbert | 34.108, 34.123-1, 34.123-2 | PCG-23 | RP-100068 |  |  |
| 998 | 340 | **In Case of Emergency numbers storage and easy access on UICC** |  | 519d? | 2007-03-13 A | 2009-03-06 A | 100% | 2007-03-13 | 2009-03-06 | 519d? |  | S1,C6 | 8864h | 8864h | ICE | Vodafone | armin.toepfer@vodafone.com | Rel-8 | SP-38 | Alain |  | PCG-21 |  |  |  |
| 999 | 340.1 | Stage 1 for ICE |  | 262d? | 2007-03-13 A | 2008-03-12 A | 100% | 2007-03-13 | 2008-03-12 | 262d? | finish no earlier than 2008-03-12 | S1 | 2096h | 2096h | ICE | Vodafone | armin.toepfer@vodafone.com | Rel-8 | SP-38 | Alain | 22.030, 22.101 | PCG-21 |  |  |  |
| 1000 | 340.2 | CT6 aspects of ICE |  | 519d? | 2007-03-13 A | 2009-03-06 A | 100% | 2007-03-13 | 2009-03-06 | 519d? | finish no earlier than 2009-03-06 | C6 | 4152h | 4152h | ICE | Vodafone | armin.toepfer@vodafone.com | Rel-8 | SP-38 | Xavier | 31.102 | PCG-21 |  |  |  |
| 1001 | 341 | Local Charging Zone Requirements |  | 380d? | 2006-09-28 A | 2008-03-12 A | 100% | 2006-09-28 | 2008-03-12 | 380d? | finish no earlier than 2006-12-07 | S1 | 3040h | 3040h | LCZR | China Mobile | liuhongyfw@chinamobile.com | Rel-8 |  | Alain | 22.115 |  |  |  |  |
| 1002 | 342 | **Customized Alerting Tone (CAT) service** |  | 729d? | 2006-12-06 A | 2009-09-18 A | 100% | 2006-12-06 | 2009-09-18 | 729d? |  | S1,C1,C3,C4 | 12302h | 12302h | CAT | China Mobile | fenglingjuan@chinamobile.com | Rel-8 |  | Alain |  |  |  |  |  |
| 1003 | 342.1 | Stage 1 for CAT |  | 207d? | 2006-12-06 A | 2007-09-20 A | 100% | 2006-12-06 | 2007-09-20 | 207d? | start no earlier than 2006-12-06 | S1 | 1656h | 1656h | CAT | China Mobile | fenglingjuan@chinamobile.com | Rel-8 | SP-37 | Alain | 22.182 |  |  |  |  |
| 1004 | 342.2 | TISPAN requirements for customized multimedia information services |  | 71d? | 2007-09-03 A | 2007-12-10 A | 100% | 2007-09-03 | 2007-12-10 | 71d? | finish no earlier than 2007-12-10 | S1 | 568h | 568h | TISCMI | China Mobile | fenglingjuan@chinamobile.com | Rel-8 | SP-37 | Alain | 22.182 |  |  |  |  |
| 1005 | 342.3 | IMS CAT Supplementary Service |  | 164d? | 2008-04-21 A | 2008-12-04 A | 100% | 2008-04-21 | 2008-12-04 | 164d? | finish no earlier than 2008-12-05 | C1 | 1312h | 1312h | CAT-SS | Nortel | milanpa@nortel.com | Rel-8 | CP-39 | Frederic | 24.182 | PCG-21 |  |  |  |
| 1006 | 342.4 | CAT solution for voice and video call in CS domain |  | 389.8d? | 2008-03-12 A | 2009-09-18 A | 100% | 2008-03-12 | 2009-09-18 | 389.8d? | finish no earlier than 2009-09-11 | C3 | 3118.4h | 3118.4h | CAT-SS | Nortel | milanpa@nortel.com | Rel-8 | CP-39 | Jiwan | 29.163 | PCG-21 |  |  |  |
| 1007 | 342.5 | CAT Service in 3GPP CS domain |  | 126d? | 2008-09-12 A | 2009-03-06 A | 100% | 2008-09-12 | 2009-03-06 | 126d? | finish no earlier than 2009-03-06 | C4 | 1008h | 1008h | CAT-3G_CS | China Mobile | zhaoyuyi@chinamobile.com | Rel-8 | CP-41 | Kimmo | 23.205, 23.231, 29.002 | PCG-21 |  |  |  |
| 1008 | 342.6 | CAT Service in 3GPP CS domain |  | 57.95d? | 2008-09-12 A | 2008-12-05 A | 100% | 2008-09-12 | 2008-12-05 | 57.95d? | start no earlier than 2008-09-12 | C1 | 463.6h | 463.6h | CAT-3G_CS | China Mobile | zhaoyuyi@chinamobile.com | Rel-8 | CP-41 | Frederic | 24.008, 23.014 | PCG-21 |  |  |  |
| 1009 | 343 | **Service-Level Interworking for Messaging Services** |  | 509d? | 2007-03-26 A | 2009-03-06 A | 100% | 2007-03-26 | 2009-03-06 | 509d? |  | S1,S2,C3,C1 | 8584h | 8584h | MESSIW | Huawei | ling.liu@huawei.com; duanxiaoqin@huawei.com | Rel-8 |  | Alain |  |  |  |  |  |
| 1010 | 343.1 | Stage 1 for MESSIW | milestone | 0d? | 2007-03-26 A | 2007-03-26 A | 100% | 2007-03-26 | 2007-03-26 | 0d? | finish no earlier than 2007-12-01 | S1 |  |  | MESSIW | Huawei | ling.liu@huawei.com | Rel-8 |  | Alain | 22.105, 22.340 |  |  |  |  |
| 1011 | 343.2 | Stage 2 for MESSIW |  | 227d? | 2007-04-26 A | 2008-03-07 A | 100% | 2007-04-26 | 2008-03-07 | 227d? | finish no earlier than 2008-03-07 | S2 | 1816h | 1816h | MESSIW | Huawei | patrice.hede@huawei.com | Rel-8 |  | Maurice | 23.811, 23.204 |  |  |  |  |
| 1012 | 343.3 | Stage 3 for MESSIW |  | 201d? | 2008-05-30 A | 2009-03-06 A | 100% | 2008-05-30 | 2009-03-06 | 201d? | finish no earlier than 2008-12-05 | C3 | 1608h | 1608h | MESSIW | Huawei | xupeili@huawei.com | Rel-8 | CP-40 | Jiwan | 29.311 | PCG-21 |  |  |  |
| 1013 | 343.4 | Stage 3 for MESSIW |  | 136d? | 2008-05-30 A | 2008-12-05 A | 100% | 2008-05-30 | 2008-12-05 | 136d? | finish no earlier than 2008-12-12 | C1 | 1088h | 1088h | MESSIW | Huawei | xupeili@huawei.com | Rel-8 | CP-40 | Frederic | 24.229 | PCG-21 |  |  |  |
| 1014 | 344 | **Multimedia Priority Service** |  | 858d? | 2006-06-08 A | 2009-09-18 A | 100% | 2006-06-08 | 2009-09-18 | 858d? |  | S1,C1,C3,C4 | 22424h | 22424h | PRIOR | Telcordia | jgarraha@telcordia.com | Rel-8 | SP-34 | Alain |  |  |  |  |  |
| 1015 | 344.1 | Service Requirements for PRIOR |  | 391d? | 2006-06-08 A | 2007-12-06 A | 100% | 2006-06-08 | 2007-12-06 | 391d? | finish no earlier than 2007-11-30 | S1 | 3128h | 3128h | PRIOR-EMR | Telcordia | jgarraha@telcordia.com | Rel-8 | SP-32 | Alain | 22.153 |  |  |  |  |
| 1016 | 344.2 | Stage 3 for PRIOR |  | 732d? | 2006-12-01 A | 2009-09-18 A | 100% | 2006-12-01 | 2009-09-18 | 732d? | finish no earlier than 2009-09-18 | C1 | 5856h | 5856h | PRIOR | Alcatel-Lucent | Keith Drage (drage@alcatel-lucent.com) | Rel-8 | CP-34 | Frederic | 24.229 |  |  |  |  |
| 1017 | 344.3 | Stage 3 for PRIOR |  | 381d? | 2007-09-21 A | 2009-03-06 A | 100% | 2007-09-21 | 2009-03-06 | 381d? | finish no earlier than 2009-03-06 | C4 | 3048h | 3048h | PRIOR | Alcatel-Lucent | Keith Drage (drage@alcatel-lucent.com) | Rel-8 | CP-37 | Kimmo | 23.008, 29.228, 29.229 |  |  |  |  |
| 1018 | 344.4 | Deleted - Stage 3 for PRIOR |  | 441d? | 2007-09-21 A | 2009-05-29 A | 100% | 2007-09-21 | 2009-05-29 | 441d? | finish no earlier than 2009-05-29 | C3 | 3528h | 3528h | PRIOR | Alcatel-Lucent | Keith Drage (drage@alcatel-lucent.com) | Rel-8 | CP-37 | Jiwan | 29.212, 29.213, 29.214, 29.163 |  |  | PCG-23 | CP-44 |

Notes:
- 991: SP#43 Larger scope Feature UID_380057 (PWS) moved to Rel-9
- 992: SP#39 completed
- 993: SP#41 completed
- 994: CP#42 completed
- 995: CP#42 completed
- 996: SP#44 completed with CT1 help (GERAN2 LS_in SP-090154)
- 997: RP#47 completed. Testing for Rel-8 ETWS UID_370051
- 998: CP#43 completed (ICE Graphics not included in Rel-8)
- 999: SP#39 Stage 1 completed
- 1000: CP#43 completed (ICE Graphics not in Rel-8 / not explicitly in SA1 WID either)
- 1001: SP#39 Stage 1 completed
- 1002: CP#45 completed
- 1003: -
- 1004: SP#38 completed
- 1005: CP#42 completed
- 1006: CP#45 completed. Triggered by Study UID_360031 (TR 29.882)
- 1007: CP#43 completed. Triggered by Study UID_360031 (TR 29.882)
- 1008: CP#42 completed. Triggered by Study UID_360031 (TR 29.882)
- 1009: CP#43 completed
- 1010: SP#35 completed
- 1011: SP#39 completed
- 1012: CP#43 completed
- 1013: CP#42 completed
- 1014: CP#45 completed
- 1015: SP#38 completed
- 1016: CP#45 completed
- 1017: CP#43 completed
- 1018: CP#44 stopped (Reason: No Rel-8 solution expected (LS sent to SA2, but not prioritized in SA2)

| ID | WBS | Task | Duration | Start | Finish | Complete | Baseline start | Baseline finish | Baseline duration | Constraint | Resources | Work | Actual work | Text1 | Text4 | Text5 | Text6 | Text8 | Text3 | Text7 | Text2 | Text9 | Text12 | Text11 |
| --- | --- | --- | --- | --- | --- | --- | --- | --- | --- | --- | --- | --- | --- | --- | --- | --- | --- | --- | --- | --- | --- | --- | --- | --- |
| 1019 | 345 | **OSA Rel-8** | 202d? | 2007-08-23 A | 2008-05-30 A | 100% | 2007-08-23 | 2008-05-30 | 202d? |  | S1,C5 | 23552h | 23552h | OSA8 | Orange | Song Dong | Rel-8 | Alain |  |  |  |  |  |  |
| 1020 | 345.1 | OSA Stage 1 - Service Requirements | 145d? | 2007-08-23 A | 2008-03-12 A | 100% | 2007-08-23 | 2008-03-12 | 145d? | finish no earlier than 2007-12-04 | S1 | 1160h | 1160h | OSA8 | Orange, AePONA | Song Dong | Rel-8 | Alain | 22.127 |  |  |  |  |  |
| 1021 | 345.2 | OSA Stage 1 - NGN Service Requirement | 140d? | 2007-09-03 A | 2008-03-14 A | 100% | 2007-09-03 | 2008-03-14 | 140d? | finish no earlier than 2008-03-14 | S1 | 1120h | 1120h | OSA8-IMS | Orange | Song Dong | Rel-8 | Alain | 22.127 | SP-37 |  |  |  |  |
| 1022 | 345.3 | **OSA Stage 2/3 enhancements** | 157d? | 2007-10-25 A | 2008-05-30 A | 100% | 2007-10-25 | 2008-05-30 | 157d? |  | C5 | 20016h | 20016h | OSA8 | Alcatel-Lucent | unmehopa@alcatel-lucent.com | Rel-8 | Kimmo | 23.198, 29.198, 29.199 |  |  |  |  |  |
| 1023 | 345.3.1 | Deleted - Ensure Parlay-X composable with identity management frameworks, in particular Liberty Alliance | 157d? | 2007-10-25 A | 2008-05-30 A | 100% | 2007-10-25 | 2008-05-30 | 157d? | finish no earlier than 2008-12-25 | C5 | 1256h | 1256h | OSA8 | Ericsson | catherine.mulligan@ericsson.com | Rel-8 | Kimmo | existing 29.199-xy | CP-37 | PCG-21 | PCG-21 | CP-40 |  |
| 1024 | 345.3.2 | Parlay-X Content Management web service (store/manage meta-data) | 157d? | 2007-10-25 A | 2008-05-30 A | 100% | 2007-10-25 | 2008-05-30 | 157d? | finish no earlier than 2008-12-04 | C5 | 1256h | 1256h | OSA8 | Alcatel-Lucent | unmehopa@alcatel-lucent.com | Rel-8 | Kimmo | 29.199-21 | CP-37 |  |  |  |  |
| 1025 | 345.3.3 | Parlay-X Policy web service | 157d? | 2007-10-25 A | 2008-05-30 A | 100% | 2007-10-25 | 2008-05-30 | 157d? | finish no earlier than 2008-12-04 | C5 | 1256h | 1256h | OSA8 | Alcatel-Lucent | unmehopa@alcatel-lucent.com | Rel-8 | Kimmo | 29.199-22 | CP-37 |  |  |  |  |
| 1026 | 345.3.4 | Parlay-X Terminal status web service | 157d? | 2007-10-25 A | 2008-05-30 A | 100% | 2007-10-25 | 2008-05-30 | 157d? | finish no earlier than 2008-05-30 | C5 | 1256h | 1256h | OSA8 | Alcatel-Lucent | unmehopa@alcatel-lucent.com | Rel-8 | Kimmo | 29.199-08 | CP-37 |  |  |  |  |
| 1027 | 345.3.5 | Deleted - Identify communication format used by a particular application | 157d? | 2007-10-25 A | 2008-05-30 A | 100% | 2007-10-25 | 2008-05-30 | 157d? | finish no earlier than 2008-05-30 | C5 | 1256h | 1256h | OSA8 | Ericsson | catherine.mulligan@ericsson.com | Rel-8 | Kimmo | existing 29.199-xy | CP-37 | PCG-21 | PCG-21 | CP-40 |  |
| 1028 | 345.3.6 | Deleted - Security on User Profile Management - reuse GUP API (22.127 CR 0084 S1-071794) | 128d? | 2007-12-05 A | 2008-05-30 A | 100% | 2007-12-05 | 2008-05-30 | 128d? | finish no earlier than 2008-12-25 | C5 | 1024h | 1024h | OSA8 | Telecom Italia | vincenzo.amorino@telecomitalia.it | Rel-8 | Kimmo | PXWS Framework | CP-38 | PCG-21 | PCG-21 | CP-40 |  |
| 1029 | 345.3.7 | Deleted - Privacy on Subscriber Identity (Liberty Alliance, OASIS) (22.127 CR 0085 S1-071835) | 128d? | 2007-12-05 A | 2008-05-30 A | 100% | 2007-12-05 | 2008-05-30 | 128d? | finish no earlier than 2008-12-25 | C5 | 1024h | 1024h | OSA8 | Telecom Italia | vincenzo.amorino@telecomitalia.it | Rel-8 | Kimmo | PXWS Framework | CP-38 | PCG-21 | PCG-21 | CP-40 |  |
| 1030 | 345.3.8 | Deleted - Topology Hiding (22.127 CR 0086 S1-071838) | 128d? | 2007-12-05 A | 2008-05-30 A | 100% | 2007-12-05 | 2008-05-30 | 128d? | finish no earlier than 2008-12-25 | C5 | 1024h | 1024h | OSA8 | Telecom Italia | vincenzo.amorino@telecomitalia.it | Rel-8 | Kimmo | PXWS Framework | CP-38 | PCG-21 | PCG-21 | CP-40 |  |
| 1031 | 345.3.9 | Deleted - Subscriber event notification (22.127 CR 0087 S1-071836) | 128d? | 2007-12-05 A | 2008-05-30 A | 100% | 2007-12-05 | 2008-05-30 | 128d? | finish no earlier than 2008-12-25 | C5 | 1024h | 1024h | OSA8 | Telecom Italia | vincenzo.amorino@telecomitalia.it | Rel-8 | Kimmo | PXWS Framework | CP-38 | PCG-21 | PCG-21 | CP-40 |  |
| 1032 | 345.3.10 | Deleted - Event notification (22.127 CR 0088 S1-071762) | 128d? | 2007-12-05 A | 2008-05-30 A | 100% | 2007-12-05 | 2008-05-30 | 128d? | finish no earlier than 2008-12-25 | C5 | 1024h | 1024h | OSA8 | Telecom Italia | vincenzo.amorino@telecomitalia.it | Rel-8 | Kimmo | PXWS Framework | CP-38 | PCG-21 | PCG-21 | CP-40 |  |
| 1033 | 345.3.11 | Deleted - Access policy (22.127 CR 0089 S1-071763) | 128d? | 2007-12-05 A | 2008-05-30 A | 100% | 2007-12-05 | 2008-05-30 | 128d? | finish no earlier than 2008-12-25 | C5 | 1024h | 1024h | OSA8 | Telecom Italia | vincenzo.amorino@telecomitalia.it | Rel-8 | Kimmo | PXWS Framework | CP-38 | PCG-21 | PCG-21 | CP-40 |  |
| 1034 | 345.3.12 | Deleted - API usage accounting (22.127 CR 0090 S1-071792) | 128d? | 2007-12-05 A | 2008-05-30 A | 100% | 2007-12-05 | 2008-05-30 | 128d? | finish no earlier than 2008-12-25 | C5 | 1024h | 1024h | OSA8 | Telecom Italia | vincenzo.amorino@telecomitalia.it | Rel-8 | Kimmo | PXWS Framework | CP-38 | PCG-21 | PCG-21 | CP-40 |  |
| 1035 | 345.3.13 | Presence alignment with OMA and IETF (22.127 CR 0092 S1-071764) | 128d? | 2007-12-05 A | 2008-05-30 A | 100% | 2007-12-05 | 2008-05-30 | 128d? | finish no earlier than 2008-05-30 | C5 | 1024h | 1024h | OSA8 | Alcatel-Lucent | unmehopa@alcatel-lucent.com | Rel-8 | Kimmo | 29.199-14/13 | CP-38 | PCG-21 |  |  |  |
| 1036 | 345.3.14 | Deleted - Service identification (22.127 CR 0095 S1-071837) | 128d? | 2007-12-05 A | 2008-05-30 A | 100% | 2007-12-05 | 2008-05-30 | 128d? | finish no earlier than 2008-05-30 | C5 | 1024h | 1024h | OSA8 | Ericsson | catherine.mulligan@ericsson.com | Rel-8 | Kimmo | existing 29.199-xy | CP-38 | PCG-21 | PCG-21 | CP-40 |  |
| 1037 | 345.3.15 | Framework Enterprise Operator (Service Subscription function) | 102d? | 2008-01-10 A | 2008-05-30 A | 100% | 2008-01-10 | 2008-05-30 | 102d? | finish no earlier than 2008-05-30 | C5 | 816h | 816h | OSA8 | Alcatel-Lucent | unmehopa@alcatel-lucent.com | Rel-8 | Kimmo | 29.198-03 | CP-39 | PCG-21 |  |  |  |
| 1038 | 345.3.16 | Mobility Emergency Location | 102d? | 2008-01-10 A | 2008-05-30 A | 100% | 2008-01-10 | 2008-05-30 | 102d? | finish no earlier than 2008-05-30 | C5 | 816h | 816h | OSA8 | Alcatel-Lucent | unmehopa@alcatel-lucent.com | Rel-8 | Kimmo | 29.198-06 | CP-39 | PCG-21 |  |  |  |
| 1039 | 345.3.17 | Connectivity Manager SCF | 102d? | 2008-01-10 A | 2008-05-30 A | 100% | 2008-01-10 | 2008-05-30 | 102d? |  | C5 | 816h | 816h | OSA8 | Alcatel-Lucent | unmehopa@alcatel-lucent.com | Rel-8 | Kimmo | 29.198-10 | CP-39 | PCG-21 |  |  |  |
| 1040 | 345.3.18 | PAM Presence Agent | 102d? | 2008-01-10 A | 2008-05-30 A | 100% | 2008-01-10 | 2008-05-30 | 102d? | finish no earlier than 2008-05-30 | C5 | 816h | 816h | OSA8 | Alcatel-Lucent | unmehopa@alcatel-lucent.com | Rel-8 | Kimmo | 29.198-14 | CP-39 | PCG-21 |  |  |  |
| 1041 | 346 | **Paging Permission with Access Control (PPACR)** | 389d? | 2007-06-12 A | 2008-12-05 A | 100% | 2007-06-12 | 2008-12-05 | 389d? |  | S1,C1 | 5888h | 5888h | PPACR | NTT DoCoMo | Morita Takashi | Rel-8 | Alain |  |  |  |  |  |  |
| 1042 | 346.1 | Stage 1 for PPACR | 69d? | 2007-06-12 A | 2007-09-14 A | 100% | 2007-06-12 | 2007-09-14 | 69d? | finish no earlier than 2007-09-14 | S1 | 552h | 552h | PPACR-S1 | NTT DoCoMo | Morita Takashi | Rel-8 | Alain | 22.011 | SP-37 |  |  |  |  |
| 1043 | 346.2 | Stage 3 for PPACR (CT1) | 278d? | 2007-11-14 A | 2008-12-05 A | 100% | 2007-11-14 | 2008-12-05 | 278d? | finish no earlier than 2008-12-05 | C1 | 2224h | 2224h | PPACR-CT1 | NTT DoCoMo |  | Rel-8 | Frederic | 24.008, 23.122, 24.301 | CP-38 | PCG-21 |  |  |  |
| 1044 | 347 | Conformance Test Aspects – Paging Permission with Access Control (PPAC) | 61d? | 2010-09-17 A | 2010-12-10 A | 100% | 2010-09-17 | 2010-12-10 | 61d? | finish no earlier than 2010-12-10 | R5 | 488h | 488h | PPAC_UEConTest | NTT DoCoMo | Takao.Shimizu.rp@nttdocomo.com | Rel-8 | Ingbert | UTRA 34.108, 34.123-1, 34.123-2, 34.123-3 | RP-49 | PCG-25 |  |  | RP-101074 |

Notes:
- 1019: SP#40 maintenance & new OSA work moved to OMA. Rel-9 onwards 3GPP references to 22.127 changed to OMA Parlay Service Access Requirements (OMA-RD-Parlay_Service_Access-V1_0-20100427-A).
- 1020: SP#40 maintenance & new OSA work moved to OMA. Rel-9 onwards 3GPP references to 22.127 changed to OMA Parlay Service Access Requirements (OMA-RD-Parlay_Service_Access-V1_0-20100427-A).
- 1021: SP#40 maintenance & new OSA work moved to OMA
- 1022: SP#40 maintenance & new OSA work moved to OMA
- 1023: CP#40: Work moved to OMA
- 1024: CP#40 completed
- 1025: CP#40 completed
- 1026: CP#40 completed
- 1027: CP#40: Work moved to OMA
- 1028: SP#38 SP-070853 R8 CRs 22.127 OSA Stage 1. CP#40: Work moved to OMA
- 1029: SP#38 SP-070853 R8 CRs 22.127 OSA Stage 1. CP#40: Work moved to OMA
- 1030: SP#38 SP-070853 R8 CRs 22.127 OSA Stage 1. CP#40: Work moved to OMA
- 1031: SP#38 SP-070853 R8 CRs 22.127 OSA Stage 1. CP#40: Work moved to OMA
- 1032: SP#38 SP-070853 R8 CRs 22.127 OSA Stage 1. CP#40: Work moved to OMA
- 1033: SP#38 SP-070853 R8 CRs 22.127 OSA Stage 1. CP#40: Work moved to OMA
- 1034: SP#38 SP-070853 R8 CRs 22.127 OSA Stage 1. CP#40: Work moved to OMA
- 1035: CP#40 completed
- 1036: SP#38 SP-070853 R8 CRs 22.127 OSA Stage 1. CP#40: Work moved to OMA
- 1037: CP#40 completed
- 1038: CP#40 completed
- 1039: CP#40 completed
- 1040: CP#40 completed
- 1041: CP#42 completed. Triggered by Study UID_330016 (PPAC).
- 1042: SP#37 completed
- 1043: CP#42 completed
- 1044: RP#50 completed

| ID | WBS | Task | Duration | Start | Finish | Complete | Baseline start | Baseline finish | Baseline duration | Constraint | Resources | Work | Actual work | Text1 | Text2 | Text4 | Text6 | Text7 | Text8 | Text11 | Text12 |
| --- | --- | --- | --- | --- | --- | --- | --- | --- | --- | --- | --- | --- | --- | --- | --- | --- | --- | --- | --- | --- | --- |
| 1045 | 348 | **Charging for multi-phases services** | 70d? | 2007-12-06 A | 2008-03-12 A | 100% | 2007-12-06 | 2008-03-12 | 70d? |  | S1 | 560h | 560h | CHRGMPH | PCG-21 | Telecom Italia | Rel-8 | SP-38 | Alain |  |  |
| 1046 | 348.1 | Stage 1 for CHRGMPH | 70d? | 2007-12-06 A | 2008-03-12 A | 100% | 2007-12-06 | 2008-03-12 | 70d? | start no earlier than 2007-12-06 | S1 | 560h | 560h | CHRGMPH-s1 | PCG-21 | Telecom Italia | Rel-8 | SP-38 | Alain |  |  |
| 1047 | 349 | **Home NodeB / eNodeB** | 327d? | 2007-12-06 A | 2009-03-06 A | 100% | 2007-12-06 | 2009-03-06 | 327d? |  | S1,C1,C4 | 5720h | 5720h | HomeNB | PCG-21 | Vodafone | Rel-8 | SP-38 | Alain |  |  |
| 1048 | 349.1 | Stage 1 for Home NodeB / eNodeB | 70d? | 2007-12-06 A | 2008-03-12 A | 100% | 2007-12-06 | 2008-03-12 | 70d? | start no earlier than 2007-12-06 | S1 | 560h | 560h | HomeNB-S1 | PCG-21 | Vodafone | Rel-8 | SP-38 | Alain |  |  |
| 1049 | 349.2 | Support of Closed Subscriber Group (CSG) | 66d? | 2008-12-05 A | 2009-03-06 A | 100% | 2008-12-05 | 2009-03-06 | 66d? | finish no earlier than 2009-03-06 | C4 | 528h | 528h | HomeNB | PCG-22 | CT#42 | Rel-8 | CP-42 | Kimmo |  |  |
| 1050 | 349.3 | CSG and Idle Mode Mobility for LTE Home eNodeB | 126d? | 2008-09-12 A | 2009-03-06 A | 100% | 2008-09-12 | 2009-03-06 | 126d? | finish no earlier than 2009-03-06 | C1 | 1008h | 1008h | HomeNB-LTE | PCG-21 | Huawei | Rel-8 | CP-41 | Frederic |  |  |
| 1051 | 349.4 | CSG and Idle Mode Mobility for 3G Home NodeB | 126d? | 2008-09-12 A | 2009-03-06 A | 100% | 2008-09-12 | 2009-03-06 | 126d? | finish no earlier than 2009-03-06 | C1 | 1008h | 1008h | HomeNB-3G | PCG-21 | Qualcomm | Rel-8 | CP-41 | Frederic |  |  |
| 1052 | 350 | **UTRA HNB** | 326d? | 2008-03-07 A | 2009-06-04 A | 100% | 2008-03-07 | 2009-06-04 | 326d? |  | RP,S5 | 6832h | 6832h | HNB | PCG-21 |  | Rel-8 | SP-39 | Issam |  |  |
| 1053 | 350.1 | Support of UTRA HNB | 201d? | 2008-05-30 A | 2009-03-06 A | 100% | 2008-05-30 | 2009-03-06 | 201d? | finish no earlier than 2009-03-06 | R2 | 1608h | 1608h | HNB-supp | PCG-21 | Huawei | Rel-8 | SP-40 | Joern | RP-090040 |  |
| 1054 | 350.2 | UTRAN Architecture for 3G HNB | 136d? | 2008-05-30 A | 2008-12-05 A | 100% | 2008-05-30 | 2008-12-05 | 136d? | finish no earlier than 2008-12-05 | R3 | 1088h | 1088h | HNB-arch | PCG-21 | Alcatel-Lucent | Rel-8 | SP-40 | Juha | RP-090042 |  |
| 1055 | 350.3 | FDD Home NodeB RF requirements | 261d? | 2008-03-07 A | 2009-03-06 A | 100% | 2008-03-07 | 2009-03-06 | 261d? | finish no earlier than 2009-03-06 | R4 | 2088h | 2088h | HNB-RF | PCG-21 | Motorola | Rel-8 | SP-39 | Issam | RP-090041 |  |
| 1056 | 350.4 | 3G Home NodeB OAM&P Type 1 Management Interface | 127d? | 2008-12-11 A | 2009-06-04 A | 100% | 2008-12-11 | 2009-06-04 | 127d? | finish no earlier than 2009-06-04 | S5 | 1008h | 1008h | HNB-3G_OAM | PCG-22 | Huawei | Rel-8 | SP-42 | Dionisio |  |  |
| 1057 | 351 | **UTRA HNB – UE Conformance Testing** | 327d? | 2009-03-06 A | 2010-06-04 A | 100% | 2009-03-06 | 2010-06-04 | 327d? |  | R5 | 5224h | 5224h | HNB-UEConTest | PCG-22 |  | Rel-8 | RP-43 | Ingbert |  |  |
| 1058 | 351.1 | Conformance Test Aspects – UTRA HNB (FDD) | 326d? | 2009-03-06 A | 2010-06-04 A | 100% | 2009-03-06 | 2010-06-04 | 326d? | finish no earlier than 2010-06-04 | R5 | 2608h | 2608h | HNB-UEConTestFDD | PCG-22 | Huawei | Rel-8 | RP-43 | Ingbert | RP-100482 |  |
| 1059 | 352 | Lawful Interception in the 3GPP Rel-8 | 524d? | 2007-03-12 A | 2009-03-12 A | 100% | 2007-03-12 | 2009-03-12 | 524d? | finish no earlier than 2009-03-12 | S3 | 4192h | 4192h | LI8 |  | BMWI, Verizon | Rel-8 |  | Dionisio |  |  |
| 1060 | 353 | **Generic Bootstrapping Architecture Push Function** | 258d? | 2008-03-12 A | 2009-03-06 A | 100% | 2008-03-12 | 2009-03-06 | 258d? |  | S3,C1,C4 | 6468.8h | 6468.8h | GBAPush | PCG-21 | Ericsson | Rel-8 | SP-39 | Dionisio |  |  |
| 1061 | 353.1 | SA3 part of GBAPush (33.223) | 193d? | 2008-03-12 A | 2008-12-05 A | 100% | 2008-03-12 | 2008-12-05 | 193d? | finish no earlier than 2008-12-05 | S3 | 1544h | 1544h | GBAPush | PCG-21 | Ericsson | Rel-8 | SP-39 | Dionisio |  |  |
| 1062 | 353.2 | CT1 part of GBAPush | 178.8d? | 2008-03-12 A | 2009-03-06 A | 100% | 2008-03-12 | 2009-03-06 | 178.8d? | finish no earlier than 2009-03-06 | C1 | 1430.4h | 1430.4h | GBAPush | PCG-21 | Ericsson | Rel-8 | SP-39 | Frederic |  |  |
| 1063 | 353.3 | CT4 part of GBAPush | 178.8d? | 2008-03-12 A | 2009-03-06 A | 100% | 2008-03-12 | 2009-03-06 | 178.8d? | finish no earlier than 2009-03-06 | C4 | 1430.4h | 1430.4h | GBAPush | PCG-21 | Ericsson | Rel-8 | SP-39 | Kimmo |  |  |
| 1064 | 354 | Requirements and Test methods for Wideband Terminals | 197d? | 2008-03-12 A | 2008-12-11 A | 100% | 2008-03-12 | 2008-12-11 | 197d? | start no earlier than 2008-03-12 | S4 | 1576h | 1576h | RETEM_WB_T |  | FT, Ericsson | Rel-8 |  | Paolo |  |  |
| 1065 | 355 | Extending PSS and MBMS User Services for optimized Mobile TV | 266d? | 2007-12-06 A | 2008-12-11 A | 100% | 2007-12-06 | 2008-12-11 | 266d? | finish no earlier than 2008-12-11 | S4 | 2128h | 2128h | PSS_MBMS_OMTV |  | Ericsson | Rel-8 |  | Paolo |  |  |
| 1066 | 356 | **Encoding formats, transport formats and media description signalling for interworking, QoE, and other enhancements to MTSI-MHI** | 331d? | 2007-12-06 A | 2009-03-12 A | 100% | 2007-12-06 | 2009-03-12 | 331d? |  | S4,C3,C4 | 9640h | 9640h | MTSI_eMHI | PCG-21 | Ericsson, Qualcomm | Rel-8 | SP-40 | Paolo |  |  |
| 1067 | 356.1 | MTSI Video - Dynamic Rate Adaptation/Signalling of Image Size | 331d? | 2007-12-06 A | 2009-03-12 A | 100% | 2007-12-06 | 2009-03-12 | 331d? | finish no earlier than 2009-03-12 | S4 | 2648h | 2648h | MTSI_eMHI-DRASIS |  | Qualcomm, Samsung | Rel-8 |  | Paolo |  |  |
| 1068 | 356.2 | CT3 part of Enhancement of interworking between MTSI and CS networks | 201d? | 2008-05-30 A | 2009-03-06 A | 100% | 2008-05-30 | 2009-03-06 | 201d? | finish no earlier than 2009-03-06 | C3 | 1608h | 1608h | MTSI_eMHI | PCG-21 | Huawei | Rel-8 | CP-40 | Jiwan |  |  |
| 1069 | 356.3 | CT4 part of Enhancement of interworking between MTSI and CS networks | 201d? | 2008-05-30 A | 2009-03-06 A | 100% | 2008-05-30 | 2009-03-06 | 201d? | finish no earlier than 2009-03-06 | C4 | 1608h | 1608h | MTSI_eMHI | PCG-21 | Huawei | Rel-8 | CP-40 | Kimmo |  |  |
| 1070 | 356.4 | Deleted - CT1 part of Enhancement of interworking between MTSI and CS networks | 141d? | 2008-05-30 A | 2008-12-12 A | 100% | 2008-05-30 | 2008-12-12 | 141d? | start no earlier than 2008-05-30 | C1 | 1128h | 1128h | MTSI_eMHI | PCG-21 | Huawei | Rel-8 | CP-40 | Frederic |  | CP-42 |

Notes:
- 1045: SP#39 Stage 1 completed / Text3: 22.115 / Text5: Marco.DeLuca1@telecomitalia.it
- 1046: SP#39 completed / Text3: 22.115 / Text5: Marco.DeLuca1@telecomitalia.it
- 1047: CP#43 completed / Text5: John Watson
- 1048: SP#39 completed / Text3: 22.011, 22.115 / Text5: John Watson
- 1049: CP#43 completed. SP#42 SP-080874 22.011CR0141 confirmed Requirement to support roaming subscribers with CSG home network subscription but did NOT confirmed requirement for home network independent support of roamers in CSG / Text3: 29.002, 29.272, 23.008, 23.003 / Text5: Hannu Hietalahti
- 1050: CP#43 completed / Text3: 23.122, new (24.285, 24.301, 24.801) / Text5: zhang.peng@huawei.com
- 1051: CP#43 completed / Text3: 23.122, 24.008, new 24.285 / Text5: Osok Song
- 1052: SP#44 completed
- 1053: RP#43 completed / Text3: 25.304, 25.306, 25.331, new 25.367 / Text5: Yang Xudong (yangxudong@huawei.com)
- 1054: RP#42 completed / Text3: 25.401, 25.410, 25.412, 25.413, 25.414, 25.415, new (25.467, 25.468, 25.469) / Text5: Martin Warner (mw15@alcatel-lucent.com)
- 1055: RP#43 completed / Text3: 25.104, 25.141, new 25.967 / Text5: Ying Cai (yingcai@motorola.com)
- 1056: SP#44 completed. Complements work in BroadBand Forum / Text3: new (32.581, 32.582, 32.583, 32.584) / Text5: Zou Lan (zlan@huawei.com)
- 1057: RP#48 FDD completed. Testing for Feature UID_390033 UTRA HNB
- 1058: RP#48 completed / Text3: 34.108, 34.123-1, 34.123-2, 34.123-3 / Text5: Trica Li (trica_li@huawei.com)
- 1059: SP#43 completed / Text3: 33.106, 33.107, 33.108 / Text5: berthold.wilhelm@bnetza.de, ron_ryan@verizon.net
- 1060: CP#43 completed / Text5: Rolf Blom
- 1061: SP#42 completed 33.223 as Rel-8. TS 33.224 moved to Rel-9 under new UID_420039 / Text3: 33.223 / Text5: Rolf Blom
- 1062: CP#43 completed / Text3: 24.109 / Text5: Rolf Blom
- 1063: CP#43 completed / Text3: 29.109 / Text5: Rolf Blom
- 1064: SP#42 completed. SP#39 WID approved. / Text3: 26.131, 26.132 / Text5: stephane.ragot@orange-ftgroup.com, wanqing.shi@sonyericsson.com
- 1065: SP#42 completed. SP#38 WID approved. / Text3: 26.234, 26.346, 26.946 / Text5: thorsten.lohmar@ericsson.com
- 1066: TSG#43 completed / Text5: olle.franceschi@ericsson.com, nleung@qualcomm.com
- 1067: SP#43 completed / Text3: 26.114 / Text5: nleung@qualcomm.com & kyunghun.jung@samsung.com
- 1068: CP#43 completed / Text3: 29.163 / Text5: Tingfang Tang (tagna_online@huawei.com)
- 1069: CP#43 completed / Text3: 29.332 / Text5: Tingfang Tang (tagna_online@huawei.com)
- 1070: CP#42 stopped (No CT1-impact). WID updated CP-080422=>CP-080774 / Text5: Tingfang Tang (tagna_online@huawei.com)

| ID | WBS | Task | Duration | Start | Finish | Complete | Baseline start | Baseline finish | Baseline duration | Constraint | Resources | Work | Actual work | Text1 | Text6 | Text8 | Text4 | Text2 | Text7 | Text9 | Text12 |
| --- | --- | --- | --- | --- | --- | --- | --- | --- | --- | --- | --- | --- | --- | --- | --- | --- | --- | --- | --- | --- | --- |
| 1071 | 357 | **OAM&P 8** | 653d? | 2007-06-07 A | 2009-12-04 A | 100% | 2007-06-07 | 2009-12-04 | 653d? |  | S5,C1,C4 | 44177.6h | 44177.6h | OAM8 | Rel-8 | Dionisio |  |  |  |  |  |
| 1072 | 357.1 | **Network Infrastructure Management** | 653d? | 2007-06-07 A | 2009-12-04 A | 100% | 2007-06-07 | 2009-12-04 | 653d? |  | S5 | 19464h | 19464h | OAM8-NIM | Rel-8 | Dionisio |  |  |  |  |  |
| 1073 | 357.1.1 | Telecom Management Methodology | 461d? | 2007-06-07 A | 2009-03-12 A | 100% | 2007-06-07 | 2009-03-12 | 461d? | finish no earlier than 2009-03-12 | S5 | 3688h | 3688h | OAM8 | Rel-8 | Dionisio | Ericsson |  |  |  |  |
| 1074 | 357.1.2 | Advanced Alarming on Itf-N | 266d? | 2007-06-07 A | 2008-06-12 A | 100% | 2007-06-07 | 2008-06-12 | 266d? | finish no earlier than 2008-12-11 | S5 | 2128h | 2128h | OAM8 | Rel-8 | Dionisio | Nokia Siemens Networks |  |  |  |  |
| 1075 | 357.1.3 | CN CS Bearer Transport Network (BTN) relative NRM | 266d? | 2007-06-07 A | 2008-06-12 A | 100% | 2007-06-07 | 2008-06-12 | 266d? | finish no earlier than 2008-12-11 | S5 | 2128h | 2128h | OAM8 | Rel-8 | Dionisio | China Mobile |  |  |  |  |
| 1076 | 357.1.4 | Alignment with eTOM and M.3060 architectural concepts | 210d? | 2008-02-22 A | 2008-12-11 A | 100% | 2008-02-22 | 2008-12-11 | 210d? | start no earlier than 2008-02-22 | S5 | 1680h | 1680h | OAM8 | Rel-8 | Dionisio | TeliaSonera | PCG-21 | SP-39 |  |  |
| 1077 | 357.1.5 | IRP SOAP Solution Sets | 201d? | 2008-06-05 A | 2009-03-12 A | 100% | 2008-06-05 | 2009-03-12 | 201d? | finish no earlier than 2009-03-12 | S5 | 1608h | 1608h | OAM8 | Rel-8 | Dionisio | Ericsson | PCG-21 | SP-40 |  |  |
| 1078 | 357.1.6 | Create missing specifications for IRP XML definitions | 52d? | 2009-09-24 A | 2009-12-04 A | 100% | 2009-09-24 | 2009-12-04 | 52d? | finish no earlier than 2010-03-12 | S5 | 416h | 416h | OAM8 | Rel-8 | Dionisio | ZTE | PCG-23 | SP-45 |  |  |
| 1079 | 357.1.7 | Deleted - End point modelling for reference point | 324d? | 2007-09-17 A | 2008-12-11 A | 100% | 2007-09-17 | 2008-12-11 | 324d? | finish no earlier than 2008-12-11 | S5 | 2592h | 2592h | OAM8 | Rel-8 | Dionisio | Motorola |  | SP-37 | PCG-21 | SP-41 |
| 1080 | 357.2 | **Performance Management** | 461d? | 2007-06-07 A | 2009-03-12 A | 100% | 2007-06-07 | 2009-03-12 | 461d? |  | S5 | 13712h | 13712h | OAM8-PM | Rel-8 | Dionisio |  |  |  |  |  |
| 1081 | 357.2.1 | IP bearer network Performance measurement definitions | 396d? | 2007-06-07 A | 2008-12-11 A | 100% | 2007-06-07 | 2008-12-11 | 396d? | finish no earlier than 2008-12-11 | S5 | 3168h | 3168h | OAM8 | Rel-8 | Dionisio | China Mobile |  |  |  |  |
| 1082 | 357.2.2 | HSUPA performance measurements | 396d? | 2007-06-07 A | 2008-12-11 A | 100% | 2007-06-07 | 2008-12-11 | 396d? | finish no earlier than 2008-12-11 | S5 | 3168h | 3168h | OAM8 | Rel-8 | Dionisio | China Mobile |  |  |  |  |
| 1083 | 357.2.3 | Key Performance Indicators (KPIs) for UMTS and GSM | 461d? | 2007-06-07 A | 2009-03-12 A | 100% | 2007-06-07 | 2009-03-12 | 461d? | finish no earlier than 2009-03-12 | S5 | 3688h | 3688h | OAM8 | Rel-8 | Dionisio | China Mobile |  |  |  |  |
| 1084 | 357.3 | **Trace Management** | 196d? | 2008-03-07 A | 2008-12-05 A | 100% | 2008-03-07 | 2008-12-05 | 196d? |  | S5,C1,C3,C4 | 5777.6h | 5777.6h | OAM8-Trace | Rel-8 | Dionisio |  |  |  |  |  |
| 1085 | 357.3.1 | Service Level Tracing in IMS | 196d? | 2008-03-07 A | 2008-12-05 A | 100% | 2008-03-07 | 2008-12-05 | 196d? | finish no earlier than 2008-12-05 | C1 | 1568h | 1568h | OAM8-Trace | Rel-8 | Frederic | Vodafone |  |  |  |  |
| 1086 | 357.3.2 | Service Level Tracing in IMS | 175.4d? | 2008-03-07 A | 2008-12-05 A | 100% | 2008-03-07 | 2008-12-05 | 175.4d? | finish no earlier than 2008-12-05 | C4 | 1403.2h | 1403.2h | OAM8-Trace | Rel-8 | Frederic | Vodafone | PCG-21 | CP-40 |  |  |
| 1087 | 357.3.3 | Deleted - Service Level Tracing in IMS | 175.4d? | 2008-03-07 A | 2008-12-05 A | 100% | 2008-03-07 | 2008-12-05 | 175.4d? | finish no earlier than 2008-12-05 | C3 | 1403.2h | 1403.2h | OAM8-Trace | Rel-8 | Jiwan | Vodafone | PCG-21 | CP-40 |  | CP-42 |
| 1088 | 358 | **Charging Management small Enhancements** | 716d? | 2006-03-16 A | 2008-12-11 A | 100% | 2006-03-16 | 2008-12-11 | 716d? |  | S5 | 12544h | 12544h | CH8 | Rel-8 | Dionisio |  |  |  |  |  |
| 1089 | 358.1 | Online charging correlation | 457d? | 2006-03-16 A | 2007-12-14 A | 100% | 2006-03-16 | 2007-12-14 | 457d? | start no earlier than 2006-03-16 | S5 | 3656h | 3656h | CH8 | Rel-8 | Dionisio | Orange |  |  |  |  |
| 1090 | 358.2 | SMS online charging | 137d? | 2007-06-07 A | 2007-12-14 A | 100% | 2007-06-07 | 2007-12-14 | 137d? | finish no earlier than 2007-12-14 | S5 | 1096h | 1096h | CH8 | Rel-8 | Dionisio | Vodafone |  |  |  |  |
| 1091 | 358.3 | Introduce Online Charging from SMS-SC into the SMS Charging Specifications | 61d? | 2008-09-18 A | 2008-12-11 A | 100% | 2008-09-18 | 2008-12-11 | 61d? | finish no earlier than 2008-12-11 | S5 | 488h | 488h | CH8 | Rel-8 | Dionisio | Acision | PCG-21 | SP-41 |  |  |
| 1092 | 358.4 | Deleted - WLAN Offline Charging | 244d? | 2008-01-07 A | 2008-12-11 A | 100% | 2008-01-07 | 2008-12-11 | 244d? | finish no earlier than 2008-12-11 | S5 | 1952h | 1952h | CH8 | Rel-8 | Dionisio | Alcatel-Lucent | PCG-21 | SP-38 | PCG-22 | SP-42 |
| 1093 | 359 | **Conferencing enhancements for Mp interface** | 266d? | 2007-11-30 A | 2008-12-05 A | 100% | 2007-11-30 | 2008-12-05 | 266d? |  | C4 | 6384h | 6384h | eMp | Rel-8 | Kimmo | Huawei | PCG-21 |  |  |  |
| 1094 | 359.1 | Stage 2 for eMp | 266d? | 2007-11-30 A | 2008-12-05 A | 100% | 2007-11-30 | 2008-12-05 | 266d? | finish no earlier than 2008-12-11 | C4 | 2128h | 2128h | eMp | Rel-8 | Kimmo | Huawei | PCG-21 | CP-38 |  |  |
| 1095 | 359.2 | Stage 3 for eMp | 266d? | 2007-11-30 A | 2008-12-05 A | 100% | 2007-11-30 | 2008-12-05 | 266d? | finish no earlier than 2008-12-05 | C4 | 2128h | 2128h | eMp | Rel-8 | Kimmo | Huawei | PCG-21 | CP-38 |  |  |

Notes:
- 1071: - / Text3: TR 30.818
- 1072: -
- 1073: SP#43 completed / Text3: 32.155, 32.153 / Text5: thomas.tovinger@ericsson.com
- 1074: SP#40 completed / Text3: 32.121, 32.122, 32.123 / Text5: SUERBAUM, Clemens
- 1075: SP#40 completed / Text3: 32.632, 32.633, 32.635 / Text5: Li Jian (lijian@chinamobile.com)
- 1076: SP#42 completed / Text3: 32.101/2, 32-series / Text5: tommy.berggren@teliasonera.com
- 1077: SP#43 completed / Text3: 32.111-7, 32.617, 32.417, 32.367, 32.347, 32.111-1, 32.111-2, 32.111-3, 32.111-5, 32.307, 32.317, 32.341, 32.342, 32.343, 32.345, 32.361, 32.362, 32.363, 32.365, 32.411, 32.412, 32.413, 32.415, 32.611, 32.612, 32.613, 32.615, 32.625 / Text5: edwin.tse@ericsson.com
- 1078: SP#46 completed. Create missing XML definitions specs for IRPs (Advanced Alarm Management, Communication Surveillance, Self-Configuration of Network Elements, Software Management) needed for implementation of Rel-8 Notification Log IRP (TS 32.33x) / Text3: new (32.125, 32.355, 32.505, 32.535), 32.150, 32.153, 32.335 / Text5: Shuqiang Huang (huangsq@zte.com.cn)
- 1079: SP#41 Work stopped. Contributions related to E-UTRAN/EPC to be submitted to UID_380036 E-UTRAN NRM IRP/ UID_380037 EPC NRM IRP / Text3: 32.152, 32.62/3/4x, 32.73x / Text5: Yizhi Yao (yzyao@motorola.com)
- 1080: - / Text5: Li Jian (lijian@chinamobile.com)
- 1081: SP#42 completed / Text3: 32.321, 32.322, 32.323, 32.325 / Text5: lilianyuan@chinamobile.com
- 1082: SP#42 completed / Text3: 32.405 / Text5: Li Jian (lijian@chinamobile.com)
- 1083: SP#43 completed / Text3: 32.410 / Text5: Li Jian (lijian@chinamobile.com), Liang Shuangchun (liangshuangchun@cmdi.chinamobile.com)
- 1084: -
- 1085: CP#42 completed / Text3: 24.323, 24.229 / Text5: peter.dawes@vodafone.com
- 1086: CP#42 completed / Text3: 29.228, 29.229 / Text5: peter.dawes@vodafone.com
- 1087: CP#42 stopped (No CT3-impact) / Text5: peter.dawes@vodafone.com
- 1088: SP#42 completed / Text3: TR 30.818
- 1089: SP#38 completed / Text3: 32.296 / Text5: Chahine, Rony
- 1090: SP#38 completed / Text3: 32.240, 32.299, new 32.274 / Text5: Gavin.Wong@vodafone.com
- 1091: SP#42 completed. Linked to SA2 UID 32081 (Support of SMS over IP networks) and CT4 UID 340016 (Routeing of MT-SMS via the HPLMN). / Text3: 32.274, 32.299 / Text5: erik.gebler@acision.com
- 1092: SP#42 stopped / Text3: 32.252, 32.298, 32.299 / Text5: Maryse.Gardella@alcatel.fr
- 1093: CP#42 completed / Text5: Chencheng@huawei.com
- 1094: CP#42 completed / Text3: 23.333 / Text5: Chencheng@huawei.com
- 1095: CP#42 completed / Text3: 29.333 / Text5: Chencheng@huawei.com

| ID | WBS | Task | Type | Duration | Start | Finish | Complete | Baseline start | Baseline finish | Baseline duration | Constraint | Resources | Work | Actual work | Text1 | Text4 | Text5 | Text6 | Text8 | Text7 | Text12 | Text11 | Text2 |
| --- | --- | --- | --- | --- | --- | --- | --- | --- | --- | --- | --- | --- | --- | --- | --- | --- | --- | --- | --- | --- | --- | --- | --- |
| 1096 | 360 | **Contact Manager for 3GPP UICC applications** |  | 642d? | 2006-06-22 A | 2008-12-05 A | 100% | 2006-06-22 | 2008-12-05 | 642d? |  | C6 | 13352h | 13352h | eUPHBOOK | Gemalto | Jacques.seif@gemalto.com | Rel-8 | Xavier |  |  |  |  |
| 1097 | 360.1 | Requirements for Contact Manager |  | 392d? | 2006-06-22 A | 2007-12-21 A | 100% | 2006-06-22 | 2007-12-21 | 392d? | finish no earlier than 2007-12-21 | C6 | 3136h | 3136h | eUPHBOOK-St1 | Gemalto | Jacques.seif@gemalto.com | Rel-8 | Xavier |  |  |  |  |
| 1098 | 360.2 | External interface for eUPHBOOK |  | 220d? | 2007-05-07 A | 2008-03-07 A | 100% | 2007-05-07 | 2008-03-07 | 220d? | finish no earlier than 2008-03-07 | C6 | 1760h | 1760h | eUPHBOOK-Ext_Spec | Gemalto | Jacques.seif@gemalto.com | Rel-8 | Xavier |  |  |  |  |
| 1099 | 360.3 | Internal interface for eUPHBOOK |  | 415d? | 2007-05-07 A | 2008-12-05 A | 100% | 2007-05-07 | 2008-12-05 | 415d? | finish no earlier than 2008-12-05 | C6 | 3320h | 3320h | eUPHBOOK-Int_Spec | Gemalto | Jacques.seif@gemalto.com | Rel-8 | Xavier | CP-37 |  |  |  |
| 1100 | 360.4 | Deleted - Implementation of eUPHBOOK | milestone | 0d? | 2007-06-21 A | 2007-06-21 A | 100% | 2007-06-21 | 2007-06-21 | 0d? | start no earlier than 2007-06-21 | C6 |  |  | eUPHBOOK-St23 | Giesecke & Devrient | Claus Dietze | Rel-8 | Xavier |  | SP-33 |  |  |
| 1101 | 361 | **Rel-8 LTE – 3G Long Term Evolution - Evolved Packet System RAN part** |  | 644d? | 2006-09-25 A | 2009-03-12 A | 100% | 2006-09-25 | 2009-03-12 | 644d? |  | RP,S5 | 44896h | 44896h | LTE | NTT DoCoMo | Takehiro Nakamura (nakamurata@nttdocomo.co.jp) | Rel-8 |  |  |  | RP-080741 |  |
| 1102 | 361.1 | LTE – Physical Layer |  | 380d? | 2006-09-25 A | 2008-03-07 A | 100% | 2006-09-25 | 2008-03-07 | 380d? | finish no earlier than 2007-09-14 | R1 | 3040h | 3040h | LTE-Phys | NTT DoCoMo | Sadayuki Abeta | Rel-8 | Patrick |  |  | RP-080741 |  |
| 1103 | 361.2 | LTE – Radio Interface Layer 2 and 3 Protocol Aspect |  | 575d? | 2006-09-25 A | 2008-12-05 A | 100% | 2006-09-25 | 2008-12-05 | 575d? | finish no earlier than 2008-12-11 | R2 | 4600h | 4600h | LTE-L23 | Nokia Siemens Networks | benoist.sebire@nokia.com | Rel-8 | Joern |  |  | RP-080741 |  |
| 1104 | 361.3 | LTE – eUTRAN Interfaces |  | 575d? | 2006-09-25 A | 2008-12-05 A | 100% | 2006-09-25 | 2008-12-05 | 575d? | finish no earlier than 2008-12-11 | R3 | 4600h | 4600h | LTE-interfaces | Ericsson | Martin Israelsson | Rel-8 | Juha |  |  | RP-080741 |  |
| 1105 | 361.4 | LTE – Evolved UTRA and UTRAN RF Radio Transmission/Reception, System Performance Requirements and Conformance Testing |  | 575d? | 2006-09-25 A | 2008-12-05 A | 100% | 2006-09-25 | 2008-12-05 | 575d? | finish no earlier than 2008-12-11 | R4 | 4600h | 4600h | LTE-RF | Nokia Siemens Networks | Tuomo Saynajakangas | Rel-8 | Issam |  |  | RP-080741 |  |
| 1106 | 361.5 | LTE – FDD repeaters |  | 386d? | 2007-09-14 A | 2009-03-06 A | 100% | 2007-09-14 | 2009-03-06 | 386d? | finish no earlier than 2009-03-06 | R4 | 3088h | 3088h | LTE-Repeaters | Powerwave Technologies, Andrew Wireless | ralf.michanikl@andrew.com, Alf.Ahlstrom@pwav.com | Rel-8 | Issam | RP-37 |  | RP-090037 |  |
| 1107 | 361.6 | **E-UTRAN Data Definitions** |  | 389d? | 2007-09-17 A | 2009-03-12 A | 100% | 2007-09-17 | 2009-03-12 | 389d? |  | S5 | 13096h | 13096h | E-UTRAN-OAM |  |  | Rel-8 | Dionisio | SP-39 |  |  | PCG-21 |
| 1108 | 361.6.1 | Subscriber and Equipment Trace for E-UTRAN and EPC |  | 389d? | 2007-09-17 A | 2009-03-12 A | 100% | 2007-09-17 | 2009-03-12 | 389d? | finish no earlier than 2009-03-12 | S5 | 3112h | 3112h | E-UTRAN-OAM | Ericsson | robert.petersen@ericsson.com | Rel-8 | Dionisio | SP-37 |  |  |  |
| 1109 | 361.6.2 | E-UTRAN Network Resource Model (NRM) Integration Reference Point (IRP) |  | 309d? | 2008-01-07 A | 2009-03-12 A | 100% | 2008-01-07 | 2009-03-12 | 309d? | finish no earlier than 2009-03-12 | S5 | 2472h | 2472h | E-UTRAN-OAM | Ericsson | ELMDAHL, Per | Rel-8 | Dionisio | SP-38 |  |  | PCG-21 |
| 1110 | 361.6.3 | Performance measurements for E-UTRAN |  | 275d? | 2008-02-22 A | 2009-03-12 A | 100% | 2008-02-22 | 2009-03-12 | 275d? | finish no earlier than 2009-03-12 | S5 | 2200h | 2200h | E-UTRAN-OAM | Motorola, Huawei | Yizhi Yao (yzyao@motorola.com) | Rel-8 | Dionisio | SP-39 |  |  | PCG-21 |
| 1111 | 361.6.4 | Key Performance Indicators (KPIs) for E-UTRAN |  | 275d? | 2008-02-22 A | 2009-03-12 A | 100% | 2008-02-22 | 2009-03-12 | 275d? | finish no earlier than 2009-03-12 | S5 | 2200h | 2200h | E-UTRAN-OAM | Ericsson | ulf.hubinette@ericsson.com | Rel-8 | Dionisio | SP-39 |  |  | PCG-21 |
| 1112 | 361.7 | **Self-Organizing Networks (SON)** |  | 210d? | 2008-02-22 A | 2008-12-11 A | 100% | 2008-02-22 | 2008-12-11 | 210d? |  | S5 | 6720h | 6720h | LTE_SON-OAM | Vodafone | GOMPAKIS, Panagiotis | Rel-8 | Dionisio | SP-39 |  |  | PCG-21 |
| 1113 | 361.7.1 | SON Concepts and requirements |  | 210d? | 2008-02-22 A | 2008-12-11 A | 100% | 2008-02-22 | 2008-12-11 | 210d? |  | S5 | 1680h | 1680h | LTE_SON-OAM | Vodafone | GOMPAKIS, Panagiotis | Rel-8 | Dionisio | SP-39 |  |  | PCG-21 |
| 1114 | 361.7.2 | Self-Establishment of eNBs, including automated Software Management |  | 210d? | 2008-02-22 A | 2008-12-11 A | 100% | 2008-02-22 | 2008-12-11 | 210d? | start no earlier than 2008-02-22 | S5 | 1680h | 1680h | LTE_SON-OAM | Nokia Siemens Networks | SUERBAUM, Clemens | Rel-8 | Dionisio | SP-39 |  |  | PCG-21 |
| 1115 | 361.7.3 | SON Automatic Neighbour Relations (ANR) List Management |  | 210d? | 2008-02-22 A | 2008-12-11 A | 100% | 2008-02-22 | 2008-12-11 | 210d? | finish no earlier than 2008-12-11 | S5 | 1680h | 1680h | LTE_SON-OAM | Ericsson | edwin.tse@ericsson.com | Rel-8 | Dionisio | SP-39 |  |  | PCG-21 |
| 1116 | 362 | **Rel-8 LTE – Terminal Conformance Test Specification** |  | 657d? | 2007-06-01 A | 2009-12-04 A | 100% | 2007-06-01 | 2009-12-04 | 657d? |  | R5 | 17544h | 17544h | LTE-UEConTest |  |  | Rel-8 | Ingbert |  |  |  |  |
| 1117 | 362.1 | 3G LTE – Terminal Protocol Conformance Test Specifications |  | 657d? | 2007-06-01 A | 2009-12-04 A | 100% | 2007-06-01 | 2009-12-04 | 657d? | finish no earlier than 2009-12-04 | R5 | 5256h | 5256h | LTE-UEConTest_SIG | NEC, Motorola | david.lecompte@nectech.fr, Jacob.John@motorola.com | Rel-8 | Ingbert |  |  | RP-091060 |  |
| 1118 | 362.2 | LTE – Terminal Radio Transmission and Reception Conformance Test Specifications |  | 657d? | 2007-06-01 A | 2009-12-04 A | 100% | 2007-06-01 | 2009-12-04 | 657d? |  | R5 | 5256h | 5256h | LTE-UEConTest_RF | Agilent | andrea_leonardi@agilent.com | Rel-8 | Ingbert |  |  | RP-091059 |  |
| 1119 | 362.3 | Deleted - LTE – Terminal Radio Transmission and Reception Conformance Test Specifications |  | 401d? | 2007-06-01 A | 2008-12-12 A | 100% | 2007-06-01 | 2008-12-12 | 401d? |  | R5 | 3208h | 3208h | LTE-UEConTest_RF | Agilent | andrea_leonardi@agilent.com | Rel-8 | Ingbert |  | RP-41 | RP-091059 |  |

Notes:
- 1096: CP#42 completed. CP#40: WID updated CP-070622=>CP-080382. aka Enhanced USIM phonebook
- 1097: CP#38 completed / Text3: 21.111
- 1098: CP#39 completed / Text3: new 31.220
- 1099: CP#42 completed / Text3: new 31.221
- 1100: SP#33 stopped / Text3: 31.102
- 1101: RP#43 completed. Role model for SAE/LTE system wide project management by SA2 in SP-060166 / Text3: 36.300, 36.938
- 1102: RP#39 completed / Text3: 36.201, 36.211, 36.212, 36.213, 36.214, 25.215, 25.225
- 1103: RP#42 completed / Text3: 36.302, 36.304, 36.306, 36.314, 36.321, 36.322, 36.323, 36.331, 25.302, 25.304, 25.331
- 1104: RP#42 completed / Text3: 36.401, 36.410, 36.411, 36.412, 36.413, 36.414, 36.420, 36.421, 36.422, 36.423, 36.424, 25.413
- 1105: RP#42 completed. RP#47 abandoned draft 36.801, 36.803, 36.804 / Text3: 36.101, 36.104, 36.113, 36.124, 36.133, 36.141, 36.942, 25.123, 25.133
- 1106: RP#43 completed. RP#47 create Rel-9 TR 36.956 (see R4-100386, RP-100320_RAN4 Report) / Text3: 36.106, 36.143, 25.113
- 1107: SP#43 completed
- 1108: SP#43 completed / Text3: 32.421, 2.422, 32.423, 2.441, 32.442, 32.443, 32.445
- 1109: SP#43 completed / Text3: new (32.761, 32.762, 32.763, 32.765)
- 1110: SP#43 completed / Text3: new 32.425
- 1111: SP#43 completed / Text3: new (32.450, 32.451)
- 1112: SP#42 completed (WT UID_390007 moved to Rel-9)
- 1113: SP#42 completed / Text3: new 32.500
- 1114: SP#42 completed / Text3: new (32.501, 32.502, 32.503, 32.531, 32.532, 32.533)
- 1115: SP#42 completed / Text3: 32.761, 32.762, 32.763, 32.765, new 32.511
- 1116: Testing for Feature UID_20068 (LTE)
- 1117: RP#46 completed / Text3: 36.521-1, 36.521-2, 36.508, 36.509, 36.523-1, 36.523-2, 36.523-3
- 1118: RP#46 completed. RP#50 TR 36.903 v100 for Approval / Text3: 36.521-1, 36.521-2, 36.521-3, new TR 36.903
- 1119: RP#41 stopped / Text3: 36.521-1, 36.521-2, 36.521-3

| ID | WBS | Task | Duration | Start | Finish | Complete | Baseline start | Baseline finish | Baseline duration | Constraint | Resources | Work | Actual work | Text1 | Text6 | Text8 | Text4 | Text5 | Text11 | Text2 | Text7 | Text9 | Text12 |
| --- | --- | --- | --- | --- | --- | --- | --- | --- | --- | --- | --- | --- | --- | --- | --- | --- | --- | --- | --- | --- | --- | --- | --- |
| 1120 | 363 | **Rel-8 Improvements of the Radio Interface** | 525d? | 2007-03-05 A | 2009-03-06 A | 100% | 2007-03-05 | 2009-03-06 | 525d? |  | RP | 18152h | 18152h | RInImp8 | Rel-8 | Issam |  |  |  |  |  |  |  |
| 1121 | 363.1 | UMTS 1500 MHz | 140d? | 2007-03-05 A | 2007-09-14 A | 100% | 2007-03-05 | 2007-09-14 | 140d? | finish no earlier than 2007-09-14 | R4 | 1120h | 1120h | RInImp8-UMTS1500 | Rel-8 | Issam | NTT DoCoMo | Takehiro Nakamura (nakamurata@nttdocomo.co.jp) | RP-070526 |  |  |  |  |
| 1122 | 363.2 | UMTS 700 MHz FDD | 325d? | 2007-03-05 A | 2008-05-30 A | 100% | 2007-03-05 | 2008-05-30 | 325d? | finish no earlier than 2008-06-12 | R4 | 2600h | 2600h | RInImp8-UMTS700 | Rel-8 | Issam | Nokia | Tuomo Saynajakangas | RP-080260 |  |  |  |  |
| 1123 | 363.3 | UMTS 1880 MHz TDD | 126d? | 2008-09-12 A | 2009-03-06 A | 100% | 2008-09-12 | 2009-03-06 | 126d? | finish no earlier than 2009-03-09 | R4 | 1008h | 1008h | RInImp9-UMTS1880TDD | Rel-8 | Issam | CATT | Yuexia Song (songyuexia@datangmobile.cn) | RP-090044 | PCG-21 | RP-41 |  |  |
| 1124 | 363.4 | UMTS 2300 MHz TDD LCR | 195d? | 2007-12-17 A | 2008-09-12 A | 100% | 2007-12-17 | 2008-09-12 | 195d? | finish no earlier than 2008-09-12 | R4 | 1560h | 1560h | RInImp8-UMTS2300TDD | Rel-8 | Issam | CATT | songyuexia@datangmobile.cn | RP-080517 | PCG-21 | RP-38 |  |  |
| 1125 | 363.5 | Further Improved Minimum Performance Requirements for HSDPA UE (FDD) - Two-Branch Interference Cancellation | 265d? | 2007-03-05 A | 2008-03-07 A | 100% | 2007-03-05 | 2008-03-07 | 265d? | finish no earlier than 2008-03-12 | R4 | 2120h | 2120h | RInImp8-2BIC | Rel-8 | Issam | AT&T | Marc Grant | RP-080041 |  |  |  |  |
| 1126 | 363.6 | CS Voice Service over HSPA | 167d? | 2007-07-19 A | 2008-03-07 A | 100% | 2007-07-19 | 2008-03-07 | 167d? |  | R2 | 1336h | 1336h | RInImp8-CsHspa | Rel-8 | Joern | Nokia Siemens Networks | woonhee.hwang@nsn.com | RP-080042 |  | RP-37 |  |  |
| 1127 | 363.7 | Performance requirements for 15 code reception with 16QAM/QPSK (FDD) | 126d? | 2007-06-11 A | 2008-03-07 A | 100% | 2007-06-11 | 2008-03-07 | 126d? | finish no earlier than 2008-06-12 | R4 | 1008h | 1008h | RInImp8-Hsdpa15codes | Rel-8 | Issam | Vodafone | tim.frost@vodafone.com | RP-080043 |  | RP-37 |  |  |
| 1128 | 363.8 | Deleted - UMTS 2300 MHz FDD/TDD | 400d? | 2007-03-05 A | 2008-09-12 A | 100% | 2007-03-05 | 2008-09-12 | 400d? | finish no earlier than 2008-12-11 | R4 | 3200h | 3200h | RInImp8-UMTS2300 | Rel-8 | Issam | AT&T | Marc Grant | RP-080515 |  |  | PCG-21 | RP-41 |
| 1129 | 364 | **Rel-8 Improvements of the Radio Interface - UE Conformance Testing** | 396d? | 2007-06-01 A | 2008-12-05 A | 100% | 2007-06-01 | 2008-12-05 | 396d? |  | R5 | 6256h | 6256h | RInImp-UEConTest | Rel-8 | Ingbert |  |  |  |  |  |  |  |
| 1130 | 364.1 | Conformance Test Aspects – CS Voice Service over HSPA | 336d? | 2007-06-01 A | 2008-09-12 A | 100% | 2007-06-01 | 2008-09-12 | 336d? | finish no earlier than 2008-09-12 | R5 | 2688h | 2688h | RInImp8-CsHspa_UEConTest | Rel-8 | Ingbert | Huawei | baoyi@huawei.com | RP-080542 |  |  |  |  |
| 1131 | 364.2 | Conformance Test Aspects – Performance requirements for 15 code reception with 16QAM/QPSK (FDD) | 195d? | 2008-03-07 A | 2008-12-05 A | 100% | 2008-03-07 | 2008-12-05 | 195d? | finish no earlier than 2008-12-05 | R5 | 1560h | 1560h | RInImp8-UEConTest_ Hsdpa15codes | Rel-8 | Ingbert | Ericsson | Mikael.Ziren@Ericsson.com | RP-080818 | PCG-21 | RP-40 |  |  |
| 1132 | 365 | **Rel-8 RAN improvements** | 520d? | 2007-06-04 A | 2009-05-29 A | 100% | 2007-06-04 | 2009-05-29 | 520d? |  | RP | 29776h | 29776h | RANimp | Rel-8 |  |  |  |  |  |  |  |  |
| 1133 | 365.1 | Combination of 64QAM and MIMO for HSDPA (FDD) | 205d? | 2007-06-04 A | 2008-09-12 A | 100% | 2007-06-04 | 2008-09-12 | 205d? | finish no earlier than 2008-09-12 | R1 | 1640h | 1640h | RANimp-64QamMimoHsdpa | Rel-8 | Patrick | Ericsson | Johan.Bergman@ericsson.com | RP-080518 |  |  |  |  |
| 1134 | 365.2 | Improved L2 for uplink | 186d? | 2007-09-14 A | 2008-05-30 A | 100% | 2007-09-14 | 2008-05-30 | 186d? | finish no earlier than 2008-05-30 | R2 | 1488h | 1488h | RANimp-UplinkL2dataRates | Rel-8 | Joern | Ericsson | Janne.Peisa@ericsson.com | RP-080265 |  | RP-37 |  |  |
| 1135 | 365.3 | Enhanced Uplink for CELL_FACH State in FDD | 321d? | 2007-09-14 A | 2008-12-05 A | 100% | 2007-09-14 | 2008-12-05 | 321d? | finish no earlier than 2008-12-12 | R2 | 2568h | 2568h | RANimp-UplinkEnhState | Rel-8 | Joern | Nokia Siemens Networks | markus.wimmer@nsn.com | RP-080804 |  | RP-37 |  |  |
| 1136 | 365.4 | Enhanced UE Discontinuous Reception (DRX) for FDD | 261d? | 2007-09-14 A | 2008-09-12 A | 100% | 2007-09-14 | 2008-09-12 | 261d? | finish no earlier than 2008-09-12 | R2 | 2088h | 2088h | RANimp-DRX | Rel-8 | Joern | Nokia | luis.barreto@nokia.com | RP-080520 |  | RP-37 |  |  |
| 1137 | 365.5 | Enhancements for Serving Radio Network Subsystem (SRNS) Relocation Procedure | 261d? | 2007-09-14 A | 2008-09-12 A | 100% | 2007-09-14 | 2008-09-12 | 261d? | finish no earlier than 2008-09-12 | R3 | 2088h | 2088h | RANimp-SrnsReloc | Rel-8 | Juha | Nokia Siemens Networks | masatoshi.nakamata@nsn.com | RP-080521 |  | RP-37 |  |  |
| 1138 | 365.6 | Enhancements for FDD HSPA Evolution | 321d? | 2007-09-14 A | 2008-12-05 A | 100% | 2007-09-14 | 2008-12-05 | 321d? | finish no earlier than 2008-12-05 | R3,R2 | 2568h | 2568h | RANimp-HSPAEvo | Rel-8 | Juha | Nokia Siemens Networks | masatoshi.nakamata@nsn.com | RP-080805 |  | RP-37 |  |  |
| 1139 | 365.7 | 64QAM for 1.28 Mcps TDD HSDPA | 264d? | 2007-12-04 A | 2008-12-05 A | 100% | 2007-12-04 | 2008-12-05 | 264d? | finish no earlier than 2008-12-05 | R1 | 2112h | 2112h | RANimp-64Qam1.28TDD | Rel-8 | Patrick | ZTE | zfmail@zte.com.cn | RP-080806 | PCG-21 | RP-38 |  |  |
| 1140 | 365.8 | Enhanced CELL_FACH state in 1.28 Mcps TDD | 264d? | 2007-12-04 A | 2008-12-05 A | 100% | 2007-12-04 | 2008-12-05 | 264d? | finish no earlier than 2008-12-12 | R2 | 2112h | 2112h | RANimp-EnhState1.28TDD | Rel-8 | Joern | ZTE | zhang.yincheng@zte.com.cn | RP-080807 | PCG-21 | RP-38 |  |  |
| 1141 | 365.9 | Continuous Connectivity for packet data users for 1.28 Mcps TDD | 321d? | 2008-03-07 A | 2009-05-29 A | 100% | 2008-03-07 | 2009-05-29 | 321d? | finish no earlier than 2009-05-29 | R1 | 2568h | 2568h | RANimp-LCRCPC | Rel-8 | Patrick | TD Tech | chenying@td-tech.com | RP-090394 | PCG-21 | RP-39 |  |  |
| 1142 | 365.10 | HSPA VoIP to WCDMA/GSM CS continuity | 261d? | 2008-03-07 A | 2009-03-06 A | 100% | 2008-03-07 | 2009-03-06 | 261d? | finish no earlier than 2009-03-06 | R2 | 2088h | 2088h | RANimp-HSPAVoIP | Rel-8 | Joern | Nokia | Simone.Provvedi@nokia.com | RP-090050 | PCG-21 | RP-39 |  |  |
| 1143 | 365.11 | HS-DSCH Serving Cell Change Enhancements | 196d? | 2008-03-07 A | 2008-12-05 A | 100% | 2008-03-07 | 2008-12-05 | 196d? | finish no earlier than 2008-12-12 | R2 | 1568h | 1568h | RANimp-HSDSCH | Rel-8 | Joern | Ericsson | henrik.enbuske@ericsson.com | RP-080811 | PCG-21 | RP-39 |  |  |
| 1144 | 365.12 | MIMO for 1.28 Mcps TDD. Linked to Rel-8 Study on Scope of future HSPA Evolution for 1.28 Mcps TDD (UID_370041) TR 25.824 | 201d? | 2007-11-01 A | 2009-03-06 A | 100% | 2007-11-01 | 2009-03-06 | 201d? | finish no earlier than 2009-05-29 | R1,R4 | 1608h | 1608h | RANimp-MIMOLCR | Rel-8 | Patrick | CATT | wangke@datangmobile.cn | RP-090313 | PCG-21 | RP-40 |  |  |
| 1145 | 365.13 | Dual-Cell HSDPA operation on adjacent carriers | 140d? | 2008-05-30 A | 2008-12-11 A | 100% | 2008-05-30 | 2008-12-11 | 140d? | finish no earlier than 2009-05-29 | R1,R4 | 1120h | 1120h | RANimp-DCHSDPA | Rel-8 | Patrick | Ericsson | johan.bergman@ericsson.com | RP-080814 | PCG-21 | RP-40 |  |  |

Notes:
- 1120: -
- 1121: RP#37 completed / Text3: 25.101, 25.104, 25.133, 25.141, 25.331, 25.942, 25.306, 25.307, 34.121
- 1122: RP#40 completed / Text3: 25.101, 25.104, 25.133, 25.141, 25.331, 25.942, 25.306, 25.307, 34.121
- 1123: RP#43 completed / Text3: 25.102, 25.105, 25.113, 25.123, 25.142, 34.124, 25.307
- 1124: RP#41 completed. RP#47 abandoned draft 25.828 / Text3: 25.102, 25.105, 25.113, 25.123, 25.142, 34.124, 25.306, 25.331, 34.122
- 1125: RP#39 completed / Text3: 25.101
- 1126: RP#39 completed / Text3: 25.323, 25.331, 25.322
- 1127: RP#39 completed / Text3: 25.101
- 1128: RP#41 stopped / Text3: 25.101, 25.104, 25.133, 25.141, 25.331, 25.942, 25.306, 25.307, 34.121
- 1129: 05/08: Linked to Feature UID_20028 (RInImp)
- 1130: RP#41 completed / Text3: 34.108, 34.123-1, 34.123-2, 34.123-3
- 1131: RP#42 completed / Text3: 34.121-1, 34.121-2
- 1132: -
- 1133: RP#41 completed / Text3: 25.308, 25.211, 25.212, 25.213, 25.306, 25.331, 25.433, 25.435, 25.423, 25.425, 25.101, 25.104, 25.141
- 1134: RP#40 completed. Linked to UID_370037 Enhanced Uplink for CELL_FACH State in FDD / Text3: 25.319, 25.301, 25.306, 25.321, 25.331, 25.433, 25.435, 25.423, 25.425, 25.427
- 1135: RP#42 completed. Linked to UID_370036 Improved L2 for uplink / Text3: 25.309, 25.211, 25.214, 25.321, 25.331, 25.423, 25.433
- 1136: RP#41 completed. Continuation of Rel-7 work item "Continuous connectivity for packet data users" UID_20046. / Text3: 25.306, 25.308, 25.321, 25.331, 25.423
- 1137: RP#41 completed. Linked to UID_370040 Enhancements for FDD HSPA Evolution / Text3: 25.306, 25.308, 25.321, 25.331, 25.423, 25.433, 25.214, 25.133
- 1138: RP#42 completed. Triggered by Rel-7 Study on Scope of future FDD HSPA Evolution (UID_20065) TR 25.999 / Text3: 25.401, 25.413, 25.420, 25.423, 25.427, 25.433, 25.446, 25.301, 25.346
- 1139: RP#42 completed. Linked to Rel-8 Study on Scope of future HSPA Evolution for 1.28 Mcps TDD (UID_370041) TR 25.824 / Text3: 25.102, 25.105, 25.123, 25.142, 25.201, 25.221, 25.222, 25.223, 25.224, 25.306, 25.308, 25.321, 25.331, 25.423, 25.433
- 1140: RP#42 completed. Linked to Rel-8 Study on Scope of future HSPA Evolution for 1.28 Mcps TDD (UID_370041) TR 25.824 / Text3: 25.123, 25.221, 25.222, 25.224, 25.301, 25.302, 25.304, 25.306, 25.308, 25.319, 25.321, 25.331, 25.401, 25.423, 25.425, 25.433, 25.435
- 1141: RP#44 completed. Linked to Rel-8 Study on Scope of future HSPA Evolution for 1.28 Mcps TDD (UID_370041) TR 25.824 / Text3: 25.929, 25.308, 25.319
- 1142: RP#43 completed / Text3: 25.331, 25.413
- 1143: RP#42 completed / Text3: 25.101, 25.104, 25.133, 25.212, 25.214, 25.308, 25.321, 25.331, 25.423, 25.433
- 1144: RP#43 completed / Text3: 25.201, 25.221, 25.222, 25.223, 25.224, 25.306, 25.308, 25.321, 25.331, 25.423, 25.433, 25.102, 25.105, 25.142
- 1145: RP#42 completed. Triggered by UID_390032 Study on Dual-Cell HSDPA (withdrawn TR 25.825 v100). / Text3: 25.101, 25.104, 25.133, 25.141, 25.211, 25.212, 25.213, 25.214, 25.215, 25.306, 25.308, 25.321, 25.331, 25.423, 25.433

| ID | WBS | Task | Duration | Start | Finish | Complete | Remaining | Baseline start | Baseline finish | Baseline duration | Total slack | Constraint | Resources | Work | Actual work | Text1 | Text6 | Text8 | Text2 | Text4 | Text7 | Text11 |
| --- | --- | --- | --- | --- | --- | --- | --- | --- | --- | --- | --- | --- | --- | --- | --- | --- | --- | --- | --- | --- | --- | --- |
| 1146 | 366 | **Rel-8 RAN improvements - UE Conformance Testing** | 602d? | 2008-05-30 A | 2010-09-17 A | 100% |  | 2008-05-30 | 2010-09-17 | 602d? |  |  | R5 | 29391.2h | 29391.2h | RANimp-UEConTest | Rel-8 | Ingbert |  |  |  |  |
| 1147 | 366.1 | Conformance Test Aspects – Combination of 64QAM and MIMO for HSDPA (FDD) | 322d? | 2008-09-12 A | 2009-12-04 A | 100% |  | 2008-09-12 | 2009-12-04 | 322d? |  | finish no earlier than 2009-12-04 | R5 | 2576h | 2576h | RANimp-UEConTest_64QamMimoHsdpa | Rel-8 | Ingbert | PCG-21 | Ericsson | RP-41 | RP-091058 |
| 1148 | 366.2 | Conformance Test Aspects – Improved L2 for uplink | 341d? | 2008-05-30 A | 2009-09-18 A | 100% |  | 2008-05-30 | 2009-09-18 | 341d? |  | finish no earlier than 2009-09-18 | R5 | 2728h | 2728h | RANimp-UEConTest_UplinkL2dataRates | Rel-8 | Ingbert | PCG-21 | Ericsson | RP-40 | RP-090712 |
| 1149 | 366.3 | Conformance Test Aspects – 1.28 Mcps TDD Improved L2 support for high data rates | 342d? | 2009-05-29 A | 2010-09-17 A | 100% |  | 2009-05-29 | 2010-09-17 | 342d? |  | finish no earlier than 2010-09-17 | R5 | 2736h | 2736h | RANimp-UEConTest_ImprovedL2LCRTDD | Rel-8 | Ingbert | PCG-23 | CATT | RP-44 | RP-100737 |
| 1150 | 366.4 | Conformance Test Aspects – 64QAM for 1.28 Mcps TDD HSDPA | 261d? | 2008-05-30 A | 2009-05-29 A | 100% |  | 2008-05-30 | 2009-05-29 | 261d? |  | finish no earlier than 2009-05-29 | R5 | 2088h | 2088h | RANimp-UEConTest_64Qam1.28TDD | Rel-8 | Ingbert | PCG-21 | ZTE | RP-40 | RP-090415 |
| 1151 | 366.5 | Conformance Test Aspects – Dual-Cell HSDPA operation on adjacent carriers | 391d? | 2008-12-05 A | 2010-06-04 A | 100% |  | 2008-12-05 | 2010-06-04 | 391d? |  | finish no earlier than 2010-06-04 | R5 | 3128h | 3128h | RANimp-UEConTest_DCHSDPA | Rel-8 | Ingbert | PCG-22 | Qualcomm | RP-42 | RP-100479 |
| 1152 | 366.6 | Conformance Test Aspects – Enhanced Uplink for CELL_FACH State in FDD | 326d? | 2009-03-06 A | 2010-06-04 A | 100% |  | 2009-03-06 | 2010-06-04 | 326d? |  | finish no earlier than 2010-06-04 | R5 | 2608h | 2608h | RANimp-UEConTest_EnhancedRACHCellFACHState | Rel-8 | Ingbert | PCG-22 | Nokia | RP-43 | RP-100483 |
| 1153 | 366.7 | Conformance Test Aspects – Receiver Type3i | 196d? | 2009-03-06 A | 2009-12-04 A | 100% |  | 2009-03-06 | 2009-12-04 | 196d? |  | finish no earlier than 2009-12-04 | R5 | 1568h | 1568h | RANimp-UEConTest_ReceiverType3i | Rel-8 | Ingbert | PCG-22 | Qualcomm | RP-43 | RP-091066 |
| 1154 | 366.8 | Conformance Test Aspects – Enhanced CELL_FACH State in LCR TDD | 341d? | 2009-05-30 A | 2010-09-17 A | 100% |  | 2009-05-30 | 2010-09-17 | 341d? |  | finish no earlier than 2010-09-17 | R5 | 2728h | 2728h | RANimp-UEConTest_EnhancedCellFACHStateLCRTDD | Rel-8 | Ingbert | PCG-23 | CATT | RP-44 | RP-100735 |
| 1155 | 366.9 | Conformance Test Aspects – Continuous Connectivity for packet data users for 1.28 Mcps TDD | 261d? | 2009-09-18 A | 2010-09-17 A | 100% |  | 2009-09-18 | 2010-09-17 | 261d? |  | finish no earlier than 2010-09-17 | R5 | 2088h | 2088h | RANimp-UEConTest_CPCLCRTDD | Rel-8 | Ingbert | PCG-23 | ZTE | RP-45 | RP-100739 |
| 1156 | 366.10 | Conformance Test Aspects – MIMO for 1.28 Mcps TDD | 186d? | 2009-09-18 A | 2010-06-04 A | 100% |  | 2009-09-18 | 2010-06-04 | 186d? |  | finish no earlier than 2010-06-04 | R5 | 1488h | 1488h | RANimp-UEConTest_MIMOLCRTDD | Rel-8 | Ingbert | PCG-23 | ZTE | RP-45 | RP-100660 |
| 1157 | 366.11 | Conformance Test Aspects – HS-DSCH Serving Cell Change Enhancements | 131d? | 2009-09-18 A | 2010-03-19 A | 100% |  | 2009-09-18 | 2010-03-19 | 131d? |  | finish no earlier than 2010-03-12 | R5 | 1048h | 1048h | HSDSCH_UEConTest | Rel-8 | Ingbert | PCG-23 | Qualcomm | RP-45 | RP-100077 |
| 1158 | 367 | 3.84 Mcps TDD MBSFN Integrated Mobile Broadcast | 395d? | 2007-06-04 A | 2008-12-05 A | 100% |  | 2007-06-04 | 2008-12-05 | 395d? |  |  | R1 | 3160h | 3160h | MBSFN-DOB | Rel-8 | Patrick |  | Ericsson |  | RP-080218 |
| 1159 | 368 | Conformance Test Aspects – 3.84 Mcps TDD MBSFN Integrated Mobile Broadcast | 211d? | 2009-05-30 A | 2010-03-19 A | 100% |  | 2009-05-30 | 2010-03-19 | 211d? |  | finish no earlier than 2010-03-19 | R5 | 1688h | 1688h | MBSFN_IMB_UEConTest | Rel-8 | Ingbert | PCG-23 | IPwireless | RP-44 | RP-100070 |
| 1160 | 369 | **GERAN support for GERAN - 3G Long Term Evolution interworking** | 1227d? | 2006-09-08 A | 2011-05-20 | 88% | 143.38d? | 2006-09-08 | 2011-05-20 | 1227d? | 475d |  | GP,G1,C1 | 35016h | 30924.1h | GELTE | Rel-8 | Paolo |  | Nokia, Nokia Siemens Networks |  |  |
| 1161 | 369.1 | G1 part of GERAN support for GERAN - 3G Long Term Evolution interworking | 641d? | 2006-09-08 A | 2009-02-20 A | 100% |  | 2006-09-08 | 2009-02-20 | 641d? |  | finish no earlier than 2009-02-20 | G1 | 5128h | 5128h | GELTE | Rel-8 | Paolo |  | Nokia, Nokia Siemens Networks |  |  |
| 1162 | 369.2 | G2 part of GERAN support for GERAN - 3G Long Term Evolution interworking | 641d? | 2006-09-08 A | 2009-02-20 A | 100% |  | 2006-09-08 | 2009-02-20 | 641d? |  | finish no earlier than 2009-02-20 | G2 | 5128h | 5128h | GELTE | Rel-8 | Paolo |  | Nokia, Nokia Siemens Networks |  |  |
| 1163 | 369.3 | CT1 part of GERAN support for GERAN - 3G Long Term Evolution interworking | 641d? | 2006-09-08 A | 2009-02-20 A | 100% |  | 2006-09-08 | 2009-02-20 | 641d? |  | finish no earlier than 2009-02-20 | C1 | 5128h | 5128h | GELTE | Rel-8 | Paolo |  | Nokia, Nokia Siemens Networks |  |  |
| 1164 | 369.4 | Testing for GERAN support for GERAN - 3G Long Term Evolution interworking | 1227d? | 2006-09-08 A | 2011-05-20 | 70% | 368.1d? | 2006-09-08 | 2011-05-20 | 1227d? | 475d | finish no earlier than 2011-05-20 | G3new | 9816h | 6871.2h | GELTE | Rel-8 | Ingbert |  | Nokia, Nokia Siemens Networks |  |  |
| 1165 | 370 | U-TDOA Enhancement | 131d? | 2007-05-18 A | 2007-11-16 A | 100% |  | 2007-05-18 | 2007-11-16 | 131d? |  | finish no earlier than 2007-05-18 | GP | 1048h | 1048h | GUTEN | Rel-8 | Paolo |  | TruePosition |  |  |
| 1166 | 371 | **GAN Enhancements** | 604.2d? | 2007-05-15 A | 2009-09-04 A | 100% |  | 2007-05-15 | 2009-09-04 | 604.2d? |  |  | GP | 9432h | 9432h | GANENH | Rel-8 | Paolo |  | T-Mobile |  |  |
| 1167 | 371.1 | Update to GAN specifications | 126d? | 2007-08-31 A | 2008-02-22 A | 100% |  | 2007-08-31 | 2008-02-22 | 126d? |  | finish no earlier than 2008-02-22 | GP | 1008h | 1008h | GANENH-SPEC | Rel-8 | Paolo |  | T-Mobile |  |  |
| 1168 | 371.2 | Update TS 51.010 Mobile Station (MS) Conformance Specification for GAN Enhancements | 526d? | 2007-05-15 A | 2009-09-04 A | 100% |  | 2007-05-15 | 2009-09-04 | 526d? |  | finish no earlier than 2009-09-04 | G3new | 4208h | 4208h | GANENH-MStest | Rel-8 | Ingbert |  | T-Mobile |  |  |
| 1169 | 372 | **AoIP (A-interface over IP)** | 2335d? | 2000-01-03 A | 2008-12-11 A | 100% |  | 2000-01-03 | 2008-12-11 | 2335d? |  |  | GP,S4,C4,C1,C3 | 41412.1h | 41412.1h | AoIP | Rel-8 | Paolo | PCG-21 | China Mobile, Ericsson |  |  |
| 1170 | 372.1 | GERAN aspects of AoIP | 2321d? | 2000-01-03 A | 2008-11-21 A | 100% |  | 2000-01-03 | 2008-11-21 | 2321d? |  | finish no earlier than 2008-11-21 | GP | 18560h | 18560h | AoIP | Rel-8 | Paolo | PCG-21 | China Mobile, Ericsson | SP-40 |  |
| 1171 | 372.2 | Media Requirements for CS over IP based User Plane | 267d? | 2007-12-05 A | 2008-12-11 A | 100% |  | 2007-12-05 | 2008-12-11 | 267d? |  | finish no earlier than 2008-12-11 | S4 | 1996.09h | 1996.09h | AoIP-CSoIP | Rel-8 | Paolo | PCG-21 | China Mobile, Ericsson | SP-40 |  |
| 1172 | 372.3 | Core Network Impacts for A-Interface User Plane over IP | 136d? | 2008-05-30 A | 2008-12-05 A | 100% |  | 2008-05-30 | 2008-12-05 | 136d? |  | start no earlier than 2008-05-30 | C4 | 1088h | 1088h | AoIP-CN | Rel-8 | Kimmo | PCG-21 | Ericsson | CP-40 |  |
| 1173 | 372.4 | Core Network Impacts for A-Interface User Plane over IP | 68d? | 2008-05-30 A | 2008-12-05 A | 100% |  | 2008-05-30 | 2008-12-05 | 68d? |  | finish no earlier than 2008-12-05 | C1 | 544h | 544h | AoIP-CN | Rel-8 | Frederic | PCG-21 | Ericsson | CP-40 |  |
| 1174 | 372.5 | Core Network Impacts for A-Interface User Plane over IP | 68d? | 2008-05-30 A | 2008-12-05 A | 100% |  | 2008-05-30 | 2008-12-05 | 68d? |  | finish no earlier than 2008-12-05 | C3 | 544h | 544h | AoIP-CN | Rel-8 | Jiwan | PCG-21 | Ericsson | CP-40 |  |
| 1175 | 373 | New multicarrier BTS class | 261d? | 2007-08-31 A | 2008-08-29 A | 100% |  | 2007-08-31 | 2008-08-29 | 261d? |  | finish no earlier than 2008-08-29 | G1 | 2088h | 2088h | MCBTS | Rel-8 | Paolo |  | Alcatel-Lucent |  |  |

Notes:
- 1146: Linked to Feature UID_20029 (RANimp)
- 1147: RP#46 completed. Testing for UID_360013 / Text3: 34.108, 34.121-1, 34.121-2, 34.123-1, 34.123-2 / Text5: leif.mattisson@ericsson.com
- 1148: RP#45 completed. Testing for UID_370036 / Text3: 34.108, 34.123-1, 34.123-2, 34.123-3 / Text5: leif.mattisson@ericsson.com
- 1149: RP#49 completed. Testing for Rel-7 UID_340039 Improved L2 support for high data rates and Rel-8 UID_370036 Improved L2 for uplink / Text3: 34.108, 34.123-1, 34.123-2, 34.123-3 / Text5: Xiaozhong Chen (chenxiaozhong@datangmobile.cn)
- 1150: RP#44 completed. Testing for UID_380075 / Text3: 34.108, 34.122, 34.123-1, 34.123-2, 34.123-3 / Text5: ma.zijiang@zte.com.cn
- 1151: RP#48 completed. Testing for UID_400052 / Text3: 34.108, 34.121-1, 34.121-2, 34.123-1, 34.123-2, 34.123-3 / Text5: Shubhang Vora (svora@qualcomm.com)
- 1152: RP#48 completed. Testing for UID_370037 / Text3: 34.108, 34.121-1, 34.121-2, 34.123-1, 34.123-2, 34.123-3 / Text5: jarkko.hellsten@nokia.com
- 1153: RP#46 completed. Testing for Receiver Type3i in 25.101 UE radio Tx and Rx FDD / Text3: 34.108, 34.121-1, 34.121-2 / Text5: Ashok Kumar Narayanaswamy (anarayan@qualcomm.com)
- 1154: RP#49 completed. Testing for UID_380076 / Text3: 34.108, 34.123-1, 34.123-2, 34.123-3 / Text5: Xiaozhong Chen (chenxiaozhong@datangmobile.cn)
- 1155: RP#49 completed. Testing for UID_390028 / Text3: 34.108, 34.123-1, 34.123-2, 34.123-3 / Text5: huang.he4@zte.com.cn
- 1156: PR#48 completed. Testing for UID_400050 / Text3: 34.108, 34.122, 34.123-1, 34.123-2, 34.123-3 / Text5: huang.chun2@zte.com.cn
- 1157: RP#47 completed. Testing for UID_390030 / Text3: 34.108, 34.121-1, 34.121-2, 34.123-1, 34.123-2, 34.123-3 / Text5: Shubhang Vora (svora@qualcomm.com)
- 1158: RP#42 completed. WID updated RP-070493=>RP-081124 (changed WI title "MBSFN Downlink Optimized Broadcast (DOB) 3.84 Mcps TDD" => "3.84Mcps TDD MBSFN Integrated Mobile Broadcast"). / Text3: 25.102, 25.105, 25.123, 25.201, 25.221, 25.222, 25.223, 25.224, 25.304, 25.306, 25.331, 25.346, 25.402, 25.433 / Text5: Lars.Lindbom@ericsson.com
- 1159: RP#47 completed. Testing for Rel-8 MBSFN-DOB UID_360008 / Text3: 34.108, 34.122, 34.123-1, 34.123-2, 34.123-3 / Text5: Phil Young (pyoung@ipwireless.com)
- 1160: GP#41 completed (MS conformance testing open) / Text3: 44.018, 44.060, 45.002, 45.008, 45.010, 48.008, 48.018, 51.010 / Text5: sergio.parolari@nsn.com, vlora.rexhepi@nokia.com
- 1161: GP#41 completed / Text3: 43.055, 43.129, 43.246, 45.002, 45.008, 45.010 / Text5: sergio.parolari@nsn.com, vlora.rexhepi@nokia.com
- 1162: GP#41 completed / Text3: 44.018, 44.060, 48.008, 48.018 / Text5: sergio.parolari@nsn.com, vlora.rexhepi@nokia.com
- 1163: - / Text3: 24.008 / Text5: sergio.parolari@nsn.com, vlora.rexhepi@nokia.com
- 1164: GP#49 completion 03/11=>05/11 / Text3: 51.010 / Text5: sergio.parolari@nsn.com, vlora.rexhepi@nokia.com
- 1165: GP#36 completed U-TDOA (Uplink Time Difference of Arrival) / Text3: 43.059, 45.008, 48.071 / Text5: Terry Brooks (terri.brooks@trueposition.com)
- 1166: GP#37 completed. GP#43 completed Testing / Text5: mohammed.versi@t-mobile.com
- 1167: GP#37 completed / Text3: 43.318, 44.318 / Text5: mohammed.versi@t-mobile.com
- 1168: GP#43 completed / Text3: 51.010 / Text5: mohammed.versi@t-mobile.com
- 1169: GP#40/TSG#42 completed . Triggered by TR 43.903 Study on A-interface over IP (AINTIP) UID_50589. / Text5: wangshuaiyu@chinamobile.com, paul.schliwa-bertling@ericsson.com
- 1170: GP#40 completed. GP#39 updated WID GP-080901=>GP-081362. / Text3: 48.001, 48.002, 48.008, 48.020, 49.008, 48.103 / Text5: wangshuaiyu@chinamobile.com, paul.schliwa-bertling@ericsson.com
- 1171: SP#42 completed / Text3: 26.102, 26.103, 26.202 / Text5: Karl.Hellwig@Ericsson.com
- 1172: CP#42 completed. Updated WID CP-080278=>CP-080722 / Text3: 23.205, 23.153, 23.231, 29.232 / Text5: philip.hodges@ericsson.com
- 1173: CP#42 completed. Updated WID CP-080278=>CP-080722 / Text3: 23.009 / Text5: philip.hodges@ericsson.com
- 1174: CP#42 completed. Updated WID CP-080278=>CP-080722 / Text3: 29.007 / Text5: philip.hodges@ericsson.com
- 1175: GP#39 completed / Text3: 45.005, 45.050, 51.021 / Text5: thomas.bitzer@alcatel-lucent.de

| ID | WBS | Task | Type | Duration | Start | Finish | Complete | Baseline start | Baseline finish | Baseline duration | Constraint | Resources | Work | Actual work | Text1 | Text4 | Text6 | Text8 | Text2 | Text3 | Text7 | Text11 | Text12 | Text9 |
| --- | --- | --- | --- | --- | --- | --- | --- | --- | --- | --- | --- | --- | --- | --- | --- | --- | --- | --- | --- | --- | --- | --- | --- | --- |
| 1176 | 374 | **Support for Additional Navigation Satellite Systems (ANSS) for LCS** |  | 150d? | 2008-05-16 A | 2008-12-11 A | 100% | 2008-05-16 | 2008-12-11 | 150d? |  | S1,G2 | 3384h | 3384h | ANSS | Qualcomm | Rel-8 | Paolo |  |  |  |  |  |  |
| 1177 | 374.1 | Stage 1 for ANSS for LCS |  | 1d? | 2008-12-11 A | 2008-12-11 A | 100% | 2008-12-11 | 2008-12-11 | 1d? | start no earlier than 2008-12-11 | S1 | 8h | 8h | ANSS |  | Rel-8 | Alain | PCG-22 | 22.071 | SP-42 |  |  |  |
| 1178 | 374.2 | Support for Additional Navigation Satellite Systems (ANSS) for LCS |  | 136d? | 2008-05-16 A | 2008-11-21 A | 100% | 2008-05-16 | 2008-11-21 | 136d? | start no earlier than 2008-05-16 | G2 | 1088h | 1088h | ANSS | Qualcomm | Rel-8 | Paolo |  | 43.059, 44.031, 49.031, 44.071, 48.031, 51.010 |  |  |  |  |
| 1179 | 374.3 | Support for Additional Navigation Satellite Systems (ANSS) for LCS |  | 136d? | 2008-05-30 A | 2008-12-05 A | 100% | 2008-05-30 | 2008-12-05 | 136d? | finish no earlier than 2008-12-08 | R2 | 1088h | 1088h | RANimp-ANSS | Qualcomm | Rel-8 | Joern | PCG-21 | 25.305, 25.306, 25.331, 25.413, 25.423, 25.433, 25.453 | RP-40 | RP-080813 |  |  |
| 1180 | 375 | **Conformance testing for the Latency Reductions feature** |  | 532d? | 2008-02-22 A | 2010-03-05 A | 100% | 2008-02-22 | 2010-03-05 | 532d? |  | G1, G3new | 10592h | 10592h | CTLATRED | Ericsson | Rel-8 | Paolo | PCG-21 |  |  |  |  |  |
| 1181 | 375.1 | MS conformance testing for the Latency Reductions feature |  | 532d? | 2008-02-22 A | 2010-03-05 A | 100% | 2008-02-22 | 2010-03-05 | 532d? | finish no earlier than 2010-03-05 | G3new | 4248h | 4248h | CTLATRED-MStest | Ericsson | Rel-8 | Ingbert | PCG-21 | 51.010 |  |  |  |  |
| 1182 | 375.2 | BTS conformance testing for the Latency Reductions feature |  | 261d? | 2008-02-22 A | 2009-02-20 A | 100% | 2008-02-22 | 2009-02-20 | 261d? | finish no earlier than 2009-02-20 | G1 | 2088h | 2088h | CTLATRED-BTStest | Ericsson | Rel-8 | Paolo | PCG-21 | 51.021 |  |  |  |  |
| 1183 | 376 | MS conformance testing of changes introduced by WI "Support of Packet-switched Handover for GERAN A/Gb mode" |  | 196d? | 2008-02-22 A | 2008-11-21 A | 100% | 2008-02-22 | 2008-11-21 | 196d? | finish no earlier than 2008-11-21 | G3new | 1568h | 1568h | PSHCT-MStest | Rohde & Schwarz | Rel-8 | Ingbert | PCG-21 | 51.010 |  |  |  |  |
| 1184 | 377 | (Small) Technical Enhancements and Improvements for Rel-8 |  | 509d? | 2007-01-01 A | 2008-12-11 A | 100% | 2007-01-01 | 2008-12-11 | 509d? | finish no earlier than 2008-12-11 | All | 4072h | 4072h | TEI8 |  | Rel-8 | All |  |  |  |  |  |  |
| 1185 | 378 | Test - (Small) Technical Enhancements and Improvements for Rel-8 |  | 672d? | 2007-03-07 A | 2010-12-24 A | 100% | 2007-03-07 | 2010-12-24 | 672d? | finish no earlier than 2010-12-24 | R5,G3new | 5376h | 5376h | TEI8_Test |  | Rel-8 | Ingbert | PCG-21 |  | RP-40 |  |  |  |
| 1186 | 379 | **Deleted - All-IP Network** |  | 448d? | 2004-06-28 A | 2006-03-15 A | 100% | 2004-06-28 | 2006-03-15 | 448d? |  | S1 | 7168h | 7168h | AIPN | NTT DoCoMo | Rel-8 | Alain |  |  |  |  | SP-38 |  |
| 1187 | 379.1 | Deleted - Stage 1 |  | 448d? | 2004-06-28 A | 2006-03-15 A | 100% | 2004-06-28 | 2006-03-15 | 448d? | finish no earlier than 2006-03-15 | S1 | 3584h | 3584h | AIPN | NTT DoCoMo | Rel-8 | Alain |  | 22.258 |  |  | SP-38 |  |
| 1188 | 380 | Deleted - was Rel7 - LCS for 3GPP Interworking WLAN | milestone | 0d? | 2007-09-28 A | 2007-09-28 A | 100% | 2007-09-28 | 2007-09-28 | 0d? | start no earlier than 2007-09-28 | S2 |  |  | LCS4_IWLAN | LG Electronics | Rel-8 | Maurice |  | 23.234, 23.271, 23.167 |  |  | SP-35 |  |
| 1189 | 381 | Deleted - never approved- FBI Phase 2 | milestone | 0d | 2007-09-28 A | 2007-09-28 A | 100% | 2007-09-28 | 2007-09-28 | 0d | start no earlier than 2007-09-28 | S2 |  |  | FBI2 | Nokia Siemens Networks | Rel-8 | Maurice |  |  |  |  | SP-38 |  |
| 1190 | 382 | Deleted -Enhancements to BS30 Bearer service for Videotelephony | milestone | 0d? | 2007-03-15 A | 2007-03-15 A | 100% | 2007-03-15 | 2007-03-15 | 0d? | finish no earlier than 2007-03-15 | S1 |  |  | BS30 |  | Rel-8 | Alain |  | 22.002, 22.004, 22.101, 22.105, 24.008 |  |  | SP-38 |  |
| 1191 | 383 | Deleted - IMS Enhancements Rel-8 |  | 75d? | 2007-09-03 A | 2007-12-14 A | 100% | 2007-09-03 | 2007-12-14 | 75d? |  | S1 | 600h | 600h | IMS8 | Telecom Italia | Rel-8 | Alain |  |  | SP-37 |  | SP-38 |  |
| 1192 | 384 | **Deleted - Contact Manager Conformance Test specifications** |  | 471d? | 2008-06-02 A | 2010-03-19 A | 100% | 2008-06-02 | 2010-03-19 | 471d? |  | C6 | 11304h | 11304h | eUPHBOOK-Test | Comprion, Gemalto | Rel-8 | Xavier | PCG-21 |  | CP-40 |  | CP-47 | PCG-24 |
| 1193 | 384.1 | Deleted - Contact Manager for 3GPP UICC applications test specifications |  | 471d? | 2008-06-02 A | 2010-03-19 A | 100% | 2008-06-02 | 2010-03-19 | 471d? | finish no earlier than 2010-03-19 | C6 | 3768h | 3768h | eUPHBOOK-Test | Comprion | Rel-8 | Xavier | PCG-21 | 31.320 (external interface for communication with the ME) | CP-40 |  | CP-47 | PCG-24 |
| 1194 | 384.2 | Deleted - Contact Manager API for Java™ Card test specification |  | 471d? | 2008-06-02 A | 2010-03-19 A | 100% | 2008-06-02 | 2010-03-19 | 471d? | finish no earlier than 2010-03-19 | C6 | 3768h | 3768h | eUPHBOOK-Test | Gemalto | Rel-8 | Xavier | PCG-21 | 31.321 (internal interface (API)) | CP-40 |  | CP-47 | PCG-24 |
| 1195 | 385 | Deleted - MS conformance testing of Support of Conversational Services in A/Gb mode via the PS domain |  | 401d? | 2008-02-25 A | 2009-09-04 A | 100% | 2008-02-25 | 2009-09-04 | 401d? | finish no earlier than 2009-09-04 | G3new | 3208h | 3208h | SCSAGBCT-MStest | Nokia | Rel-8 | Ingbert | PCG-21 | 51.010 |  |  | GP-43 | PCG-23 |
| 1196 | 386 | Release 8 Studies |  | 1332d? | 2005-10-07 A | 2010-11-12 A | 100% | 2005-10-07 | 2010-11-12 | 1332d? | start no earlier than 2000-01-03 | CP,GP,RP,SP | 10656h | 10656h |  |  | Rel-8 | All |  |  |  |  |  |  |
| 1197 | 387 | Study on Customised Alerting Tone (CAT) Requirements |  | 245d? | 2005-10-07 A | 2006-09-14 A | 100% | 2005-10-07 | 2006-09-14 | 245d? | start no earlier than 2005-10-07 | S1 | 1960h | 1960h | FS_CAT | China Mobile | Rel-8 | Alain |  | 22.982 |  |  |  |  |
| 1198 | 388 | Study on Facilitating Machine to Machine Communication in GSM and UMTS (M2M) |  | 350d? | 2005-11-04 A | 2007-03-08 A | 100% | 2005-11-04 | 2007-03-08 | 350d? | finish no earlier than 2006-06-16 | S1 | 2800h | 2800h | FS_M2M | Siemens | Rel-8 | Alain |  | 22.868 |  |  |  |  |
| 1199 | 389 | Study on Network Composition |  | 526d? | 2005-12-07 A | 2007-12-12 A | 100% | 2005-12-07 | 2007-12-12 | 526d? | finish no earlier than 2006-09-27 | S1 | 4208h | 4208h | FS_NetComp | Nokia Siemens Networks | Rel-8 | Alain |  | 22.980 |  |  |  |  |
| 1200 | 390 | Study on Requirements of IMS Multimedia Conferencing |  | 330d? | 2006-06-08 A | 2007-09-12 A | 100% | 2006-06-08 | 2007-09-12 | 330d? | finish no earlier than 2007-03-21 | S1 | 2640h | 2640h | FS_IMSconf | China Mobile | Rel-8 | Alain |  | 22.948 |  |  |  |  |
| 1201 | 391 | Study on support of a Public Warning System |  | 140d? | 2007-09-03 A | 2008-03-14 A | 100% | 2007-09-03 | 2008-03-14 | 140d? |  | S1 | 1120h | 1120h | FS_PWS | T-Mobile | Rel-8 | Alain |  | 22.968 |  |  |  |  |
| 1202 | 392 | Study on Paging Permission with Access Control |  | 256d? | 2006-09-28 A | 2007-09-20 A | 100% | 2006-09-28 | 2007-09-20 | 256d? | finish no earlier than 2007-09-20 | S1 | 2048h | 2048h | FS_PPAC | NTT DoCoMo | Rel-8 | Alain |  | 22.908 |  |  |  |  |
| 1203 | 393 | Study on Non-3GPP access Network Selection Principles (NSP) |  | 392d? | 2006-12-06 A | 2008-06-05 A | 100% | 2006-12-06 | 2008-06-05 | 392d? | finish no earlier than 2007-11-19 | S1 | 3136h | 3136h | FS_N3GtoNSP | Telefónica O2 | Rel-8 | Alain |  | 22.912 |  |  |  |  |
| 1204 | 394 | Study on Value Added Services for Short Message Service |  | 263d? | 2006-12-06 A | 2007-12-07 A | 100% | 2006-12-06 | 2007-12-07 | 263d? | finish no earlier than 2007-12-07 | S1 | 2104h | 2104h | FS_VAS4SMS | China Mobile | Rel-8 | Alain |  | 22.942 |  |  |  |  |
| 1205 | 395 | Study on Service continuity between mobile and WLAN networks |  | 262d? | 2006-12-06 A | 2007-12-06 A | 100% | 2006-12-06 | 2007-12-06 | 262d? | finish no earlier than 2008-12-25 | S1 | 2096h | 2096h | FS_SMLSWLAN | NEC | Rel-8 | Alain |  | 22.937 |  |  |  |  |
| 1206 | 396 | Study on Services Alignment and Migration |  | 331d? | 2006-12-06 A | 2008-03-12 A | 100% | 2006-12-06 | 2008-03-12 | 331d? | finish no earlier than 2007-09-20 | S1 | 2648h | 2648h | FS_ServAl | Telefónica O2 | Rel-8 | Alain |  | 22.983 | SP-37 |  |  |  |

Notes:
- 1176: GP#40 completed. Align with RANimp-ANSS ongoing work item. GP#40 WID updated GP-080776=>GP-081784 (Conformance testing moved to A-GNSS WID) / Text5: Mungal Dhanda
- 1177: SP#42 completed by 22.071 CR0077
- 1178: GP#40 completed. Align with RANimp-ANSS ongoing work item. GP#40 WID updated GP-080776=>GP-081784 (Conformance testing moved to A-GNSS WID) / Text5: Mungal Dhanda
- 1179: SR in RP-080813. RP#42 WI closed at 95%. GERAN leading the work / considers performance requirements for Rel-9 / Text5: Etienne Chaponniere (echaponn@qualcomm.com)
- 1180: GP#45 completed / Text5: mats.y.samuelsson@ericsson.com, hakan.e.grunditz@ericsson.com
- 1181: GP#45 completed / Text5: hakan.e.grunditz@ericsson.com
- 1182: GP#41 completed / Text5: mats.y.samuelsson@ericsson.com
- 1183: GP#40 completed / Text5: Franz.Segerer@ROHDE-SCHWARZ.COM
- 1184: SP#42 completed
- 1185: -
- 1186: SP#38 stopped. 25/07/08 Moved UID_31059 Study on All-IP Network (FS_AIPN/was AIPFS ) to Rel-7 out of the stopped Rel-8 Feature UID_31067 Deleted - All-IP Network (AIPN) / Text5: c.masyu@nttdocomo.co.jp
- 1187: 22.258 withdrawn, superseded by 22.278 (UID 320022). SP#38 stopped / Text5: c.masyu@nttdocomo.co.jp
- 1188: SP-35 stopped / Text5: dhshim@lge.com
- 1189: SP#38 stopped
- 1190: SP#38 stopped (no support) / Text5: andre.jarvis@three.co.uk
- 1191: SP#38 stopped
- 1192: CP#47 work stopped/abandoned / Text5: Udo Willenbrink, Jacques Seif
- 1193: CP#47 work stopped/abandoned / Text5: Udo Willenbrink (uwillenbrink@comprion.com )
- 1194: CP#47 work stopped/abandoned / Text5: jacques.seif@gemalto.com
- 1195: GP#43 work stopped/abandoned (completion 0%) / Text5: arsi.heino@nokia.com
- 1196: -
- 1197: Spin-off Rel-8 Feature Customized Alerting Tone (CAT) Service UID_340029 / Text5: Qing Huang (huangqing@chinamobile.com)
- 1198: SP#35 completed. Spin-off SA3 Study on Security Aspects of Remote Provisioning and Change of Subscription for M2M (UID_370053). SP#40 Spin-off new Feature UID_410030 (NIMTC) / Text5: Juergen Merkel
- 1199: SP#38 completed / Text5: Joerg Swetina (joerg.swetina@nw.neclab.eu)
- 1200: SP#37 completed. Spin-off New Feature UID_370026 Value-Added Services for Short Message Service (VAS4SMS) / Text5: Qing Huang (huangqing@chinamobile.com)
- 1201: SP#39 completed. Spin-off Rel-9 Feature UID_380057 (PWS) / Text5: mark.younge@t-mobile.com
- 1202: SP#37 completed. Spin-off new Feature UID_370084 (PPACR) / Text5: Katsuhiro NOGUCHI (noguchi@nttdocomo.co.jp)
- 1203: SP#38 completed. Spin-off New Feature UID_380062 (N3GTONSP). SP#40 WID updated SP-060930=>SP-080318. TR re-approved with new # 22.812=>22.912 / Text5: chris.friel@O2.com
- 1204: SP#38 completed. Spin-off New Feature UID_370026 (VAS4SM) / Text5: Qing Huang (huangqing@chinamobile.com)
- 1205: SP#38 completed / Text5: joerg.swetina@neclab.eu
- 1206: SP#39 completed. Spin-off Rel-9 Feature UID_330017 Services Alignment and Migration (ServAl) / Text5: chris.friel@O2.com

| ID | WBS | Task | Duration | Start | Finish | Complete | Baseline start | Baseline finish | Baseline duration | Constraint | Resources | Work | Actual work | Text1 | Text4 | Text5 | Text6 | Text8 | Text3 | Text2 | Text7 | Text11 | Text9 | Text12 |
| --- | --- | --- | --- | --- | --- | --- | --- | --- | --- | --- | --- | --- | --- | --- | --- | --- | --- | --- | --- | --- | --- | --- | --- | --- |
| 1207 | 397 | **Study on 3GPP System Architecture Evolution** | 1115d? | 2004-12-03 A | 2009-03-12 A | 100% | 2004-12-03 | 2009-03-12 | 1115d? |  | S2,S3 | 23456h | 23456h | FS_SAE | Vodafone | Chris Pudney | Rel-8 | Maurice |  |  |  |  |  |  |
| 1208 | 397.1 | Stage 2 Interim conclusion for RAN Work to start | 990d? | 2004-12-03 A | 2008-09-18 A | 100% | 2004-12-03 | 2008-09-18 | 990d? | finish no earlier than 2005-09-23 | S2 | 7920h | 7920h | FS_SAE | Vodafone | Chris Pudney | Rel-8 | Maurice | 23.882 |  |  |  |  |  |
| 1209 | 397.2 | Stage 2 study on 3GPP architectural development | 704d? | 2006-01-09 A | 2008-09-18 A | 100% | 2006-01-09 | 2008-09-18 | 704d? | finish no earlier than 2007-09-28 | S2 | 5632h | 5632h | FS_SAE | Vodafone | Chris Pudney | Rel-8 | Maurice | 23.882 |  |  |  |  |  |
| 1210 | 397.3 | Security study for Inter-access mobility between non-3GPP and 3GPP system | 334d? | 2007-09-03 A | 2009-03-12 A | 100% | 2007-09-03 | 2009-03-12 | 334d? | finish no earlier than 2009-03-12 | S3 | 2672h | 2672h | FS_SAE | Nokia | dajiang.zhang@nokia.com | Rel-8 | Dionisio | 33.821, 33.822 |  |  |  |  |  |
| 1211 | 398 | Study on Stage 2 aspects of IMS Service Brokering | 589d? | 2006-06-19 A | 2008-09-18 A | 100% | 2006-06-19 | 2008-09-18 | 589d? | finish no earlier than 2008-09-18 | S2 | 4712h | 4712h | FS_ISB_ST2 | Telcordia | raquel@research.telcordia.com | Rel-8 | Maurice | 23.810 |  |  |  |  |  |
| 1212 | 399 | Study on IMS utilizing multicast bearer services | 447d? | 2006-03-22 A | 2007-12-06 A | 100% | 2006-03-22 | 2007-12-06 | 447d? | finish no earlier than 2007-12-03 | S2 | 3576h | 3576h | FS_MLTICAST-IMS | Nokia Siemens Networks |  | Rel-8 | Maurice | 23.847 |  |  |  |  |  |
| 1213 | 400 | Study on Multimedia Session Continuity | 291d? | 2007-04-26 A | 2008-06-05 A | 100% | 2007-04-26 | 2008-06-05 | 291d? | finish no earlier than 2008-06-05 | S2 | 2328h | 2328h | FS_MMSC | LG Electronics |  | Rel-8 | Maurice | 23.893 |  |  |  |  |  |
| 1214 | 401 | **Study on centralized IMS service control** | 363d? | 2006-10-23 A | 2008-03-12 A | 100% | 2006-10-23 | 2008-03-12 | 363d? |  | S2,S1 | 7952h | 7952h | FS_ICS | Ericsson | peter.bleckert@ericsson.com | Rel-8 | Alain |  | PCG-21 | SP-38 |  |  |  |
| 1215 | 401.1 | Study on centralized IMS services requirements | 268d? | 2007-03-05 A | 2008-03-12 A | 100% | 2007-03-05 | 2008-03-12 | 268d? | start no earlier than 2007-03-05 | S1 | 2144h | 2144h | FS_ICS-S1 | NEC | joerg.swetina@neclab.eu | Rel-8 | Alain | 22.892 |  | SP-37 |  |  |  |
| 1216 | 401.2 | Study on centralized IMS services control | 363d? | 2006-10-23 A | 2008-03-12 A | 100% | 2006-10-23 | 2008-03-12 | 363d? | finish no earlier than 2008-02-21 | S2 | 2904h | 2904h | FS_IMS_CSC | Alcatel-Lucent | andy.bennett@alcatel-lucent.com | Rel-8 | Maurice | 23.892 |  |  |  |  |  |
| 1217 | 402 | Study on Architecture of IMS based Customized Alerting Tone (CAT) | 208d? | 2007-12-04 A | 2008-09-18 A | 100% | 2007-12-04 | 2008-09-18 | 208d? | finish no earlier than 2008-09-08 | S2 | 1664h | 1664h | FS_CAT-St2 | China Mobile | WANG, Jing (wangjing@chinamobilecom) | Rel-8 | Maurice | 23.872 | PCG-21 | SP-38 |  |  |  |
| 1218 | 403 | Study on Home (e)NodeB Security | 321d? | 2007-12-20 A | 2009-03-12 A | 100% | 2007-12-20 | 2009-03-12 | 321d? | finish no earlier than 2009-03-10 | S3 | 2568h | 2568h | FS_HNB_Sec | Huawei | yangyanmei@huawei.com | Rel-8 | Dionisio | 33.820 | PCG-21 | SP-38 |  |  |  |
| 1219 | 404 | Study on Transferring of emergency call data – in-band modem solution | 265d? | 2006-12-07 A | 2007-12-12 A | 100% | 2006-12-07 | 2007-12-12 | 265d? | finish no earlier than 2008-09-18 | S4 | 2120h | 2120h | eCALLIBMS | Airbiquity | lhong@airbiquity.com | Rel-8 | Paolo | 26.967 |  |  |  |  |  |
| 1220 | 405 | Study on Element Operations Systems Function (EOSF) definition | 266d? | 2007-06-07 A | 2008-06-12 A | 100% | 2007-06-07 | 2008-06-12 | 266d? | finish no earlier than 2008-12-11 | S5 | 2128h | 2128h | OAM7-NIM- EOSF | China Mobile | Li Jian (lijian@chinamobile.com) | Rel-8 | Dionisio | 32.819 |  |  |  |  |  |
| 1221 | 406 | Study on SA5 MTOSI XML Harmonization | 351d? | 2006-05-10 A | 2007-09-12 A | 100% | 2006-05-10 | 2007-09-12 | 351d? | finish no earlier than 2007-12-14 | S5 | 2808h | 2808h | OAM8-NIM-XML | Nortel | jduguay@nortel.com | Rel-8 | Dionisio | 32.818 |  |  |  |  |  |
| 1222 | 407 | Study on Common Profile Storage (CPS) Framework of User Data for network services and management | 244d? | 2006-07-03 A | 2007-06-07 A | 100% | 2006-07-03 | 2007-06-07 | 244d? | finish no earlier than 2007-06-07 | S5 | 1952h | 1952h | OAM7-CPS | T-Mobile | istvan.aba@t-mobile.at | Rel-8 | Dionisio | 32.808 |  |  |  |  |  |
| 1223 | 408 | Study on Management for LTE and SAE | 526d? | 2006-12-07 A | 2008-12-11 A | 100% | 2006-12-07 | 2008-12-11 | 526d? | finish no earlier than 2008-12-11 | S5 | 4208h | 4208h | FS_OAM_LTE_SAE | Ericsson | robert.petersen@ericsson.com | Rel-8 | Dionisio | 32.816 |  |  |  |  |  |
| 1224 | 409 | Study on Charging Aspects of 3GPP System Evolution | 179d? | 2007-04-02 A | 2007-12-06 A | 100% | 2007-04-02 | 2007-12-06 | 179d? | finish no earlier than 2007-12-06 | S5 | 1432h | 1432h | FS_SAEcharg | Nokia Siemens Networks | Gerald.Goermer@nsn.com | Rel-8 | Dionisio | 32.820 |  |  |  |  |  |
| 1225 | 410 | Study on AS-MRFC media server control protocol | 583d? | 2006-03-22 A | 2008-06-13 A | 100% | 2006-03-22 | 2008-06-13 | 583d? | finish no earlier than 2008-06-13 | C1 | 4664h | 4664h | MRFC | Hewlett-Packard | mark.syrett@hp.com | Rel-8 | Frederic | 24.880 |  |  |  |  |  |
| 1226 | 411 | Study on IMS Restoration Procedures | 310d? | 2007-03-26 A | 2008-05-30 A | 100% | 2007-03-26 | 2008-05-30 | 310d? | finish no earlier than 2008-05-30 | C4 | 2480h | 2480h | FS_IMS_RP | Ericsson | german.blanco@ericsson.com | Rel-8 | Kimmo | 23.820 |  |  |  |  |  |
| 1227 | 412 | Study on IMS Application Server Service Data Descriptions for AS interoperability | 261d? | 2007-09-14 A | 2008-09-12 A | 100% | 2007-09-14 | 2008-09-12 | 261d? | finish no earlier than 2008-09-12 | C4 | 2088h | 2088h | FS_IMS_ASIO | Alcatel-Lucent | Jean-Jacques Trottin | Rel-8 | Kimmo | 29.864 |  |  |  |  |  |
| 1228 | 413 | Study on Customized Alerting Tone (CAT) solution for voice and video call in CS domain | 261d? | 2007-09-14 A | 2008-09-12 A | 100% | 2007-09-14 | 2008-09-12 | 261d? |  | C4 | 626.4h | 626.4h | FS_CAT_VVC_CS | China Mobile | zhanghao@chinamobile.com | Rel-8 | Kimmo | 29.882 |  |  |  |  |  |
| 1229 | 414 | Study on InterWorking Function between MAP based and Diameter based interfaces | 266d? | 2007-11-30 A | 2008-12-05 A | 100% | 2007-11-30 | 2008-12-05 | 266d? | finish no earlier than 2008-12-05 | C4 | 2128h | 2128h | FS_MAP2Diam | Huawei | liming49985@huawei.com | Rel-8 | Kimmo | 29.805 | PCG-21 | CP-38 |  |  |  |
| 1230 | 415 | Study on Scope of future HSPA Evolution for 1.28 Mcps TDD | 186d? | 2007-09-14 A | 2008-05-30 A | 100% | 2007-09-14 | 2008-05-30 | 186d? | finish no earlier than 2008-05-30 | R1 | 1488h | 1488h | FS_RAN-LCRTDDHSPAEvo | RITT | Xu Fei | Rel-8 | Patrick | 25.824 |  | RP-37 | RP-080290 |  |  |
| 1231 | 416 | Study on Synchronized E-DCH for UTRA FDD | 126d? | 2007-09-14 A | 2008-03-07 A | 100% | 2007-09-14 | 2008-03-07 | 126d? | finish no earlier than 2008-03-14 | R1 | 1008h | 1008h | FS_RAN-UplinkSync | Nokia Siemens Networks | Karri.Ranta-aho@nsn.com | Rel-8 | Patrick | 25.823 |  | RP-37 | RP-080068 |  |  |
| 1232 | 417 | Study on Improved network controlled mobility between LTE and 3GPP2/mobile WiMAX radio technologies | 131d? | 2007-06-04 A | 2007-12-03 A | 100% | 2007-06-04 | 2007-12-03 | 131d? | finish no earlier than 2007-12-03 | R4 | 1048h | 1048h | FS_RAN-LTEmob | Motorola | hao.bi@Motorola.com | Rel-8 | Issam | 36.938 |  |  | RP-070827 |  |  |
| 1233 | 418 | Study on 3G Home NodeB/eNodeB | 325d? | 2007-03-05 A | 2008-05-30 A | 100% | 2007-03-05 | 2008-05-30 | 325d? | finish no earlier than 2008-05-30 | R4 | 2600h | 2600h | FS_RAN-HNBeNB | Motorola | howard.thomas@motorola.com | Rel-8 | Issam | 25.820 |  |  | RP-080289 |  |  |
| 1234 | 419 | Study on A-interface over IP | 126d? | 2007-08-31 A | 2008-02-22 A | 100% | 2007-08-31 | 2008-02-22 | 126d? | finish no earlier than 2008-02-22 | GP | 1008h | 1008h | AINTIP | China Mobile, Ericsson | paul.schliwa-bertling@ericsson.com | Rel-8 | Paolo | 43.903 |  |  |  |  |  |
| 1235 | 420 | Study on Multi-User Reusing-One-Slot | 782d? | 2007-11-16 A | 2010-11-12 A | 100% | 2007-11-16 | 2010-11-12 | 782d? | finish no earlier than 2010-11-12 | GP | 6248h | 6248h | MUROS | Nokia Siemens Networks | juergen.hofmann@nsn.com | Rel-8 | Paolo | 45.914 |  |  |  |  |  |
| 1236 | 421 | Study on Optimized Transmit Pulse Shape for Downlink EGPRS2-B | 657d? | 2007-11-16 A | 2010-05-21 A | 100% | 2007-11-16 | 2010-05-21 | 657d? | finish no earlier than 2010-05-27 | G1 | 5248.44h | 5248.44h | WIDER | Research In Motion, Nokia Siemens Networks | jdwyer@RIM.COM and eddie.riddington@nsn.com | Rel-8 | Paolo | 45.913 |  |  |  |  |  |
| 1237 | 422 | Deleted - Study on Mobility between 3GPP-WLAN Interworking and 3GPP Systems | 393d? | 2007-03-20 A | 2008-09-18 A | 100% | 2007-03-20 | 2008-09-18 | 393d? | finish no earlier than 2008-09-18 | S2 | 3144h | 3144h | FS_SM3GWLAN | Orange |  | Rel-8 | Maurice | withdrawn 23.827 |  |  |  | PCG-21 | SP-41 |
| 1238 | 423 | Deleted - equals 340035 -FS on Service continuity between mobile and WLAN networks | 75d? | 2007-09-03 A | 2007-12-14 A | 100% | 2007-09-03 | 2007-12-14 | 75d? | finish no earlier than 2007-12-14 | S1 | 600h | 600h | FSSCMobToW | BT | mike.meyerstein@bt.com | Rel-8 | Alain | 22.937 |  | SP-37 |  | PCG-21 | SP-39 |
| 1239 | 424 | Deleted - Study on Evaluation of LCS Control Plane Solution for EPS | 100d? | 2008-01-14 A | 2008-05-30 A | 100% | 2008-01-14 | 2008-05-30 | 100d? | finish no earlier than 2009-03-20 | S2 | 800h | 800h | FS_LCS_EPS | SiRF |  | Rel-8 | Maurice | 23.891 |  | SP-38 |  | PCG-21 | SP-40 |
| 1240 | 425 | Deleted - Study on HS-PDSCH serving cell change enhancements | 60d? | 2007-12-17 A | 2008-03-07 A | 100% | 2007-12-17 | 2008-03-07 | 60d? | finish no earlier than 2008-06-12 | R4 | 480h | 480h | FS_RAN-HSPDSCH | Qualcomm |  | Rel-8 | Issam | none | PCG-21 | RP-38 | RP-080070 | PCG-21 | RP-39 |
| 1241 | 426 | Deleted - Study on Dual-Cell HSDPA operation | 261d? | 2007-08-15 A | 2009-03-06 A | 100% | 2007-08-15 | 2009-03-06 | 261d? | finish no earlier than 2009-03-06 | R1 | 2088h | 2088h | FS_RAN-DCHS | Qualcomm | Josef Blanz | Rel-8 | Patrick | withdrawn 25.825 v100 | PCG-21 | RP-39 | RP-090066 | PCG-22 | RP-43 |
| 1242 | 427 | Release 7 Features | 679d? | 2005-05-02 A | 2007-12-06 A | 100% | 2005-05-02 | 2007-12-06 | 679d? | start no earlier than 2000-01-01 | CP,GP,RP,SP | 5432h | 5432h |  |  |  | Rel-7 | All |  |  |  |  |  |  |

Notes:
- 1207: SP#43 completed
- 1208: SP#41 completed
- 1209: SP#41 completed
- 1210: SP#43 completed
- 1211: SP#41 completed. No spin-off activity proposed. [Note: IMS Service Brokering enhancements UID_31088 moved back from R8 to R7 to give a home to 22228CR0036_(Rel-7)_S1-051232. Hence, Rel-7 ISB has Stage 1 only (and is misaligned with Rel-7 Stages 2/3.]
- 1212: SP#38 completed
- 1213: SP#40 completed
- 1214: SP#39 completed
- 1215: SP#39 completed
- 1216: SP#39 completed
- 1217: SP#41 completed as Rel-8
- 1218: SP#43 completed. Linked to RAN4 Study on 3G Home NodeB/eNodeB (UID_350039) and to SA5 Study on Self-Organizing Networks (SON) related OAM interfaces for Home NodeB (UID_360007)
- 1219: SP#38 completed. Spin-off WID UID_34042 (eCall_Phase2)
- 1220: SP#40 completed. SID updated SP-050608=>SP-070307
- 1221: SP#37 completed. SID updated SP-050295=>SP-070305
- 1222: SP#36 completed. Spin-off New Feature UID_400034 User Data Convergence (UDC)
- 1223: SP#42 completed
- 1224: SP#38 completed
- 1225: CP#40 completed. Spin-off New Feature UID_380035 (MRFC_TS)
- 1226: CP#40 completed. Spin-off WID UID_400012 (IMS_RP)
- 1227: CP#41 completed. Linked to SA5 Study on Common Profile Storage framework UID_320006. Spin-off WID UID_410003 (IMS_ASIO)
- 1228: CP#41 completed. Spin-off WID under Feature CAT UID_340029
- 1229: CP#42 completed. Spin-off implementation Building Block UID_410007 (MAP2Diam) under the SAES Feature UID_320005
- 1230: RP#40 completed
- 1231: RP#39 completed
- 1232: RP#38 completed
- 1233: RP#40 completed
- 1234: GP#37 completed. Spin-off implementation Feature AoIP (A-interface over IP) UID_50591
- 1235: GP#48 completed as Rel-8. Spin-off implementation WI UID_420002 VAMOS (Voice services over Adaptive Multi-user channels on One Slot)
- 1236: GP#46 completed
- 1237: SP#41 stopped. Draft TR 23.827 content implemented in TS 23.327.
- 1238: SP#39 stopped
- 1239: SP#40 spin-off Feature UID_400038 (LCS_CPS_EPS). SP#40 FS stopped
- 1240: RP#39 stopped (no TR produced). Spin-off HS-DSCH Serving Cell Change Enhancements (UID_39003)
- 1241: RP#43 stopped (draft TR 25.825 v100 withdrawn). Conclusions in RP-090318 (RAN1 findings of the UTRA Multi-Carrier Evolution study). RP#42 New WI approved on Dual-Cell HSDPA operation on adjacent carriers (UID_400052)
- 1242: -

| ID | WBS | Task | Type | Duration | Start | Finish | Complete | Baseline start | Baseline finish | Baseline duration | Constraint | Resources | Work | Actual work | Text1 | Text4 | Text5 | Text6 | Text8 | Text12 | Text11 | Text7 | Text2 |
| --- | --- | --- | --- | --- | --- | --- | --- | --- | --- | --- | --- | --- | --- | --- | --- | --- | --- | --- | --- | --- | --- | --- | --- |
| 1243 | 428 | **Identification of Communication Services in IMS** |  | 620d? | 2005-05-02 A | 2007-09-14 A | 100% | 2005-05-02 | 2007-09-14 | 620d? |  | S2,S1,C1,S5 | 13016h | 13016h | ServID | Ericsson | stephen.terrill@ericsson.com | Rel-7 | Maurice |  |  |  |  |
| 1244 | 428.1 | TR on ServID |  | 232d? | 2005-05-02 A | 2006-03-21 A | 100% | 2005-05-02 | 2006-03-21 | 232d? | finish no earlier than 2006-03-20 | S2 | 1856h | 1856h | ServID | Ericsson | stephen.terrill@ericsson.com | Rel-7 | Maurice |  |  |  |  |
| 1245 | 428.2 | Stage 1,2 of ServID |  | 144d? | 2005-11-11 A | 2006-05-31 A | 100% | 2005-11-11 | 2006-05-31 | 144d? | start no earlier than 2005-11-11 | S1,S2 | 1152h | 1152h | ServID | Ericsson | stephen.terrill@ericsson.com | Rel-7 | Maurice |  |  |  |  |
| 1246 | 428.3 | Stage 3 of ServID |  | 250d? | 2006-03-31 A | 2007-03-15 A | 100% | 2006-03-31 | 2007-03-15 | 250d? | finish no earlier than 2007-03-15 | C1 | 2000h | 2000h | ServID | Ericsson | christer.holmberg@ericsson.com | Rel-7 | Frederic |  |  |  |  |
| 1247 | 428.4 | Charging of ServID |  | 381d? | 2006-03-31 A | 2007-09-14 A | 100% | 2006-03-31 | 2007-09-14 | 381d? | finish no earlier than 2007-09-14 | S5 | 3048h | 3048h | ServID | Orange | alain.bibas@orange-ft.com | Rel-7 | Dionisio |  |  |  |  |
| 1248 | 429 | **Supporting Globally Routable User Agent URIs in IMS** |  | 415d? | 2005-11-14 A | 2007-06-15 A | 100% | 2005-11-14 | 2007-06-15 | 415d? |  | S2,S1,C1 | 7760h | 7760h | GRUU | Research In Motion | Adrian Buckley (abuckley@rim.com) | Rel-7 | Maurice |  |  |  |  |
| 1249 | 429.1 | Deleted - TR on GRUU |  | 219d? | 2005-11-14 A | 2006-09-14 A | 100% | 2005-11-14 | 2006-09-14 | 219d? | finish no earlier than 2006-09-14 | S2 | 1752h | 1752h | GRUU | Research In Motion | Adrian Buckley (abuckley@rim.com) | Rel-7 | Maurice | SP-32 |  |  |  |
| 1250 | 429.2 | Stage 1,2 of GRUU |  | 65d? | 2006-07-03 A | 2006-09-29 A | 100% | 2006-07-03 | 2006-09-29 | 65d? | start no earlier than 2006-07-03 | S1,S2 | 520h | 520h | GRUU | Research In Motion | Adrian Buckley (abuckley@rim.com) | Rel-7 | Maurice |  |  |  |  |
| 1251 | 429.3 | Stage 3 of GRUU |  | 271d? | 2006-06-02 A | 2007-06-15 A | 100% | 2006-06-02 | 2007-06-15 | 271d? | finish no earlier than 2007-06-15 | C1 | 2168h | 2168h | GRUU | CableLabs | Bernie McKibben (b.mckibben@cablelabs.com) | Rel-7 | Frederic |  |  |  |  |
| 1252 | 430 | **Multimedia Telephony Service for IMS** |  | 357d? | 2006-02-01 A | 2007-06-15 A | 100% | 2006-02-01 | 2007-06-15 | 357d? |  | S1,C1,S4 | 8976h | 8976h | MTSI | Ericsson | peter.bleckert@ericsson.com | Rel-7 | Alain |  |  |  |  |
| 1253 | 430.1 | Stage 1 of MTSI |  | 173d? | 2006-02-01 A | 2006-09-29 A | 100% | 2006-02-01 | 2006-09-29 | 173d? | start no earlier than 2006-02-01 | S1 | 1384h | 1384h | MTSI-REQ | Ericsson | peter.bleckert@ericsson.com | Rel-7 | Alain |  |  |  |  |
| 1254 | 430.2 | Stage 3 of MTSI |  | 330d? | 2006-03-10 A | 2007-06-14 A | 100% | 2006-03-10 | 2007-06-14 | 330d? | finish no earlier than 2007-06-15 | C1 | 2640h | 2640h | MTSI | Ericsson | christer.holmberg@ericsson.com | Rel-7 | Frederic |  |  |  |  |
| 1255 | 430.3 | Media handling and interaction in MTSI |  | 262d? | 2006-03-15 A | 2007-03-15 A | 100% | 2006-03-15 | 2007-03-15 | 262d? | finish no earlier than 2007-03-15 | S4 | 2096h | 2096h | MTSI-MHI | Ericsson | olle.franceschi@ericsson.com | Rel-7 | Paolo |  |  |  |  |
| 1256 | 430.4 | Deleted - duplicates UID7039 - IMS Multimedia Telephony Service | milestone | 0d? | 2007-06-15 A | 2007-06-15 A | 100% | 2007-06-15 | 2007-06-15 | 0d? | start no earlier than 2007-06-15 | S1 |  |  | MMTEL | Ericsson | peter.bleckert@ericsson.com | Rel-7 | Alain | SP-32 |  |  |  |
| 1257 | 431 | Multimedia Telephony Service for IMS (MTSI) - UE Conformance Testing |  | 387d | 2007-09-19 A | 2009-03-12 A | 100% | 2007-09-19 | 2009-03-12 | 387d | finish no earlier than 2009-03-13 | R5 | 1664h | 1664h | MTSI-UEConTest | Ericsson, Motorola | Leif.Mattisson@ericsson.com, Jacob.John@motorola.com | Rel-7 | Ingbert |  | RP-090056 |  |  |
| 1258 | 432 | TISPAN requirements for Multimedia Telephony with PSTN/ISDN simulation services |  | 58d? | 2007-09-18 A | 2007-12-06 A | 100% | 2007-09-18 | 2007-12-06 | 58d? | start no earlier than 2007-09-18 | S1 | 464h | 464h | TMMTEL7 |  |  | Rel-7 | Alain |  |  | SP-37 |  |
| 1259 | 433 | **Maintenance of TISPAN release 1 common IMS** |  | 58d? | 2007-09-18 A | 2007-12-06 A | 100% | 2007-09-18 | 2007-12-06 | 58d? |  | S2 | 1392h | 1392h | MCIMSTR1 | Ericsson | Raymond Forbes | Rel-7 | Maurice |  |  | SP-38 | PCG-21 |
| 1260 | 433.1 | SA1 aspects of MCIMSTR1 |  | 58d? | 2007-09-18 A | 2007-12-06 A | 100% | 2007-09-18 | 2007-12-06 | 58d? | finish no earlier than 2007-12-06 | S1 | 464h | 464h | MCIMSTR1-S1 | Telecom Italia | Marco.DeLuca1@telecomitalia.it | Rel-7 | Alain |  |  | SP-38 | PCG-21 |
| 1261 | 433.2 | SA2 aspects of MCIMSTR1 |  | 58d? | 2007-09-18 A | 2007-12-06 A | 100% | 2007-09-18 | 2007-12-06 | 58d? | finish no earlier than 2007-12-06 | S2 | 464h | 464h | MCIMSTR1-S2 | Ericsson | Raymond Forbes | Rel-7 | Maurice |  |  | SP-38 | PCG-21 |
| 1262 | 434 | **PS domain and IMS impacts for supporting IMS Emergency calls** |  | 1760d? | 2000-09-18 A | 2007-06-15 A | 100% | 2000-09-18 | 2007-06-15 | 1760d? |  | S2,S1 | 44157h | 44157h | EMC1 | Siemens | Rainer Liebhart | Rel-7 | Maurice |  |  |  |  |
| 1263 | 10.1.1 | Service Requirements for IP-based emergency calls |  | 985d | 2000-09-18 A | 2004-06-25 A | 100% | 2000-09-18 | 2004-06-25 | 985d | finish no earlier than 2004-06-25 | S1 | 7880h | 7880h | EMC1 | Siemens | Rainer Liebhart | Rel-7 | Alain |  |  |  |  |
| 1264 | 434.2 | Study on Stage 2 for IMS-level solution |  | 668d? | 2003-02-26 A | 2005-09-16 A | 100% | 2003-02-26 | 2005-09-16 | 668d? | finish no earlier than 2005-09-16 | S2 | 5344h | 5344h | EMC1 | Siemens | Rainer Liebhart | Rel-7 | Maurice |  |  |  |  |
| 1265 | 434.3 | Study on Stage 2 for GPRS-level solution |  | 301d? | 2004-10-14 A | 2005-12-08 A | 100% | 2004-10-14 | 2005-12-08 | 301d? | finish no earlier than 2005-12-08 | S2 | 2408h | 2408h | EMC1 | Siemens | Rainer Liebhart | Rel-7 | Maurice |  |  |  |  |
| 1266 | 434.4 | Stage 2 Specification Phase - IMS-level |  | 200d? | 2005-09-05 A | 2006-06-09 A | 100% | 2005-09-05 | 2006-06-09 | 200d? | finish no earlier than 2006-06-09 | S2 | 1600h | 1600h | EMC1 | Siemens | Rainer Liebhart | Rel-7 | Maurice |  |  |  |  |
| 1267 | 434.5 | Deleted - Stage 2 Specification Phase - GPRS-level | milestone | 0d? | 2007-03-02 A | 2007-03-02 A | 100% | 2007-03-02 | 2007-03-02 | 0d? | start no earlier than 2007-03-02 | S2 |  |  | EMC1 | Siemens | Rainer Liebhart | Rel-7 | Maurice | SP-32 |  |  |  |

Notes:
- 1243: WID approved SP#28. WID updated SP#32
- 1244: - / Text3: 23.816
- 1245: - / Text3: 22.228, 23.228, 23.203
- 1246: CP#32 approved WID / Text3: 23.218, 24.229
- 1247: - / Text3: 32.260, 32.298, 32.299
- 1248: SP#29 approved WID
- 1249: Abandoned
- 1250: SP#29 approved WID / Text3: 22.228, 23.228, 23.218, 24.229
- 1251: CP#32 approved WID / Text3: 24.229
- 1252: -
- 1253: - / Text3: 22.173
- 1254: - / Text3: 24.173
- 1255: - / Text3: 26.114
- 1256: - / Text3: 22.173
- 1257: RP#43 completed. Linked UID_7038 (MTSI) / Text3: 34.123-1, 34.123-2, 34.123-3, 34.229-1, 34.229-2
- 1258: - / Text3: 22.273 (EI 181 002 maintenance)
- 1259: - / Text3: http://www.3gpp.org/specs/TISPAN-IMS-ansfer.htm
- 1260: - / Text3: 22.173, 22.273
- 1261: - / Text3: 23.406, 23.417, 23.508,23.509, 23.511
- 1262: -
- 1263: - / Text3: 22.976 (DB shows 04/2003 withdrawn Study on PS domain services and capabilities (az: belongs this really here ?!)
- 1264: - / Text3: 23.867
- 1265: - / Text3: 23.867
- 1266: - / Text3: 23.167, 23.228, 23.060, 23.002, 23.271
- 1267: -

| ID | WBS | Task | Type | Duration | Start | Finish | Complete | Baseline start | Baseline finish | Baseline duration | Constraint | Resources | Work | Actual work | Text1 | Text4 | Text5 | Text6 | Text8 | Text3 | Text12 | Text10 | Text11 |
| --- | --- | --- | --- | --- | --- | --- | --- | --- | --- | --- | --- | --- | --- | --- | --- | --- | --- | --- | --- | --- | --- | --- | --- |
| 1268 | 10.1 | **Emergency Call Enhancements for IP& PS Based Calls – stage 3** |  | 375d | 2006-01-09 A | 2007-06-15 A | 100% | 2006-01-09 | 2007-06-15 | 375d |  | C1 | 12845h | 12845h | EMC1 | Ericsson | alf.heidermark@ericsson.com | Rel-7 | Frederic |  |  |  |  |
| 1269 | 10.1.2 | CT1 IMS aspects to support IMS Emergency sessions |  | 350.82d | 2006-01-09 A | 2007-06-15 A | 100% | 2006-01-09 | 2007-06-15 | 350.82d | finish no earlier than 2007-06-15 | C1 | 2806.57h | 2806.57h | EMC1 | Ericsson | alf.heidermark@ericsson.com | Rel-7 | Frederic | 24.229 |  |  |  |
| 1270 | 10.1.2 | Deleted - CT3 IMS aspects to support IMS Emergency sessions |  | 95d | 2006-05-08 A | 2006-09-15 A | 100% | 2006-05-08 | 2006-09-15 | 95d | finish no earlier than 2006-09-15 | C3 | 760h | 760h | EMC1 | Ericsson | alf.heidermark@ericsson.com | Rel-7 | Jiwan | 29.163 | CP-33 |  |  |
| 1271 | 10.1.5 | Deleted - CT3 PS domain aspects to support IMS Emergency sessions |  | 95d | 2006-05-08 A | 2006-09-15 A | 100% | 2006-05-08 | 2006-09-15 | 95d | start no earlier than 2006-05-08 | C3 | 760h | 760h | EMC1 | Ericsson | alf.heidermark@ericsson.com | Rel-7 | Jiwan | 29.061 | CP-33 |  |  |
| 1272 | 10.1.5 | CT1 PS domain aspects to support IMS Emergency sessions |  | 349.9d | 2006-01-09 A | 2007-06-15 A | 100% | 2006-01-09 | 2007-06-15 | 349.9d | finish no earlier than 2007-06-15 | C1 | 2799.2h | 2799.2h | EMC1 | Ericsson | alf.heidermark@ericsson.com | Rel-7 | Frederic | 24.008, 24.234 |  |  |  |
| 1273 | 10.1.5 | CT4 PS domain aspects to support IMS Emergency sessions |  | 365d | 2006-01-09 A | 2007-06-01 A | 100% | 2006-01-09 | 2007-06-01 | 365d | finish no earlier than 2007-06-01 | C4 | 2920h | 2920h | EMC1-GPRSc4 | Ericsson | alf.heidermark@ericsson.com | Rel-7 | Kimmo | 29.060 |  |  |  |
| 1274 | 435 | IMS Support of Conferencing |  | 355d? | 2005-11-04 A | 2007-03-15 A | 100% | 2005-11-04 | 2007-03-15 | 355d? | finish no earlier than 2007-03-15 | C1 | 2840h | 2840h | IMSconf | Alcatel-Lucent | Keith Drage (drage@alcatel-lucent.com) | Rel-7 | Frederic | 24.147, 24.229 |  |  |  |
| 1275 | 436 | Performance Characterization of VoIMS over HSDPA\EUL channels |  | 713d? | 2005-03-15 A | 2007-12-06 A | 100% | 2005-03-15 | 2007-12-06 | 713d? | finish no earlier than 2007-12-06 | S4 | 5704h | 5704h | VoIMS-PCVoIMS | Alcatel-Lucent | mcgowan@alcatel-lucent.com | Rel-7 | Paolo | 26.935 |  |  |  |
| 1276 | 437 | **WLAN-UMTS Interworking Phase 2** |  | 371d? | 2004-01-05 A | 2005-06-07 A | 100% | 2004-01-05 | 2005-06-07 | 371d? |  | S1 | 3888h | 3888h | WLAN2 | Telenor | frederic.paint@telenor.com | Rel-7 | Alain | 33.234 (SP-36 SA3 CRs approved) |  |  |  |
| 1277 | 437.1 | Stage 1 on Session Continuity |  | 115d? | 2004-01-05 A | 2004-06-11 A | 100% | 2004-01-05 | 2004-06-11 | 115d? | start no earlier than 2004-01-05 | S1 | 920h | 920h | WLAN-SC |  |  | Rel-7 | Alain | 22.234 |  | SP-24 |  |
| 1278 | 437.2 | Stage 2 on Session Continuity: covered by SAE | milestone | 0d? | 2005-06-07 A | 2005-06-07 A | 100% | 2005-06-07 | 2005-06-07 | 0d? | finish no earlier than 2005-06-07 | S2 |  |  | WLAN-SC |  |  | Rel-7 | Maurice |  |  |  |  |
| 1279 | 438 | **WLAN Interworking – Private Network access from WLAN 3GPP IP Access** |  | 252d? | 2005-10-10 A | 2006-09-26 A | 100% | 2005-10-10 | 2006-09-26 | 252d? |  | S2,C1,C3,C4 | 8936h | 8936h | WLANPNA | NEC | Toshiyuki Tamura (tamurato@aj.jp.nec.com) | Rel-7 | Maurice |  |  |  |  |
| 1280 | 438.1 | WLAN-PNA - Stage 2 |  | 185d? | 2005-10-10 A | 2006-06-23 A | 100% | 2005-10-10 | 2006-06-23 | 185d? | start no earlier than 2005-10-10 | S2 | 1480h | 1480h | WLANPNA-st2 | NEC | Toshiyuki Tamura (tamurato@aj.jp.nec.com) | Rel-7 | Maurice | 23.234, 33.234 |  |  |  |
| 1281 | 438.2 | **WLAN-PNA - Stage 3** |  | 170d? | 2006-02-01 A | 2006-09-26 A | 100% | 2006-02-01 | 2006-09-26 | 170d? |  | C1,C3,C4 | 5440h | 5440h | WLANPNA-st3 | NEC |  | Rel-7 | Frederic |  |  |  |  |
| 1282 | 438.2.1 | CT1 aspets for WLAN-PNA |  | 170d? | 2006-02-01 A | 2006-09-26 A | 100% | 2006-02-01 | 2006-09-26 | 170d? | start no earlier than 2006-02-01 | C1 | 1360h | 1360h | WLANPNA-st3 | NEC |  | Rel-7 | Frederic | 24.234 |  |  |  |
| 1283 | 438.2.2 | CT3 aspets for WLAN-PNA |  | 170d? | 2006-02-01 A | 2006-09-26 A | 100% | 2006-02-01 | 2006-09-26 | 170d? | start no earlier than 2006-02-01 | C3 | 1360h | 1360h | WLANPNA-st3 | NEC |  | Rel-7 | Jiwan | 29.161 |  |  |  |
| 1284 | 438.2.3 | Deleted - CT4 aspets for WLAN-PNA |  | 170d? | 2006-02-01 A | 2006-09-26 A | 100% | 2006-02-01 | 2006-09-26 | 170d? | start no earlier than 2006-02-01 | C4 | 1360h | 1360h | WLANPNA-st3 | NEC |  | Rel-7 | Kimmo | 29.234 | CP-32 |  |  |
| 1285 | 439 | **Enhancements to support QoS provisioning over 3GPP/WLAN Interworking** |  | 520d? | 2005-03-14 A | 2007-03-09 A | 100% | 2005-03-14 | 2007-03-09 | 520d? |  | S2,C4,C1 | 8360h | 8360h | WLANQOS | Samsung |  | Rel-7 | Maurice |  |  |  |  |
| 1286 | 439.1 | Deleted - TR on support of QoS on WLAN |  | 232d? | 2005-03-14 A | 2006-01-31 A | 100% | 2005-03-14 | 2006-01-31 | 232d? | start no earlier than 2005-03-14 | S2 | 1856h | 1856h | WLANQOS | Samsung |  | Rel-7 | Maurice | 23.836 | SP-32 |  |  |
| 1287 | 439.2 | Stage 2 on support of QoS over 3GPP/WLAN interworking |  | 108d? | 2006-02-01 A | 2006-06-30 A | 100% | 2006-02-01 | 2006-06-30 | 108d? | start no earlier than 2006-02-01 | S2 | 864h | 864h | WLANQOS | Samsung |  | Rel-7 | Maurice | 23.234 |  |  |  |
| 1288 | 439.3 | Stage 3 CT4 on support of QoS over 3GPP/WLAN Interworking |  | 121d? | 2006-09-22 A | 2007-03-09 A | 100% | 2006-09-22 | 2007-03-09 | 121d? | finish no earlier than 2007-03-09 | C4 | 968h | 968h | WLANQOS | Huawei | zhang.peng@huawei.com | Rel-7 | Kimmo | 29.234, 23.008 |  |  |  |
| 1289 | 439.4 | Stage 3 CT1 on support of QoS over 3GPP/WLAN Interworking |  | 64d? | 2006-09-04 A | 2006-11-30 A | 100% | 2006-09-04 | 2006-11-30 | 64d? | finish no earlier than 2006-11-30 | C1 | 512h | 512h | WLANQOS | Huawei | zhang.peng@huawei.com | Rel-7 | Frederic | 24.234 |  |  |  |
| 1290 | 440 | **Location Services enhancements** |  | 906d? | 2004-06-28 A | 2007-12-17 A | 100% | 2004-06-28 | 2007-12-17 | 906d? |  | S1,S2,GP,C4,R2 | 46933.6h | 46933.6h | LCS3 |  |  | Rel-7 | Alain |  |  |  |  |
| 1291 | 440.1 | Stage 2 for LCS3 (including IMS emergency location aspects) |  | 446d? | 2004-12-31 A | 2006-09-15 A | 100% | 2004-12-31 | 2006-09-15 | 446d? | finish no earlier than 2006-09-15 | S2 | 3568h | 3568h | LCS3 | SiRF | brodilitz@sirf.com | Rel-7 | Maurice | 23.271 |  |  |  |
| 1292 | 440.2 | LCS Enhancements related to Location-Based Services |  | 695d? | 2005-01-03 A | 2007-08-31 A | 100% | 2005-01-03 | 2007-08-31 | 695d? | finish no earlier than 2007-08-31 | GP | 5560h | 5560h | LCS3-LBS | SiRF | kjudge@sirf.com | Rel-7 | Paolo | 43.059, 44.031, 48.008, 49.031 |  |  |  |
| 1293 | 440.3 | CT4 aspects for LCS UEPos-LBS |  | 240d? | 2006-01-02 A | 2006-12-01 A | 100% | 2006-01-02 | 2006-12-01 | 240d? | finish no earlier than 2006-12-01 | C4 | 1920h | 1920h | LCS3-UEPos-LBS | SiRF | brodilitz@sirf.com | Rel-7 | Kimmo | 24.030, 24.080, 29.002 |  |  |  |
| 1294 | 440.4 | UE positioning - Velocity |  | 394d? | 2005-03-15 A | 2006-09-15 A | 100% | 2005-03-15 | 2006-09-15 | 394d? | finish no earlier than 2006-09-15 | R2 | 3152h | 3152h | LCS3-UEPos-Velocity | SiRF | BRodilitz@SiRF.com | Rel-7 | Joern | 25.305, 25.331, 25.410, 25.413, 25.453 |  |  | RP-060459 |
| 1295 | 440.5 | Inclusion of Uplink TDOA UE positioning method in the UTRAN specifications |  | 849d? | 2004-09-15 A | 2007-12-17 A | 100% | 2004-09-15 | 2007-12-17 | 849d? | finish no earlier than 2007-12-17 | R2 | 6792h | 6792h | LCS3-UEPos-UTDOA | TruePosition | Robert Gross (rgross@polariswireless.com) | Rel-7 | Joern | 25.305, 25.453 |  |  | RP-070797 |

Notes:
- 1268: -
- 1269: -
- 1270: Cancelled for Rel-7 and there is now corresponding Rel-8 WI
- 1271: Cancelled for Rel-7 and there is now corresponding Rel-8 WI
- 1272: -
- 1273: -
- 1274: CP#35 revised WID
- 1275: -
- 1276: Created at TSG#27 because of WLAN items belonging to Rel-7
- 1277: -
- 1278: -
- 1279: -
- 1280: Approved at SP#29
- 1281: Approved at CP#29
- 1282: Approved at CP#29
- 1283: Approved at CP#29
- 1284: CT4#31; no impacts identified, therefore completed. CP-32 stopped
- 1285: Moved from FS section Feb 06. SP-30 updated WID
- 1286: SP-32 stopped
- 1287: SP-30 updated WID
- 1288: CP-32 approved WID
- 1289: CP-32 approved WID
- 1290: -
- 1291: SP#27 approved WID.
- 1292: -
- 1293: -
- 1294: Completed Sept 2006; SR in RP-060459
- 1295: Completed Nov 2007; SR in RP-070797

| ID | WBS | Task | Type | Duration | Start | Finish | Complete | Baseline start | Baseline finish | Baseline duration | Constraint | Resources | Work | Actual work | Text1 | Text4 | Text5 | Text6 | Text8 | Text12 | Text11 | Text2 | Text7 |
| --- | --- | --- | --- | --- | --- | --- | --- | --- | --- | --- | --- | --- | --- | --- | --- | --- | --- | --- | --- | --- | --- | --- | --- |
| 1296 | 440.6 | **LCS for 3GPP Interworking WLAN** |  | 700d? | 2004-06-28 A | 2007-03-02 A | 100% | 2004-06-28 | 2007-03-02 | 700d? |  | S1 | 11901.6h | 11901.6h | LCS3-IWLAN | Telcordia | Mike Loushine | Rel-7 | Alain |  |  |  |  |
| 1297 | 440.6.1 | FS on 3GPP system to WLAN Interworking with LCS |  | 512.7d? | 2004-06-28 A | 2006-06-30 A | 100% | 2004-06-28 | 2006-06-30 | 512.7d? | finish no earlier than 2005-09-29 | S1 | 4101.6h | 4101.6h | LCS3-IWLAN-FSs1 | Telcordia | Mike Loushine | Rel-7 | Alain |  |  |  |  |
| 1298 | 440.6.2 | Deleted - Study of work on an LCS architecture for I-WLAN. |  | 180d? | 2006-06-26 A | 2007-03-02 A | 100% | 2006-06-26 | 2007-03-02 | 180d? | finish no earlier than 2007-03-02 | S2 | 1440h | 1440h | LCS3-IWLAN-FSs2 | LG Electronics | dhshim@lge.com ; phede@lge.com | Rel-7 | Maurice | SP-35 |  |  |  |
| 1299 | 440.6.3 | Stage 2 for LCS architecture for I-WLAN |  | 95d? | 2006-10-23 A | 2007-03-02 A | 100% | 2006-10-23 | 2007-03-02 | 95d? | finish no earlier than 2007-03-02 | S2 | 760h | 760h | LCS3-IWLAN | LG Electronics | dhshim@lge.com ; phede@lge.com | Rel-7 | Maurice |  |  |  |  |
| 1300 | 440.7 | Deleted - UE positioning Rel-7 |  | 849d? | 2004-09-15 A | 2007-12-17 A | 100% | 2004-09-15 | 2007-12-17 | 849d? |  | RP | 6792h | 6792h | LCS3-UEpos |  |  | Rel-7 | Joern | RP-38 |  |  |  |
| 1301 | 440.8 | Deleted - RAN2 aspects for LBS | milestone | 0d? | 2005-06-15 A | 2005-06-15 A | 100% | 2005-06-15 | 2005-06-15 | 0d? | start no earlier than 2005-06-15 | R2 |  |  | LCS3-UEPos-LBS | SiRF | BRodilitz@SiRF.com | Rel-7 | Joern | RP-31 |  |  |  |
| 1302 | 441 | **MBMS Enhancements** |  | 625d? | 2005-07-11 A | 2007-11-30 A | 100% | 2005-07-11 | 2007-11-30 | 625d? |  | S1,R1,C3 | 10844.6h | 10844.6h | MBMSE | China Mobile | liuhongyfw@chinamobile.com | Rel-7 | Alain |  |  |  |  |
| 1303 | 441.1 | Stage 1 of MBMSE |  | 109d? | 2005-07-11 A | 2005-12-08 A | 100% | 2005-07-11 | 2005-12-08 | 109d? | finish no earlier than 2005-12-08 | S1 | 872h | 872h | MBMSE | China Mobile | liuhongyfw@chinamobile.com | Rel-7 | Alain |  |  |  |  |
| 1304 | 441.2 | MBMS FDD Physical layer Enhancements |  | 117.29d? | 2006-12-15 A | 2007-06-04 A | 100% | 2006-12-15 | 2007-06-04 | 117.29d? | finish no earlier than 2007-06-04 | R1 | 938.32h | 938.32h | MBMSE-RANPhysFDD | Ericsson | Lars.Lindbom@ericsson.com | Rel-7 | Patrick |  | RP-070290 |  |  |
| 1305 | 441.3 | MBMS TDD Physical layer Enhancements |  | 117.29d? | 2006-12-15 A | 2007-06-04 A | 100% | 2006-12-15 | 2007-06-04 | 117.29d? | finish no earlier than 2007-06-04 | R1 | 938.32h | 938.32h | MBMSE-RANPhysTDD | IPWireless | Nicholas Anderson | Rel-7 | Patrick |  | RP-070291 |  |  |
| 1306 | 441.4 | MBMS Low Chip Rate TDD Physical Layer Enhancement |  | 127d? | 2007-03-16 A | 2007-09-10 A | 100% | 2007-03-16 | 2007-09-10 | 127d? | finish no earlier than 2007-09-10 | R1 | 1016h | 1016h | MBMSE-RANPhysLCRTDD | RITT | Lin Hui | Rel-7 | Patrick |  | RP-070292 |  |  |
| 1307 | 441.5 | MBMS Mz interface |  | 260d? | 2006-12-04 A | 2007-11-30 A | 100% | 2006-12-04 | 2007-11-30 | 260d? | finish no earlier than 2007-05-11 | C3 | 2080h | 2080h | MBMSMz | Huawei | Deng Tingting (ttdeng@huawei.com) | Rel-7 | Jiwan |  |  |  |  |
| 1308 | 442 | **MBMS - UE Conformance Testing** |  | 657d? | 2007-06-01 A | 2009-12-04 A | 100% | 2007-06-01 | 2009-12-04 | 657d? |  | R5 | 13848h | 13848h | MBMSE_UEConTest |  |  | Rel-7 | Ingbert |  |  | PCG-21 | SP-40 |
| 1309 | 442.1 | Conformance Test Aspects – MBMS TDD Physical layer Enhancements – MBSFN for HCR and VHCR TDD |  | 336d? | 2007-06-01 A | 2008-09-12 A | 100% | 2007-06-01 | 2008-09-12 | 336d? | start no earlier than 2007-06-01 | R5 | 2688h | 2688h | MBMSE-RANPhysTDD_UEConTest | IPWireless | tspeight@ipwireless.com | Rel-7 | Ingbert |  | RP-080541 |  |  |
| 1310 | 442.2 | Conformance Test Aspects – MBMS LCR TDD Physical Layer Enhancement |  | 342d? | 2008-05-30 A | 2009-09-18 A | 100% | 2008-05-30 | 2009-09-18 | 342d? | finish no earlier than 2009-09-18 | R5 | 2728h | 2728h | MBMSE-RANPhysLCRTDD_UEConTest | CATT | chenxiaozhong@datangmobile.cn | Rel-7 | Ingbert |  | RP-090715 | PCG-21 | RP-40 |
| 1311 | 442.3 | Conformance Test Aspects – MBSFN for FDD |  | 397d? | 2008-05-30 A | 2009-12-04 A | 100% | 2008-05-30 | 2009-12-04 | 397d? | finish no earlier than 2009-12-04 | R5 | 3176h | 3176h | MBMSE-UEConTest_RANPhysFDD | Huawei | Xiang Li (trica_li@huawei.com) | Rel-7 | Ingbert |  | RP-091214 | PCG-21 | RP-40 |
| 1312 | 443 | MBMS User Service Extensions |  | 392d? | 2005-12-07 A | 2007-06-07 A | 100% | 2005-12-07 | 2007-06-07 | 392d? | finish no earlier than 2007-06-07 | S4 | 3136h | 3136h | MBMSUSE | Ericsson | Thorsten.Lohmar@ericsson.com | Rel-7 | Paolo |  |  |  |  |
| 1313 | 444 | **Advanced Global Navigation Satellite System (A-GNSS) concept** |  | 830d? | 2004-06-28 A | 2007-08-31 A | 100% | 2004-06-28 | 2007-08-31 | 830d? |  | S1,GP,R2 | 9553.6h | 9553.6h | LCS3-AGNSS | Alcatel | Michel.monnerat@thalesaleniaspace.com | Rel-7 | Alain |  |  |  |  |
| 1314 | 444.1 | Towards A-GNSS Concept |  | 811.2d? | 2004-06-28 A | 2007-08-31 A | 100% | 2004-06-28 | 2007-08-31 | 811.2d? | finish no earlier than 2007-08-31 | GP | 6489.6h | 6489.6h | AGNSS-GP | Alcatel | richard.couty@space.alcatel.fr | Rel-7 | Paolo |  |  |  |  |
| 1315 | 444.2 | Global Navigation Satellite System (GNSS) in UTRAN |  | 383d? | 2005-12-15 A | 2007-06-04 A | 100% | 2005-12-15 | 2007-06-04 | 383d? | finish no earlier than 2007-06-04 | R2 | 3064h | 3064h | LCS3-GNSS-UTRAN | France Telecom | alain.abinakhoul@francetelecom.com | Rel-7 | Joern |  | RP-070482 |  |  |
| 1316 | 444.3 | Deleted - Towards A-GNSS Concept | milestone | 0d? | 2007-02-16 A | 2007-02-16 A | 100% | 2007-02-16 | 2007-02-16 | 0d? | start no earlier than 2007-02-16 | S1 |  |  | GNSS | Alcatel | richard.couty@space.alcatel.fr | Rel-7 | Alain | SP-34 |  |  |  |
| 1317 | 445 | A-GPS Minimum Performance |  | 351d? | 2006-04-28 A | 2007-08-31 A | 100% | 2006-04-28 | 2007-08-31 | 351d? | finish no earlier than 2007-08-31 | GP | 2808h | 2808h | GAGR | Spirent | richard.catmur@spirentcom.com | Rel-7 | Paolo |  |  |  |  |
| 1318 | 446 | **USSD message delivery and transfer to USIM** |  | 376d? | 2004-03-05 A | 2005-08-12 A | 100% | 2004-03-05 | 2005-08-12 | 376d? |  | S1,C6 | 2762.4h | 2762.4h | USSD-USIM | Axalto | Christophe Dubois (cdubois@axalto.com) | Rel-7 | Alain |  |  |  |  |
| 1319 | 446.1 | Stage 1 |  | 152d? | 2004-03-18 A | 2004-10-15 A | 100% | 2004-03-18 | 2004-10-15 | 152d? | start no earlier than 2004-03-18 | S1 | 1216h | 1216h | USSD-USIM | Axalto | Christophe Dubois (cdubois@axalto.com) | Rel-7 | Alain |  |  |  |  |
| 1320 | 446.2 | Alignment with requirements regarding USSD usage |  | 193.3d? | 2004-03-05 A | 2005-08-12 A | 100% | 2004-03-05 | 2005-08-12 | 193.3d? | finish no earlier than 2005-08-12 | C6 | 1546.4h | 1546.4h | USSD-USIM | Axalto | Christophe Dubois (cdubois@axalto.com) | Rel-7 | Xavier |  |  |  |  |

Notes:
- 1296: -
- 1297: - / Text3: 22.935
- 1298: Updated WID at SP#32 to change "stage 2" to "study" , duplicated UID 320017 deleted. SP#33 TR for Information. Last mention SP-35 Mar 2007 (abandoned ?) / Text3: 23.837
- 1299: WID at SP#55 / Text3: 23.234, 23.271, 23.167
- 1300: -
- 1301: - / Text3: 25.305, 25.331, 25.410, 25.413, 25.453
- 1302: -
- 1303: Structure created by MCC to include RAN aspects under SA1 Feature / Text3: 22.146, 22.246, 22.228
- 1304: Completed May 2007; SR in RP-070290 / Text3: 25.211, 25.212, 25.213, 25.101, 25.104, 25.331, 25.433, 25.346, 25.306
- 1305: Completed May 2007; SR in RP-070291 / Text3: 25.346, 25.221, 25.222, 25.223, 25.224, 25.306, 25.331, 25.402, 25.433, 25.102, 25.105, 25.123
- 1306: Completed May 2007; SR in RP-070292 / Text3: 25.346, 25.221, 25.222, 25.223, 25.224, 25.306, 25.331, 25.402, 25.433, 25.102, 25.105, 25.123
- 1307: - / Text3: 29.061
- 1308: Linked to Rel-7 Feature UID_31084 (MBMSE)
- 1309: RP#41 completed / Text3: 34.108, 34.122, 34.123-1/2/3
- 1310: RP#45 completed / Text3: 34.108, 34.123-1
- 1311: RP#46 completed / Text3: 34.108, 34.109, 34.121-1, 34.121-2, 34.123-1, 34.123-2, 34.123-3
- 1312: - / Text3: 26.346, 26.946
- 1313: -
- 1314: GP#36 completed
- 1315: Completed Sept 2006; SR in RP-070482 / Text3: 25.305, 25.331, 25.306, 25.413, 25.423, 25.433, 25.453, 25.302, 25.215, 25.401, 25.402, 25.450, 25.452
- 1316: -
- 1317: - / Text3: 45.005, 51.010
- 1318: -
- 1319: - / Text3: 22.090
- 1320: -

| ID | WBS | Task | Type | Duration | Start | Finish | Complete | Baseline start | Baseline finish | Baseline duration | Constraint | Resources | Work | Actual work | Text1 | Text4 | Text5 | Text6 | Text8 | Text3 | Text12 |
| --- | --- | --- | --- | --- | --- | --- | --- | --- | --- | --- | --- | --- | --- | --- | --- | --- | --- | --- | --- | --- | --- |
| 1321 | 447 | **Combinational Services** |  | 296d? | 2005-01-17 A | 2006-03-06 A | 100% | 2005-01-17 | 2006-03-06 | 296d? |  | S1,S2,C1,S4 | 5176h | 5176h | CSICS | TeliaSonera | Robert.Frank@teliasonera.com | Rel-7 | Alain |  |  |
| 1322 | 447.1 | Stage 1 for CSICS |  | 104d? | 2005-01-17 A | 2005-06-09 A | 100% | 2005-01-17 | 2005-06-09 | 104d? | start no earlier than 2005-01-17 | S1 | 832h | 832h | CSICS | TeliaSonera | Robert.Frank@teliasonera.com | Rel-7 | Alain | 22.279 |  |
| 1323 | 447.2 | Stage 2 for CSICS |  | 130d? | 2005-01-17 A | 2005-07-15 A | 100% | 2005-01-17 | 2005-07-15 | 130d? | start no earlier than 2005-01-17 | S2 | 1040h | 1040h | CSICS | TeliaSonera | Robert.Frank@teliasonera.com | Rel-7 | Maurice | 23.279 |  |
| 1324 | 447.3 | Stage 3 for CSICS CN aspects |  | 221d? | 2005-05-02 A | 2006-03-06 A | 100% | 2005-05-02 | 2006-03-06 | 221d? | finish no earlier than 2006-03-06 | C1 | 1768h | 1768h | CSICS | Vodafone | peter.dawes@vodafone.com | Rel-7 | Frederic | 24.879, 24.279, 24.229, 24.008 |  |
| 1325 | 447.4 | Stage 3 for codec aspects |  | 192d? | 2005-03-15 A | 2005-12-07 A | 100% | 2005-03-15 | 2005-12-07 | 192d? | finish no earlier than 2005-12-07 | S4 | 1536h | 1536h | CSICS-Codec | Ericsson | Per.Frojdh@ericsson.com | Rel-7 | Paolo | 26.141, 26.235 |  |
| 1326 | 448 | **CAMEL Trunk Triggers** |  | 251d? | 2004-12-17 A | 2005-12-05 A | 100% | 2004-12-17 | 2005-12-05 | 251d? |  | S1,C4 | 6024h | 6024h | TTCAMEL | Nortel | Amar Deol (deola@nortelnetworks.com) | Rel-7 | Alain |  |  |
| 1327 | 448.1 | Stage 1 for CAMEL Trunk Triggers |  | 251d? | 2004-12-17 A | 2005-12-05 A | 100% | 2004-12-17 | 2005-12-05 | 251d? |  | S1 | 2008h | 2008h | TTCAMEL | Nortel | Amar Deol (deola@nortelnetworks.com) | Rel-7 | Alain | 22.078 |  |
| 1328 | 448.2 | CAMEL Trunk Originated Trigger Detection Points |  | 251d? | 2004-12-17 A | 2005-12-05 A | 100% | 2004-12-17 | 2005-12-05 | 251d? | start no earlier than 2004-12-17 | C4 | 2008h | 2008h | CamelR7 | Nortel | David Hutton (dhutton@nortel.com) | Rel-7 | Kimmo |  |  |
| 1329 | 449 | **IMS Service Brokering enhancements** |  | 69d? | 2005-12-07 A | 2006-03-13 A | 100% | 2005-12-07 | 2006-03-13 | 69d? |  | S1 | 1104h | 1104h | ISB | Telcordia | jbakker@telcordia.com | Rel-7 | Alain | 22.228 |  |
| 1330 | 449.1 | Stage 1 for ISB |  | 69d? | 2005-12-07 A | 2006-03-13 A | 100% | 2005-12-07 | 2006-03-13 | 69d? | finish no earlier than 2006-03-13 | S1 | 552h | 552h | ISB-s1 | Telcordia | jbakker@telcordia.com | Rel-7 | Alain | 22.228 |  |
| 1331 | 450 | **Enhancements of VGCS for public authority officials** |  | 731d? | 2004-08-27 A | 2007-06-15 A | 100% | 2004-08-27 | 2007-06-15 | 731d? |  | S1,C1,C4,G2 | 25920h | 25920h | EVGCS |  |  | Rel-7 | Alain | 43.068, 44.068, 24.008, 29.002 |  |
| 1332 | 450.1 | Stage 1 | milestone | 0d? | 2004-08-27 A | 2004-08-27 A | 100% | 2004-08-27 | 2004-08-27 | 0d? | finish no earlier than 2004-08-27 | S1 |  |  | EVGCS | Siemens | Joerg Swetina (joerg.swetina@nw.neclab.eu) | Rel-7 | Alain | 42.068, 43.068 |  |
| 1333 | 450.2 | **Architecture and protocol aspects** |  | 731d? | 2004-08-27 A | 2007-06-15 A | 100% | 2004-08-27 | 2007-06-15 | 731d? |  | C1,C4 | 14904h | 14904h | EVGCS | Siemens | robert.zaus@nsn.com | Rel-7 | Frederic | 43.068, 44.068 |  |
| 1334 | 450.2.1 | CT1 aspects of EVGCS |  | 731d? | 2004-08-27 A | 2007-06-15 A | 100% | 2004-08-27 | 2007-06-15 | 731d? | finish no earlier than 2006-09-15 | C1 | 5848h | 5848h | EVGCS | Siemens | robert.zaus@nsn.com | Rel-7 | Frederic | 43.068, 44.068, 24.008 |  |
| 1335 | 450.2.2 | CT4 aspects of EVGCS |  | 401d? | 2004-08-27 A | 2006-03-10 A | 100% | 2004-08-27 | 2006-03-10 | 401d? | finish no earlier than 2006-03-10 | C4 | 3208h | 3208h | EVGCS | Siemens | robert.zaus@nsn.com | Rel-7 | Kimmo | 29.002 |  |
| 1336 | 450.3 | GERAN2 aspects |  | 646d? | 2004-08-27 A | 2007-02-16 A | 100% | 2004-08-27 | 2007-02-16 | 646d? | finish no earlier than 2007-02-16 | G2 | 5168h | 5168h | EVGCS | Siemens | kenneth.isaacs@roke.co.uk | Rel-7 | Gert |  |  |
| 1337 | 451 | **Improvements of VGCS for parallel use of services** |  | 523d? | 2005-03-15 A | 2007-03-15 A | 100% | 2005-03-15 | 2007-03-15 | 523d? |  | S1 | 12230.2h | 12230.2h | IVGCS |  |  | Rel-7 | Alain |  |  |
| 1338 | 451.1 | Service Requirements for VGCS improvements |  | 62d? | 2005-03-15 A | 2005-06-08 A | 100% | 2005-03-15 | 2005-06-08 | 62d? | finish no earlier than 2005-06-08 | S1 | 496h | 496h | IVGCS | T-Mobile | kurt.bischinger@t-mobile.at | Rel-7 | Alain | 42.068 |  |
| 1339 | 451.2 | Stage 2 modifications for VGCS improvements |  | 335d? | 2005-12-01 A | 2007-03-14 A | 100% | 2005-12-01 | 2007-03-14 | 335d? | start no earlier than 2005-12-01 | C1 | 2680h | 2680h | IVGCS | T-Mobile | kurt.bischinger@t-mobile.at | Rel-7 | Frederic | 43.068 |  |
| 1340 | 451.3 | **Protocol aspects** |  | 336d? | 2005-12-01 A | 2007-03-15 A | 100% | 2005-12-01 | 2007-03-15 | 336d? |  | C1 | 5376h | 5376h | IVGCS | T-Mobile | Dieter Jacobsohn | Rel-7 | Frederic | 44.068 |  |
| 1341 | 451.3.1 | CT1 aspects of IVGCS |  | 336d? | 2005-12-01 A | 2007-03-15 A | 100% | 2005-12-01 | 2007-03-15 | 336d? | finish no earlier than 2007-03-15 | C1 | 2688h | 2688h | IVGCS | T-Mobile |  | Rel-7 | Frederic | 43.068, 44.068 |  |
| 1342 | 451.3.2 | Deleted - CT4 aspects of IVGCS | milestone | 0d? | 2007-03-09 A | 2007-03-09 A | 100% | 2007-03-09 | 2007-03-09 | 0d? | finish no earlier than 2007-03-09 | C4 |  |  | IVGCS-St3-c4 | T-mobile |  | Rel-7 | Kimmo | 29.002 | CP-35 |
| 1343 | 452 | **OSA Rel-7** |  | 584d? | 2005-03-15 A | 2007-06-08 A | 100% | 2005-03-15 | 2007-06-08 | 584d? |  | S1,C5 | 17920h | 17920h | OSA7 | AePONA | eamonn.murray@aepona.com | Rel-7 | Alain |  |  |
| 1344 | 452.1 | Service Requirements for OSA Service Broker |  | 62d? | 2005-03-15 A | 2005-06-08 A | 100% | 2005-03-15 | 2005-06-08 | 62d? | finish no earlier than 2005-06-08 | S1 | 496h | 496h | OSA7-SB | AePONA | eamonn.murray@aepona.com | Rel-7 | Alain | 22.127 |  |
| 1345 | 452.2 | Stage 2 OSA API Service Brokering |  | 156d? | 2006-04-28 A | 2006-12-01 A | 100% | 2006-04-28 | 2006-12-01 | 156d? |  | C5 | 1248h | 1248h | OSA7-SB | AePONA | damian.oneill@aepona.com | Rel-7 | Kimmo | 23.198 |  |
| 1346 | 452.3 | Stage 3 OSA API Service Brokering |  | 156d? | 2006-04-28 A | 2006-12-01 A | 100% | 2006-04-28 | 2006-12-01 | 156d? | finish no earlier than 2006-12-01 | C5 | 1248h | 1248h | OSA7-SB | AePONA | damian.oneill@aepona.com | Rel-7 | Kimmo | 29.198-16 |  |

Notes:
- 1321: -
- 1322: -
- 1323: -
- 1324: -
- 1325: -
- 1326: -
- 1327: -
- 1328: -
- 1329: No CR submitted in rel-8 (according to CR database).
- 1330: No Rel-8 changes
- 1331: Moved from Rel-6 UID_50563 Enhancements of VGCS in public networks for communication of public authority officials
- 1332: Voice Group Call Service
- 1333: -
- 1334: -
- 1335: -
- 1336: -
- 1337: Voice Group Call Service
- 1338: -
- 1339: -
- 1340: Previous name (before CT32) was Architecture and protocol aspects
- 1341: -
- 1342: CT4#33 stage 2 solution is still open. ...
- 1343: -
- 1344: az: WID URL corrected
- 1345: -
- 1346: -

| ID | WBS | Task | Type | Duration | Start | Finish | Complete | Baseline start | Baseline finish | Baseline duration | Constraint | Resources | Work | Actual work | Text1 | Text3 | Text4 | Text5 | Text6 | Text8 | Text12 | Text11 |
| --- | --- | --- | --- | --- | --- | --- | --- | --- | --- | --- | --- | --- | --- | --- | --- | --- | --- | --- | --- | --- | --- | --- |
| 1347 | 452.4 | **OSA Stage 2/3 enhancements** |  | 291d? | 2006-04-28 A | 2007-06-08 A | 100% | 2006-04-28 | 2007-06-08 | 291d? |  | C5 | 10256h | 10256h | OSA7 | 29.198/9, 23.198 | AePONA | damian.oneill@aepona.com | Rel-7 | Kimmo |  |  |
| 1348 | 452.4.1 | Parlay X Message Broadcast Web Service |  | 156d? | 2006-04-28 A | 2006-12-01 A | 100% | 2006-04-28 | 2006-12-01 | 156d? | finish no earlier than 2006-12-01 | C5 | 1248h | 1248h | OSA7 | 29.199-15, 23.198 | ETRI |  | Rel-7 | Kimmo |  |  |
| 1349 | 452.4.2 | Parlay X Geocoding Web Service |  | 156d? | 2006-04-28 A | 2006-12-01 A | 100% | 2006-04-28 | 2006-12-01 | 156d? | finish no earlier than 2006-12-01 | C5 | 1248h | 1248h | OSA7 | 29.199-16, 23.198 | ETRI |  | Rel-7 | Kimmo |  |  |
| 1350 | 452.4.3 | Parlay X Application driven QoS Web Service |  | 226d? | 2006-04-28 A | 2007-03-09 A | 100% | 2006-04-28 | 2007-03-09 | 226d? | finish no earlier than 2007-03-09 | C5 | 1808h | 1808h | OSA7 | 29.199-17, 23.198 | BT |  | Rel-7 | Kimmo |  |  |
| 1351 | 452.4.4 | Parlay-X Device Capabilities and Configuration |  | 162d? | 2006-10-26 A | 2007-06-08 A | 100% | 2006-10-26 | 2007-06-08 | 162d? | finish no earlier than 2007-06-09 | C5 | 1296h | 1296h | OSA7 | 29.199-18, 23.198 | Telenor |  | Rel-7 | Kimmo |  |  |
| 1352 | 452.4.5 | Parlay-X Multimedia Streaming Session Management Web Service |  | 97d? | 2006-10-26 A | 2007-03-09 A | 100% | 2006-10-26 | 2007-03-09 | 97d? | start no earlier than 2006-10-26 | C5 | 776h | 776h | OSA7 | 29.199-19, 23.198 | Telenor |  | Rel-7 | Kimmo |  |  |
| 1353 | 452.4.6 | Parlay-X Multimedia Multicast Control Web Service |  | 97d? | 2006-10-26 A | 2007-03-09 A | 100% | 2006-10-26 | 2007-03-09 | 97d? | start no earlier than 2006-10-26 | C5 | 776h | 776h | OSA7 | 29.199-20, 23.198 | ETRI |  | Rel-7 | Kimmo |  |  |
| 1354 | 452.4.7 | OSA API Conference Call Control SCF |  | 97d? | 2006-10-26 A | 2007-03-09 A | 100% | 2006-10-26 | 2007-03-09 | 97d? | start no earlier than 2006-10-26 | C5 | 776h | 776h | OSA7 | 29.198-04-5, 23.198 | Ericsson |  | Rel-7 | Kimmo |  |  |
| 1355 | 453 | **Selective Disabling of UE Capabilities** |  | 624.36d? | 2005-01-24 A | 2007-06-15 A | 100% | 2005-01-24 | 2007-06-15 | 624.36d? |  | S1,S2,C1 | 12351.7h | 12351.7h | SDoUE |  | Motorola |  | Rel-7 | Alain |  |  |
| 1356 | 453.1 | Stage 1 of SDoUE |  | 393.6d? | 2005-01-24 A | 2006-12-08 A | 100% | 2005-01-24 | 2006-12-08 | 393.6d? | finish no earlier than 2006-12-08 | S1 | 3148.8h | 3148.8h | SDoUE-CR | 22.011 | Motorola |  | Rel-7 | Alain |  |  |
| 1357 | 453.2 | Deleted - TR on different possible architectures |  | 195d? | 2005-03-21 A | 2005-12-16 A | 100% | 2005-03-21 | 2005-12-16 | 195d? | finish no earlier than 2005-12-16 | S2 | 1560h | 1560h | SDoUE-FS | 23.805 abandonned at SP-30; descendant C1 24.305 | Vodafone | Gavin.Wong@vodafone.com | Rel-7 | Maurice | SP-30 |  |
| 1358 | 453.3 | Stage 3 of SDoUE |  | 331d? | 2006-03-10 A | 2007-06-15 A | 100% | 2006-03-10 | 2007-06-15 | 331d? | finish no earlier than 2007-06-15 | C1 | 2648h | 2648h | SDoUE | 24.305 | Ericsson | christian.herrero@ericsson.com | Rel-7 | Frederic |  |  |
| 1359 | 454 | **Network selection enhancements (NSP)** |  | 328d? | 2006-03-15 A | 2007-06-15 A | 100% | 2006-03-15 | 2007-06-15 | 328d? |  | S1 | 6320h | 6320h | NSP-CR | 22.101, 22.011, 23.122, 24.008, 25.304, 31.102, 45.008 | O2 | chris.friel@O2.com | Rel-7 | Alain |  |  |
| 1360 | 454.1 | Stage 1 of NSP |  | 191d? | 2006-03-15 A | 2006-12-06 A | 100% | 2006-03-15 | 2006-12-06 | 191d? | start no earlier than 2006-03-15 | S1 | 1528h | 1528h | NSP-TS | 22.101, 22.011, 23.122, 24.008, 25.304, 31.102, 45.008 | O2 | chris.friel@O2.com | Rel-7 | Alain |  |  |
| 1361 | 454.2 | Procedural aspects of NSP |  | 271d? | 2006-06-02 A | 2007-06-15 A | 100% | 2006-06-02 | 2007-06-15 | 271d? | finish no earlier than 2007-06-15 | C1 | 2168h | 2168h | NSP-CR | 23.122, 24.008, 31.102 | Motorola | Andrew Howell | Rel-7 | Frederic |  |  |
| 1362 | 455 | Network selection enhancements (NSP) - UE Conformance Testing |  | 396d? | 2007-06-01 A | 2008-12-05 A | 100% | 2007-06-01 | 2008-12-05 | 396d? | finish no earlier than 2008-12-05 | R5 | 3168h | 3168h | NSP-CR_UEConTest | 34.108, 34.123-1, 34.123-2, 34.123-3 | Nokia | jarkko.hellsten@nokia.com | Rel-7 | Ingbert |  | RP-080819 |
| 1363 | 456 | **Access Class Barring and Overload Protection** |  | 650d? | 2004-03-15 A | 2006-09-08 A | 100% | 2004-03-15 | 2006-09-08 | 650d? |  | S2,C1 | 3568h | 3568h | ACBOP | 23.898 | Vodafone | Chris Pudney | Rel-7 | Maurice |  |  |
| 1364 | 456.1 | TR on Stage 2 |  | 274d? | 2004-03-15 A | 2005-03-31 A | 100% | 2004-03-15 | 2005-03-31 | 274d? | finish no earlier than 2005-03-31 | S2 | 2192h | 2192h | ACBOP | 23.898 | NTT DoCoMo | Jean-Jacques Davidian (davidian@docomo.fr) | Rel-7 | Maurice |  |  |
| 1365 | 456.2 | Stage 3 CN aspects of ACBOP |  | 172d? | 2005-06-06 A | 2006-01-31 A | 100% | 2005-06-06 | 2006-01-31 | 172d? | start no earlier than 2005-06-06 | C1 | 1376h | 1376h | ACBOP | 24.008 |  |  | Rel-7 | Frederic |  |  |
| 1366 | 456.3 | Deleted - Potential impact on Iu interface Overload functionality | milestone | 0d? | 2004-03-15 A | 2004-03-15 A | 100% | 2004-03-15 | 2004-03-15 | 0d? | finish no earlier than 2004-03-15 | RP |  |  | ACBOP | 25.413 |  |  | Rel-7 | Issam | RP-25 |  |
| 1367 | 456.4 | Deleted - Extra ACBOP information in RAN | milestone | 0d? | 2004-03-15 A | 2004-03-15 A | 100% | 2004-03-15 | 2004-03-15 | 0d? | finish no earlier than 2004-03-15 | RP |  |  | ACBOP | 25.331 |  |  | Rel-7 | Issam | RP-25 |  |
| 1368 | 456.5 | Deleted - Extra ACBOP information in GERAN | milestone | 0d? | 2006-09-08 A | 2006-09-08 A | 100% | 2006-09-08 | 2006-09-08 | 0d? | start no earlier than 2006-09-08 | GP |  |  | ACBOP | 44.018 |  |  | Rel-7 | Paolo | RP-33 |  |
| 1369 | 457 | **System enhancements for fixed broadband access to IMS** |  | 876d? | 2003-11-05 A | 2007-03-14 A | 100% | 2003-11-05 | 2007-03-14 | 876d? |  | S2,S3,S5,C1,C3,C4 | 36656h | 36656h | FBI |  |  |  | Rel-7 | Maurice |  |  |
| 1370 | 457.1 | **TISPAN Rel 1 related aspects** |  | 873d? | 2003-11-05 A | 2007-03-09 A | 100% | 2003-11-05 | 2007-03-09 | 873d? |  | S2 | 31568h | 31568h | FBI-TIS1 |  |  |  | Rel-7 | Maurice |  |  |
| 1371 | 457.1.1 | Stage 2 of FBI for TISPAN R1 |  | 365d? | 2004-10-14 A | 2006-03-08 A | 100% | 2004-10-14 | 2006-03-08 | 365d? | start no earlier than 2004-10-14 | S2 | 2920h | 2920h | FBI-TIS1 |  |  |  | Rel-7 | Maurice |  |  |

Notes:
- 1347: CP#34: WID updated. Completion 12/06 =>03/07
- 1348: -
- 1349: -
- 1350: -
- 1351: -
- 1352: -
- 1353: -
- 1354: -
- 1355: Moved from FS section Feb 06
- 1356: Moved from FS section Feb 06
- 1357: Moved from FS section Feb 06. Abandoned at SP-30
- 1358: -
- 1359: -
- 1360: -
- 1361: -
- 1362: RP#42 completed. Testing for Feature UID_7041 (NSP-CR)
- 1363: -
- 1364: -
- 1365: -
- 1366: -
- 1367: -
- 1368: -
- 1369: -
- 1370: -
- 1371: -

| ID | WBS | Task | Duration | Start | Finish | Complete | Baseline start | Baseline finish | Baseline duration | Constraint | Resources | Work | Actual work | Text1 | Text4 | Text5 | Text6 | Text8 | Text3 | Text12 |
| --- | --- | --- | --- | --- | --- | --- | --- | --- | --- | --- | --- | --- | --- | --- | --- | --- | --- | --- | --- | --- |
| 1372 | 457.1.2 | **Protocol impact of FBI for TISPAN R1** | 873d? | 2003-11-05 A | 2007-03-09 A | 100% | 2003-11-05 | 2007-03-09 | 873d? |  | C1 | 20720h | 20720h | FBI-TIS1 | Siemens | peter.leis@nsn.com | Rel-7 | Frederic |  |  |
| 1373 | 457.1.2.1 | CT1 aspects of FBI for TISPAN R1 | 802d? | 2003-11-05 A | 2006-11-30 A | 100% | 2003-11-05 | 2006-11-30 | 802d? | finish no earlier than 2006-11-30 | C1 | 6416h | 6416h | FBI-TIS1 | Siemens | peter.leis@nsn.com | Rel-7 | Frederic | 24.819, 24.229 |  |
| 1374 | 457.1.2.2 | CT3 aspects of FBI for TISPAN R1 | 808d? | 2003-11-05 A | 2006-12-08 A | 100% | 2003-11-05 | 2006-12-08 | 808d? | finish no earlier than 2006-12-08 | C3 | 6464h | 6464h | FBI-TIS1 | Siemens | peter.leis@nsn.com | Rel-7 | Jiwan | 29.163, 29.209 |  |
| 1375 | 457.1.2.3 | CT4 aspects of FBI for TISPAN R1 | 301d? | 2006-01-13 A | 2007-03-09 A | 100% | 2006-01-13 | 2007-03-09 | 301d? | finish no earlier than 2007-03-09 | C4 | 2408h | 2408h | FBI-TIS1-st3-c4 | Siemens | peter.leis@nsn.com | Rel-7 | Kimmo | 29.229 |  |
| 1376 | 457.1.3 | Security Enhancements for FBI | 118d? | 2005-06-28 A | 2005-12-08 A | 100% | 2005-06-28 | 2005-12-08 | 118d? | start no earlier than 2005-06-28 | S3 | 944h | 944h | FBI-ISE | Ericsson | Bengt.Sahlin@ericsson.com | Rel-7 | Dionisio | 33.203 |  |
| 1377 | 457.2 | **PacketCable Related aspects** | 291d? | 2006-02-01 A | 2007-03-14 A | 100% | 2006-02-01 | 2007-03-14 | 291d? |  | S2,S5,C1 | 5088h | 5088h | FBI-PCBL | CableLabs | Bernie McKibben (b.mckibben@cablelabs.com) | Rel-7 | Maurice |  |  |
| 1378 | 457.2.1 | Stage 1,2 of FBI for PacketCable | 228d? | 2006-02-01 A | 2006-12-15 A | 100% | 2006-02-01 | 2006-12-15 | 228d? | finish no earlier than 2006-12-15 | S2 | 1824h | 1824h | FBI-PCBL | CableLabs | Bernie McKibben (b.mckibben@cablelabs.com) | Rel-7 | Maurice | 22.228, 23.228 |  |
| 1379 | 457.2.2 | Protocol impact of FBI for PacketCable | 228d? | 2006-05-01 A | 2007-03-14 A | 100% | 2006-05-01 | 2007-03-14 | 228d? | finish no earlier than 2007-03-15 | C1 | 1824h | 1824h | FBI-PCBL |  |  | Rel-7 | Frederic |  |  |
| 1380 | 457.2.3 | SA5 Charging aspects of FBI for PacketCable | 180d? | 2006-03-31 A | 2006-12-07 A | 100% | 2006-03-31 | 2006-12-07 | 180d? | finish no earlier than 2006-12-07 | S5 | 1440h | 1440h | FBI-PCBL-CH | CableLabs | Bernie McKibben (b.mckibben@cablelabs.com) | Rel-7 | Dionisio | 32.240, 32.260, 32.298, 32.299 |  |
| 1381 | 458 | **Support of SMS over generic 3GPP IP access** | 696d? | 2004-10-14 A | 2007-06-14 A | 100% | 2004-10-14 | 2007-06-14 | 696d? |  | S2,C4,C1 | 12408h | 12408h | SMSIP | Huawei | zhangwenlin@huawei.com | Rel-7 | Maurice |  |  |
| 1382 | 458.1 | FS on SMSIP | 173d? | 2004-10-14 A | 2005-06-13 A | 100% | 2004-10-14 | 2005-06-13 | 173d? | start no earlier than 2004-10-14 | S2 | 1384h | 1384h | SMSIP | Huawei | zhangwenlin@huawei.com | Rel-7 | Maurice | 23.804 |  |
| 1383 | 458.2 | Stage 2 for SMSIP | 333d? | 2005-06-08 A | 2006-09-15 A | 100% | 2005-06-08 | 2006-09-15 | 333d? | finish no earlier than 2006-09-15 | S2 | 2664h | 2664h | SMSIP | Huawei | zhangwenlin@huawei.com | Rel-7 | Maurice | 23.204 |  |
| 1384 | 458.3 | **Stage 3 for SMSIP** | 527d? | 2005-06-08 A | 2007-06-14 A | 100% | 2005-06-08 | 2007-06-14 | 527d? |  | C4,C1 | 8360h | 8360h | SMSIP-St3 | Nokia | jari.jansson@nokia.com | Rel-7 | Kimmo |  |  |
| 1385 | 458.3.1 | CT1 aspects for SMSIP | 527d? | 2005-06-08 A | 2007-06-14 A | 100% | 2005-06-08 | 2007-06-14 | 527d? | finish no earlier than 2007-06-15 | C1 | 4216h | 4216h | SMSIP | Nokia | jari.jansson@nokia.com | Rel-7 | Frederic | 23.040, 24.229 |  |
| 1386 | 458.3.2 | CT4 aspects for SMSIP | 518d? | 2005-06-08 A | 2007-06-01 A | 100% | 2005-06-08 | 2007-06-01 | 518d? | finish no earlier than 2007-06-01 | C4 | 4144h | 4144h | SMSIP-St3-c4 | Nokia | jari.jansson@nokia.com | Rel-7 | Kimmo | 23.008, 29.002 |  |
| 1387 | 459 | **Evolution of Policy Control and Charging** | 817d? | 2004-10-14 A | 2007-11-30 A | 100% | 2004-10-14 | 2007-11-30 | 817d? |  | S2,S5,C3,C1 | 30336h | 30336h | PCC | Nokia | balazs.bertenyi@nsn.com | Rel-7 | Maurice |  |  |
| 1388 | 459.1 | Deleted - TR for PCC | 315d? | 2004-10-14 A | 2005-12-29 A | 100% | 2004-10-14 | 2005-12-29 | 315d? | finish no earlier than 2005-12-28 | S2 | 2520h | 2520h | PCC | Nokia | balazs.bertenyi@nsn.com | Rel-7 | Maurice | 23.803 | SP-33 |
| 1389 | 459.2 | Stage 2 for PCC | 315d? | 2005-07-04 A | 2006-09-15 A | 100% | 2005-07-04 | 2006-09-15 | 315d? | finish no earlier than 2006-09-15 | S2 | 2520h | 2520h | PCC | Nokia | balazs.bertenyi@nsn.com | Rel-7 | Maurice | 23.203 |  |
| 1390 | 459.3 | Evolution of policy control and flow based bearer level charging | 109d? | 2006-08-01 A | 2006-12-29 A | 100% | 2006-08-01 | 2006-12-29 | 109d? | start no earlier than 2006-08-01 | S2 | 872h | 872h | PCC | Nokia | balazs.bertenyi@nsn.com | Rel-7 | Maurice | 23.207, 23.002, 23.228 |  |
| 1391 | 459.4 | SA5 Charging aspects of PCC | 316d? | 2006-03-31 A | 2007-06-15 A | 100% | 2006-03-31 | 2007-06-15 | 316d? | finish no earlier than 2007-06-15 | S5 | 2528h | 2528h | PCC-CH | Orange | alain.bibas@orange-ft.com | Rel-7 | Dionisio | 32.250, 32.251, 32.298, 32.299 |  |
| 1392 | 459.5 | Gx reference point for Policy and Charging Control | 521d? | 2005-12-02 A | 2007-11-30 A | 100% | 2005-12-02 | 2007-11-30 | 521d? | finish no earlier than 2007-09-14 | C3 | 4168h | 4168h | PCC-Gx | Siemens | Thomas.Belling@nsn.com | Rel-7 | Jiwan | 29.212 (not progressed to Rel-7: 29.210, 29.207, 29.208) |  |
| 1393 | 459.6 | **Rx reference point for PCC CT3 aspects** | 521d? | 2005-12-02 A | 2007-11-30 A | 100% | 2005-12-02 | 2007-11-30 | 521d? |  | C3,C1 | 11192h | 11192h | PCC-Rx | Ericsson | j.javier.pastor@ericsson.com | Rel-7 | Jiwan |  |  |
| 1394 | 459.6.1 | PCC-Rx CT3 aspects | 521d? | 2005-12-02 A | 2007-11-30 A | 100% | 2005-12-02 | 2007-11-30 | 521d? | finish no earlier than 2007-09-14 | C3 | 4168h | 4168h | PCC-Rx-c3 | Ericsson | j.javier.pastor@ericsson.com | Rel-7 | Jiwan | 29.213, 29.214 (not progressed to Rel-7: 29.209, 29.211) |  |
| 1395 | 459.6.2 | PCC-Rx CT1 aspects | 357d? | 2005-12-02 A | 2007-06-15 A | 100% | 2005-12-02 | 2007-06-15 | 357d? | finish no earlier than 2007-06-15 | C1 | 2856h | 2856h | PCC-Rx-Gx-c1 | Ericsson | j.javier.pastor@ericsson.com | Rel-7 | Frederic | 24.229 |  |

Notes:
- 1372: -
- 1373: end date updated by CT1-chairman after CP#33
- 1374: -
- 1375: CT4#32: a set of CRs on FBI for cable labs
- 1376: Duplicated entry ("ACCSEC2", "Access Security Enhancements", SP-040865) deleted by A.Sultan
- 1377: -
- 1378: -
- 1379: -
- 1380: 03/2006 SP#31 WID approved
- 1381: SP#33 updated WID (removed MMS)
- 1382: SP#33 updated WID
- 1383: SP#33 updated WID
- 1384: CP#34 updated WID
- 1385: CP#34 updated WID
- 1386: CP#34 updated WID
- 1387: SP-29 approved WID. SP-31 updated WID adding SA5 charging. 23.125 will be discontinued from Rel-7.
- 1388: SP-30: S2 has no intention for TR completion
- 1389: SP-29 approved WID. SP-31 updated WID. 23.125 will be discontinued from Rel-7.
- 1390: SP-29 approved WID. SP-31 updated WID. 23.125 will be discontinued from Rel-7.
- 1391: SP-31 updated WID with SA5 charging.
- 1392: -
- 1393: WID approved at CP#30, Revised at CP#31, Revised at CP#33
- 1394: -
- 1395: -

| ID | WBS | Task | Type | Duration | Start | Finish | Complete | Baseline start | Baseline finish | Baseline duration | Constraint | Resources | Work | Actual work | Text1 | Text4 | Text5 | Text6 | Text8 | Text3 | Text12 |
| --- | --- | --- | --- | --- | --- | --- | --- | --- | --- | --- | --- | --- | --- | --- | --- | --- | --- | --- | --- | --- | --- |
| 1396 | 460 | **Voice call continuity between CS and IMS (incl. I-WLAN)** |  | 641d? | 2004-12-31 A | 2007-06-15 A | 100% | 2004-12-31 | 2007-06-15 | 641d? |  | S2,S1,S5,C1,C4 | 12224h | 12224h | VCC | Alcatel-Lucent | Keith Drage (drage@alcatel-lucent.com) | Rel-7 | Maurice |  |  |
| 1397 | 460.1 | TR for VCC |  | 245d? | 2004-12-31 A | 2005-12-08 A | 100% | 2004-12-31 | 2005-12-08 | 245d? | finish no earlier than 2005-12-08 | S2 | 1960h | 1960h | VCC | Alcatel-Lucent | andy.bennett@alcatel-lucent.com | Rel-7 | Maurice | 23.806 |  |
| 1398 | 460.2 | Stage 1 for VCC |  | 140d? | 2005-03-17 A | 2005-09-28 A | 100% | 2005-03-17 | 2005-09-28 | 140d? | finish no earlier than 2005-09-28 | S1 | 1120h | 1120h | VCC | Alcatel-Lucent | andy.bennett@alcatel-lucent.com | Rel-7 | Alain | 22.101 |  |
| 1399 | 460.3 | Stage 2 for VCC |  | 264d? | 2005-09-06 A | 2006-09-08 A | 100% | 2005-09-06 | 2006-09-08 | 264d? | finish no earlier than 2006-09-08 | S2 | 2112h | 2112h | VCC | Alcatel-Lucent | andy.bennett@alcatel-lucent.com | Rel-7 | Maurice | 23.206 |  |
| 1400 | 460.4 | SA5 Charging aspects of VCC |  | 325d? | 2006-03-17 A | 2007-06-14 A | 100% | 2006-03-17 | 2007-06-14 | 325d? | finish no earlier than 2007-06-14 | S5 | 2600h | 2600h | VCC-CH | Orange | alain.bibas@orange-ft.com | Rel-7 | Dionisio | 32.250, 32.260 |  |
| 1401 | 460.5 | **Stage 3 for VCC** |  | 358d? | 2006-02-01 A | 2007-06-15 A | 100% | 2006-02-01 | 2007-06-15 | 358d? |  | C1,C4 | 4432h | 4432h | VCC | Alcatel-Lucent | Keith Drage (drage@alcatel-lucent.com) | Rel-7 | Frederic |  |  |
| 1402 | 460.5.1 | CT1 aspects of VCC |  | 358d? | 2006-02-01 A | 2007-06-15 A | 100% | 2006-02-01 | 2007-06-15 | 358d? | finish no earlier than 2007-06-15 | C1 | 2864h | 2864h | VCC | Alcatel-Lucent | Keith Drage (drage@alcatel-lucent.com) | Rel-7 | Frederic | 24.206, 24.216 |  |
| 1403 | 460.5.2 | CT4 aspects of VCC |  | 196d? | 2006-06-09 A | 2007-03-09 A | 100% | 2006-06-09 | 2007-03-09 | 196d? | start no earlier than 2006-06-09 | C4 | 1568h | 1568h | VCC-St3-c4 | Alcatel-Lucent | Keith Drage (drage@alcatel-lucent.com) | Rel-7 | Kimmo | 23.003 |  |
| 1404 | 460.5.3 | Deleted - CT3 aspects of VCC | milestone | 0d? | 2006-11-02 A | 2006-11-02 A | 100% | 2006-11-02 | 2006-11-02 | 0d? | finish no earlier than 2006-11-02 | C3 |  |  | VCC | Alcatel-Lucent | Keith Drage (drage@alcatel-lucent.com) | Rel-7 | Jiwan | 29.163 | CP-33 |
| 1405 | 461 | **One Tunnel solution for optimization of Packet Data Traffic** |  | 418d? | 2006-03-27 A | 2007-10-31 A | 100% | 2006-03-27 | 2007-10-31 | 418d? |  | S2 | 7048h | 7048h | OPTUNEL | Nokia | antti.j.pasanen@nokia.com | Rel-7 | Maurice |  |  |
| 1406 | 461.1 | Deleted - Study on Stage 2 for One Tunnel solution |  | 125d? | 2006-03-27 A | 2006-09-15 A | 100% | 2006-03-27 | 2006-09-15 | 125d? | finish no earlier than 2005-09-12 | S2 | 1000h | 1000h | OPTUNEL-Study | Nokia | antti.j.pasanen@nokia.com | Rel-7 | Maurice | 23.809 | SP-34 |
| 1407 | 461.2 | One Tunnel Deployment Guideline |  | 268d? | 2006-10-23 A | 2007-10-31 A | 100% | 2006-10-23 | 2007-10-31 | 268d? | finish no earlier than 2007-10-31 | S2 | 2144h | 2144h | OPTUNEL-Guide | Huawei | lan.liu@huawei.com | Rel-7 | Maurice | 23.919 |  |
| 1408 | 461.3 | Stage 2 specification for One Tunnel solution |  | 70d? | 2006-09-11 A | 2006-12-15 A | 100% | 2006-09-11 | 2006-12-15 | 70d? | finish no earlier than 2006-12-15 | S2 | 560h | 560h | OPTUNEL-Stage2 | Nokia | antti.j.pasanen@nokia.com | Rel-7 | Maurice | 23.060 |  |
| 1409 | 462 | **CSI Terminating Session handling** |  | 267d? | 2006-06-08 A | 2007-06-15 A | 100% | 2006-06-08 | 2007-06-15 | 267d? |  | S2,C1 | 4728h | 4728h | CSItermS | Samsung | Osok Song | Rel-7 | Maurice |  |  |
| 1410 | 462.1 | Stage 2 of CStermS |  | 192d? | 2006-06-08 A | 2007-03-02 A | 100% | 2006-06-08 | 2007-03-02 | 192d? | start no earlier than 2006-06-08 | S2 | 1536h | 1536h | CSItermS | Samsung | Osok Song | Rel-7 | Maurice | 23.279 |  |
| 1411 | 462.2 | Stage 3 of CStermS |  | 132d? | 2006-12-14 A | 2007-06-15 A | 100% | 2006-12-14 | 2007-06-15 | 132d? | finish no earlier than 2007-06-15 | C1 | 1056h | 1056h | CSItermS | Samsung | chenho.chin@samsung.com | Rel-7 | Frederic | 24.229, 24.279 |  |
| 1412 | 462.3 | Deleted - duplicated with UID 340015 -Stage 3 CSI Terminating Session handling | milestone | 0d? | 2007-03-09 A | 2007-03-09 A | 100% | 2007-03-09 | 2007-03-09 | 0d? | start no earlier than 2007-03-09 | C1 |  |  | CSItermS | Samsung | chenho.chin@samsung.com | Rel-7 | Frederic | 24.229, 24.179, 24.279 | CP-34 |
| 1413 | 463 | Liberty Alliance and 3GPP Security Interworking |  | 451d? | 2005-03-10 A | 2006-11-30 A | 100% | 2005-03-10 | 2006-11-30 | 451d? | finish no earlier than 2006-11-30 | S3 | 3608h | 3608h | LibSec | Nokia | Silke.Holtmanns@nokia.com | Rel-7 | Dionisio | 33.980 |  |
| 1414 | 464 | Trust Requirements for Open Platforms in 3GPP |  | 499d? | 2005-01-03 A | 2006-11-30 A | 100% | 2005-01-03 | 2006-11-30 | 499d? | finish no earlier than 2006-11-30 | S3 | 3992h | 3992h | TrustOP | Nokia | Silke.Holtmanns@nokia.com | Rel-7 | Dionisio | 33.905 |  |
| 1415 | 465 | Development of UEA2 and UIA2 |  | 268d? | 2004-12-01 A | 2005-12-09 A | 100% | 2004-12-01 | 2005-12-09 | 268d? | finish no earlier than 2005-12-09 | S3 | 2144h | 2144h | AlgUEA2 | TeliaSonera | per.christoffersson@teliasonera.com | Rel-7 | Dionisio | 35.919, 35.215, 35.216, 35.217, 35.218 |  |
| 1416 | 466 | Lawful Interception in the 3GPP Rel-7 architecture |  | 118d? | 2005-06-28 A | 2005-12-08 A | 100% | 2005-06-28 | 2005-12-08 | 118d? | start no earlier than 2005-06-28 | S3 | 944h | 944h | LI-7A | BMWI | berthold.wilhelm@regtp.de | Rel-7 | Dionisio | 33.106, 33.107, 33.108 |  |
| 1417 | 467 | Key establishment between a UICC and a terminal |  | 201.45d? | 2005-12-07 A | 2006-09-28 A | 100% | 2005-12-07 | 2006-09-28 | 201.45d? | finish no earlier than 2006-09-28 | S3 | 1611.6h | 1611.6h | KeyEstUTerm | Gemalto | mireille.pauliac@gemplus.com | Rel-7 | Dionisio | 33.110 |  |
| 1418 | 468 | NDS Authentication Framework Extension for Transport Layer Security |  | 50d? | 2006-09-28 A | 2006-12-06 A | 100% | 2006-09-28 | 2006-12-06 | 50d? | finish no earlier than 2006-09-28 | S3 | 400h | 400h | NDSAFTLS | Nokia | tiina.s.koskinen@nokia.com | Rel-7 | Dionisio | 33.310 |  |
| 1419 | 469 | **Security enhancements** |  | 319d? | 2005-09-12 A | 2006-11-30 A | 100% | 2005-09-12 | 2006-11-30 | 319d? |  | S3,C1,C4 | 4856h | 4856h | SEC7 |  |  | Rel-7 | Dionisio |  |  |
| 1420 | 469.1 | HTTPS connection between a UICC and a NAF |  | 1d? | 2005-09-12 A | 2005-09-12 A | 100% | 2005-09-12 | 2005-09-12 | 1d? | start no earlier than 2005-09-12 | S3,C1 | 8h | 8h | SEC7-HSUN | Gemalto | JSeif@axalto.com, mireille.pauliac@gemplus.com | Rel-7 | Dionisio | 33.918, 33.222, 24.109 |  |
| 1421 | 469.2 | 2G GBA: 2G SIM usage in 3GPP GAA framework |  | 61d? | 2005-09-12 A | 2005-12-05 A | 100% | 2005-09-12 | 2005-12-05 | 61d? | finish no earlier than 2005-12-05 | S3 | 488h | 488h | SEC7-2GGBA | Nokia | Silke.Holtmanns@nokia.com | Rel-7 | Dionisio | 33.920, 33.220 |  |
| 1422 | 469.3 | Generic Authentication Architecture usage extensions and optimizations |  | 319d? | 2005-09-12 A | 2006-11-30 A | 100% | 2005-09-12 | 2006-11-30 | 319d? | finish no earlier than 2006-11-30 | S3 | 2552h | 2552h | SEC7-GAA2 | Nokia | Silke.Holtmanns@nokia.com | Rel-7 | Dionisio | 33.220, 29.109, 24.109, (33.223 goes to R8) |  |

Notes:
- 1396: WID approved SP#27; updated SP#28; updated SP#32
- 1397: -
- 1398: -
- 1399: -
- 1400: 03/2006 SP#31 WID approved
- 1401: -
- 1402: -
- 1403: -
- 1404: -
- 1405: -
- 1406: S2#52 CREATED. TR for Info SP-33. SP-34: S2 Report intention to discontinue TR
- 1407: -
- 1408: S2#52 CREATED
- 1409: Triggered by the abandoned Study UID_32117
- 1410: -
- 1411: CP-34 approved WID. CP-35 updated WID
- 1412: CP-34 approved WID
- 1413: WID approved SP#27.
- 1414: WID approved SP#26.
- 1415: WID approved SP#26, Dependant on Funding Availability.
- 1416: -
- 1417: -
- 1418: TLS profile is moved to Rel-8
- 1419: -
- 1420: -
- 1421: -
- 1422: 33.223 goes to R8

| ID | WBS | Task | Duration | Start | Finish | Complete | Baseline start | Baseline finish | Baseline duration | Constraint | Resources | Work | Actual work | Text1 | Text4 | Text5 | Text6 | Text8 | Text3 | Text12 | Text2 | Text7 |
| --- | --- | --- | --- | --- | --- | --- | --- | --- | --- | --- | --- | --- | --- | --- | --- | --- | --- | --- | --- | --- | --- | --- |
| 1423 | 469.4 | **SS7 TCAP security Gateway** | 241d? | 2005-09-12 A | 2006-08-14 A | 100% | 2005-09-12 | 2006-08-14 | 241d? |  | S3,C4 | 1808h | 1808h | SEC7-NDS-TCAPsec | Siemens | marc.blommaert.ext@nsn.com | Rel-7 | Dionisio |  |  |  |  |
| 1424 | 469.4.1 | SA3 aspects of SEC7-NDS-TCAPsec | 130d? | 2005-09-12 A | 2006-03-10 A | 100% | 2005-09-12 | 2006-03-10 | 130d? | finish no earlier than 2006-03-10 | S3 | 1040h | 1040h | SEC7-NDS-TCAPsec-SA3 | Siemens | marc.blommaert.ext@nsn.com | Rel-7 | Dionisio | 33.204 |  |  |  |
| 1425 | 469.4.2 | TCAPsec Gateway | 96d? | 2006-04-03 A | 2006-08-14 A | 100% | 2006-04-03 | 2006-08-14 | 96d? | start no earlier than 2006-04-01 | C4 | 768h | 768h | SEC7-TCAP | Siemens | Ulrich.wiehe@gksag.de | Rel-7 | Kimmo | 29.204, 29.002 |  |  |  |
| 1426 | 470 | IMS Stage 3 IETF Protocol alignment | 589d? | 2004-12-10 A | 2007-03-14 A | 100% | 2004-12-10 | 2007-03-14 | 589d? | finish no earlier than 2007-03-15 | C1 | 4712h | 4712h | IMSProtoc |  |  | Rel-7 | Frederic | 24.930 |  |  |  |
| 1427 | 471 | **Interoperability between VGCS/VBS and A/Gb flexibility** | 253d? | 2006-03-22 A | 2007-03-09 A | 100% | 2006-03-22 | 2007-03-09 | 253d? |  | C1,C4 | 3296h | 3296h | VGCSFlex | Siemens | robert.zaus@nsn.com | Rel-7 | Frederic |  |  |  |  |
| 1428 | 471.1 | CT1 aspects of VGCSFlex | 159d? | 2006-03-22 A | 2006-10-30 A | 100% | 2006-03-22 | 2006-10-30 | 159d? | finish no earlier than 2006-10-30 | C1 | 1272h | 1272h | VGCSFlex | Siemens | robert.zaus@nsn.com | Rel-7 | Frederic | 43.068, 43.069 |  |  |  |
| 1429 | 471.2 | CT4 aspects of VGCSFlex | 253d? | 2006-03-22 A | 2007-03-09 A | 100% | 2006-03-22 | 2007-03-09 | 253d? | finish no earlier than 2007-03-09 | C4 | 2024h | 2024h | VGCSFlex-c4 | Siemens | robert.zaus@nsn.com | Rel-7 | Kimmo | 29.002 |  |  |  |
| 1430 | 472 | DIAMETER on the GGSN Gi interface | 586d? | 2004-09-10 A | 2006-12-08 A | 100% | 2004-09-10 | 2006-12-08 | 586d? | finish no earlier than 2006-12-08 | C3 | 4688h | 4688h | DIAMGi | Vodafone | Nico.Gabriele@vodafone.com | Rel-7 | Jiwan | 29.061 |  |  |  |
| 1431 | 473 | DIAMETER on the PDG Wi interface | 586d? | 2004-09-10 A | 2006-12-08 A | 100% | 2004-09-10 | 2006-12-08 | 586d? | finish no earlier than 2006-12-08 | C3 | 4688h | 4688h | DIAMWi | Vodafone | Nico.Gabriele@vodafone.com | Rel-7 | Jiwan | 29.161 |  |  |  |
| 1432 | 474 | Interworking between the 3GPP CS domain with BICC or ISUP as signalling protocol and external SIP-I networks | 478d? | 2006-09-22 A | 2008-07-22 A | 100% | 2006-09-22 | 2008-07-22 | 478d? | finish no earlier than 2007-09-14 | C3 | 3824h | 3824h | ExtSIPI | Siemens | Thomas.Belling@nsn.com | Rel-7 | Jiwan | 29.164 |  |  |  |
| 1433 | 475 | PDU multiplexing at Nb Interface with IP transport | 427d? | 2006-12-04 A | 2008-07-22 A | 100% | 2006-12-04 | 2008-07-22 | 427d? | start no earlier than 2006-12-04 | C3 | 3416h | 3416h | NbIPMux | Alcatel-Lucent | Jean.Rzeznik@alcatel-lucent.fr | Rel-7 | Jiwan | 29.414 |  |  |  |
| 1434 | 476 | **Mp (MRFC - MRFP) interface** | 345d? | 2006-02-13 A | 2007-06-08 A | 100% | 2006-02-13 | 2007-06-08 | 345d? |  | C4,C1 | 4384h | 4384h | Mp | Ericsson | philip.hodges@ericsson.com | Rel-7 | Kimmo |  |  |  |  |
| 1435 | 476.1 | CT1 aspects of Mp | 1d | 2006-02-13 A | 2006-02-13 A | 100% | 2006-02-13 | 2006-02-13 | 1d | finish no earlier than 2006-02-13 | C1 | 8h | 8h | Mp | Ericsson | philip.hodges@ericsson.com | Rel-7 | Frederic | 24.229 |  |  |  |
| 1436 | 476.2 | Deleted - CT3 aspects of Mp | 1d | 2006-09-22 A | 2006-09-22 A | 100% | 2006-09-22 | 2006-09-22 | 1d | start no earlier than 2006-09-22 | C3 | 8h | 8h | Mp | Ericsson | philip.hodges@ericsson.com | Rel-7 | Jiwan | 29.162 | CP-33 |  |  |
| 1437 | 476.3 | Procedures description | 201d? | 2006-06-02 A | 2007-03-09 A | 100% | 2006-06-02 | 2007-03-09 | 201d? | finish no earlier than 2007-03-09 | C4 | 1608h | 1608h | Mp-PROCc4 | Huawei | Chencheng@huawei.com | Rel-7 | Kimmo | 23.333 |  |  |  |
| 1438 | 476.4 | Stage 3 | 345d | 2006-02-13 A | 2007-06-08 A | 100% | 2006-02-13 | 2007-06-08 | 345d | finish no earlier than 2007-06-08 | C4 | 2760h | 2760h | Mp-St3c4 | Ericsson | philip.hodges@ericsson.com | Rel-7 | Kimmo | 29.333 |  |  |  |
| 1439 | 477 | Routeing of MT-SMS via the HPLMN | 71d? | 2006-12-01 A | 2007-03-09 A | 100% | 2006-12-01 | 2007-03-09 | 71d? | finish no earlier than 2007-03-09 | C4,C1 | 568h | 568h | SMSviaH | Vodafone | Nick.Russell@vodafone.com | Rel-7 | Kimmo | 23.040, 29.002 |  |  |  |
| 1440 | 478 | Mobile Termination whilst the MS is moving to another MSC | 60d? | 2007-03-09 A | 2007-05-31 A | 100% | 2007-03-09 | 2007-05-31 | 60d? | start no earlier than 2007-03-09 | C4 | 480h | 480h | MTmovMS | Alcatel-Lucent | bruno.landais@alcatel-lucent.fr | Rel-7 | Kimmo | 23.008, 23.012, 23.018, 23.078, 23.079, 29.002 |  |  |  |
| 1441 | 479 | ISIM API for Java Card | 620d? | 2005-03-14 A | 2007-07-27 A | 100% | 2005-03-14 | 2007-07-27 | 620d? | finish no earlier than 2007-07-27 | C6 | 4960h | 4960h | APIJAVA | Sun | Sebastian Hans | Rel-7 | Xavier | 31.103, 102 241 |  |  |  |
| 1442 | 480 | Rel-7 (U)SIM API Testing (TS 31.213) | 211d? | 2009-05-30 A | 2010-03-19 A | 100% | 2009-05-30 | 2010-03-19 | 211d? | finish no earlier than 2010-03-12 | C6 | 1688h | 1688h | USIM_API_test | Sagem Orga | gerrit.hartbrod@sagem-orga.com | Rel-7 | Xavier | 31.213 |  | PCG-23 | CP-44 |
| 1443 | 481 | High speed interface between the UICC and the ME | 311d? | 2006-09-22 A | 2007-11-30 A | 100% | 2006-09-22 | 2007-11-30 | 311d? | finish no earlier than 2007-11-30 | C6 | 2488h | 2488h | HSI | Gemalto | jacques.seif@GEMALTO.COM | Rel-7 | Xavier | 31.101 |  |  |  |
| 1444 | 482 | Video Codec Performance Requirements | 634d? | 2005-01-03 A | 2007-06-07 A | 100% | 2005-01-03 | 2007-06-07 | 634d? | finish no earlier than 2007-06-07 | S4 | 5072h | 5072h | VICPer | Siemens | juergen.pandel@siemens.com | Rel-7 | Paolo | 26.234, 26.235, 26.346, 26.140, 26.902 |  |  |  |
| 1445 | 483 | Dynamic and Interactive Multimedia Scenes | 583d? | 2005-03-15 A | 2007-06-07 A | 100% | 2005-03-15 | 2007-06-07 | 583d? | finish no earlier than 2007-06-07 | S4 | 4664h | 4664h | DIMS | Streamezzo | gaelle.martin-cocher@streamezzo.com | Rel-7 | Paolo | 26.140, 26.142, 26.234, 26.244, 23.346 |  |  |  |
| 1446 | 484 | 3G-324M Video Telephony Call Setup Times Improvements | 341d? | 2005-06-08 A | 2006-09-27 A | 100% | 2005-06-08 | 2006-09-27 | 341d? | finish no earlier than 2006-09-27 | S4 | 2728h | 2728h | VTCSTI | Vodafone | edward.hall@vodafone.co.uk | Rel-7 | Paolo | 26.911 |  |  |  |

Notes:
- 1423: -
- 1424: -
- 1425: -
- 1426: TR 24.930: Signalling flows for the session setup in the IM CN subsystem based on Session Initiation Protocol (SIP)
- 1427: Voice Group Call Service
- 1428: -
- 1429: -
- 1430: -
- 1431: -
- 1432: -
- 1433: -
- 1434: -
- 1435: -
- 1436: CP#34: CT3 not involved in Mp interface definition
- 1437: -
- 1438: -
- 1439: WID approved in CP#34
- 1440: -
- 1441: -
- 1442: CP#47 completed. Update of Rel-6 (U)SIM API for Java Card Testing UID_43007 under Rel-6 UICC/USIM enhancements and interworking UID_1800
- 1443: Following ETSI publication of TS 102 600, expected to be completed at CT6 meeting 45
- 1444: -
- 1445: -
- 1446: -

| ID | WBS | Task | Type | Duration | Start | Finish | Complete | Baseline start | Baseline finish | Baseline duration | Constraint | Resources | Work | Actual work | Text1 | Text4 | Text5 | Text6 | Text8 | Text12 |
| --- | --- | --- | --- | --- | --- | --- | --- | --- | --- | --- | --- | --- | --- | --- | --- | --- | --- | --- | --- | --- |
| 1447 | 485 | **Optimizations for Multimedia Telephony over IMS** |  | 0d? | 2005-09-28 A | 2005-09-28 A | 100% | 2005-09-28 | 2005-09-28 | 0d? |  | S4 |  |  | OMTIMS | Ericsson | olle.franceschi@ericsson.com | Rel-7 | Paolo |  |
| 1448 | 485.1 | Deleted - Characterisation of Adaptive Jitter Management Performance for VoIP Services | milestone | 0d? | 2005-09-28 A | 2005-09-28 A | 100% | 2005-09-28 | 2005-09-28 | 0d? | start no earlier than 2007-03-15 | S4 |  |  | OMTIMS-CAJMP | Lucent | dhuo@lucent.com | Rel-7 | Paolo | SP-35 |
| 1449 | 486 | End-to-End Multimedia Services Performance Metrics |  | 382d? | 2005-09-28 A | 2007-03-15 A | 100% | 2005-09-28 | 2007-03-15 | 382d? | finish no earlier than 2007-03-15 | S4 | 3056h | 3056h | E2EMSPM | China Mobile | zhangyanyf@chinamobile.com | Rel-7 | Paolo |  |
| 1450 | 487 | Packet Switched Streaming Enhancements |  | 261d? | 2006-06-08 A | 2007-06-07 A | 100% | 2006-06-08 | 2007-06-07 | 261d? | finish no earlier than 2007-06-07 | S4 | 2088h | 2088h | PSSe | Ericsson | olle.franceschi@ericsson.com | Rel-7 | Paolo |  |
| 1451 | 488 | **OAM&P Rel-7** |  | 472.86d? | 2005-09-02 A | 2007-06-26 A | 100% | 2005-09-02 | 2007-06-26 | 472.86d? |  | S5 | 82725.8h | 82725.8h | OAM7 | Huawei | Christian.Toche@huawei.com | Rel-7 | Dionisio |  |
| 1452 | 488.1 | **Network Infrastructure Management** |  | 465d? | 2005-09-02 A | 2007-06-14 A | 100% | 2005-09-02 | 2007-06-14 | 465d? |  | S5 | 41800h | 41800h | OAM7-NIM |  |  | Rel-7 | Dionisio |  |
| 1453 | 488.1.1 | Enhance NRM to accommodate NGN (IMS as basis of the Next Generation Network) |  | 465d? | 2005-09-02 A | 2007-06-14 A | 100% | 2005-09-02 | 2007-06-14 | 465d? | finish no earlier than 2007-06-14 | S5 | 3720h | 3720h | OAM7-NIM | Motorola |  | Rel-7 | Dionisio |  |
| 1454 | 488.1.2 | Co-operative Element Management interface (CO-OP) (Study + Implementation) |  | 400d? | 2005-09-02 A | 2007-03-15 A | 100% | 2005-09-02 | 2007-03-15 | 400d? | finish no earlier than 2007-03-15 | S5 | 3200h | 3200h | OAM7-NIM | Motorola |  | Rel-7 | Dionisio |  |
| 1455 | 488.1.3 | Network Management (NM) Itf-N performance criteria |  | 465d? | 2005-09-02 A | 2007-06-14 A | 100% | 2005-09-02 | 2007-06-14 | 465d? | finish no earlier than 2007-06-14 | S5 | 3720h | 3720h | OAM7-NIM | China Mobile |  | Rel-7 | Dionisio |  |
| 1456 | 488.1.4 | Delta synchronization between IRP Manager and IRP Agent (Study + Implementation) |  | 465d? | 2005-09-02 A | 2007-06-14 A | 100% | 2005-09-02 | 2007-06-14 | 465d? | finish no earlier than 2007-06-14 | S5 | 3720h | 3720h | OAM7-NIM | Siemens |  | Rel-7 | Dionisio |  |
| 1457 | 488.1.5 | Subscription Management (SuM) IRP Solution Sets |  | 330d? | 2005-09-02 A | 2006-12-07 A | 100% | 2005-09-02 | 2006-12-07 | 330d? | finish no earlier than 2006-12-07 | S5 | 2640h | 2640h | OAM7-NIM | Ericsson |  | Rel-7 | Dionisio |  |
| 1458 | 488.1.6 | Integration Reference Point (IRP) Security Management |  | 400d? | 2005-09-02 A | 2007-03-15 A | 100% | 2005-09-02 | 2007-03-15 | 400d? | finish no earlier than 2007-03-15 | S5 | 3200h | 3200h | OAM7-NIM | Huawei | Christian.Toche@huawei.com | Rel-7 | Dionisio |  |
| 1459 | 488.1.7 | Partial suspension of Itf-N during maintenance/testing (Study + Implementation) |  | 465d? | 2005-09-02 A | 2007-06-14 A | 100% | 2005-09-02 | 2007-06-14 | 465d? | finish no earlier than 2007-06-14 | S5 | 3720h | 3720h | OAM7-NIM | Siemens |  | Rel-7 | Dionisio |  |
| 1460 | 488.1.8 | Deleted - Management of Legacy Equipment |  | 336d? | 2005-09-02 A | 2006-12-15 A | 100% | 2005-09-02 | 2006-12-15 | 336d? | finish no earlier than 2006-12-15 | S5 | 2688h | 2688h | OAM7-NIM | Siemens |  | Rel-7 | Dionisio | SP-35 |
| 1461 | 488.1.9 | Deleted - Rules for Vendor Specific Extensions |  | 400d? | 2005-09-02 A | 2007-03-15 A | 100% | 2005-09-02 | 2007-03-15 | 400d? | finish no earlier than 2007-03-15 | S5 | 3200h | 3200h | OAM7-NIM | Siemens |  | Rel-7 | Dionisio | SP-35 |
| 1462 | 488.1.10 | Backward and Forward Compatibility of IRP systems |  | 465d? | 2005-09-02 A | 2007-06-14 A | 100% | 2005-09-02 | 2007-06-14 | 465d? | finish no earlier than 2007-06-14 | S5 | 3720h | 3720h | OAM7-NIM | Ericsson |  | Rel-7 | Dionisio |  |
| 1463 | 488.1.11 | Repeater Network Resource Model (NRM) definition |  | 214d? | 2006-02-13 A | 2006-12-07 A | 100% | 2006-02-13 | 2006-12-07 | 214d? | finish no earlier than 2006-12-07 | S5 | 1712h | 1712h | OAM7-NIM | China Mobile |  | Rel-7 | Dionisio |  |
| 1464 | 488.1.12 | UTRAN radio channel power monitoring |  | 284d? | 2006-02-13 A | 2007-03-15 A | 100% | 2006-02-13 | 2007-03-15 | 284d? | finish no earlier than 2007-03-15 | S5 | 2272h | 2272h | OAM7-NIM | China Mobile |  | Rel-7 | Dionisio |  |
| 1465 | 488.1.13 | Notification XML Schema |  | 71d? | 2006-12-07 A | 2007-03-15 A | 100% | 2006-12-07 | 2007-03-15 | 71d? | finish no earlier than 2007-03-15 | S5 | 568h | 568h | OAM7-NIM | Huawei | Christian.Toche@huawei.com | Rel-7 | Dionisio |  |
| 1466 | 488.2 | **Performance Management** |  | 465d? | 2005-09-02 A | 2007-06-14 A | 100% | 2005-09-02 | 2007-06-14 | 465d? |  | S5 | 22992h | 22992h | OAM7-PM |  |  | Rel-7 | Dionisio |  |
| 1467 | 488.2.1 | Performance measurements definition for CN CS |  | 400d? | 2005-09-02 A | 2007-03-15 A | 100% | 2005-09-02 | 2007-03-15 | 400d? | finish no earlier than 2007-03-15 | S5 | 3200h | 3200h | OAM7-PM | China Mobile |  | Rel-7 | Dionisio |  |
| 1468 | 488.2.2 | Enhancement UTRAN performance measurements definition |  | 465d? | 2005-09-02 A | 2007-06-14 A | 100% | 2005-09-02 | 2007-06-14 | 465d? | finish no earlier than 2007-06-14 | S5 | 3720h | 3720h | OAM7-PM | China Mobile |  | Rel-7 | Dionisio |  |
| 1469 | 488.2.3 | Add TDD specific counters in Performance measurement |  | 330d? | 2005-09-02 A | 2006-12-07 A | 100% | 2005-09-02 | 2006-12-07 | 330d? | finish no earlier than 2006-12-15 | S5 | 2640h | 2640h | OAM7-PM | CATT |  | Rel-7 | Dionisio |  |
| 1470 | 488.2.4 | ATM bearer network Performance measurements |  | 400d? | 2005-09-02 A | 2007-03-15 A | 100% | 2005-09-02 | 2007-03-15 | 400d? | finish no earlier than 2007-03-15 | S5 | 3200h | 3200h | OAM7-PM | ZTE |  | Rel-7 | Dionisio |  |
| 1471 | 488.2.5 | Performance measurements definition for IMS |  | 465d? | 2005-09-02 A | 2007-06-14 A | 100% | 2005-09-02 | 2007-06-14 | 465d? | finish no earlier than 2007-06-14 | S5 | 3720h | 3720h | OAM7-PM | China Mobile |  | Rel-7 | Dionisio |  |
| 1472 | 488.2.6 | HSDPA performance measurements |  | 349d? | 2006-02-13 A | 2007-06-14 A | 100% | 2006-02-13 | 2007-06-14 | 349d? | finish no earlier than 2007-06-14 | S5 | 2792h | 2792h | OAM7-PM | China Mobile |  | Rel-7 | Dionisio |  |

Notes:
- 1447: - / Text3: 26.235, 26.236
- 1448: SP-35 stopped
- 1449: - / Text3: 26.944
- 1450: - / Text3: 26.234, 26.244
- 1451: - / Text3: TR 30.817
- 1452: -
- 1453: - / Text3: 32.731/2/3/5, 32.631/2/3/5
- 1454: - / Text3: 32.806, 32.814, 32.101
- 1455: - / Text3: 32.811
- 1456: - / Text3: 32.391/2/3/5
- 1457: - / Text3: 32.307/317/607/667/665, 32.101, 32.175
- 1458: - / Text3: 32.372/3/5, 32.111,32.30x,32.32x,32.33x,32.34x,32.35x,32.36x,32.41x,32.60x,32.61x,32.66x
- 1459: - / Text3: 32.381/2/3/5
- 1460: Request to TSG#35 to STOP the WI / Text3: new 32.xxx
- 1461: Request to TSG#35 to STOP the WI / Text3: 32.62n; For n = 1 to 5
- 1462: - / Text3: 32.154
- 1463: - / Text3: 32.721/2/3/5
- 1464: - / Text3: 32.405, 32.64n; For n = 1 to 5
- 1465: 12/2006 SP#34 WID approved / Text3: New 32.325/345/365/415, CR to 32.335/615/665
- 1466: -
- 1467: - / Text3: 32.407, 32.408
- 1468: - / Text3: 32.405
- 1469: - / Text3: 32.405
- 1470: - / Text3: No impact on 32.404, 32.405, 32.406, 32.407
- 1471: - / Text3: 32.404,32.409,32.437, 32.632/3/4/5
- 1472: - / Text3: 32.405

| ID | WBS | Task | Type | Duration | Start | Finish | Complete | Baseline start | Baseline finish | Baseline duration | Constraint | Resources | Work | Actual work | Text1 | Text4 | Text6 | Text8 | Text12 | Text5 | Text11 |
| --- | --- | --- | --- | --- | --- | --- | --- | --- | --- | --- | --- | --- | --- | --- | --- | --- | --- | --- | --- | --- | --- |
| 1473 | 44.5 | **Trace Management** |  | 472.86d? | 2005-09-02 A | 2007-06-26 A | 100% | 2005-09-02 | 2007-06-26 | 472.86d? |  | S5 | 14150.9h | 14150.9h | OAM7-Trace | Vodafone | Rel-7 | Dionisio |  |  |  |
| 1474 | 488.3.1 | End-to-end Service Level tracing for IMS |  | 350d? | 2005-11-11 A | 2007-03-15 A | 100% | 2005-11-11 | 2007-03-15 | 350d? | finish no earlier than 2007-03-15 | S5 | 2800h | 2800h | OAM7-Trace | Vodafone | Rel-7 | Dionisio | SP-31 |  |  |
| 1475 | 488.3.2 | Trace record content for UTRAN TDD |  | 330d? | 2005-09-02 A | 2006-12-07 A | 100% | 2005-09-02 | 2006-12-07 | 330d? | finish no earlier than 2006-12-07 | S5 | 2640h | 2640h | OAM7-Trace | Nokia | Rel-7 | Dionisio |  |  |  |
| 1476 | 488.3.3 | IRP for Subscriber and Equipment Trace Management |  | 465d? | 2005-09-02 A | 2007-06-14 A | 100% | 2005-09-02 | 2007-06-14 | 465d? | finish no earlier than 2007-06-14 | S5 | 3720h | 3720h | OAM7-Trace | Nokia | Rel-7 | Dionisio |  |  |  |
| 1477 | 488.3.4 | Deleted - SIP enhancements for trace | milestone | 0d? | 2007-06-15 A | 2007-06-26 A | 100% | 2007-06-15 | 2007-06-26 | 0d? | start no earlier than 2007-06-15 | C1 |  |  | OAM7-Trace |  | Rel-7 | Frederic | CP-32 |  |  |
| 1478 | 488.3.5 | Deleted - duplicated with UID 35063 - IRP for Subscriber and Equipment Trace Management |  | 336d? | 2005-09-02 A | 2006-12-15 A | 100% | 2005-09-02 | 2006-12-15 | 336d? | finish no earlier than 2006-12-15 | S5 | 2688h | 2688h | OAM7-Trace | Nokia | Rel-7 | Dionisio | SP-33 |  |  |
| 1479 | 489 | **Charging Management small Enhancements Rel-7** |  | 279d? | 2006-05-22 A | 2007-06-14 A | 100% | 2006-05-22 | 2007-06-14 | 279d? |  | S5 | 5952h | 5952h | CH7 | Orange | Rel-7 | Dionisio |  | alain.bibas@orange-ft.com |  |
| 1480 | 489.1 | Alternate Charged Party (ACP) for IMS |  | 279d? | 2006-05-22 A | 2007-06-14 A | 100% | 2006-05-22 | 2007-06-14 | 279d? | finish no earlier than 2007-06-14 | S5 | 2232h | 2232h | CH7-IMS-ACP | Lucent | Rel-7 | Dionisio |  | njmazzarella@alcatel-lucent.com |  |
| 1481 | 489.2 | Align 3GPP Charging with OMA PoC Enabler Release 2.0 |  | 186d? | 2006-09-28 A | 2007-06-14 A | 100% | 2006-09-28 | 2007-06-14 | 186d? | finish no earlier than 2007-06-14 | S5 | 1488h | 1488h | CH7-PoC | Siemens | Rel-7 | Dionisio |  | Gerald.Goermer@nsn.com |  |
| 1482 | 8.5 | **Multiple-Input Multiple-Output (MIMO) antennas** |  | 1301d? | 2003-03-14 A | 2008-03-07 A | 100% | 2003-03-14 | 2008-03-07 | 1301d? |  | R1,R5 | 45440h | 45440h | MIMO | Alcatel-Lucent | Rel-7 | Patrick |  | hchuang@Alcatel-Lucent.com | RP-070037, RP-070531 |
| 1483 | 490.1 | MIMO - Physical layer |  | 915d? | 2003-09-12 A | 2007-03-15 A | 100% | 2003-09-12 | 2007-03-15 | 915d? | finish no earlier than 2007-03-15 | R1 | 7320h | 7320h | MIMO-Phys | Alcatel-Lucent | Rel-7 | Patrick |  | hchuang@Alcatel-Lucent.com | RP-070037 |
| 1484 | 490.2 | MIMO - Layer 2,3 aspects |  | 915d? | 2003-09-12 A | 2007-03-15 A | 100% | 2003-09-12 | 2007-03-15 | 915d? | finish no earlier than 2007-03-15 | R2 | 7320h | 7320h | MIMO-L23 | Alcatel-Lucent | Rel-7 | Joern |  | hchuang@Alcatel-Lucent.com | RP-070037 |
| 1485 | 490.3 | MIMO - Iub/Iur Protocol Aspects |  | 1045d? | 2003-03-14 A | 2007-03-15 A | 100% | 2003-03-14 | 2007-03-15 | 1045d? | finish no earlier than 2007-03-15 | R3 | 8360h | 8360h | MIMO-IurIub | Alcatel-Lucent | Rel-7 | Juha |  | hchuang@Alcatel-Lucent.com | RP-070037 |
| 1486 | 490.4 | MIMO - RF Radio Transmission/Reception, System Performance Requirements and Conformance Testing |  | 982d? | 2003-12-12 A | 2007-09-17 A | 100% | 2003-12-12 | 2007-09-17 | 982d? | finish no earlier than 2007-09-17 | R4 | 7856h | 7856h | MIMO-RF | Alcatel-Lucent | Rel-7 | Issam |  | ngm@Alcatel-Lucent.com | RP-070531 |
| 1487 | 490.5 | **UE Conformance Testing for Multiple Input Multiple Output antennas (MIMO)** |  | 261d? | 2007-03-09 A | 2008-03-07 A | 100% | 2007-03-09 | 2008-03-07 | 261d? |  | R5 | 4176h | 4176h | MIMO-UEConTest | Qualcomm | Rel-7 | Ingbert |  | svora@qualcomm.com |  |
| 1488 | 490.5.1 | Conformance Test Aspects – Multiple Input Multiple Output Antennas (MIMO) for FDD |  | 261d? | 2007-03-09 A | 2008-03-07 A | 100% | 2007-03-09 | 2008-03-07 | 261d? | finish no earlier than 2008-03-07 | R5 | 2088h | 2088h | MIMO-UEConTest_FDD | Qualcomm | Rel-7 | Ingbert |  | svora@qualcomm.com |  |
| 1489 | 491 | **Rel-7 Improvements of the Radio Interface** |  | 709d? | 2004-09-15 A | 2007-06-04 A | 100% | 2004-09-15 | 2007-06-04 | 709d? |  | RP | 29696h | 29696h | RInImp |  | Rel-7 | Issam |  |  |  |
| 1490 | 491.1 | Extended UMTS 1.7/2.1 GHz |  | 198d? | 2006-03-15 A | 2006-12-15 A | 100% | 2006-03-15 | 2006-12-15 | 198d? | finish no earlier than 2006-12-15 | R4 | 1584h | 1584h | RInImp-UMTS1721Ext | Ericsson | Rel-7 | Issam |  | Johan Sköld (johan.skold@ericsson.com) | RP-060681 |
| 1491 | 491.2 | UMTS 2.6 GHz 7.68 Mcps TDD |  | 67d? | 2006-06-15 A | 2006-09-15 A | 100% | 2006-06-15 | 2006-09-15 | 67d? | finish no earlier than 2006-09-15 | R4 | 536h | 536h | RInImp-UMTS26VHCRTDD | IPWireless | Rel-7 | Issam |  | Shin Horng Wong (shwong@ipwireless.com) | RP-060451 |
| 1492 | 491.3 | UMTS 2.6 GHz |  | 195d? | 2004-09-15 A | 2005-06-14 A | 100% | 2004-09-15 | 2005-06-14 | 195d? | finish no earlier than 2005-06-14 | R4 | 1560h | 1560h | RInImp-UMTS2600 | Nokia | Rel-7 | Issam |  | jussi.numminen@nokia.com | RP-050184 |
| 1493 | 491.4 | UMTS 2.6 GHz TDD |  | 261d? | 2004-12-15 A | 2005-12-14 A | 100% | 2004-12-15 | 2005-12-14 | 261d? | finish no earlier than 2005-12-15 | R4 | 2088h | 2088h | RInImp-UMTS2600TDD | IPWireless | Rel-7 | Issam |  | Shin Horng Wong (shwong@ipwireless.com) | RP-050661 |
| 1494 | 491.5 | UMTS 900 MHz |  | 261d? | 2004-12-15 A | 2005-12-14 A | 100% | 2004-12-15 | 2005-12-14 | 261d? | finish no earlier than 2005-12-15 | R4 | 2088h | 2088h | RInImp-UMTS900 | Nortel | Rel-7 | Issam |  | Yannick Li (yli@nortelnetworks.com) | RP-050662 |
| 1495 | 491.6 | UMTS 1700 MHz |  | 197d? | 2005-03-15 A | 2005-12-14 A | 100% | 2005-03-15 | 2005-12-14 | 197d? | finish no earlier than 2005-12-15 | R4 | 1576h | 1576h | RInImp-UMTS1700 | NTT DoCoMo | Rel-7 | Issam |  | Takehiro Nakamura (nakamurata@nttdocomo.co.jp) | RP-050824 |
| 1496 | 491.7 | UE Antenna Performance Evaluation Method and Requirements |  | 644d? | 2004-12-15 A | 2007-06-04 A | 100% | 2004-12-15 | 2007-06-04 | 644d? | finish no earlier than 2007-06-04 | R4 | 5152h | 5152h | RInImp-UEAnt | TeliaSonera | Rel-7 | Issam |  | Christian.Bergljung@TeliaSonera.com | RP-070281 |
| 1497 | 491.8 | Improved Performance Requirements for HSDPA UE based on Rx Diversity (type 1) & LMMSE equalizer (type 2) | milestone | 0d? | 2005-03-15 A | 2005-03-15 A | 100% | 2005-03-15 | 2005-03-15 | 0d? | finish no earlier than 2005-03-15 | R4 |  |  | RInImp-HSPerf-Type3 | Cingular | Rel-7 | Issam |  | Marc Grant | RP-060015 |

Notes:
- 1473: -
- 1474: 07/2005: OMA (Stage 1), Stage 2/3 SA5, CT1/3/4 / Text3: CR 32.101, 32.421/2/3.
- 1475: - / Text3: CR 32.421/2/3.
- 1476: - / Text3: 32.441/2/3/5, CRs 32.632/3/5
- 1477: combined with UID 11067
- 1478: - / Text3: 32.421,32.422,32.423. 3 new 32.4x1,2,3
- 1479: - / Text3: TR 30.817
- 1480: - / Text3: 32.240, 32.260, 32.298, 32.299
- 1481: 09/2006 SP#33 WID approved / Text3: 32.240, 32.272, 32.299, 32.298
- 1482: Completed Sep 2007; SR in RP-070037and RP-070531 / Text3: 25.876, 25.996
- 1483: Completed Sep 2007; SR in RP-070037 / Text3: 25.211, 25.212, 25.213, 25.214, 25.215, 25.221
- 1484: Completed Sep 2007; SR in RP-070037 / Text3: 25.876
- 1485: Completed Sep 2007; SR in RP-070037
- 1486: Completed Sep 2007; SR in RP-070531
- 1487: BB place holder for a number of RAN5 Tasks
- 1488: - / Text3: TS 34.108, TS 34.109, TS 34.121-1, TS 34.121-2, TS 34.123-1, TS 34.123-2, TS 34.123-3
- 1489: Generic feature
- 1490: RP#34 completed. Introduction of Band X (Extended UMTS 1.7/2.1 GHz) in 25.307 / Text3: 25.806, 25.101, 25.104, 25.133, 24.141, 25.331, 25.306, 25.307, 25.423, 25.461, 25.463, 34.121
- 1491: RP#33 completed / Text3: 25.102, 25.105, 25.123, 25.113, 25.142, 34.124
- 1492: RP#28 completed / Text3: 25.101, 25.104, 25.133, 25.141, 25.331, 25.942, 25.306, 25.307, 34.121
- 1493: RP#30 completed / Text3: 25.102, 25.105, 25.113, 25.123, 25.142, 25.331, 25.942, 25.306, 25.307, 34.122, 34.124
- 1494: RP#30 completed / Text3: 25.101, 25.104, 25.113, 25.133, 25.141, 25.331, 25.942, 25.306, 25.307, 34.121
- 1495: RP#30 completed / Text3: 25.101, 25.104, 25.113, 25.133, 25.141, 25.306, 25.307, 25.331, 34.121
- 1496: RP#36 completed / Text3: 25.101, 25.963
- 1497: RP#27 completed / Text3: 25.101

| ID | WBS | Task | Type | Duration | Start | Finish | Complete | Baseline start | Baseline finish | Baseline duration | Constraint | Deadline | Resources | Work | Actual work | Text1 | Text4 | Text5 | Text6 | Text8 | Text11 | Text12 | Text9 | Text10 |
| --- | --- | --- | --- | --- | --- | --- | --- | --- | --- | --- | --- | --- | --- | --- | --- | --- | --- | --- | --- | --- | --- | --- | --- | --- |
| 1498 | 491.9 | **Additional minimum UE performance requirement for non-HSDPA channels based on type 1 enhanced receiver (Rx Diversity)** |  | 327d? | 2005-09-15 A | 2006-12-15 A | 100% | 2005-09-15 | 2006-12-15 | 327d? |  |  | R4 | 7344h | 7344h | RInImp-RxDiv | Qualcomm | Serge Willenegger (sergew@qualcomm.com) | Rel-7 | Issam |  |  |  |  |
| 1499 | 491.9.1 | Additional minimum UE performance requirement for DL physical channels in support of DCH/HS-DSCH operation based on type 1 enhanced receiver (RX-Diversity) |  | 195d? | 2005-09-15 A | 2006-06-14 A | 100% | 2005-09-15 | 2006-06-14 | 195d? | finish no earlier than 2006-06-15 |  | R4 | 1560h | 1560h | RInImp-RxDiv-DCH | Cingular | Marc Grant | Rel-7 | Issam | RP-060235 |  |  |  |
| 1500 | 491.9.2 | Additional minimum UE performance requirement for downlink physical channels in support of MTCH and MCCH operation based on type 1 enhanced receiver (Rx-Diversity) |  | 198d? | 2006-03-15 A | 2006-12-15 A | 100% | 2006-03-15 | 2006-12-15 | 198d? | finish no earlier than 2006-12-15 |  | R4 | 1584h | 1584h | RInImp-RxDiv-MBMS | Qualcomm | Serge Willenegger (sergew@qualcomm.com) | Rel-7 | Issam | RP-060678 |  |  |  |
| 1501 | 491.9.3 | Additional minimum UE performance requirement for downlink physical channels in support of E-DCH operation based on type 1 enhanced receiver (Rx-Diversity) |  | 198d? | 2006-03-15 A | 2006-12-15 A | 100% | 2006-03-15 | 2006-12-15 | 198d? | finish no earlier than 2006-12-15 |  | R4 | 1584h | 1584h | RInImp-RxDiv-EDCH | Qualcomm | Serge Willenegger (sergew@qualcomm.com) | Rel-7 | Issam | RP-060679 |  |  |  |
| 1502 | 491.10 | Deleted Improved support of gaming over HSDPA/EDCH |  | 262d? | 2005-12-15 A | 2006-12-15 A | 100% | 2005-12-15 | 2006-12-15 | 262d? | finish no earlier than 2006-12-15 |  | R2 | 2096h | 2096h | RInImp-Gaming | Cingular | Don Zelmer (dz1069@att.com) | Rel-7 | Joern | RP-060680 | RP-34 |  |  |
| 1503 | 491.11 | Deleted (not approved at PCG) - UMTS 2.6 GHz FDD DL External | milestone | 0d? | 2005-09-15 A | 2005-09-15 A | 100% | 2005-09-15 | 2005-09-15 | 0d? | finish no earlier than 2005-09-15 |  | R4 |  |  | RInImp-UMTS2600Ext | T-mobile | han.van.bussel@t-mobile.de | Rel-7 | Issam |  | RP-31 | PCG-16 |  |
| 1504 | 492 | **Rel-7 Improvements of the Radio Interface - UE Conformance Testing** |  | 741d? | 2005-11-11 A | 2008-09-12 A | 100% | 2005-11-11 | 2008-09-12 | 741d? |  |  | R5 | 17568h | 17568h | RInImp-UEConTest |  |  | Rel-7 | Ingbert |  |  |  |  |
| 1505 | 16.5.1 | UE Conformance Test for UMTS 2600 MHz |  | 146d | 2005-11-11 A | 2006-06-02 A | 100% | 2005-11-11 | 2006-06-02 | 146d | finish no earlier than 2006-06-02 | 2006-06-02 | R5 | 1168h | 1168h | RInImp-UMTS2600_Test | Nokia | Aleksi.Heino@nokia.com | Rel-7 | Ingbert |  |  |  | Fri 7/11/05 |
| 1506 | 16.5.1 | UE Conformance Test for UMTS 900 MHz (band VIII) |  | 146d | 2005-11-11 A | 2006-06-02 A | 100% | 2005-11-11 | 2006-06-02 | 146d | finish no earlier than 2006-06-02 | 2006-06-02 | R5 | 1168h | 1168h | RInImp-UMTS900_Test | Qualcomm | hanye@qualcomm.com | Rel-7 | Ingbert |  |  |  | Fri 11/03/05 |
| 1507 | 492.3 | Conformance Test Aspects – Improved Performance of HSDPA Receiver type 3 |  | 191d? | 2006-03-10 A | 2006-12-01 A | 100% | 2006-03-10 | 2006-12-01 | 191d? | finish no earlier than 2006-12-01 |  | R5 | 1528h | 1528h | RInImp-HSPerf-Type3_Test | Motorola | carolyn.taylor@motorola.com | Rel-7 | Ingbert |  |  |  |  |
| 1508 | 492.4 | UE antenna Over The Air (OTA) conformance testing |  | 518d? | 2006-09-20 A | 2008-09-12 A | 100% | 2006-09-20 | 2008-09-12 | 518d? | finish no earlier than 2008-09-12 |  | R5 | 4144h | 4144h | RInImp-UEAnt_Test | Nokia | Aleksi.Heino@nokia.com | Rel-7 | Ingbert | RP-080535 |  |  |  |
| 1509 | 492.5 | UE conformance testing for FDD Inter-Band Operation |  | 131d? | 2006-06-02 A | 2006-12-01 A | 100% | 2006-06-02 | 2006-12-01 | 131d? | finish no earlier than 2006-12-01 |  | R5 | 1048h | 1048h | RInImp-InterBand_Test | NEC, Motorola | Jacob.John@motorola.com | Rel-7 | Ingbert |  |  |  |  |
| 1510 | 492.6 | Conformance Test Aspects – Extended UMTS 1.7/2.1 GHz |  | 131d? | 2006-12-01 A | 2007-06-01 A | 100% | 2006-12-01 | 2007-06-01 | 131d? | finish no earlier than 2007-06-01 |  | R5 | 1048h | 1048h | RInImp-UEConTest_UMTS1721Ext | Motorola | carolyn.taylor@motorola.com | Rel-7 | Ingbert | RP-070312 |  |  |  |
| 1511 | 492.7 | Conformance Test Aspects – Minimum UE performance requirement for downlink physical channels in support of E-DCH operation based on type 1 enhanced receiver (Rx-Diversity) |  | 136d? | 2007-06-01 A | 2007-12-07 A | 100% | 2007-06-01 | 2007-12-07 | 136d? | finish no earlier than 2007-12-07 |  | R5 | 1088h | 1088h | RInImp-UEConTest_RxDivEDCH | Motorola | carolyn.taylor@motorola.com | Rel-7 | Ingbert | RP-070810 |  |  |  |
| 1512 | 492.8 | Conformance Test Aspects – Minimum UE performance requirement for downlink physical channels in support of MTCGH and MCCH operation based on type 1 enhanced receiver (Rx-Diversity) |  | 201d? | 2007-06-01 A | 2008-03-07 A | 100% | 2007-06-01 | 2008-03-07 | 201d? | finish no earlier than 2008-03-07 |  | R5 | 1608h | 1608h | RInImp-UEConTest_RxDivMBMS | Ericsson | leif.mattisson@ericsson.com | Rel-7 | Ingbert | RP-080056 |  |  |  |
| 1513 | 493 | **Rel-7 RAN improvements** |  | 653d? | 2004-12-15 A | 2007-06-15 A | 100% | 2004-12-15 | 2007-06-15 | 653d? |  |  | RP | 29952h | 29952h | RANimp |  |  | Rel-7 |  |  |  |  |  |
| 1514 | 493.1 | Optimization of channelisation code utilisation for 1.28 Mcps TDD |  | 523d? | 2004-12-15 A | 2006-12-15 A | 100% | 2004-12-15 | 2006-12-15 | 523d? | finish no earlier than 2006-12-15 |  | R1 | 4184h | 4184h | RANimp-RABSE-CodOptLCRTDD | UTStarcom | Ka Leong Lo (kaleong.lo@UTSTAR.COM) | Rel-7 | Patrick | RP-060682 |  |  |  |
| 1515 | 493.2 | Delay optimization for procedures applicable to CS and PS Connections |  | 394d? | 2005-03-15 A | 2006-09-15 A | 100% | 2005-03-15 | 2006-09-15 | 394d? | finish no earlier than 2006-09-15 |  | R2 | 3152h | 3152h | RANimp-DelayOpt | Nokia | juho.pirskanen@nokia.com | Rel-7 | Joern | RP-060453 |  |  |  |
| 1516 | 493.3 | Improved support of IMS Realtime Services using HSDPA/HSUPA |  | 197d? | 2005-03-15 A | 2005-12-14 A | 100% | 2005-03-15 | 2005-12-14 | 197d? | start no earlier than 2005-03-15 |  | R2 | 1576h | 1576h | RANimp-IMSRealTime | Cingular | Don Zelmer (dz1069@att.com) | Rel-7 | Joern | RP-050667 |  |  |  |
| 1517 | 493.4 | UE Performance Requirements for MBMS (TDD) |  | 328d? | 2005-03-15 A | 2006-06-15 A | 100% | 2005-03-15 | 2006-06-15 | 328d? | finish no earlier than 2006-06-15 |  | R4 | 2624h | 2624h | MBMS-RAN-RF-TDD | IPwireless | shwong@ipwireless.com | Rel-7 | Issam | RP-060477 |  |  |  |
| 1518 | 493.5 | Continuous connectivity for packet data users |  | 524d? | 2005-03-14 A | 2007-03-15 A | 100% | 2005-03-14 | 2007-03-15 | 524d? | finish no earlier than 2007-03-15 |  | R1 | 4192h | 4192h | RANimp-CPC | Siemens | Joern.Krause@siemens.com | Rel-7 | Patrick | RP-070033 |  |  |  |
| 1519 | 493.6 | Extended WCDMA Cell Range |  | 198d? | 2006-03-15 A | 2006-12-15 A | 100% | 2006-03-15 | 2006-12-15 | 198d? | finish no earlier than 2006-12-15 |  | R3 | 1584h | 1584h | RANimp-ExtCell | Ericsson | Muhammad Kazmi | Rel-7 | Juha | RP-060685 |  |  |  |
| 1520 | 493.7 | 7.68 Mcps TDD Enhanced Uplink |  | 198d? | 2006-03-15 A | 2006-12-15 A | 100% | 2006-03-15 | 2006-12-15 | 198d? | finish no earlier than 2006-12-15 |  | R1 | 1584h | 1584h | RANimp-VHCRTDD-EDCH | IPwireless | nanderson@ipwireless.com | Rel-7 | Patrick | RP-060684 |  |  |  |
| 1521 | 493.8 | Enhanced CELL_FACH State in FDD |  | 181d? | 2006-09-25 A | 2007-06-04 A | 100% | 2006-09-25 | 2007-06-04 | 181d? | finish no earlier than 2007-06-04 |  | R2 | 1448h | 1448h | RANimp-EnhState | Nokia | juho.pirskanen@nokia.com | Rel-7 | Joern | RP-070286 |  |  |  |
| 1522 | 493.9 | 64QAM for HSDPA (FDD) |  | 110d? | 2006-12-15 A | 2007-06-04 A | 100% | 2006-12-15 | 2007-06-04 | 110d? | finish no earlier than 2007-06-04 |  | R1 | 880h | 880h | RANimp-64QamDownlink | Ericsson | Johan.Bergman@ericsson.com | Rel-7 | Patrick | RP-070287 |  |  |  |
| 1523 | 493.10 | Improved L2 support for high data rates |  | 122d? | 2006-12-15 A | 2007-06-04 A | 100% | 2006-12-15 | 2007-06-04 | 122d? | finish no earlier than 2007-06-04 |  | R2 | 976h | 976h | RANimp-L2DataRates | Ericsson | Janne.Peisa@ericsson.com | Rel-7 | Joern | RP-070289 |  |  |  |
| 1524 | 493.11 | Introduction of 16QAM in HSUPA (FDD) |  | 110d? | 2006-12-15 A | 2007-06-04 A | 100% | 2006-12-15 | 2007-06-04 | 110d? | finish no earlier than 2007-06-04 |  | R1 | 880h | 880h | RANimp-16QamUplink | Nokia | Karri.Ranta-aho@nsn.com | Rel-7 | Patrick | RP-070288 |  |  |  |

Notes:
- 1498: - / Text3: 25.101
- 1499: RP#32 completed / Text3: 25.101
- 1500: RP#34 completed / Text3: 25.101
- 1501: RP#34 completed / Text3: 25.101
- 1502: RP#34 stopped. SR in RP-060680
- 1503: This item was conditionnaly approved pending decision of PCG#16 who decided not to approve it / Text3: 25.101, 25.104, 25.133, 25.141, 25.331, 25.942, 25.306, 25.307, 34.121
- 1504: Linked to Feature UID_20028 (RInImp)
- 1505: RP#32 completed / Text3: 34.108, 34.121
- 1506: RP#32 completed / Text3: 34.108, 34.121
- 1507: RP#34 completed / Text3: 34.121, 34.108
- 1508: RP#41 completed (GERAN aspects might need to be included later) / Text3: 34.114
- 1509: RP#34 completed / Text3: 34.108, 34.123-1, 34.123-2, 34.123-3
- 1510: RP#36 completed / Text3: 34.108, 34.121-1, 34.121-2
- 1511: RP#38 completed
- 1512: RP#39 completed
- 1513: Generic feature
- 1514: RP#34 completed
- 1515: RP#33 completed / Text3: 25.815, 25.321, 25.322, 25.331
- 1516: RP#30 completed
- 1517: RP#32 completed / Text3: 25.102, 25.123
- 1518: RP#35 completed / Text3: 25.903, 25.201, 25.211, 25.212, 25.214, 25.308, 25.321, 25.331, 25.423, 25.433, 25.101, 25.133
- 1519: RP#34 completed / Text3: 25.133, 25.423, 25.425, 25.433, 25.435, 25.453, 25.331
- 1520: RP#34 completed / Text3: 25.201, 25.202, 25.221, 25.222, 25.223, 25.224, 25.225, 25.331, 23.321, 25.306, 25.302, 25.401, 25.420, 25.423, 25.427, 25.433, 25.102, 25.105, 25.142
- 1521: RP#36 completed / Text3: 25.308, 25.304, 25.306, 25.321, 25.331, 25.433, 25.435, 25.423, 25.425,
- 1522: RP#36 completed / Text3: 25.308, 25.211, 25.212, 25.213, 25.306, 25.331, 25.433, 25.435, 25.423, 25.425, 25.101, 25.104, 25.141
- 1523: RP#36 completed / Text3: 25.301, 25.308,25.306, 25.321, 25.322, 25.331, 25.433, 25.435, 25.423, 25.425, 25.999
- 1524: RP#36 completed / Text3: 25.319, 25.101, 25.104, 25.133, 25.141, 25.211, 25.212, 25.213, 25.214, 25.306, 25.321, 25.331, 25.423, 25.433

| ID | WBS | Task | Duration | Start | Finish | Complete | Remaining | Baseline start | Baseline finish | Baseline duration | Total slack | Constraint | Resources | Work | Actual work | Text1 | Text4 | Text5 | Text6 | Text8 | Text11 | Text2 | Text7 |
| --- | --- | --- | --- | --- | --- | --- | --- | --- | --- | --- | --- | --- | --- | --- | --- | --- | --- | --- | --- | --- | --- | --- | --- |
| 1525 | 493.12 | **Interface to control Tower Mounted Amplifiers (TMAs)** | 271d? | 2006-06-02 A | 2007-06-15 A | 100% |  | 2006-06-02 | 2007-06-15 | 271d? |  |  | R3,S5 | 1648h | 1648h | RANImp-TMA | Vodafone | alexej.kulakov@vodafone.com | Rel-7 | Juha | RP-070140 |  |  |
| 1526 | 493.12.1 | Interface to control Tower Mounted Amplifiers (TMAs) | 206d? | 2006-06-02 A | 2007-03-16 A | 100% |  | 2006-06-02 | 2007-03-16 | 206d? |  |  | R3 | 840h | 840h | RANImp-TMA | Vodafone | alexej.kulakov@vodafone.com | Rel-7 | Juha | RP-070140 |  |  |
| 1527 | 493.12.2 | OAM aspects to Interface to control TMAs | 101d? | 2007-01-26 A | 2007-06-15 A | 100% |  | 2007-01-26 | 2007-06-15 | 101d? |  | finish no earlier than 2007-06-15 | S5 | 808h | 808h | RANImp-TMA-OAM | Vodafone | Adrian.Neal@vodafone.com | Rel-7 | Dionisio |  |  |  |
| 1528 | 494 | **Rel-7 RAN improvements - UE Conformance Testing** | 784d? | 2006-09-20 A | 2009-09-18 A | 100% |  | 2006-09-20 | 2009-09-18 | 784d? |  |  | R5 | 25472h | 25472h | RANimp-UEConTest |  |  | Rel-7 | Ingbert |  |  |  |
| 1529 | 494.1 | Conformance Test Aspects - 3.84 Mcps and 7.68 Mcps TDD Enhanced Uplink | 518d? | 2006-09-20 A | 2008-09-12 A | 100% |  | 2006-09-20 | 2008-09-12 | 518d? |  | finish no earlier than 2008-09-12 | R5 | 4144h | 4144h | RANimp-UEConTest_EDCHTDH | IPWireless | tspeight@ipwireless.com | Rel-7 | Ingbert | RP-080536 |  |  |
| 1530 | 494.2 | Conformance Test Aspects – 64QAM for HSDPA (FDD) | 257d? | 2007-03-09 A | 2008-03-03 A | 100% |  | 2007-03-09 | 2008-03-03 | 257d? |  | finish no earlier than 2008-03-03 | R5 | 2056h | 2056h | RANimp-UEConTest_64QamDownlink | Ericsson | leif.mattisson@ericsson.com | Rel-7 | Ingbert | RP-080059 |  |  |
| 1531 | 494.3 | Conformance Test Aspects – 16QAM for HSUPA (FDD) | 321d? | 2007-03-09 A | 2008-05-30 A | 100% |  | 2007-03-09 | 2008-05-30 | 321d? |  | finish no earlier than 2008-05-30 | R5 | 2568h | 2568h | RANimp-UEConTest_16QamUplink | Motorola | carolyn.taylor@motorola.com | Rel-7 | Ingbert | RP-080281 |  |  |
| 1532 | 494.4 | Conformance Test Aspects – Improved L2 support for high data rates | 321d? | 2007-03-09 A | 2008-05-30 A | 100% |  | 2007-03-09 | 2008-05-30 | 321d? |  | finish no earlier than 2008-05-30 | R5 | 2568h | 2568h | RANimp-UEConTest_L2DataRates | Ericsson | leif.mattisson@ericsson.com | Rel-7 | Ingbert | RP-080256 |  |  |
| 1533 | 494.5 | Conformance Test Aspects – Continuous connectivity for packet data users | 321d? | 2007-03-09 A | 2008-05-30 A | 100% |  | 2007-03-09 | 2008-05-30 | 321d? |  | finish no earlier than 2008-05-30 | R5 | 2568h | 2568h | RANimp-UEConTest_CPC | Nokia | jarkko.hellsten@nokia.com | Rel-7 | Ingbert | RP-080282 |  |  |
| 1534 | 494.6 | Conformance Test Aspects – Enhanced CELL_FACH state in FDD | 662d? | 2007-03-09 A | 2009-09-18 A | 100% |  | 2007-03-09 | 2009-09-18 | 662d? |  | finish no earlier than 2009-09-18 | R5 | 5296h | 5296h | RANimp-UEConTest_EnhancedCellFACHState | Nokia | jarkko.hellsten@nokia.com | Rel-7 | Ingbert | RP-090711 |  |  |
| 1535 | 495 | **7.68 Mcps TDD option** | 783d? | 2004-09-15 A | 2007-09-14 A | 100% |  | 2004-09-15 | 2007-09-14 | 783d? |  |  | RP | 24496h | 24496h | VHCRTDD | IPwireless | Martin Beale (mbeale@ipwireless.com) | Rel-7 |  | RP-060684 |  |  |
| 1536 | 495.1 | VHCRTDD: Stage 2 | 391d? | 2004-09-15 A | 2006-03-15 A | 100% |  | 2004-09-15 | 2006-03-15 | 391d? |  | finish no earlier than 2006-03-15 | R1 | 3128h | 3128h | VHCRTDD-Stage2 | IPwireless | Martin Beale (mbeale@ipwireless.com) | Rel-7 | Patrick | RP-060684 |  |  |
| 1537 | 495.2 | VHCRTDD: Physical Layer | 391d? | 2004-09-15 A | 2006-03-15 A | 100% |  | 2004-09-15 | 2006-03-15 | 391d? |  | finish no earlier than 2006-03-15 | R1 | 3128h | 3128h | VHCRTDD-Phys | IPwireless | Martin Beale (mbeale@ipwireless.com) | Rel-7 | Patrick | RP-060684 |  |  |
| 1538 | 495.3 | VHCRTDD: Layer 2 and layer 3 protocol aspects | 391d? | 2004-09-15 A | 2006-03-15 A | 100% |  | 2004-09-15 | 2006-03-15 | 391d? |  | finish no earlier than 2006-03-15 | R2 | 3128h | 3128h | VHCRTDD-L23 | IPwireless | drichards@ipwireless.com | Rel-7 | Joern | RP-060684 |  |  |
| 1539 | 495.4 | VHCRTDD: UTRAN Iub/Iur Protocol Aspects | 391d? | 2004-09-15 A | 2006-03-15 A | 100% |  | 2004-09-15 | 2006-03-15 | 391d? |  | finish no earlier than 2006-03-15 | R3 | 3128h | 3128h | VHCRTDD-IurIub | IPwireless | Peter Legg (plegg@ipwireless.com) | Rel-7 | Juha | RP-060684 |  |  |
| 1540 | 495.5 | VHCRTDD: RF Radio Transmission/ Reception, System Performance Requirements and Conformance Testing | 457d? | 2004-09-15 A | 2006-06-15 A | 100% |  | 2004-09-15 | 2006-06-15 | 457d? |  | finish no earlier than 2006-06-15 | R4 | 3656h | 3656h | VHCRTDD-RF | IPwireless | Shin Horng Wong (shwong@ipwireless.com) | Rel-7 | Issam | RP-060684 |  |  |
| 1541 | 495.6 | Conformance Test Aspects - 7.68 Mcps TDD | 258d? | 2006-09-20 A | 2007-09-14 A | 100% |  | 2006-09-20 | 2007-09-14 | 258d? |  | finish no earlier than 2007-09-10 | R5 | 2064h | 2064h | VHCRTDD-UEConTest | IPWireless | tspeight@ipwireless.com | Rel-7 | Ingbert | RP-070307 |  |  |
| 1542 | 496 | **3.84 Mcps TDD Enhanced Uplink** | 394d? | 2005-03-15 A | 2006-09-15 A | 100% |  | 2005-03-15 | 2006-09-15 | 394d? |  |  | RP | 18384h | 18384h | EDCHTDD | IPwireless | nanderson@ipwireless.com | Rel-7 |  | RP-060462 |  |  |
| 1543 | 496.1 | EDCHTDD: Stage 2 | 328d? | 2005-03-15 A | 2006-06-15 A | 100% |  | 2005-03-15 | 2006-06-15 | 328d? |  | finish no earlier than 2006-06-15 | R2 | 2624h | 2624h | EDCHTDD-Stage2 | IPwireless | nanderson@ipwireless.com | Rel-7 | Joern | RP-060462 |  |  |
| 1544 | 496.2 | EDCHTDD: Physical Layer | 394d? | 2005-03-15 A | 2006-09-15 A | 100% |  | 2005-03-15 | 2006-09-15 | 394d? |  | finish no earlier than 2006-09-15 | R1 | 3152h | 3152h | EDCHTDD-Phys | IPwireless | nanderson@ipwireless.com | Rel-7 | Patrick | RP-060462 |  |  |
| 1545 | 496.3 | EDCHTDD: Layer 2 and 3 Protocol Aspects | 394d? | 2005-03-15 A | 2006-09-15 A | 100% |  | 2005-03-15 | 2006-09-15 | 394d? |  | finish no earlier than 2006-09-15 | R2 | 3152h | 3152h | EDCHTDD-L23 | IPwireless | drichards@ipwireless.com | Rel-7 | Joern | RP-060462 |  |  |
| 1546 | 496.4 | EDCHTDD: UTRAN Iub/Iur Protocol Aspects | 394d? | 2005-03-15 A | 2006-09-15 A | 100% |  | 2005-03-15 | 2006-09-15 | 394d? |  | finish no earlier than 2006-09-15 | R3 | 3152h | 3152h | EDCHTDD-IurIub | Interdigital | jim.miller@interdigital.com | Rel-7 | Juha | RP-060462 |  |  |
| 1547 | 496.5 | EDCHTDD: RF Radio Transmission/ Reception, System Performance Requirements and Conformance Testing | 394d? | 2005-03-15 A | 2006-09-15 A | 100% |  | 2005-03-15 | 2006-09-15 | 394d? |  | finish no earlier than 2006-09-15 | R4 | 3152h | 3152h | EDCHTDD-RF | IPwireless | Shin Horng Wong (shwong@ipwireless.com) | Rel-7 | Issam | RP-060462 |  |  |
| 1548 | 497 | **1.28 Mcps TDD Enhanced Uplink** | 653d? | 2006-03-15 A | 2008-09-12 A | 100% |  | 2006-03-15 | 2008-09-12 | 653d? |  |  | RP | 14760h | 14760h | LCRTDD-EDCH | CATT | Haijing Hu | Rel-7 |  | RP-070296 |  |  |
| 1549 | 497.1 | 1.28 Mcps TDD Enhanced Uplink: Physical Layer | 262d? | 2006-03-15 A | 2007-03-15 A | 100% |  | 2006-03-15 | 2007-03-15 | 262d? |  | finish no earlier than 2007-03-15 | R1 | 2096h | 2096h | LCRTDD-EDCH-Phys | CATT | Ke Wang | Rel-7 | Patrick | RP-070038 |  |  |
| 1550 | 497.2 | 1.28 Mcps TDD Enhanced Uplink: Layer 2 and 3 Protocol Aspects | 262d? | 2006-03-15 A | 2007-03-15 A | 100% |  | 2006-03-15 | 2007-03-15 | 262d? |  | finish no earlier than 2007-03-15 | R2 | 2096h | 2096h | LCRTDD-EDCH-L23 | CATT | Haiyang Quan | Rel-7 | Joern | RP-070038 |  |  |
| 1551 | 497.3 | 1.28 Mcps TDD Enhanced Uplink: UTRAN Iub/Iur Protocol Aspects | 262d? | 2006-03-15 A | 2007-03-15 A | 100% |  | 2006-03-15 | 2007-03-15 | 262d? |  | finish no earlier than 2007-03-15 | R3 | 2096h | 2096h | LCRTDD-EDCH-IubIur | CATT | Yincheng Zhang | Rel-7 | Juha | RP-070038 |  |  |
| 1552 | 497.4 | 1.28 Mcps TDD Enhanced Uplink: RF Radio Transmission/ Reception, System Performance Requirements and Conformance Testing | 328d? | 2006-03-15 A | 2007-06-15 A | 100% |  | 2006-03-15 | 2007-06-15 | 328d? |  | finish no earlier than 2007-06-15 | R4 | 2624h | 2624h | LCRTDD-EDCH-RF | CATT | Yuexia Song | Rel-7 | Issam | RP-070296 |  |  |
| 1553 | 497.5 | 1.28 Mcps TDD Enhanced Uplink - UE Conformance Testing | 257d? | 2007-09-20 A | 2008-09-12 A | 100% |  | 2007-09-20 | 2008-09-12 | 257d? |  | finish no earlier than 2008-09-11 | R5 | 624h | 624h | LCRTDD-EDCH-UEConTest | CATT | chenxiaozhong@datangmobile.cn | Rel-7 | Ingbert | RP-080539 |  |  |
| 1554 | 498 | Conformance Test Aspects – Multiple Band and Multiple Frequency operation for LCR TDD | 321d? | 2010-09-17 A | 2011-12-09 | 40% | 192.6d? | 2010-09-17 | 2011-12-09 | 321d? | 330d | finish no earlier than 2011-12-09 | R5 | 2568h | 1027.2h | LCRTDD_MB_MF_UEConTest | CATR | Ms Jun Chen (chenjun@catr.cn) | Rel-7 | Ingbert | RP-110038 | PCG-25 | RP-49 |
| 1555 | 499 | MS Antenna Performance Evaluation Method and Requirements | 731d? | 2005-01-28 A | 2007-11-16 A | 100% |  | 2005-01-28 | 2007-11-16 | 731d? |  | finish no earlier than 2007-11-16 | GP | 5848h | 5848h | APEMR | TeliaSonera | Ulf.Tegth@teliasonera.com | Rel-7 | Paolo |  |  |  |

Notes:
- 1525: RP#35 completed
- 1526: RP#35 completed
- 1527: SP#36 completed / Text3: 32.642, 32.643, 32.645 – Align with RAN 25.466
- 1528: Linked to Feature UID_20029 (RANimp)
- 1529: RP#41 completed / Text3: 34.108, 34.122, 34.123-1, 34.123-2, 34.123-3
- 1530: RP#39 completed / Text3: 34.108, 34.121-1, 34.121-2, 34.123-1, 34.123-2, 34.123-3
- 1531: RP#40 completed / Text3: 34.108, 34.121-1, 34.121-2, 34.123-1, 34.123-2, 34.123-3
- 1532: RP#40 completed / Text3: 34.108, 34.123-1, 34.123-2, 34.123-3
- 1533: RP#40 completed / Text3: 34.108, 34.121-1, 34.121-2, 34.123-1, 34.123-2, 34.123-3
- 1534: RP#45 completed / Text3: 34.108, 34.123-1, 34.123-2, 34.123-3
- 1535: RP#31 completed
- 1536: RP#31 completed / Text3: 25.202
- 1537: RP#31 completed / Text3: 25.221, 25.222, 25.223, 25.224,25.225
- 1538: RP#31 completed / Text3: 25.301, 25.302, 25.305, 25.306, 25.321, 25.331
- 1539: RP#31 completed / Text3: 25.401, 25.420, 25.423, 25.425, 25.427, 25.430, 25.433, 25.435
- 1540: RP#32 completed / Text3: 25.102, 25.105, 25.123, 25.133, 25.142
- 1541: RP#37 completed / Text3: 34.108, 34.122, 34.123-1, 34.123-2, 34.123-3
- 1542: RP#33 completed
- 1543: RP#33 completed
- 1544: RP#33 completed / Text3: 25.201, 25.221,25.222, 25.223, 25.224, 25.225
- 1545: RP#33 completed / Text3: 25.301, 25.302, 25.306, 25.321, 25.331
- 1546: RP#33 completed / Text3: 25.401, 25.420, 25.423, 25.427, 25.430, 25.433, 25.435
- 1547: RP#33 completed / Text3: 25.102, 25.105, 25.123, 25.142
- 1548: RP#35 completed
- 1549: RP#35 completed / Text3: 25.201, 25.221, 25.222, 25.223, 25.224, 25.225
- 1550: RP#35 completed / Text3: 25.301, 25.302, 25.306, 25.321, 25.331
- 1551: RP#35 completed / Text3: 25.401, 25.420, 25.423, 25.425, 25.427, 25.430, 25.433, 25.435
- 1552: RP#36 completed / Text3: 25.102, 25.105, 25.123, 25.142
- 1553: RP#41 completed / Text3: 34.108, 34.122, 34.123-1/2/3
- 1554: Core specification was introduced via Rel-7 CR under TEI7 (RP#37 RP-070650) and via 2 Rel-8 work items: RInImp9-UMTS1880TDD and RInImp8-UMTS2300TDD. / Text3: UTRA 34.108, 34.123-1, 34.123-2, 34.123-3
- 1555: GP#36 completed for R7 / Text3: 25.914, 25.144, 45.005

| ID | WBS | Task | Type | Duration | Start | Finish | Complete | Baseline start | Baseline finish | Baseline duration | Constraint | Resources | Work | Actual work | Text1 | Text4 | Text5 | Text6 | Text8 | Text12 |
| --- | --- | --- | --- | --- | --- | --- | --- | --- | --- | --- | --- | --- | --- | --- | --- | --- | --- | --- | --- | --- |
| 1556 | 500 | **Lower 700 MHz Inclusion in the GERAN Specifications** |  | 390d? | 2005-01-03 A | 2006-06-30 A | 100% | 2005-01-03 | 2006-06-30 | 390d? |  | GP | 7632h | 7632h | GSM710 | UTC | dcotton@mtview.union-tel.com | Rel-7 | Paolo |  |
| 1557 | 500.1 | Inclusion of the 698 – 746 MHz band into GERAN core specifications |  | 129d? | 2005-01-03 A | 2005-06-30 A | 100% | 2005-01-03 | 2005-06-30 | 129d? | finish no earlier than 2005-06-30 | G1 | 1032h | 1032h | GSM710-core |  |  | Rel-7 | Paolo |  |
| 1558 | 500.2 | G1 aspects of GSM710 |  | 217.5d? | 2005-08-31 A | 2006-06-30 A | 100% | 2005-08-31 | 2006-06-30 | 217.5d? | finish no earlier than 2006-06-30 | G1 | 1740h | 1740h | GSM-710-test |  |  | Rel-7 | Paolo |  |
| 1559 | 500.3 | G3 aspects of GSM710 |  | 217.5d? | 2005-08-31 A | 2006-06-30 A | 100% | 2005-08-31 | 2006-06-30 | 217.5d? | finish no earlier than 2006-06-30 | G3new | 1740h | 1740h | GSM-710-test |  |  | Rel-7 | Ingbert |  |
| 1560 | 501 | **Support of Conversational Services in A/Gb mode via the PS domain** |  | 626d? | 2005-04-08 A | 2007-08-31 A | 100% | 2005-04-08 | 2007-08-31 | 626d? |  | GP | 15442.8h | 15442.8h | SCSAGB | Ericsson | gunnar.hedby@ericsson.com | Rel-7 | Paolo |  |
| 1561 | 501.1 | Minimise the transfer delay between the SGSN and the MS |  | 604.95d? | 2005-04-08 A | 2007-08-31 A | 100% | 2005-04-08 | 2007-08-31 | 604.95d? | finish no earlier than 2007-08-31 | GP | 4839.6h | 4839.6h | SCSAGB-MTD | Ericsson | gunnar.hedby@ericsson.com | Rel-7 | Paolo |  |
| 1562 | 501.2 | Definition of radio resource management functionality |  | 626d? | 2005-04-08 A | 2007-08-31 A | 100% | 2005-04-08 | 2007-08-31 | 626d? | finish no earlier than 2007-08-31 | G1 | 5008h | 5008h | SCSAGB-RRM | Ericsson | gunnar.hedby@ericsson.com | Rel-7 | Paolo |  |
| 1563 | 501.3 | Support of Conversational Services in A/Gb mode via the PS domain – RLC Non-Persistent mode |  | 101d? | 2006-06-30 A | 2006-11-17 A | 100% | 2006-06-30 | 2006-11-17 | 101d? | finish no earlier than 2006-11-17 | G2 | 808h | 808h | SCSAGB-RLCNP | Ericsson | gunnar.hedby@ericsson.com | Rel-7 | Gert |  |
| 1564 | 501.4 | Deleted- Radio Channel Support | milestone | 0d? | 2006-07-17 A | 2006-07-17 A | 100% | 2006-07-17 | 2006-07-17 | 0d? | start no earlier than 2006-07-17 | G2 |  |  | SCSAGB-RCHS | Ericsson | gunnar.hedby@ericsson.com | Rel-7 | Gert | SP-32 |
| 1565 | 501.5 | Deleted- Modifications to FLO | milestone | 0d? | 2006-07-17 A | 2006-07-17 A | 100% | 2006-07-17 | 2006-07-17 | 0d? | start no earlier than 2006-07-17 | G2 |  |  | SCSAGB-FLO | Ericsson | gunnar.hedby@ericsson.com | Rel-7 | Gert | SP-32 |
| 1566 | 502 | **Addition of new frequency band to GSM (T-GSM810)** |  | 626d? | 2005-04-08 A | 2007-08-31 A | 100% | 2005-04-08 | 2007-08-31 | 626d? |  | GP | 12112h | 12112h | TGSM810 | Huawei | chende@huawei.com | Rel-7 | Paolo |  |
| 1567 | 502.1 | Changes to core specification |  | 106d? | 2005-04-08 A | 2005-09-02 A | 100% | 2005-04-08 | 2005-09-02 | 106d? | finish no earlier than 2005-09-02 | GP | 848h | 848h | TGSM810-Core | Huawei | chende@huawei.com | Rel-7 | Paolo |  |
| 1568 | 502.2 | Changes to MS testing specification |  | 626d? | 2005-04-08 A | 2007-08-31 A | 100% | 2005-04-08 | 2007-08-31 | 626d? | finish no earlier than 2007-08-31 | G3new | 5008h | 5008h | TGSM810-MStest | Huawei | chende@huawei.com | Rel-7 | Ingbert |  |
| 1569 | 502.3 | Changes to BTS testing specification |  | 156d? | 2005-04-08 A | 2005-11-11 A | 100% | 2005-04-08 | 2005-11-11 | 156d? | finish no earlier than 2005-11-11 | G1 | 1248h | 1248h | TGSM810-BTStest | Huawei | chende@huawei.com | Rel-7 | Paolo |  |
| 1570 | 503 | **Handover of dedicated and shared resources while in Dual Transfer Mode** |  | 421d? | 2005-04-08 A | 2006-11-17 A | 100% | 2005-04-08 | 2006-11-17 | 421d? |  | GP | 12672h | 12672h | HODSRDTM | Nokia | rami.vaittinen@nokia.com | Rel-7 | Paolo |  |
| 1571 | 503.1 | Handover of dedicated and shared resources while in Dual Transfer Mode |  | 321d? | 2005-04-08 A | 2006-06-30 A | 100% | 2005-04-08 | 2006-06-30 | 321d? | finish no earlier than 2006-06-30 | G2 | 2568h | 2568h | HODSRDTM-G2 | Nokia | rami.vaittinen@nokia.com | Rel-7 | Gert |  |
| 1572 | 503.2 | Deleted - MS Conformance Testing |  | 421d? | 2005-04-08 A | 2006-11-17 A | 100% | 2005-04-08 | 2006-11-17 | 421d? | finish no earlier than 2006-11-17 | G3new | 3368h | 3368h | HODSRDTM-Mstest | Nokia | rami.vaittinen@nokia.com | Rel-7 | Ingbert | GP-32 |
| 1573 | 503.3 | Deleted - BTS conformance testing |  | 421d? | 2005-04-08 A | 2006-11-17 A | 100% | 2005-04-08 | 2006-11-17 | 421d? | finish no earlier than 2006-11-17 | G1 | 3368h | 3368h | HODSRDTM-BTStest | Nokia | rami.vaittinen@nokia.com | Rel-7 | Paolo | GP-32 |
| 1574 | 504 | **Mobile Station Receive Diversity (DARP Phase II)** |  | 526d? | 2005-11-11 A | 2007-11-16 A | 100% | 2005-11-11 | 2007-11-16 | 526d? |  | GP | 16360h | 16360h | MSRD2 | Nokia | kent.pedersen@nokia.com | Rel-7 | Paolo |  |
| 1575 | 504.1 | Performance Requirements for Mobile Station Receive Diversity, DARP Phase II |  | 331d? | 2005-11-11 A | 2007-02-16 A | 100% | 2005-11-11 | 2007-02-16 | 331d? | finish no earlier than 2007-02-16 | GP | 2648h | 2648h | MSRD2-PerfReq | Nokia | kent.pedersen@nokia.com | Rel-7 | Paolo |  |
| 1576 | 504.2 | Capability signalling of Mobile Station Receive Diversity, DARP Phase II |  | 331d? | 2005-11-11 A | 2007-02-16 A | 100% | 2005-11-11 | 2007-02-16 | 331d? | finish no earlier than 2007-02-16 | GP | 2648h | 2648h | MSRD2-CapSig | Nokia | kent.pedersen@nokia.com | Rel-7 | Paolo |  |
| 1577 | 504.3 | Test Scenarios for Mobile Station Receive Diversity, DARP Phase II |  | 331d? | 2005-11-11 A | 2007-02-16 A | 100% | 2005-11-11 | 2007-02-16 | 331d? | finish no earlier than 2007-02-16 | GP | 2648h | 2648h | MSRD2-TestSc | Nokia | kent.pedersen@nokia.com | Rel-7 | Paolo |  |
| 1578 | 504.4 | MS conformance test of DARP Phase II (MSRD) |  | 526d? | 2005-11-11 A | 2007-11-16 A | 100% | 2005-11-11 | 2007-11-16 | 526d? | finish no earlier than 2007-11-16 | GP | 4208h | 4208h | MSRD2-Msconf | Nokia | kent.pedersen@nokia.com | Rel-7 | Ingbert |  |
| 1579 | 505 | **Downlink Dual Carrier** |  | 947d? | 2006-01-20 A | 2009-09-04 A | 100% | 2006-01-20 | 2009-09-04 | 947d? |  | GP | 15446.6h | 15446.6h | GDCDL | Nokia Siemens Networks | leonardo.provvedi@roke.co.uk | Rel-7 | Paolo |  |
| 1580 | 505.1 | Downlink Dual Carrier Stage 2 |  | 116d? | 2006-01-20 A | 2006-06-30 A | 100% | 2006-01-20 | 2006-06-30 | 116d? | finish no earlier than 2006-06-30 | G1 | 928h | 928h | GDCDL-Stage2 | Nokia Siemens Networks | leonardo.provvedi@roke.co.uk | Rel-7 | Paolo |  |
| 1581 | 505.2 | Downlink Dual Carrier Stage 3 |  | 421d? | 2006-01-20 A | 2007-08-31 A | 100% | 2006-01-20 | 2007-08-31 | 421d? | finish no earlier than 2007-08-31 | G1 | 3368h | 3368h | GDCDL-Stage2 | Nokia Siemens Networks | leonardo.provvedi@roke.co.uk | Rel-7 | Paolo |  |
| 1582 | 505.3 | Downlink Dual Carrier – MS Conformance Test |  | 446.82d? | 2006-01-20 A | 2009-09-04 A | 100% | 2006-01-20 | 2009-09-04 | 446.82d? | finish no earlier than 2009-09-04 | G3new | 3574.6h | 3574.6h | GDCDL-MStest | Nokia Siemens Networks | leonardo.provvedi@roke.co.uk | Rel-7 | Ingbert |  |
| 1583 | 506 | Support of SIGTRAN in GERAN |  | 116d? | 2006-01-20 A | 2006-06-30 A | 100% | 2006-01-20 | 2006-06-30 | 116d? | finish no earlier than 2006-06-30 | GP | 928h | 928h | GSIGT | Ericsson | peter.ostrup@ericsson.com | Rel-7 | Ingbert |  |

Notes:
- 1556: - / Text3: 24.008, 43.022, 44.018, 44.118, 45, 001, 45.005, 51.010, 51.021
- 1557: Completed / Text3: 24.008, 43.022, 44.018, 44.118, 45, 001, 45.005,
- 1558: - / Text3: 51.021
- 1559: - / Text3: 51.010
- 1560: Originally started Nov. 2003 as GP-030443
- 1561: -
- 1562: -
- 1563: - / Text3: 43.955, 43.064, 44.060, 45.001, 45.002, 45.003, 45.005, 45.010, 51.010, 51.021
- 1564: -
- 1565: -
- 1566: - / Text3: 45.005, 45.050, 24.008, 45.008, 45.001, 43.022, 43.030, 44.018, 44.060, 51.010-1, 51.021
- 1567: - / Text3: 45.005, 45.050, 24.008, 45.008, 45.001, 43.022, 43.030, 44.018, 44.060
- 1568: - / Text3: 51010-1
- 1569: - / Text3: 51021
- 1570: GP#30 completed. Started at GP#24
- 1571: GP#30 completed / Text3: 43.055, 44.018, 44.060
- 1572: Stopped, no work done. 12/2008 Marked as stopped ("deleted") / Text3: 51-010
- 1573: Stopped, no work done. 12/2008 Marked as stopped ("deleted") / Text3: 51.026
- 1574: GP#36 completed
- 1575: GP#33 completed / Text3: 45.005
- 1576: GP#33 completed / Text3: 24.008
- 1577: GP#33 completed / Text3: 45.005
- 1578: GP#36 completed / Text3: 51.010
- 1579: GP#35 completed
- 1580: GP#30 completed / Text3: 43.055, 43.064
- 1581: GP#35 completed / Text3: 24.008, 44.018, 44.060, 45.001, 45.002, 45.005, 45.008
- 1582: GP#43 completed / Text3: 51.010
- 1583: GP#30 completed / Text3: 48.001, 48.006, 43.059, 49.031

| ID | WBS | Task | Type | Duration | Start | Finish | Complete | Remaining | Baseline start | Baseline finish | Baseline duration | Total slack | Constraint | Resources | Work | Actual work | Text1 | Text4 | Text5 | Text6 | Text8 | Text12 |
| --- | --- | --- | --- | --- | --- | --- | --- | --- | --- | --- | --- | --- | --- | --- | --- | --- | --- | --- | --- | --- | --- | --- |
| 1584 | 507 | **Latency Reductions** |  | 306d? | 2006-06-30 A | 2007-08-31 A | 100% |  | 2006-06-30 | 2007-08-31 | 306d? |  |  | GP | 7344h | 7344h | LATRED | Ericsson | Hakan.Persson@Ericsson.com | Rel-7 | Paolo |  |
| 1585 | 507.1 | Improved Ack/Nack reporting |  | 306d? | 2006-06-30 A | 2007-08-31 A | 100% |  | 2006-06-30 | 2007-08-31 | 306d? |  | finish no earlier than 2007-08-31 | G2 | 2448h | 2448h | LATRED-ACKNAR | Ericsson | Hakan.Persson@Ericsson.com | Rel-7 | Gert |  |
| 1586 | 507.2 | Reduced TTI |  | 306d? | 2006-06-30 A | 2007-08-31 A | 100% |  | 2006-06-30 | 2007-08-31 | 306d? |  | finish no earlier than 2007-08-31 | G2 | 2448h | 2448h | LATRED-REDTTI | Ericsson | Hakan.Persson@Ericsson.com | Rel-7 | Gert |  |
| 1587 | 508 | PS Handover between GERAN/UTRAN mode and GAN Mode |  | 166d? | 2006-06-30 A | 2007-02-16 A | 100% |  | 2006-06-30 | 2007-02-16 | 166d? |  | finish no earlier than 2007-02-16 | G2 | 1328h | 1328h | GUGAN | Ericsson | John.Diachina@Ericsson.com | Rel-7 | Gert |  |
| 1588 | 509 | **Higher Uplink performance for GERAN Evolution** |  | 1227d? | 2006-09-08 A | 2011-05-20 | 88% | 145.07d? | 2006-09-08 | 2011-05-20 | 1227d? | 475d |  | GP | 37184h | 32786.8h | HUGE | Nokia Siemens Networks, Ericsson | eddie.riddington@nokia.com, stefan.g.eriksson@ericsson.com | Rel-7 | Paolo |  |
| 1589 | 509.1 | Stage 2 for HUGE |  | 261d? | 2006-09-08 A | 2007-09-07 A | 100% |  | 2006-09-08 | 2007-09-07 | 261d? |  | finish no earlier than 2007-09-07 | G1 | 2088h | 2088h | HUGE-Stage2 | Nokia Siemens Networks, Ericsson | eddie.riddington@nokia.com, stefan.g.eriksson@ericsson.com | Rel-7 | Paolo |  |
| 1590 | 509.2 | Layer 1 Support for HUGE |  | 381d? | 2006-09-08 A | 2008-02-22 A | 100% |  | 2006-09-08 | 2008-02-22 | 381d? |  | finish no earlier than 2008-02-22 | G1 | 3048h | 3048h | HUGE-Layer1 | Nokia Siemens Networks, Ericsson | eddie.riddington@nokia.com, stefan.g.eriksson@ericsson.com | Rel-7 | Paolo |  |
| 1591 | 509.3 | Layer 2/3 Support for HUGE |  | 256d? | 2006-09-08 A | 2007-08-31 A | 100% |  | 2006-09-08 | 2007-08-31 | 256d? |  | finish no earlier than 2007-08-31 | G2 | 2048h | 2048h | HUGE-Layer23 | Nokia Siemens Networks, Ericsson | eddie.riddington@nokia.com, stefan.g.eriksson@ericsson.com | Rel-7 | Gert |  |
| 1592 | 509.4 | Performance requirements for HUGE |  | 516d? | 2006-09-08 A | 2008-08-29 A | 100% |  | 2006-09-08 | 2008-08-29 | 516d? |  | finish no earlier than 2008-08-29 | G1 | 4128h | 4128h | HUGE-Perfreq | Nokia Siemens Networks, Ericsson | eddie.riddington@nokia.com, stefan.g.eriksson@ericsson.com | Rel-7 | Paolo |  |
| 1593 | 509.5 | BTS Conformance Test for HUGE |  | 782d? | 2006-09-08 A | 2009-09-04 A | 100% |  | 2006-09-08 | 2009-09-04 | 782d? |  | finish no earlier than 2009-09-04 | G1 | 6248h | 6248h | HUGE-BTStest | Nokia Siemens Networks, Ericsson | eddie.riddington@nokia.com, stefan.g.eriksson@ericsson.com | Rel-7 | Paolo |  |
| 1594 | 509.6 | MS Conformance Test for HUGE |  | 1226d? | 2006-09-08 A | 2011-05-20 | 67% | 404.58d? | 2006-09-08 | 2011-05-20 | 1226d? | 475d | finish no earlier than 2011-05-20 | G3new | 9808h | 6571.36h | HUGE-Mstest | Nokia Siemens Networks, Ericsson | eddie.riddington@nokia.com, stefan.g.eriksson@ericsson.com | Rel-7 | Ingbert |  |
| 1595 | 510 | **REduced symbol Duration, Higher Order modulation and Turbo coding (RED HOT) for downlink** |  | 1177d? | 2006-11-17 A | 2011-05-20 | 83% | 205.57d? | 2006-11-17 | 2011-05-20 | 1177d? | 475d |  | GP | 28808h | 23776.6h | REDHOT | Ericsson, Nokia Siemens Networks, Marvell | stefan.g.eriksson@ericsson.com | Rel-7 | Paolo |  |
| 1596 | 510.1 | Stage 2 for REDHOT |  | 206d? | 2006-11-17 A | 2007-08-31 A | 100% |  | 2006-11-17 | 2007-08-31 | 206d? |  | finish no earlier than 2007-08-31 | G1 | 1648h | 1648h | REDHOT-Stage2 | Ericsson, Nokia Siemens Networks, Marvell | stefan.g.eriksson@ericsson.com | Rel-7 | Paolo |  |
| 1597 | 510.2 | Stage 3 for REDHOT |  | 391d? | 2006-11-17 A | 2008-05-16 A | 100% |  | 2006-11-17 | 2008-05-16 | 391d? |  | finish no earlier than 2008-05-16 | G1 | 3128h | 3128h | REDHOT-Stage3 | Ericsson, Nokia Siemens Networks, Marvell | stefan.g.eriksson@ericsson.com | Rel-7 | Paolo |  |
| 1598 | 510.3 | BTS Conformance Tests for REDHOT |  | 651d? | 2006-11-17 A | 2009-05-15 A | 100% |  | 2006-11-17 | 2009-05-15 | 651d? |  | finish no earlier than 2009-05-15 | G1 | 5208h | 5208h | REDHOT-BTStest | Ericsson, Nokia Siemens Networks, Marvell | stefan.g.eriksson@ericsson.com | Rel-7 | Paolo |  |
| 1599 | 510.4 | MS Conformance Tests for REDHOT |  | 1176d? | 2006-11-17 A | 2011-05-20 | 64% | 423.36d? | 2006-11-17 | 2011-05-20 | 1176d? | 475d | finish no earlier than 2011-05-20 | G3new | 9408h | 6021.12h | REDHOT-Mstest | Ericsson, Nokia Siemens Networks, Marvell | stefan.g.eriksson@ericsson.com | Rel-7 | Ingbert |  |
| 1600 | 511 | (Small) Technical Enhancements and Improvements for Rel-7 | milestone | 0d? | 2007-03-26 A | 2007-03-26 A | 100% |  | 2007-03-26 | 2007-03-26 | 0d? |  | start no earlier than 2007-03-26 | All |  |  | TEI7 |  |  | Rel-7 | All |  |
| 1601 | 512 | Test - (Small) Technical Enhancements and Improvements for Rel-7 |  | 389d? | 2006-06-02 A | 2007-11-28 A | 100% |  | 2006-06-02 | 2007-11-28 | 389d? |  | finish no earlier than 2010-06-04 | R5 | 3112h | 3112h | TEI7_Test |  |  | Rel-7 | Ingbert |  |
| 1602 | 513 | **Deleted - PS domain and IMS support for IMS Emergency sessions** |  | 63.69d? | 2006-06-23 A | 2006-09-21 A | 100% |  | 2006-06-23 | 2006-09-21 | 63.69d? |  |  | S2 |  |  | IMS-EMER | Nokia | curt.c.wong@nokia.com | Rel-7 | Maurice | SP-30 |
| 1603 | 513.1 | Deleted - IMS aspects to support IMS Emergency sessions | milestone | 0d? | 2006-06-23 A | 2006-09-21 A | 100% |  | 2006-06-23 | 2006-09-21 | 0d? |  | start no earlier than 2006-06-23 | S2 |  |  | IMS-EMER | Nokia | curt.c.wong@nokia.com | Rel-7 | Maurice | SP-30 |
| 1604 | 513.2 | Deleted - PS domain aspects to support IMS Emergency sessions | milestone | 0d? | 2006-06-23 A | 2006-09-21 A | 100% |  | 2006-06-23 | 2006-09-21 | 0d? |  | start no earlier than 2006-06-23 | S2 |  |  | IMS-EMER | Nokia | curt.c.wong@nokia.com | Rel-7 | Maurice | SP-30 |
| 1605 | 16.7 | **Deleted - IMS Local services** |  | 0d? | 2006-01-06 A | 2006-01-06 A | 100% |  | 2006-01-06 | 2006-01-06 | 0d? |  |  | S2 |  |  | IMSLocal |  |  | Rel-7 | Maurice | SP-28 |
| 1606 | 16.7.1 | Deleted - Stage 2 | milestone | 0d | 2006-01-06 A | 2006-01-06 A | 100% |  | 2006-01-06 | 2006-01-06 | 0d |  | start no earlier than 2006-01-06 | S2 |  |  | IMSLocal |  |  | Rel-7 | Maurice | SP-26 |
| 1607 | 514.2 | Deleted - Stage 3 for IMS Local services | milestone | 0d? | 2006-01-06 A | 2006-01-06 A | 100% |  | 2006-01-06 | 2006-01-06 | 0d? |  | finish no earlier than 2006-01-06 | C1 |  |  | IMSLocal | Lucent | Keith Drage (drage@alcatel-lucent.com) | Rel-7 | Frederic | SP-25 |
| 1608 | 515 | Deleted - IMS Phase 3 | milestone | 0d? | 2006-01-06 A | 2006-01-06 A | 100% |  | 2006-01-06 | 2006-01-06 | 0d? |  | start no earlier than 2006-01-06 | S2 |  |  |  |  |  | Rel-7 | Maurice | SP-25 |
| 1609 | 516 | Deleted - Improvements of Radio Interface | milestone | 0d? | 2004-09-15 A | 2004-09-15 A | 100% |  | 2004-09-15 | 2004-09-15 | 0d? |  | start no earlier than 2004-09-15 | RP |  |  | RInImp |  |  | Rel-7 | Issam | SP-24 |
| 1610 | 517 | Deleted: Generic User Profile Phase 2 | milestone | 0d | 2005-08-08 A | 2006-06-30 A | 100% |  | 2005-08-08 | 2006-06-30 | 0d |  |  | C4 |  |  |  |  |  | Rel-7 | Kimmo | SP-27 |
| 1611 | 30.4 | Deleted - Stage 3 - Common objects | milestone | 0d | 2005-08-08 A | 2006-06-30 A | 100% |  | 2005-08-08 | 2006-06-30 | 0d |  | finish no earlier than 2006-06-30 | C4 |  |  |  |  |  | Rel-7 | Kimmo | SP-27 |
| 1612 | 519 | Release 7 Studies |  | 841d? | 2004-06-28 A | 2007-09-17 A | 100% |  | 2004-06-28 | 2007-09-17 | 841d? |  |  | CP,GP,RP,SP | 6728h | 6728h |  |  |  | Rel-7 | All |  |
| 1613 | 520 | Study on Multimedia Telephony Capabilities for IMS |  | 276d? | 2005-07-11 A | 2006-07-31 A | 100% |  | 2005-07-11 | 2006-07-31 | 276d? |  |  | S1 | 2145.6h | 2145.6h | MITE | Ericsson | peter.bleckert@ericsson.com | Rel-7 | Alain |  |
| 1614 | 521 | Study on Behaviour of Multi system UEs |  | 384d? | 2004-06-28 A | 2005-12-15 A | 100% |  | 2004-06-28 | 2005-12-15 | 384d? |  | start no earlier than 2004-06-28 | S1 | 3072h | 3072h | BMSU | Qualcomm | dwilliams@qualcomm.com | Rel-7 | Alain |  |
| 1615 | 522 | Study on Combining CS calls and IMS sessions |  | 189d? | 2004-06-28 A | 2005-03-17 A | 100% |  | 2004-06-28 | 2005-03-17 | 189d? |  | start no earlier than 2004-06-28 | S1 | 1512h | 1512h | IRTSD-CS_IMS | TeliaSonera | robert.frank@teliasonera.com | Rel-7 | Alain |  |
| 1616 | 523 | Study on All-IP Network |  | 188d? | 2004-06-28 A | 2005-03-16 A | 100% |  | 2004-06-28 | 2005-03-16 | 188d? |  | start no earlier than 2004-06-28 | S1 | 1504h | 1504h | FS_AIPN | NTT DoCoMo | Shin-ichi Isobe (isobes@nttdocomo.co.jp) | Rel-7 | Alain |  |
| 1617 | 524 | Study on Videotelephony teleservice |  | 231d? | 2005-03-01 A | 2006-01-17 A | 100% |  | 2005-03-01 | 2006-01-17 | 231d? |  |  | S1 | 1848h | 1848h | VidTel | T-Mobile | michael.kurz@t-mobile.at | Rel-7 | Alain |  |
| 1618 | 525 | Study on Network Selection Principles |  | 193d? | 2005-03-15 A | 2005-12-08 A | 100% |  | 2005-03-15 | 2005-12-08 | 193d? |  |  | S1 | 1544h | 1544h | NetSel | O2 | chris.friel@O2.com | Rel-7 | Alain |  |
| 1619 | 526 | Study on Multimedia Priority Service |  | 851d? | 2003-03-28 A | 2006-06-30 A | 100% |  | 2003-03-28 | 2006-06-30 | 851d? |  | finish no earlier than 2005-12-16 | S1 | 6808h | 6808h | PRIOR-MM | Telcordia | James Garrahan (jgarraha@telcordia.com) | Rel-7 | Alain |  |
| 1620 | 527 | Study on Transferring of emergency Call data |  | 190d? | 2005-07-11 A | 2006-03-31 A | 100% |  | 2005-07-11 | 2006-03-31 | 190d? |  | finish no earlier than 2005-12-08 | S1 | 1520h | 1520h | eCALL | Motorola | jian.j.wu@motorola.com | Rel-7 | Alain |  |
| 1621 | 528 | Study on Enhancement of E2E QoS |  | 281.4d? | 2004-06-28 A | 2005-09-15 A | 100% |  | 2004-06-28 | 2005-09-15 | 281.4d? |  | finish no earlier than 2005-12-01 | S2 | 2251.2h | 2251.2h | QoS7 | Huawei | Robert Jaksa | Rel-7 | Maurice |  |
| 1622 | 529 | Study on SOAP/HTTP IRP Solution Sets |  | 330d? | 2005-09-02 A | 2006-12-07 A | 100% |  | 2005-09-02 | 2006-12-07 | 330d? |  | finish no earlier than 2006-12-07 | S5 | 2640h | 2640h | OAM7-NIM-XML | Nortel | Suzèle Lariven (lariven@nortel.com) | Rel-7 | Dionisio |  |
| 1623 | 530 | Study on Itf-N Implementation Conformance Statement (ICS) template |  | 400d? | 2005-09-02 A | 2007-03-15 A | 100% |  | 2005-09-02 | 2007-03-15 | 400d? |  | finish no earlier than 2007-03-15 | S5 | 3200h | 3200h | OAM7-NIM-ICS | China Mobile | Li Yewen (liyewen@chinamobile.com) | Rel-7 | Dionisio |  |
| 1624 | 531 | Study on IRP Information Model |  | 400d? | 2005-09-02 A | 2007-03-15 A | 100% |  | 2005-09-02 | 2007-03-15 | 400d? |  | finish no earlier than 2007-03-15 | S5 | 3200h | 3200h | OAM7-NIM-IM | Motorola | trevor.pirt@motorola.com | Rel-7 | Dionisio |  |
| 1625 | 532 | Study on Bandwidth Saving at Nb Interface with IP transport |  | 261d? | 2006-03-10 A | 2007-03-09 A | 100% |  | 2006-03-10 | 2007-03-09 | 261d? |  | finish no earlier than 2007-03-09 | C3 | 2088h | 2088h | BSNbIP | Siemens | Thomas.Belling@siemens.com | Rel-7 | Jiwan |  |
| 1626 | 533 | Study on Routeing of MT-SMS via the HPLMN |  | 301d? | 2005-10-07 A | 2006-12-01 A | 100% |  | 2005-10-07 | 2006-12-01 | 301d? |  | finish no earlier than 2006-12-01 | C4 | 2408h | 2408h | SMS7 | Vodafone | Nick.Russell@vodafone.com | Rel-7 | Kimmo |  |
| 1627 | 534 | Study on the TCAPsec Gateway concept |  | 96d? | 2005-10-28 A | 2006-03-10 A | 100% |  | 2005-10-28 | 2006-03-10 | 96d? |  | finish no earlier than 2006-03-10 | C4 | 768h | 768h | SEC7-TCAP | Siemens | Ulrich.wiehe@gksag.de | Rel-7 | Kimmo |  |
| 1628 | 535 | Study on using M2PA in 3GPP network |  | 318d? | 2006-03-22 A | 2007-06-08 A | 100% |  | 2006-03-22 | 2007-06-08 | 318d? |  | finish no earlier than 2007-06-08 | C4 | 2544h | 2544h | FS-M2PA | China Mobile | zhaoyuyi@chinamobile.com | Rel-7 | Kimmo |  |

Notes:
- 1584: GP#35 completed / Text3: 45.001, 45.002, 45.003, 45.005, 45.010, 43.055, 43.064, 44.060, 51.010-1, 51.021
- 1585: GP#35 completed / Text3: 45.001, 45.002, 45.003, 45.005, 45.010, 43.055, 43.064, 44.060, 51.010-1, 51.021
- 1586: GP#35 completed / Text3: 45.001, 45.002, 45.003, 45.005, 45.010, 43.055, 43.064, 44.060, 51.010-1, 51.021
- 1587: GP#33 completed / Text3: 43.318, 44.318, 43.129, 25.306, 24.008, 44.060, 25.331, 51.010
- 1588: -
- 1589: GP#35 completed / Text3: 43.055, 43.064
- 1590: GP#37 completed / Text3: 45.001, 45.002, 45.003, 45.004, 45.008
- 1591: GP#35 completed / Text3: 24.008, 44.018, 44.060
- 1592: GP#39 completed / Text3: 45.005
- 1593: GP#43 completed / Text3: 51.021
- 1594: GP#49 completion 03/11=>05/11 / Text3: 51.010
- 1595: GP#38 completed. SP#42 split core from testing specification work.
- 1596: GP#35 completed / Text3: 43.055, 43.064
- 1597: GP#38 completed / Text3: 24.008, 44.018, 44.060, 45.001, 45.002, 45.003, 45.004, 45.005, 45.008
- 1598: GP#42 completed / Text3: 51.021
- 1599: GP#49 completion 03/11=>05/11 / Text3: 51.010
- 1600: - / Text3: CP-070260
- 1601: -
- 1602: Approved at SP#29 / Text3: 23.867, 23.abc, 23.060, 23.002, 23.271
- 1603: Approved at SP#29 / Text3: 23.867, 23.abc, 23.060, 23.002, 23.271
- 1604: Approved at SP#29 / Text3: 23.867, 23.abc, 23.060, 23.002, 23.271
- 1605: - / Text3: 23.228
- 1606: DAB - Not yet required in SA2 as it exists in previous releases
- 1607: -
- 1608: -
- 1609: Stage 2 description of Interim conclusion
- 1610: Created at TSG#27 by A. Sultan because of the move to Rel-7 of "Common Objects".
- 1611: No progress in CN4#26. This have to be moved to Rel-7. It was deleted from WID / Text3: 24.241
- 1612: -
- 1613: Spin-off Feature UID_7038 (MTSI) / Text3: 22.973
- 1614: - / Text3: 22.936
- 1615: - / Text3: 22.979
- 1616: 07/08 Moved to Rel-7 as Study out of stopped Rel-8 Feature UID_31067 All-IP Network (AIPN) / Text3: 22.978
- 1617: - / Text3: 22.903
- 1618: Spin-off Feature Network selection enhancements (NSP-CR) UID_7041 / Text3: 22.811
- 1619: Spin-off Feature PRIOR UID_340044 / Text3: 22.953
- 1620: - / Text3: 22.967
- 1621: - / Text3: 23.802
- 1622: SP#34 completed / Text3: 32.809
- 1623: SP#35 completed / Text3: 32.812
- 1624: SP#35 completed / Text3: 32.810
- 1625: Moved to FS at CT32 (in line with slides) / Text3: 29.814
- 1626: Previously known as "Study of a SMS Centre for MT SMS" / Text3: 23.840
- 1627: TR 29.800 content moved to TS 29.204 under implementation WI UID_310005 TCAPsec Gateway / Text3: 29.800
- 1628: - / Text3: 29.801

| ID | WBS | Task | Type | Duration | Start | Finish | Complete | Baseline start | Baseline finish | Baseline duration | Constraint | Resources | Work | Actual work | Text1 | Text3 | Text4 | Text5 | Text6 | Text8 | Text11 | Text12 |
| --- | --- | --- | --- | --- | --- | --- | --- | --- | --- | --- | --- | --- | --- | --- | --- | --- | --- | --- | --- | --- | --- | --- |
| 1629 | 536 | **Study on Support of (G)MSC-S - (G)MSC-S Nc Interface based on the SIP-I protocol** |  | 350d? | 2006-05-15 A | 2007-09-14 A | 100% | 2006-05-15 | 2007-09-14 | 350d? |  | C4 | 7800h | 7800h | NcSIP | 29.802 | Vodafone | david.hutton@vodafone.com | Rel-7 | Kimmo |  |  |
| 1630 | 536.1 | CT4 aspects of NcSIP |  | 275d? | 2006-05-15 A | 2007-06-01 A | 100% | 2006-05-15 | 2007-06-01 | 275d? | finish no earlier than 2007-06-01 | C4 | 2200h | 2200h | NcSIP | 29.802 | Vodafone | david.hutton@vodafone.com | Rel-7 | Kimmo |  |  |
| 1631 | 536.2 | CT3 aspects of NcSIP |  | 350d? | 2006-05-15 A | 2007-09-14 A | 100% | 2006-05-15 | 2007-09-14 | 350d? | finish no earlier than 2007-09-14 | C3 | 2800h | 2800h | NcSIP | 29.802 | Ericsson | ragnar.huslende@ericsson.com | Rel-7 | Jiwan |  |  |
| 1632 | 537 | Study on Evolved UTRA and UTRAN |  | 458d? | 2004-12-15 A | 2006-09-15 A | 100% | 2004-12-15 | 2006-09-15 | 458d? | finish no earlier than 2006-09-15 | RP | 3664h | 3664h | RANFS-Evo | 25.912 | NTT DoCoMo | nakamurata@NTTDOCOMO.CO.JP | Rel-7 | Issam | RP-060472 |  |
| 1633 | 538 | Study on Performance Evaluation of the UE behaviour in high speed trains with speeds up to 350 kmph |  | 328d? | 2005-03-15 A | 2006-06-15 A | 100% | 2005-03-15 | 2006-06-15 | 328d? | finish no earlier than 2006-06-15 | R4 | 2624h | 2624h | RANFS-HSTrains | none | Vodafone | Mike.vogel@vodafone.com,tim.frost@vodafone.com | Rel-7 | Issam | RP-060412 |  |
| 1634 | 539 | Study on UTRA Tower Mounted Amplifier (FDD) |  | 195d? | 2005-06-15 A | 2006-03-14 A | 100% | 2005-06-15 | 2006-03-14 | 195d? | finish no earlier than 2006-03-15 | R4 | 1560h | 1560h | RANFS-TMA | 25.818 | Ericsson | Klas.Sjerling@ericsson.com | Rel-7 | Issam | RP-060035 |  |
| 1635 | 540 | Study on Continuous connectivity for packet data users |  | 132d? | 2005-03-15 A | 2005-09-14 A | 100% | 2005-03-15 | 2005-09-14 | 132d? | finish no earlier than 2005-09-15 | R1 | 1056h | 1056h | RANFS-cont-packet | none | Siemens | joerg.gustrau@siemens.com | Rel-7 | Patrick | RP-050427 |  |
| 1636 | 541 | Study on Improvement of the Multimedia Broadcast Multicast Service (MBMS) in UTRAN |  | 262d? | 2005-12-15 A | 2006-12-15 A | 100% | 2005-12-15 | 2006-12-15 | 262d? | finish no earlier than 2006-12-15 | R2 | 2096h | 2096h | RANFS-MBMSImp | 25.905 | LG Electronics | leego@lge.com | Rel-7 | Joern | RP-060692 |  |
| 1637 | 542 | Study on Performance Improvements in Small Cells using HSDPA/EDCH |  | 131d? | 2005-12-15 A | 2006-06-15 A | 100% | 2005-12-15 | 2006-06-15 | 131d? | finish no earlier than 2006-06-15 | R4 | 1048h | 1048h | SMALLCELLS | none | Cingular | Marc Grant | Rel-7 | Issam | RP-060263 |  |
| 1638 | 543 | Study on Further Improved Performance Requirements for UMTS/HSDPA UE (FDD) |  | 383d? | 2005-12-15 A | 2007-06-04 A | 100% | 2005-12-15 | 2007-06-04 | 383d? | finish no earlier than 2007-06-04 | R4 | 3064h | 3064h | RANFS-IC | 25.963 | Cingular | Marc Grant | Rel-7 | Issam | RP-070499 |  |
| 1639 | 544 | Study on Scope of future FDD HSPA Evolution |  | 394d? | 2006-03-15 A | 2007-09-17 A | 100% | 2006-03-15 | 2007-09-17 | 394d? | finish no earlier than 2007-09-17 | RP | 3152h | 3152h | RANFS-HSPAEvo | 25.999 | Cingular | Don Zelmer (dz1069@att.com) | Rel-7 | Issam | RP-070533 |  |
| 1640 | 545 | Study on Dynamically reconfiguring a FDD UE receiver to reduce power consumption when desired Quality of Service is met | milestone | 0d? | 2007-06-22 A | 2007-06-22 A | 100% | 2007-06-22 | 2007-06-22 | 0d? |  | R4 |  |  | FSUEPow | 25.906 | Nokia | Chris.callender@nokia.com, tiina.s.koskinen@nokia.com | Rel-7 | Issam | RP-070534 |  |
| 1641 | 546 | Study on Future GERAN Evolution |  | 486d? | 2005-04-08 A | 2007-02-16 A | 100% | 2005-04-08 | 2007-02-16 | 486d? | finish no earlier than 2007-02-16 | GP | 3888h | 3888h | FGE | 45.912 | Nokia | eddie.riddington@nokia.com | Rel-7 | Paolo |  |  |
| 1642 | 547 | Study on GAN Enhancements | milestone | 0d? | 2007-08-31 A | 2007-08-31 A | 100% | 2007-08-31 | 2007-08-31 | 0d? | start no earlier than 2007-08-31 | GP |  |  | EGAN | 43.902 | T-Mobile | janne.linkola@t-mobile.com | Rel-7 | Paolo |  |  |
| 1643 | 548 | Deleted - Study on IMS with real time services deployment |  | 316d? | 2004-06-28 A | 2005-09-12 A | 100% | 2004-06-28 | 2005-09-12 | 316d? |  | S1 | 2528h | 2528h | IRTSD |  |  |  | Rel-7 | Alain |  | SP-30 |
| 1644 | 549 | Deleted - Covered by SI - Personal Network (PN) and Personal Area Network (PAN) | milestone | 0d? | 2005-12-08 A | 2005-12-20 A | 100% | 2005-12-08 | 2005-12-20 | 0d? | start no earlier than 2005-12-08 | S1 |  |  | PNPAN |  | Vodafone | armin.toepfer@vodafone.com | Rel-7 | Alain |  | SP-30 |
| 1645 | 550 | Deleted - Study on Personal Network and Personal Area Network | milestone | 0d? | 2006-10-20 A | 2006-10-20 A | 100% | 2006-10-20 | 2006-10-20 | 0d? | finish no earlier than 2006-10-20 | S1 |  |  | PNPAN |  |  |  | Rel-7 | Alain |  | SP-31 |
| 1646 | 551 | Deleted - Covered by SI - Multimedia Telephony Capabilities for IMS | milestone | 0d? | 2005-12-08 A | 2005-12-20 A | 100% | 2005-12-08 | 2005-12-20 | 0d? | start no earlier than 2005-12-08 | S1 |  |  | MITE |  | Ericsson | peter.bleckert@ericsson.com | Rel-7 | Alain |  | SP-30 |
| 1647 | 552 | Deleted - Covered by SI - Transferring of emergency Call data | milestone | 0d? | 2005-12-08 A | 2005-12-08 A | 100% | 2005-12-08 | 2005-12-08 | 0d? | start no earlier than 2005-12-08 | S1 |  |  | eCALL |  | Motorola | steven.vardy@motorola.com | Rel-7 | Alain |  | SP-30 |
| 1648 | 553 | Deleted - Covered by SI - MBMS Enhancements | milestone | 0d? | 2005-12-08 A | 2005-12-08 A | 100% | 2005-12-08 | 2005-12-08 | 0d? | start no earlier than 2005-12-08 | S1 |  |  | MBMSE |  | China Mobile | liuhongyfw@chinamobile.com | Rel-7 | Alain |  | SP-30 |
| 1649 | 554 | Deleted - Study on Customised Alerting Tone (CAT) Requirements (was duplicated) | milestone | 0d? | 2006-06-30 A | 2006-06-30 A | 100% | 2006-06-30 | 2006-06-30 | 0d? | start no earlier than 2006-06-30 | S1 |  |  | CAT |  |  |  | Rel-7 | Alain |  | SP-31 |
| 1650 | 555 | Deleted - Study on LCS architecture for I-WLAN (covered by 32108) | milestone | 0d? | 2006-12-08 A | 2006-12-08 A | 100% | 2006-12-08 | 2006-12-08 | 0d? | start no earlier than 2006-12-08 | S2 |  |  | IMS-SE |  | LG Electronics | Donghee Shim dhshim@lge.com ; phede@lge.com | Rel-7 | Maurice |  | SP-33 |
| 1651 | 556 | Deleted - IMS security extensions (covered by UID33027) | milestone | 0d? | 2005-12-08 A | 2005-12-08 A | 100% | 2005-12-08 | 2005-12-08 | 0d? | start no earlier than 2005-12-08 | S3 |  |  | IMS-SE |  | Ericsson | Bengt.Sahlin@ericsson.com | Rel-7 | Dionisio |  | SP-30 |
| 1652 | 557 | **Deleted - Study on applicability of GALILEO for LCS** |  | 0d? | 2005-06-30 A | 2005-06-30 A | 100% | 2005-06-30 | 2005-06-30 | 0d? |  | S2 |  |  | Galileo |  |  |  | Rel-7 | Maurice |  | SP-25 |
| 1653 | 557.1 | Deleted - TR on Stage 2 | milestone | 0d? | 2005-06-30 A | 2005-06-30 A | 100% | 2005-06-30 | 2005-06-30 | 0d? | finish no earlier than 2005-06-30 | S2 |  |  | Galileo |  |  |  | Rel-7 | Maurice |  | SP-25 |
| 1654 | 557.2 | Deleted - GERAN review of the TR | milestone | 0d? | 2005-06-30 A | 2005-06-30 A | 100% | 2005-06-30 | 2005-06-30 | 0d? | start no earlier than 2005-06-30 | GP |  |  | Galileo |  |  |  | Rel-7 | Paolo |  | SP-26 |
| 1655 | 558 | Deleted - Study on Stage 2 (IMS services using CS bearers) |  | 316d? | 2004-06-28 A | 2005-09-12 A | 100% | 2004-06-28 | 2005-09-12 | 316d? | finish no earlier than 2005-09-12 | S2 | 2528h | 2528h | IRTSD-IMSCS | 23.899 | Nortel | Mark Watson | Rel-7 | Maurice |  | SP-30 |

Notes:
- 1629: -
- 1630: -
- 1631: -
- 1632: RP#33 (Sep 2006) completed. SR in RP-060472
- 1633: RP#32 (Jun 2006) completed. SR in RP-060412
- 1634: RP#31 (Mar 2006) completed. SR in RP-060035
- 1635: RP#29 (Sep 2006) completed. SR in RP-050427
- 1636: RP#34 (Dec 2006) completed. SR in RP-060692
- 1637: RP#32 (Jun 2006) closed (no progress). SR in RP-060263
- 1638: RP#36 (May 2007) completed. SR in RP-070499
- 1639: RP#37 (Sep 2007) completed. SR in RP-070533
- 1640: RP#37 (Sep 2007) completed. SR in RP-070534
- 1641: GP#33 completed
- 1642: GP#35 completed
- 1643: -
- 1644: -
- 1645: Moved from FS section Feb 06
- 1646: -
- 1647: -
- 1648: -
- 1649: Awaiting MCC SA3 input
- 1650: S2#52: Entry created
- 1651: -
- 1652: -
- 1653: -
- 1654: -
- 1655: SP-30: S2 has no intention for TR completion

| ID | WBS | Task | Type | Duration | Start | Finish | Complete | Baseline start | Baseline finish | Baseline duration | Constraint | Resources | Work | Actual work | Text1 | Text6 | Text8 | Text12 | Text3 | Text4 | Text5 | Text7 | Text10 |
| --- | --- | --- | --- | --- | --- | --- | --- | --- | --- | --- | --- | --- | --- | --- | --- | --- | --- | --- | --- | --- | --- | --- | --- |
| 1656 | 559 | **Deleted - VoIMS bearer related enhancements** |  | 0d? | 2006-07-21 A | 2006-07-21 A | 100% | 2006-07-21 | 2006-07-21 | 0d? |  | S2 |  |  | VoIMS | Rel-7 | Maurice | SP-32 |  |  |  |  |  |
| 1657 | 559.1 | Deleted - Study on enhancement of radio performance for VoIMS | milestone | 0d? | 2006-07-21 A | 2006-07-21 A | 100% | 2006-07-21 | 2006-07-21 | 0d? | start no earlier than 2006-07-21 | S2 |  |  | VoIMS | Rel-7 | Maurice | SP-32 | 23.807 | Nortel | Laurence Lautier (lautierl@nortel.com) |  |  |
| 1658 | 560 | Deleted - Study on IMS enhancements and optimizations for real time communication. |  | 430d? | 2005-10-10 A | 2007-06-01 A | 100% | 2005-10-10 | 2007-06-01 | 430d? | finish no earlier than 2007-06-01 | S2 | 3440h | 3440h | IMS-RT | Rel-7 | Maurice | SP-35 | 23.818 | Ericsson | stephen.terrill@ericsson.com |  |  |
| 1659 | 561 | Deleted - Study on Terminating Session handling |  | 255d? | 2006-01-09 A | 2006-12-29 A | 100% | 2006-01-09 | 2006-12-29 | 255d? | finish no earlier than 2006-12-29 | S2 | 2040h | 2040h | CSIterm | Rel-7 | Maurice | SP-32 | 23.819 | Samsung |  |  |  |
| 1660 | 562 | Deleted - Study on Transferring of emergency call data – in-band modem solution (moved to Rel-8) | milestone | 0d? | 2007-06-22 A | 2007-06-22 A | 100% | 2007-06-22 | 2007-06-22 | 0d? | start no earlier than 2007-06-22 | S4 |  |  | eCALLIBMS | Rel-7 | Paolo | SP-38 | 26.967 | Airbiquity | lhong@airbiquity.com |  |  |
| 1661 | 563 | Deleted - Study on IRP usage scenarios |  | 330d? | 2005-09-02 A | 2006-12-07 A | 100% | 2005-09-02 | 2006-12-07 | 330d? | finish no earlier than 2006-12-07 | S5 | 2640h | 2640h | OAM-Study | Rel-7 | Dionisio | SP-32 | 32.8xy | Lucent |  |  |  |
| 1662 | 564 | Deleted - Study on Interference Cancellation for UTRA FDD UE (covered by UID 20053) |  | 1d? | 2007-03-28 A | 2007-03-28 A | 100% | 2007-03-28 | 2007-03-28 | 1d? | start no earlier than 2007-03-28 | R4 | 8h | 8h | RANFS-InterfCanc | Rel-7 | Issam | SP-38 |  |  |  |  |  |
| 1663 | 565 | Deleted - Study on enhanced support of Video Telephony | milestone | 0d? | 2006-06-30 A | 2006-06-30 A | 100% | 2006-06-30 | 2006-06-30 | 0d? | start no earlier than 2006-06-30 | GP |  |  | VIDGER | Rel-7 | Paolo | SP-32 |  | Ericsson | stefan.g.eriksson@ericsson.com |  |  |
| 1664 | 566 | Release 6 Features |  | 915d? | 2002-06-28 A | 2005-12-30 A | 100% | 2002-06-28 | 2005-12-30 | 915d? |  | NP,GP, RP,SP,TP | 7320h | 7320h |  | Rel-6 | All |  |  |  |  |  |  |
| 1665 | 8 | **Rel-6 Improvements of Radio Interface** |  | 1717d? | 2000-08-14 A | 2007-03-13 A | 100% | 2000-08-14 | 2007-03-13 | 1717d? |  | RP | 57776h | 57776h | RInImp | Rel-6 |  |  |  |  |  |  |  |
| 1666 | 567.1 | Improved support of IMS Realtime Services using HSDPA/EDCH |  | 197d? | 2005-03-15 A | 2005-12-14 A | 100% | 2005-03-15 | 2005-12-14 | 197d? | finish no earlier than 2005-12-14 | R2 | 1576h | 1576h | RInImp-IMSRealTime | Rel-6 | Joern |  |  | Cingular | Don Zelmer (dz1069@att.com) |  |  |
| 1667 | 567.2 | Improving Receiver Performance Requirements for the FDD UE |  | 401d | 2002-03-08 A | 2003-09-19 A | 100% | 2002-03-08 | 2003-09-19 | 401d | start no earlier than 2002-03-08 | R4 | 3208h | 3208h | RInImp-UERecPerf | Rel-6 | Issam |  | 25.101 | Intel | shimon.moshavi@INTEL.COM |  |  |
| 1668 | 8.2 | **Base station classification** |  | 603d | 2000-08-14 A | 2002-12-04 A | 100% | 2000-08-14 | 2002-12-04 | 603d |  | R4 | 9648h | 9648h | RInImp-BSClass | Rel-6 | Issam |  |  |  |  |  |  |
| 1669 | 8.2.1 | FDD Base station classification |  | 603d | 2000-08-14 A | 2002-12-04 A | 100% | 2000-08-14 | 2002-12-04 | 603d | finish no earlier than 2002-12-04 | R4 | 4824h | 4824h | RInImp-BSClass-FDD | Rel-6 | Issam |  | 25.104, 25.141 | Nokia | antti.toskala@nokia.com |  |  |
| 1670 | 567.4 | UMTS-850 |  | 266d | 2002-12-06 A | 2003-12-12 A | 100% | 2002-12-06 | 2003-12-12 | 266d | finish no earlier than 2003-12-15 | R4 | 2128h | 2128h | RInImp-UMTS850 | Rel-6 | Issam |  | 25.101, 25.104, 25.133, 25.141, 25.307, 25.331, 25.942 | Cingular | Don Zelmer (dz1069@att.com) |  |  |
| 1671 | 567.5 | DS-CDMA introduction in the 800 MHz band |  | 196d | 2003-03-14 A | 2003-12-12 A | 100% | 2003-03-14 | 2003-12-12 | 196d | finish no earlier than 2003-12-15 | R4 | 1568h | 1568h | RInImp-UMTS800 | Rel-6 | Issam |  | 25.101, 25.104, 25.133, 25.141, 25.307, 25.331 | NTT DoCoMo | Takehiro Nakamura (nakamurata@nttdocomo.co.jp) |  |  |
| 1672 | 567.6 | UMTS 1.7/2.1 GHz | milestone | 0d? | 2003-03-14 A | 2003-03-14 A | 100% | 2003-03-14 | 2003-03-14 | 0d? |  | R4 |  |  | RInImp-UMTS1721 | Rel-6 | Issam |  | 25.101, 25.104, 25.133, 25.141, 25.307, 25.331 | Nokia | jussi.numminen@NOKIA.COM |  |  |
| 1673 | 567.7 | Conformance Test Aspects – UMTS 1.7/2.1 GHz Band |  | 191d? | 2006-03-10 A | 2006-12-01 A | 100% | 2006-03-10 | 2006-12-01 | 191d? | finish no earlier than 2006-12-01 | R5 | 1528h | 1528h | RInImp-UMTS1721_Test | Rel-6 | Ingbert |  | TS34.121, TS34.108 | Motorola | carolyn.taylor@motorola.com |  |  |
| 1674 | 567.8 | **Improved Receiver Performance Requirements for HSDPA** |  | 908d | 2003-09-19 A | 2007-03-13 A | 100% | 2003-09-19 | 2007-03-13 | 908d |  | R4,R5 | 24384h | 24384h | RInImp-HSPerf | Rel-6 | Issam |  |  | Nokia | jussi.numminen@NOKIA.COM |  |  |
| 1675 | 567.8.1 | Improved Minimum Performance Requirements for HSDPA UE categories 7 and 8 |  | 650d | 2004-09-15 A | 2007-03-13 A | 100% | 2004-09-15 | 2007-03-13 | 650d |  | R4 | 3624h | 3624h | RInImp-HSPerf-10code | Rel-6 | Issam |  | 25.101 | Nokia | jussi.numminen@nokia.com |  |  |
| 1676 | 567.8.2 | Testing of Improved Minimum Performance for HSDPA |  | 650d | 2003-09-19 A | 2006-03-16 A | 100% | 2003-09-19 | 2006-03-16 | 650d | finish no earlier than 2006-03-16 | R5 | 5200h | 5200h | RInImp-HSPerf-10Code_Test | Rel-6 | Ingbert |  | 34.108, 34.121, 34.122, 34.123-1, 34.123-2, 34.123-3 | Motorola | carolyn.taylor@motorola.com | TSG | 19/9/2003 |
| 1677 | 567.8.3 | Performance Requirements of Receive Diversity for HSDPA |  | 387d | 2003-12-15 A | 2005-06-07 A | 100% | 2003-12-15 | 2005-06-07 | 387d |  | R4 | 3096h | 3096h | RInImp-HSPerf-RxDiv | Rel-6 | Issam |  | 25.101 | NTT DoCoMo | Takehiro Nakamura (nakamurata@nttdocomo.co.jp) |  |  |
| 1678 | 567.8.4 | Testing of Performance of Receiver diversity for HSDPA |  | 650d | 2003-09-19 A | 2006-03-16 A | 100% | 2003-09-19 | 2006-03-16 | 650d | finish no earlier than 2006-03-16 | R5 | 5200h | 5200h | RInImp-HSPerf-RxDiv_Test | Rel-6 | Ingbert |  | 34.108, 34.121, 34.122, 34.123-1, 34.123-2, 34.123-3 | Motorola | carolyn.taylor@motorola.com | TSG | 19/9/2003 |
| 1679 | 568 | **Rel-6 RAN Feasibility Studies** |  | 1196d? | 2000-08-14 A | 2005-03-14 A | 100% | 2000-08-14 | 2005-03-14 | 1196d? |  | RP | 43048h | 43048h |  | Rel-6 |  |  |  |  |  |  |  |
| 1680 | 568.1 | FS of the improved access to UE measurement data for CRNC to support TDD RRM |  | 270d? | 2002-12-06 A | 2003-12-18 A | 100% | 2002-12-06 | 2003-12-18 | 270d? | finish no earlier than 2003-09-19 | R3 | 2160h | 2160h | RANimp-RRMopt-FSUEMsD | Rel-6 | Juha |  | 25.801, 25.423 | Interdigital | jim.miller@interdigital.com |  | SP-24 |
| 1681 | 568.2 | FS on Radio link performance enhancements |  | 1067d | 2000-08-14 A | 2004-09-14 A | 100% | 2000-08-14 | 2004-09-14 | 1067d | finish no earlier than 2004-09-14 | R1 | 8536h | 8536h | RInImp-Rlperf | Rel-6 | Patrick |  | 25.899 | Nokia | antti.toskala@nokia.com |  |  |
| 1682 | 568.3 | FS on Improvement of inter-frequency and inter-system measurements for 1.28 Mcps TDD |  | 461d | 2001-12-14 A | 2003-09-19 A | 100% | 2001-12-14 | 2003-09-19 | 461d | start no earlier than 2001-12-14 | R1 | 3688h | 3688h | RInImp-IfIsMLCR | Rel-6 | Patrick |  | 25.888 | Samsung | Li Xiao Qiang (xqli@samsung.co.kr) |  |  |
| 1683 | 568.4 | FS for the analysis of OFDM for UTRAN enhancement |  | 526d | 2002-06-10 A | 2004-06-14 A | 100% | 2002-06-10 | 2004-06-14 | 526d | start no earlier than 2002-06-10 | R1 | 4208h | 4208h | RInImp-FSOFDM | Rel-6 | Patrick |  | 25.892 | Nortel | Sarah Boumendil |  |  |
| 1684 | 568.5 | FS on Uplink Enhancements for Dedicated Transport Channels |  | 396d | 2002-09-06 A | 2004-03-12 A | 100% | 2002-09-06 | 2004-03-12 | 396d | finish no earlier than 2004-03-12 | R1 | 3168h | 3168h | RInImp-FSUpDTrCh | Rel-6 | Patrick |  | 25.896 | Nokia | Karri.Ranta-aho@nsn.com |  |  |
| 1685 | 568.6 | FS on Analysis on Higher Chip Rates for UTRA TDD evolutions |  | 528d | 2002-09-06 A | 2004-09-14 A | 100% | 2002-09-06 | 2004-09-14 | 528d | finish no earlier than 2004-09-14 | R1 | 4224h | 4224h | RInImp-FSVHCRTDD | Rel-6 | Patrick |  | 25.895 | IPWireless | mbeale@ipwireless.com |  |  |
| 1686 | 568.7 | FS on Low Output Powers for general purpose FDD BSs |  | 128d | 2003-06-13 A | 2004-03-12 A | 100% | 2003-06-13 | 2004-03-12 | 128d | finish no earlier than 2004-03-12 | R3 | 1024h | 1024h | RInImp-FSLoPw | Rel-6 | Juha |  | 25.807 | Telefónica | Ana Burgos (burgos_a@tsm.es) |  |  |
| 1687 | 568.8 | FS on Uplink enhancements for UTRA TDD |  | 462d | 2003-06-06 A | 2005-03-14 A | 100% | 2003-06-06 | 2005-03-14 | 462d | finish no earlier than 2005-03-14 | R1 | 3696h | 3696h | RInImp-FSUpEnhTDD | Rel-6 | Patrick |  | 25.804 | Interdigital | Marian.Rudolf@InterDigital.com |  |  |
| 1688 | 8.8 | FS on UE antenna efficiency test methods performance requirements (2) |  | 131d | 2002-03-08 A | 2002-09-06 A | 100% | 2002-03-08 | 2002-09-06 | 131d | finish no earlier than 2002-09-06 | R4 | 1048h | 1048h | RInImp-UEAnTM2 | Rel-6 | Issam |  |  | Allgon | Alf Ahlström (alf.ahlstrom@pwav.com) |  |  |
| 1689 | 9.4 | Deleted - FS on the evolution of the UTRAN architecture |  | 592d | 2002-09-09 A | 2004-12-14 A | 100% | 2002-09-09 | 2004-12-14 | 592d | finish no earlier than 2004-12-15 | R3 | 4736h | 4736h | RANimp-FSEvo | Rel-6 | Juha | RP-26 |  | Nokia | woonhee.hwang@nsn.com, Antti.Toskala@nokia.com |  |  |

Notes:
- 1656: Created by MCC to group all VoIMS related items, after consultation of chairs
- 1657: WID approved SP#28: SA2#52: CLOSED - To be removed from the work plan
- 1658: abandoned at 65%
- 1659: SP#32 Jun 2006 Study abandoned => spin-off Implementation work UID_320029
- 1660: SP-38 stopped
- 1661: -
- 1662: Deleted. Same as FS on Further Improved Performance Requirements for UMTS/HSDPA UE (FDD)
- 1663: FS CLOSED at G#28 (no input)
- 1664: -
- 1665: -
- 1666: -
- 1667: -
- 1668: -
- 1669: -
- 1670: Introduction of UMTS850 (Band V) in 25.307
- 1671: Introduction of UMTS800 in 25.307
- 1672: Introduction of UMTS1700/2100 (Band IV)
- 1673: -
- 1674: -
- 1675: Approved at RP#25 as RP-040375
- 1676: -
- 1677: -
- 1678: -
- 1679: -
- 1680: -
- 1681: Study finished at RP#25
- 1682: -
- 1683: -
- 1684: -
- 1685: Study finished at RP#25
- 1686: -
- 1687: -
- 1688: The RInImp-UEAnTM FS was re-opened at TSG RP#15 upon request from WG4
- 1689: Study Closed, work will continue within the FS on evolved UTRA and UTRAN

| ID | WBS | Task | Type | Duration | Start | Finish | Complete | Baseline start | Baseline finish | Baseline duration | Constraint | Deadline | Resources | Work | Actual work | Text1 | Text4 | Text5 | Text6 | Text3 | Text8 | Text7 | Text9 | Text10 | Text12 |
| --- | --- | --- | --- | --- | --- | --- | --- | --- | --- | --- | --- | --- | --- | --- | --- | --- | --- | --- | --- | --- | --- | --- | --- | --- | --- |
| 1690 | 569 | **FDD Enhanced Uplink** |  | 915d | 2004-03-15 A | 2007-09-14 A | 100% | 2004-03-15 | 2007-09-14 | 915d |  |  | RP | 23664h | 23664h | EDCH | Ericsson | Joakim Bergström | Rel-6 |  |  |  |  |  |  |
| 1691 | 569.1 | FDD Enhanced Uplink - Stage 2 |  | 197d | 2004-03-15 A | 2004-12-14 A | 100% | 2004-03-15 | 2004-12-14 | 197d | finish no earlier than 2004-12-14 |  | R2 | 1576h | 1576h | EDCH-Stage2 |  |  | Rel-6 | 25.309 | Joern |  |  |  |  |
| 1692 | 569.2 | FDD Enhanced Uplink - Physical Layer |  | 261d | 2004-03-15 A | 2005-03-14 A | 100% | 2004-03-15 | 2005-03-14 | 261d | finish no earlier than 2005-03-14 |  | R1 | 2088h | 2088h | EDCH-Phys | Nokia | Karri.Ranta-aho@nsn.com | Rel-6 | 25.211, 25.212, 25.213, 25.214, 25.215 | Patrick |  |  |  |  |
| 1693 | 569.3 | FDD Enhanced Uplink - Layer 2 and 3 Protocol Aspects |  | 261d | 2004-03-15 A | 2005-03-14 A | 100% | 2004-03-15 | 2005-03-14 | 261d | finish no earlier than 2005-03-14 |  | R2 | 2088h | 2088h | EDCH-L23 | Ericsson | Joakim Bergström | Rel-6 | 25.301, 25.302, 25.306, 25.321, 25.331 | Joern |  |  |  |  |
| 1694 | 569.4 | FDD Enhanced Uplink - UTRAN Iub/Iur Protocol Aspects |  | 261d | 2004-03-15 A | 2005-03-14 A | 100% | 2004-03-15 | 2005-03-14 | 261d | finish no earlier than 2005-03-14 |  | R3 | 2088h | 2088h | EDCH-IurIub | Nortel | Saso Stojanovski | Rel-6 | 25.401, 25.420, 25.423, 25.430, 25.433 | Juha |  |  |  |  |
| 1695 | 569.5 | FDD Enhanced Uplink - RF Radio Transmission/ Reception, System Performance Requirements and Conformance Testing |  | 74d | 2004-03-15 A | 2004-06-24 A | 100% | 2004-03-15 | 2004-06-24 | 74d |  |  | R4 | 592h | 592h | EDCH-RF | Ericsson | thomas.unshelm@ERICSSON.COM | Rel-6 | 25.101, 25.104, 25.133, 25.141 | Issam |  |  |  |  |
| 1696 | 569.6 | Conformance Test Aspects – FDD Enhanced Uplink |  | 596d | 2005-06-03 A | 2007-09-14 A | 100% | 2005-06-03 | 2007-09-14 | 596d | finish no earlier than 2007-09-14 | 2006-06-02 | R5 | 4768h | 4768h | EDCH_Test | Ericsson | Leif.Mattisson@ericsson.com | Rel-6 | 34.108, 34.109, 34.121, 34.123-1, 34.123-2, 34.123-3 | Ingbert | TSG | BB | Fri 03/06/05 |  |
| 1697 | 569.7 | FDD Enhanced Uplink - RF Radio Transmission/ Reception, System Performance Requirements and Conformance Testing |  | 393d | 2004-03-15 A | 2005-09-14 A | 100% | 2004-03-15 | 2005-09-14 | 393d | finish no earlier than 2005-09-15 |  | R4 | 3144h | 3144h | EDCH-RF | Ericsson | thomas.unshelm@ERICSSON.COM | Rel-6 | 25.101, 25.104, 25.133, 25.141 | Issam |  |  |  |  |
| 1698 | 570 | **Rel-6 RAN improvements** |  | 656d? | 2002-09-09 A | 2005-03-14 A | 100% | 2002-09-09 | 2005-03-14 | 656d? |  |  | RP | 28312h | 28312h | RANimp |  |  | Rel-6 |  |  |  |  |  |  |
| 1699 | 9.2 | **RAB support enhancement** |  | 522d? | 2003-03-14 A | 2005-03-14 A | 100% | 2003-03-14 | 2005-03-14 | 522d? |  |  | R2 | 9360h | 9360h | RANimp-RABSE | Nokia | Jussi Kähtävä (juha.mikola@nokia.com) | Rel-6 | 25.862 | Joern |  |  |  |  |
| 1700 | 570.1.1 | Optimization of downlink channelisation code utilisation |  | 262d | 2004-03-12 A | 2005-03-14 A | 100% | 2004-03-12 | 2005-03-14 | 262d | finish no earlier than 2005-03-14 |  | R1 | 2096h | 2096h | RANimp-RABSE-CodeOptFDD | Nortel | Sarah Boumendil | Rel-6 |  | Patrick |  |  |  |  |
| 1701 | 570.1.2 | optimization of channelisation code utilisation for 3.84 Mcps TDD |  | 261d | 2004-03-15 A | 2005-03-14 A | 100% | 2004-03-15 | 2005-03-14 | 261d | finish no earlier than 2005-03-15 |  | R1 | 2088h | 2088h | RANimp-RABSE-CodOptTDD | IPWireless | Nicholas Anderson | Rel-6 |  | Patrick |  |  |  |  |
| 1702 | 570.1.3 | HS-DPCCH ACK/NACK Enhancement |  | 65d? | 2004-09-15 A | 2004-12-14 A | 100% | 2004-09-15 | 2004-12-14 | 65d? | finish no earlier than 2004-12-15 |  | R1 | 520h | 520h | RANimp-RABSE-ACKNACK | Nokia | Jussi Kähtävä (juha.mikola@nokia.com) | Rel-6 | 25.212, 25.214, 24.331, 25.433 | Patrick |  |  |  |  |
| 1703 | 570.1.4 | Deleted - Iu enhancements for IMS support in RAN |  | 320d? | 2003-03-14 A | 2004-06-03 A | 100% | 2003-03-14 | 2004-06-03 | 320d? | start no earlier than 2003-03-14 |  | R3 | 2560h | 2560h | RANimp-RABSE-IuEnhIMS | Nortel | Philippe.Godin@nortelnetworks.com | Rel-6 |  | Juha |  |  |  | RP-24 |
| 1704 | 570.1.5 | Deleted - Improvement of RRM across RNS and RNS/BSS | milestone | 0d? | 2003-12-05 A | 2003-12-05 A | 100% | 2003-12-05 | 2003-12-05 | 0d? | finish no earlier than 2003-12-05 |  | R3 |  |  | RANimp-RRM1 | Nokia | antti.toskala@nokia.com | Rel-6 |  | Juha |  |  |  | RP-23 |
| 1705 | 9.1 | Beamforming Enhancements |  | 66d | 2003-09-19 A | 2003-12-19 A | 100% | 2003-09-19 | 2003-12-19 | 66d | finish no earlier than 2004-03-12 |  | R1 | 528h | 528h | RANimp-BFE | Nokia | Jussi Kähtävä (juha.mikola@nokia.com) | Rel-6 | 24.215, 25.423, 25.425, 25.433, 25.435 | Patrick |  |  |  |  |
| 1706 | 570.3 | **Rel6 RRM optimization for Iur and Iub** |  | 126d | 2003-09-19 A | 2004-03-12 A | 100% | 2003-09-19 | 2004-03-12 | 126d |  |  | R3 | 2016h | 2016h | RANimp-RRMopt | Ericsson | Gert-Jan.van.Lieshout@eln.ericsson.se | Rel-6 |  | Juha |  |  |  |  |
| 1707 | 570.3.1 | Improved access to UE measurement data for CRNC to support TDD RRM |  | 126d | 2003-09-19 A | 2004-03-12 A | 100% | 2003-09-19 | 2004-03-12 | 126d | finish no earlier than 2004-03-15 |  | R3 | 1008h | 1008h | RANimp-RRMopt-UEMsD | Interdigital | jim.miller@interdigital.com | Rel-6 | 25.423 | Juha |  |  |  | RP-22 |
| 1708 | 570.4 | **Remote Control of Electrical Tilting Antennas** |  | 395d? | 2003-03-14 A | 2004-09-16 A | 100% | 2003-03-14 | 2004-09-16 | 395d? |  |  | R3 | 7464h | 7464h | RANimp-TiltAnt | Vodafone | Andreas.Hauser@vodafone.com | Rel-6 |  | Juha |  |  |  |  |
| 1709 | 570.4.1 | Tilting Antenna - RAN aspects |  | 393d? | 2003-03-14 A | 2004-09-14 A | 100% | 2003-03-14 | 2004-09-14 | 393d? | finish no earlier than 2004-09-14 |  | R3 | 3144h | 3144h | RANimp-TiltAnt | Vodafone | Andreas.Hauser@vodafone.com | Rel-6 | 25.460, 25.461, 25.462, 25.463 | Juha |  |  |  |  |
| 1710 | 570.4.2 | OAM&P impacts |  | 145d | 2004-02-27 A | 2004-09-16 A | 100% | 2004-02-27 | 2004-09-16 | 145d | finish no earlier than 2004-09-16 |  | S5 | 1160h | 1160h | RANimp-TiltAnt-OAM | Vodafone | Adrian.Neal@vodafone.com | Rel-6 | 32.804, 32.64x | Dionisio |  |  | SP-24 |  |
| 1711 | 570.5 | Network Assisted Cell Change (NACC) from UTRAN to GERAN - network-side aspects |  | 462d? | 2002-09-09 A | 2004-06-15 A | 100% | 2002-09-09 | 2004-06-15 | 462d? | finish no earlier than 2004-06-15 |  | R3 | 3696h | 3696h | RANimp-NACC | Vodafone | Brendan.McWilliams@gb.vodafone.co.uk | Rel-6 |  | Juha |  |  |  |  |
| 1712 | 12 | **Location Services enhancements 2** |  | 1024d? | 2001-01-15 A | 2004-12-16 A | 100% | 2001-01-15 | 2004-12-16 | 1024d? |  |  | S2,S5,N4,RP | 78152h | 78152h | LCS2 |  |  | Rel-6 | 23.271 | Maurice |  |  |  |  |
| 1713 | 12.1 | **Improvement on Le interface** |  | 653d? | 2002-06-17 A | 2004-12-15 A | 100% | 2002-06-17 | 2004-12-15 | 653d? |  |  | S2 | 9872h | 9872h | LCS2 |  |  | Rel-6 |  | Maurice |  |  |  |  |
| 1714 | 571.1.1 | Stage 2 |  | 331d? | 2002-06-17 A | 2003-09-22 A | 100% | 2002-06-17 | 2003-09-22 | 331d? | start no earlier than 2002-06-17 |  | S2 | 2648h | 2648h | LCS2 |  |  | Rel-6 |  | Maurice |  |  |  |  |
| 1715 | 571.1.2 | Stage 3 - impacts MLP (Mobile Location Protocol) |  | 250d? | 2004-01-01 A | 2004-12-15 A | 100% | 2004-01-01 | 2004-12-15 | 250d? | finish no earlier than 2004-12-15 |  | OMA | 2000h | 2000h | LCS2 |  | OMA-LIAISON@mail.openmobilealliance.org | Rel-6 |  |  |  |  |  |  |

Notes:
- 1690: -
- 1691: -
- 1692: -
- 1693: -
- 1694: -
- 1695: -
- 1696: -
- 1697: -
- 1698: Generic feature
- 1699: building block without particular end date
- 1700: -
- 1701: WIDS modified in RP#26, RP-040551
- 1702: Approved at RP#25 as RP-040390
- 1703: Closed RP#24 due to the lack of progress
- 1704: abandoned RP-23
- 1705: -
- 1706: -
- 1707: -
- 1708: -
- 1709: Finished at RP#25
- 1710: SP#25 09/2004 completed
- 1711: -
- 1712: -
- 1713: -
- 1714: -
- 1715: Updated according to SP-040232

| ID | WBS | Task | Type | Duration | Start | Finish | Complete | Baseline start | Baseline finish | Baseline duration | Constraint | Resources | Work | Actual work | Text1 | Text6 | Text8 | Text5 | Text4 | Text12 |
| --- | --- | --- | --- | --- | --- | --- | --- | --- | --- | --- | --- | --- | --- | --- | --- | --- | --- | --- | --- | --- |
| 1716 | 12.2 | **Enhanced support for anonymity and user privacy** |  | 638d? | 2002-07-08 A | 2004-12-15 A | 100% | 2002-07-08 | 2004-12-15 | 638d? |  | S2 | 9144h | 9144h | LCS2 | Rel-6 | Maurice |  |  |  |
| 1717 | 571.2.1 | Stage 2 |  | 255d? | 2002-07-08 A | 2003-06-27 A | 100% | 2002-07-08 | 2003-06-27 | 255d? | finish no earlier than 2003-06-27 | S2 | 2040h | 2040h | LCS2 | Rel-6 | Maurice |  |  |  |
| 1718 | 571.2.2 | Stage 3 - impacts MLP and RLP |  | 250d? | 2004-01-01 A | 2004-12-15 A | 100% | 2004-01-01 | 2004-12-15 | 250d? | finish no earlier than 2004-12-15 | OMA | 2000h | 2000h | LCS2 | Rel-6 |  | OMA-LIAISON@mail.openmobilealliance.org |  |  |
| 1719 | 12.3 | **Enhanced inter-GMLC interface** |  | 648d? | 2002-06-24 A | 2004-12-15 A | 100% | 2002-06-24 | 2004-12-15 | 648d? |  | S2 | 9704h | 9704h | LCS2 | Rel-6 | Maurice |  |  |  |
| 1720 | 571.3.1 | Stage 2 |  | 315d? | 2002-06-24 A | 2003-09-05 A | 100% | 2002-06-24 | 2003-09-05 | 315d? | finish no earlier than 2003-09-05 | S2 | 2520h | 2520h | LCS2 | Rel-6 | Maurice |  |  |  |
| 1721 | 571.3.2 | Stage 3 - definition of RLP and PCP |  | 250d? | 2004-01-01 A | 2004-12-15 A | 100% | 2004-01-01 | 2004-12-15 | 250d? | finish no earlier than 2004-12-15 | OMA | 2000h | 2000h | LCS2 | Rel-6 |  | OMA-LIAISON@mail.openmobilealliance.org |  |  |
| 1722 | 12.4 | **Location Services support for IMS public identities** |  | 473d? | 2003-02-24 A | 2004-12-15 A | 100% | 2003-02-24 | 2004-12-15 | 473d? |  | S2 | 7704h | 7704h | LCS2 | Rel-6 | Maurice |  |  |  |
| 1723 | 571.4.1 | Stage 2 |  | 240d? | 2003-02-24 A | 2004-01-23 A | 100% | 2003-02-24 | 2004-01-23 | 240d? | finish no earlier than 2004-01-23 | S2 | 1920h | 1920h | LCS2 | Rel-6 | Maurice |  |  |  |
| 1724 | 571.4.2 | Stage 3 - impacts MLP, RLP and PCP |  | 250d? | 2004-01-01 A | 2004-12-15 A | 100% | 2004-01-01 | 2004-12-15 | 250d? | finish no earlier than 2004-12-15 | OMA | 2000h | 2000h | LCS2 | Rel-6 |  | OMA-LIAISON@mail.openmobilealliance.org |  |  |
| 1725 | 12.5 | **New area event for location service triggering reports** |  | 663d? | 2002-06-03 A | 2004-12-15 A | 100% | 2002-06-03 | 2004-12-15 | 663d? |  | S2 | 11416h | 11416h | LCS2 | Rel-6 | Maurice |  |  |  |
| 1726 | 571.5.1 | Stage 2 |  | 280d? | 2002-06-03 A | 2003-06-27 A | 100% | 2002-06-03 | 2003-06-27 | 280d? | finish no earlier than 2003-06-27 | S2 | 2240h | 2240h | LCS2 | Rel-6 | Maurice |  |  |  |
| 1727 | 571.5.2 | Stage 3 for UE-CN signalling |  | 234d? | 2003-10-09 A | 2004-08-31 A | 100% | 2003-10-09 | 2004-08-31 | 234d? | start no earlier than 2003-10-09 | N4 | 1872h | 1872h | LCS2 | Rel-6 | Kimmo |  |  |  |
| 1728 | 571.5.3 | Stage 3 - impacts MLP, RLP and PCP |  | 250d? | 2004-01-01 A | 2004-12-15 A | 100% | 2004-01-01 | 2004-12-15 | 250d? | finish no earlier than 2004-12-15 | OMA | 2000h | 2000h | LCS2 | Rel-6 |  | OMA-LIAISON@mail.openmobilealliance.org |  |  |
| 1729 | 12.7 | **UE positioning** |  | 957d? | 2001-01-15 A | 2004-09-14 A | 100% | 2001-01-15 | 2004-09-14 | 957d? |  | RP | 18480h | 18480h | LCS2-UEpos | Rel-6 | Issam |  |  |  |
| 1730 | 12.8 | Open SMLC-SRNC Interface within the UTRAN to support UTRAN Rel4 positioning methods |  | 700d? | 2001-01-15 A | 2003-09-19 A | 100% | 2001-01-15 | 2003-09-19 | 700d? | finish no earlier than 2003-09-19 | R2 | 5600h | 5600h | LCS-Rel4Pos | Rel-6 | Joern | Meik.Kottkamp@siemens.com | Siemens |  |
| 1731 | 571.6.2 | A-GPS minimum performance specification |  | 333d? | 2003-06-06 A | 2004-09-14 A | 100% | 2003-06-06 | 2004-09-14 | 333d? | finish no earlier than 2004-09-14 | R4 | 2664h | 2664h | LCS-UEPos-AGPSPerf | Rel-6 | Issam | donglin.shen@attws.com | AT&T Wireless |  |
| 1732 | 12.7.2 | FS on Enhancements to OTDOA Positioning using advanced blanking methods |  | 320d | 2002-07-01 A | 2003-09-19 A | 100% | 2002-07-01 | 2003-09-19 | 320d | finish no earlier than 2003-09-19 | R2 | 2560h | 2560h | LCS2-UEpos-FSBlank | Rel-6 | Joern | david.bartlett@cursor-system.com | Cambridge Positioning Systems |  |
| 1733 | 571.6.4 | Deleted - UE positioning enhancements - other methods | milestone | 0d? | 2003-09-26 A | 2003-09-26 A | 100% | 2003-09-26 | 2003-09-26 | 0d? | finish no earlier than 2003-09-26 | R2 |  |  | LCS2-UEpos-enh | Rel-6 | Joern | Meik.Kottkamp@siemens.com | Siemens | RP-24 |
| 1734 | 571.7 | LCS charging |  | 455d? | 2003-03-21 A | 2004-12-16 A | 100% | 2003-03-21 | 2004-12-16 | 455d? | start no earlier than 2003-03-21 | S5 | 3640h | 3640h | LCS2-CH | Rel-6 | Dionisio | alain.bibas@orange-ft.com | France Telecom |  |
| 1735 | 14 | **Rel-6 Security enhancements** |  | 1018d? | 2001-01-03 A | 2004-11-26 A | 100% | 2001-01-03 | 2004-11-26 | 1018d? |  | S3 | 28824h | 28824h | SEC1 | Rel-6 | Dionisio | Peter.Howard@vodafone.com | Vodafone |  |
| 1736 | 14.1 | **Enhanced HE control of security (including positive authentication reporting)** |  | 712d | 2001-01-03 A | 2003-09-25 A | 100% | 2001-01-03 | 2003-09-25 | 712d |  | S3 | 14064h | 14064h | SEC1 | Rel-6 | Dionisio | Peter.Howard@vodafone.com | Vodafone |  |
| 1737 | 14.1.1 | Deleted - SEC1 Stage 2 (Enhanced HE control of security) |  | 378d | 2001-01-03 A | 2002-06-14 A | 100% | 2001-01-03 | 2002-06-14 | 378d | finish no earlier than 2002-06-14 | S3 | 3024h | 3024h | SEC1 | Rel-6 | Dionisio |  |  | SP-16 |
| 1738 | 14.1.3 | **Network domain security** |  | 334d | 2002-06-17 A | 2003-09-25 A | 100% | 2002-06-17 | 2003-09-25 | 334d |  | S3 | 5344h | 5344h | SEC1-NDS | Rel-6 | Dionisio | Geir-myrdahl.koien@telenor.com | Telenor |  |
| 1739 | 14.1.3.1 | IP network layer security (NDS/IP) |  | 334d | 2002-06-17 A | 2003-09-25 A | 100% | 2002-06-17 | 2003-09-25 | 334d | finish no earlier than 2003-09-25 | S3 | 2672h | 2672h | SEC1-NDS-IP | Rel-6 | Dionisio |  |  |  |
| 1740 | 572.2 | Network Domain Security; Authentication Framework (NDS/AF) |  | 521d? | 2002-02-15 A | 2004-02-13 A | 100% | 2002-02-15 | 2004-02-13 | 521d? | finish no earlier than 2004-02-13 | S3 | 4168h | 4168h | SEC1-NDS-AF | Rel-6 | Dionisio | tommi.viitanen@nokia.com | Nokia |  |
| 1741 | 572.3 | Key Management of group keys for Voice Group Call Services |  | 306d | 2003-09-26 A | 2004-11-26 A | 100% | 2003-09-26 | 2004-11-26 | 306d | finish no earlier than 2004-11-26 | S3 | 2448h | 2448h | SECGKYV | Rel-6 | Dionisio | benno.tietz@vodafone.com | Vodafone |  |

Notes:
- 1716: -
- 1717: -
- 1718: Updated according to SP-040232
- 1719: -
- 1720: -
- 1721: Updated according to SP-040232
- 1722: -
- 1723: -
- 1724: Updated according to SP-040232
- 1725: -
- 1726: -
- 1727: 31/10/2003 work has started. Current stage 3 fullfills the requirements of stage 2. ......
- 1728: Updated according to SP-040232
- 1729: -
- 1730: - / Text3: 25.305, 25.401, 25.450, 25.452, 25.453
- 1731: Finished at RP#25 / Text3: 25.171
- 1732: -
- 1733: building block without particular end date
- 1734: SP#26 12/2004 completed / Text3: 32.271
- 1735: Added BB UE authentication and rapporteur added.
- 1736: Added by SP-000575 without any dates. 18/10/00: Change of WI title, added hyperlink rapporteur new end date 03/01. New end date and correct Release to be decided S3#18
- 1737: New end date and correct Release to be decided S3#18. Marked as stopped 12/2008
- 1738: WID approved for Rel-6 at SP#17. Completed 2004-12
- 1739: Should be complete after SA3#27. Completed 2004-12 / Text3: 33.210
- 1740: WID approved SP#19. Work started after FS approved SP#18
- 1741: Approved TSG#21. Completed 2004-12 / Text3: 42.068, 43.068, 44.068, 42.069, 43.069, 44.069, 31.102, 24.008, 48.008, 42.009, 43.020

| ID | WBS | Task | Type | Duration | Start | Finish | Complete | Baseline start | Baseline finish | Baseline duration | Constraint | Resources | Work | Actual work | Text1 | Text3 | Text6 | Text8 | Text4 | Text5 | Text12 |
| --- | --- | --- | --- | --- | --- | --- | --- | --- | --- | --- | --- | --- | --- | --- | --- | --- | --- | --- | --- | --- | --- |
| 1742 | 16 | **IMS Phase 2** |  | 1840d? | 2000-08-28 A | 2007-09-14 A | 100% | 2000-08-28 | 2007-09-14 | 1840d? |  | S1,S2,S3,S5,NP,R5 | 136976h | 136976h | IMS2 | 23.228 | Rel-6 | Alain |  |  |  |
| 1743 | 573.1 | Enhancements to the Cx and Sh interfaces |  | 323d? | 2003-06-06 A | 2004-08-31 A | 100% | 2003-06-06 | 2004-08-31 | 323d? | finish no earlier than 2004-08-31 | N4 | 2584h | 2584h | IMS2-CCR |  | Rel-6 | Kimmo |  |  |  |
| 1744 | 573.2 | Conformance Test Aspects – IMS Call Control Rel-6 enhancements |  | 396d? | 2006-03-10 A | 2007-09-14 A | 100% | 2006-03-10 | 2007-09-14 | 396d? | finish no earlier than 2007-09-14 | R5 | 3168h | 3168h | IMS2_CCR_Test | 34.229-1, 34.229-2, 34.229-3, 34.108 | Rel-6 | Ingbert | Ericsson | Jacob.John@motorola.com, Leif.Mattisson@ericsson.com |  |
| 1745 | 16.12 | **IMS Group Management** |  | 715d? | 2002-03-14 A | 2004-12-08 A | 100% | 2002-03-14 | 2004-12-08 | 715d? |  | S1 | 12680h | 12680h | IMSGM |  | Rel-6 | Alain | Nokia | juha.kalliokulju@nokia.com |  |
| 1746 | 16.12.1 | Stage 1 - TS on IMS group management |  | 193d | 2002-03-14 A | 2002-12-09 A | 100% | 2002-03-14 | 2002-12-09 | 193d | finish no earlier than 2002-12-09 | S1 | 1544h | 1544h | IMSGM |  | Rel-6 | Alain | Nokia | juha.kalliokulju@nokia.com |  |
| 1747 | 573.3.2 | Stage 2 |  | 158d? | 2003-05-26 A | 2003-12-31 A | 100% | 2003-05-26 | 2003-12-31 | 158d? | finish no earlier than 2003-12-31 | S2 | 1264h | 1264h | IMSGM |  | Rel-6 | Maurice |  |  |  |
| 1748 | 573.3.3 | Stage 3 for IMS Group management (e.g. chat) |  | 519d? | 2002-12-13 A | 2004-12-08 A | 100% | 2002-12-13 | 2004-12-08 | 519d? | finish no earlier than 2004-12-08 | N1 | 4152h | 4152h | IMSGM |  | Rel-6 | Frederic | Lucent | Keith Drage (drage@alcatel-lucent.com) |  |
| 1749 | 573.4 | **IMS Conferencing** |  | 548d? | 2002-11-04 A | 2004-12-08 A | 100% | 2002-11-04 | 2004-12-08 | 548d? |  | N1 | 10960h | 10960h |  |  | Rel-6 | Frederic |  |  |  |
| 1750 | 573.4.1 | Stage 2 |  | 303d? | 2002-11-04 A | 2003-12-31 A | 100% | 2002-11-04 | 2003-12-31 | 303d? | finish no earlier than 2003-12-31 | S2 | 2424h | 2424h |  |  | Rel-6 | Maurice |  |  |  |
| 1751 | 573.4.2 | Stage 3 |  | 519d? | 2002-12-13 A | 2004-12-08 A | 100% | 2002-12-13 | 2004-12-08 | 519d? | finish no earlier than 2004-12-08 | N1 | 4152h | 4152h |  |  | Rel-6 | Frederic | Lucent | Keith Drage (drage@alcatel-lucent.com) |  |
| 1752 | 16.11 | **IMS Messaging** |  | 992d? | 2002-03-14 A | 2005-12-30 A | 100% | 2002-03-14 | 2005-12-30 | 992d? |  | S1 | 23912h | 23912h | IMSM |  | Rel-6 | Alain | Nokia | juha.kalliokulju@nokia.com |  |
| 1753 | 16.11.1 | TR on support of messaging in the IMS |  | 193d | 2002-03-14 A | 2002-12-09 A | 100% | 2002-03-14 | 2002-12-09 | 193d | finish no earlier than 2002-12-09 | S1 | 1544h | 1544h | IMSM-TR | new 22.940 | Rel-6 | Alain | Nokia | juha.kalliokulju@nokia.com |  |
| 1754 | 573.5.2 | Stage 1 22.340 |  | 23d? | 2002-11-11 A | 2002-12-11 A | 100% | 2002-11-11 | 2002-12-11 | 23d? | finish no earlier than 2002-12-11 | S1 | 184h | 184h | IMSM-TS | 22.340 | Rel-6 | Alain | Nokia | juha.kalliokulju@nokia.com |  |
| 1755 | 573.5.3 | CRs to 22.140 & 22.228 |  | 263d? | 2002-03-14 A | 2003-03-17 A | 100% | 2002-03-14 | 2003-03-17 | 263d? | finish no earlier than 2003-03-17 | S1 | 2104h | 2104h | IMSM-CR | 22.140,22.228 | Rel-6 | Alain | Nokia | juha.kalliokulju@nokia.com |  |
| 1756 | 16.11.3 | Stage 2 |  | 477d | 2002-11-04 A | 2004-08-31 A | 100% | 2002-11-04 | 2004-08-31 | 477d | finish no earlier than 2004-08-31 | S2 | 3816h | 3816h | IMSM |  | Rel-6 | Maurice |  |  |  |
| 1757 | 573.5.5 | Stage 3 for IMS Messaging |  | 519d? | 2002-12-13 A | 2004-12-08 A | 100% | 2002-12-13 | 2004-12-08 | 519d? | finish no earlier than 2004-12-08 | N1 | 4152h | 4152h | IMSM |  | Rel-6 | Frederic | Lucent | Keith Drage (drage@alcatel-lucent.com) |  |
| 1758 | 573.5.6 | SIP/SIMPLE Instant messaging |  | 522d? | 2004-01-01 A | 2005-12-30 A | 100% | 2004-01-01 | 2005-12-30 | 522d? | finish no earlier than 2005-06-30 | OMA | 4176h | 4176h |  |  | Rel-6 |  |  | OMA-LIAISON@mail.openmobilealliance.org |  |
| 1759 | 573.6 | **Additional SIP Capabilities support not covered by Rel-5** |  | 680d? | 2002-11-11 A | 2005-06-17 A | 100% | 2002-11-11 | 2005-06-17 | 680d? |  | N1 | 13392h | 13392h |  |  | Rel-6 | Frederic |  |  |  |
| 1760 | 573.6.1 | Stage 2 for add SIP cap (e.g. forking) |  | 335d? | 2002-11-11 A | 2004-02-20 A | 100% | 2002-11-11 | 2004-02-20 | 335d? | finish no earlier than 2004-02-20 | S2 | 2680h | 2680h |  |  | Rel-6 | Maurice |  |  |  |
| 1761 | 573.6.2 | Stage 3 for Additional SIP Capabilities |  | 454d? | 2002-12-13 A | 2004-09-08 A | 100% | 2002-12-13 | 2004-09-08 | 454d? | finish no earlier than 2004-09-08 | N1 | 3632h | 3632h |  |  | Rel-6 | Frederic | Lucent | Keith Drage (drage@alcatel-lucent.com) |  |
| 1762 | 573.6.3 | Procedured associated with IMS-ALG |  | 205d? | 2004-09-06 A | 2005-06-17 A | 100% | 2004-09-06 | 2005-06-17 | 205d? | start no earlier than 2004-09-06 | N1 | 1640h | 1640h |  |  | Rel-6 | Frederic |  |  |  |
| 1763 | 573.7 | Review additional SIP Capabilities against IMS |  | 454d? | 2002-12-13 A | 2004-09-08 A | 100% | 2002-12-13 | 2004-09-08 | 454d? | finish no earlier than 2004-09-08 | N1 | 3632h | 3632h |  |  | Rel-6 | Frederic | Lucent | Keith Drage (drage@alcatel-lucent.com) |  |
| 1764 | 16.5 | **Interworking between IMS and IP networks** |  | 1118d? | 2000-08-28 A | 2004-12-08 A | 100% | 2000-08-28 | 2004-12-08 | 1118d? |  | N3 | 31712h | 31712h | IMS-CCR-IWIP | 23.821, 29.061, 29.162 | Rel-6 | Gwiho | BT | nigel.holland@bt.com |  |
| 1765 | 16.5.1 | Interworking for 3GPP_SIP and IETF_SIP |  | 730d | 2000-08-28 A | 2003-06-13 A | 100% | 2000-08-28 | 2003-06-13 | 730d | finish no earlier than 2003-06-13 | N3 | 5840h | 5840h |  | New 29.962 | Rel-6 | Gwiho | Siemens | Thomas.Belling@nsn.com |  |
| 1766 | 16.5.2 | Interworking for IPv6 to IPv4 |  | 1118d | 2000-08-28 A | 2004-12-08 A | 100% | 2000-08-28 | 2004-12-08 | 1118d | finish no earlier than 2004-12-08 | N3 | 8944h | 8944h |  | 29.163 | Rel-6 | Gwiho |  |  |  |
| 1767 | 573.8.3 | Interworking for IPv6 to IPv4 (SIP / SDP aspects) |  | 87d? | 2004-05-11 A | 2004-09-08 A | 100% | 2004-05-11 | 2004-09-08 | 87d? | finish no earlier than 2004-09-08 | N1 | 696h | 696h |  |  | Rel-6 | Frederic |  |  |  |
| 1768 | 16.8.1 | stage 3 of interworking with non-IMS IP networks |  | 911d | 2001-03-14 A | 2004-09-08 A | 100% | 2001-03-14 | 2004-09-08 | 911d | finish no earlier than 2004-09-08 | N1 | 7288h | 7288h |  |  | Rel-6 | Frederic |  |  |  |
| 1769 | 16.6.1 | Interworking between IMS and CS networks |  | 929d? | 2000-08-28 A | 2004-03-18 A | 100% | 2000-08-28 | 2004-03-18 | 929d? | finish no earlier than 2004-03-18 | N3 | 7432h | 7432h | IMS-CCR-IWCS | 29.163, 29.061, 24.228, and new CN4 specification | Rel-6 | Gwiho | Vodafone | Brendan.McWilliams@gb.vodafone.co.uk |  |
| 1770 | 16.10 | Mn interface (IM-MGW to MGCF) enhancements (CN4 Part) |  | 418d | 2001-08-07 A | 2004-09-01 A | 100% | 2001-08-07 | 2004-09-01 | 418d | finish no earlier than 2004-09-01 | N4 | 3344h | 3344h | IMS-CCR-Mn |  | Rel-6 | Kimmo |  |  |  |
| 1771 | 573.11 | Study of subscriber and operators relationship in IMS and related ISIM requirements for Rel 6” |  | 20d? | 2002-11-15 A | 2002-12-12 A | 100% | 2002-11-15 | 2002-12-12 | 20d? | finish no earlier than 2002-12-12 | S1 | 160h | 160h |  |  | Rel-6 | Alain | Nokia | juha.kalliokulju@nokia.com |  |
| 1772 | 573.12 | Lawful Interception in the 3GPP Rel-6 architecture |  | 269d? | 2002-12-09 A | 2003-12-18 A | 100% | 2002-12-09 | 2003-12-18 | 269d? | finish no earlier than 2003-12-18 | S3 | 2152h | 2152h | SEC1-LI | 33.106, 33.107, 33.108 | Rel-6 | Dionisio | Reg TP | berthold.wilhelm@regtp.de |  |
| 1773 | 573.13 | IMS Subscription and access scenarios |  | 130d? | 2002-12-16 A | 2003-06-13 A | 100% | 2002-12-16 | 2003-06-13 | 130d? | start no earlier than 2002-12-16 | S1 | 1040h | 1040h |  | 22.800 | Rel-6 | Alain | TeliaSonera | FRANK, Robert |  |
| 1774 | 573.14 | IMS charging |  | 455d? | 2003-03-21 A | 2004-12-16 A | 100% | 2003-03-21 | 2004-12-16 | 455d? | finish no earlier than 2004-12-16 | S5 | 3640h | 3640h | IMS2-CH | 32.260 | Rel-6 | Dionisio | Ericsson | Patrik TEPPO |  |
| 1775 | 573.15 | IMS Management objects |  | 306d? | 2004-09-03 A | 2005-11-04 A | 100% | 2004-09-03 | 2005-11-04 | 306d? | finish no earlier than 2005-03-04 | N1 | 2448h | 2448h |  | 24.167 | Rel-6 | Frederic |  |  |  |
| 1776 | 573.16 | Deleted - Stage 2 of IMS Phase 2 | milestone | 0d? | 2003-09-19 A | 2003-09-19 A | 100% | 2003-09-19 | 2003-09-19 | 0d? | finish no earlier than 2003-09-19 | S2 |  |  | IMS2 |  | Rel-6 | Maurice |  |  | SP-21 |

Notes:
- 1742: Not yet available: verbally approved at SA15, actual WID to be provided at SA16 by Lucent
- 1743: Shared public user identities need to be solved. If email approval CR is accepted. Work 100% done....
- 1744: -
- 1745: -
- 1746: -
- 1747: -
- 1748: Depends on CN decision on CPCP in Rel-6. Complete, if unresolved IETF dependencies are dropped (-> LS to CN plenary)
- 1749: -
- 1750: -
- 1751: Depends on CN decision on IETF dependencies in Rel-6. Higher figure if CPCP is dropped (-> LS to CN plenary)
- 1752: -
- 1753: -
- 1754: -
- 1755: -
- 1756: -
- 1757: -
- 1758: Updated according to SP-040232
- 1759: -
- 1760: -
- 1761: -
- 1762: -
- 1763: -
- 1764: [DAB 14.02.02] - end date pushed back to March 2003
- 1765: [DAB - 20.08.03] - CN Part of TR Complete @ CN#20
- 1766: -
- 1767: -
- 1768: -
- 1769: [DAB - 25.05.04] - CN3 consider this work to be complete
- 1770: TISPAN issue is open
- 1771: -
- 1772: -
- 1773: -
- 1774: SP#26 12/2004 completed
- 1775: -
- 1776: -

| ID | WBS | Task | Type | Duration | Start | Finish | Complete | Baseline start | Baseline finish | Baseline duration | Constraint | Resources | Work | Actual work | Text1 | Text4 | Text5 | Text6 | Text8 | Text3 | Text10 | Text12 |
| --- | --- | --- | --- | --- | --- | --- | --- | --- | --- | --- | --- | --- | --- | --- | --- | --- | --- | --- | --- | --- | --- | --- |
| 1777 | 574 | **3GPP Enablers for services like Push to Talk over Cellular (PoC)** |  | 459d? | 2003-09-08 A | 2005-06-09 A | 100% | 2003-09-08 | 2005-06-09 | 459d? |  | S2,S4,S5 | 10696h | 10696h | PoC | Ericsson | Shabnam Sultana | Rel-6 | Maurice |  |  |  |
| 1778 | 574.1 | Feasibility Study |  | 322d? | 2003-09-08 A | 2004-11-30 A | 100% | 2003-09-08 | 2004-11-30 | 322d? | finish no earlier than 2004-11-30 | S2 | 2576h | 2576h | PoC | Ericsson | Shabnam Sultana | Rel-6 | Maurice | 23.979 | SP-24 |  |
| 1779 | 574.2 | Dependencies on OMA PoC |  | 303d? | 2004-01-01 A | 2005-02-28 A | 100% | 2004-01-01 | 2005-02-28 | 303d? | finish no earlier than 2004-12-30 | OMA | 2424h | 2424h | PoC |  | OMA-LIAISON@mail.openmobilealliance.org | Rel-6 |  |  | SP-24 |  |
| 1780 | 574.3 | Selection of one or more PoC codec(s) for PoC |  | 69d? | 2004-09-13 A | 2004-12-16 A | 100% | 2004-09-13 | 2004-12-16 | 69d? | start no earlier than 2004-09-13 | S4 | 552h | 552h | PoC |  |  | Rel-6 | Paolo | 26.235, 26.236 | SP-25 |  |
| 1781 | 574.4 | PoC charging |  | 184d? | 2004-09-27 A | 2005-06-09 A | 100% | 2004-09-27 | 2005-06-09 | 184d? | finish no earlier than 2005-06-09 | S5 | 1472h | 1472h | PoC-CH | Siemens | Gerald.Goermer@nsn.com | Rel-6 | Dionisio | 32.272 |  |  |
| 1782 | 575 | Study on Interworking aspects and migration scenarios for IPv4 based IMS Implementations |  | 210d? | 2003-09-08 A | 2004-06-25 A | 100% | 2003-09-08 | 2004-06-25 | 210d? | finish no earlier than 2004-06-25 | S2 | 1680h | 1680h | IPv4IMS | Siemens | Alexander Milinski | Rel-6 | Maurice | 23.981 |  |  |
| 1783 | 16.3 | **Interoperability and Commonality between IMS using different IP-connectivity Networks** |  | 325d? | 2002-09-16 A | 2003-12-12 A | 100% | 2002-09-16 | 2003-12-12 | 325d? |  | S2 | 9176h | 9176h | IMSCOOP |  |  | Rel-6 | Maurice | 23.864 |  |  |
| 1784 | 16.3.1 | Stage 2 for Interoperability |  | 272d | 2002-09-16 A | 2003-09-30 A | 100% | 2002-09-16 | 2003-09-30 | 272d | finish no earlier than 2003-09-30 | S2 | 2176h | 2176h | IMSCOOP | Nokia | balazs.bertenyi@nsn.com | Rel-6 | Maurice | 23.864 |  |  |
| 1785 | 576.2 | Stage 2 for commonality |  | 265d? | 2002-09-16 A | 2003-09-19 A | 100% | 2002-09-16 | 2003-09-19 | 265d? | start no earlier than 2002-09-16 | S2 | 2120h | 2120h | IMSCOOP | Nokia | balazs.bertenyi@nsn.com | Rel-6 | Maurice | 23.864 |  |  |
| 1786 | 16.3.2 | Stage 3 |  | 305d | 2002-10-14 A | 2003-12-12 A | 100% | 2002-10-14 | 2003-12-12 | 305d | finish no earlier than 2003-12-12 | N1 | 2440h | 2440h | IMSCOOP | Lucent | Keith Drage (drage@alcatel-lucent.com) | Rel-6 | Frederic |  |  |  |
| 1787 | 17 | **Support of Push Services** |  | 823d | 2001-01-03 A | 2004-02-27 A | 100% | 2001-01-03 | 2004-02-27 | 823d |  | S1 | 11390.6h | 11390.6h | PUSH | NTT Comware | Yoshinori Kitada | Rel-6 | Alain | 23.976 |  |  |
| 1788 | 17.1 | Stage 1 |  | 378d | 2001-01-03 A | 2002-06-14 A | 100% | 2001-01-03 | 2002-06-14 | 378d | finish no earlier than 2002-06-14 | S1 | 3024h | 3024h | PUSH |  |  | Rel-6 | Alain |  |  |  |
| 1789 | 17.3 | TR 23.976 on Push Architecture |  | 340d | 2002-11-11 A | 2004-02-27 A | 100% | 2002-11-11 | 2004-02-27 | 340d | finish no earlier than 2004-02-27 | S2 | 2720h | 2720h | PUSH | Research In Motion | Nick Alfano | Rel-6 | Maurice | 23.976 |  |  |
| 1790 | 18 | **Multimedia Messaging (MMS) enhancements** |  | 865d? | 2002-08-15 A | 2005-12-07 A | 100% | 2002-08-15 | 2005-12-07 | 865d? |  | T2,S1,S4,S5,OMA | 31936h | 31936h | MMS6 | Siemens | Josef.Laumen@SAL.SIEMENS.DE | Rel-6 | Kimmo |  |  |  |
| 1791 | 18.1 | **Definition of service requirements** |  | 286d? | 2002-11-15 A | 2003-12-19 A | 100% | 2002-11-15 | 2003-12-19 | 286d? |  | S1 | 4576h | 4576h | MMS6-SR |  |  | Rel-6 | Alain | 22.140 |  |  |
| 1792 | 578.1.1 | Definition of service requirements charging |  | 286d? | 2002-11-15 A | 2003-12-19 A | 100% | 2002-11-15 | 2003-12-19 | 286d? | finish no earlier than 2003-12-20 | S1 | 2288h | 2288h | MMS6-SR | Siemens | Josef.Laumen@SAL.SIEMENS.DE | Rel-6 | Alain | 22.140 |  |  |
| 1793 | 18.2 | Technical realization |  | 591d | 2002-09-06 A | 2004-12-10 A | 100% | 2002-09-06 | 2004-12-10 | 591d | finish no earlier than 2004-12-10 | T2 | 4728h | 4728h | MMS6 | Siemens | Josef.Laumen@SAL.SIEMENS.DE | Rel-6 | Kimmo | 23.140 |  |  |
| 1794 | 18.3 | OMA dependencies |  | 446d | 2003-08-15 A | 2005-04-29 A | 100% | 2003-08-15 | 2005-04-29 | 446d | finish no earlier than 2004-12-10 | OMA | 3568h | 3568h | MMS6 |  |  | Rel-6 | Kimmo | OMA specs |  |  |
| 1795 | 18.4 | MMS formats and codecs |  | 865d | 2002-08-15 A | 2005-12-07 A | 100% | 2002-08-15 | 2005-12-07 | 865d | finish no earlier than 2005-12-07 | S4 | 6920h | 6920h | MMS6-Codec | Nokia | roberto.castagno@nokia.com | Rel-6 | Paolo | 26.140, 26.936 |  |  |
| 1796 | 578.5 | Handling of private addressing schemes in MMS |  | 263d | 2003-12-10 A | 2004-12-10 A | 100% | 2003-12-10 | 2004-12-10 | 263d | finish no earlier than 2004-12-10 | T2 | 2104h | 2104h | MMS6 | T-Mobile | Steffen.Habermann@T-MOBILE.DE | Rel-6 | Kimmo | 23.140 |  |  |
| 1797 | 578.6 | MMS charging |  | 390d? | 2003-03-21 A | 2004-09-16 A | 100% | 2003-03-21 | 2004-09-16 | 390d? | start no earlier than 2003-03-21 | S5 | 3120h | 3120h | MMS6-CH |  |  | Rel-6 | Dionisio | 32.270 |  |  |
| 1798 | 578.7 | Deleted - FS Multiple MMS Relay/Server Architecture | milestone | 0d | 2004-12-10 A | 2004-12-10 A | 100% | 2004-12-10 | 2004-12-10 | 0d | finish no earlier than 2004-12-10 | T2 |  |  | MMS6 | Telefónica Móviles | Juan Gorospe (gorospe_j@tsm.es) | Rel-6 | Kimmo | probably Annex to 23.140 |  | TP-26 |
| 1799 | 19 | **Rel-6 MExE enhancements** |  | 326d | 2002-03-08 A | 2003-06-06 A | 100% | 2002-03-08 | 2003-06-06 | 326d |  | T2 | 7328h | 7328h | MEXE6 |  |  | Rel-6 | Kimmo |  |  |  |
| 1800 | 19.1 | MExE Rel-6 Improvements and Investigations |  | 264d | 2002-03-08 A | 2003-03-12 A | 100% | 2002-03-08 | 2003-03-12 | 264d | finish no earlier than 2003-03-12 | T2 | 2112h | 2112h | MEXE6-ENHANC | TTPCom | Lars Brenk ( (lsb_ttpcom@HOTMAIL.COM) | Rel-6 | Kimmo |  |  |  |
| 1801 | 19.2 | MExE Run-Time Independent Framework Feasibility Study |  | 326d | 2002-03-08 A | 2003-06-06 A | 100% | 2002-03-08 | 2003-06-06 | 326d | finish no earlier than 2003-06-06 | T2 | 2608h | 2608h | MEXE6-RTIF | Nokia Siemens Networks | balazs.bertenyi@nokia.com | Rel-6 | Kimmo | 22.857 |  |  |
| 1802 | 21 | Subscription Management |  | 650d | 2002-09-20 A | 2005-03-17 A | 100% | 2002-09-20 | 2005-03-17 | 650d | finish no earlier than 2005-03-17 | S5 | 5200h | 5200h | SuM | T-Mobile | istvan.aba@t-mobile.at | Rel-6 | Dionisio | 32.140/1, 32.171/2/5, 32.803 |  |  |

Notes:
- 1777: -
- 1778: -
- 1779: Updated according to SP-040232
- 1780: Completed
- 1781: SP#28 06/2005 completed
- 1782: -
- 1783: -
- 1784: No contributions assumed that no more will be done in 3GPP hence work may need to be done in 3GPP2
- 1785: -
- 1786: -
- 1787: Changed from FS to actual support of Push
- 1788: -
- 1789: -
- 1790: -
- 1791: -
- 1792: -
- 1793: -
- 1794: -
- 1795: -
- 1796: -
- 1797: SP#25 09/2004 completed
- 1798: originally it was intended to create a FS TR but most likely the work will become an Annex of 23.140
- 1799: -
- 1800: -
- 1801: -
- 1802: SP#27 03/2005 completed

| ID | WBS | Task | Duration | Start | Finish | Complete | Baseline start | Baseline finish | Baseline duration | Constraint | Resources | Work | Actual work | Text1 | Text4 | Text5 | Text6 | Text8 | Text3 |
| --- | --- | --- | --- | --- | --- | --- | --- | --- | --- | --- | --- | --- | --- | --- | --- | --- | --- | --- | --- |
| 1803 | 22 | **Presence Capability** | 1233d? | 2001-03-19 A | 2005-12-07 A | 100% | 2001-03-19 | 2005-12-07 | 1233d? |  | S1 | 37112h | 37112h | PRESNC | Motorola | Mark Cataldo | Rel-6 | Alain |  |
| 1804 | 22.1 | Stage 1 | 610d | 2001-03-19 A | 2003-07-18 A | 100% | 2001-03-19 | 2003-07-18 | 610d | finish no earlier than 2003-07-18 | S1 | 4880h | 4880h | PRESNC |  |  | Rel-6 | Alain | 22.141 |
| 1805 | 22.2 | Stage 2 | 268d | 2001-09-12 A | 2002-09-20 A | 100% | 2001-09-12 | 2002-09-20 | 268d | finish no earlier than 2002-09-20 | S2 | 2144h | 2144h | PRESNC | Nokia | balazs.bertenyi@nsn.com | Rel-6 | Maurice |  |
| 1806 | 22.3 | Stage 3 | 703d | 2002-04-01 A | 2004-12-08 A | 100% | 2002-04-01 | 2004-12-08 | 703d | finish no earlier than 2004-12-08 | N1 | 5624h | 5624h | PRESNC | Lucent | Keith Drage (drage@alcatel-lucent.com) | Rel-6 | Frederic |  |
| 1807 | 581.4 | Stage 3 (CN3 Part Pk interface) | 770d? | 2002-04-01 A | 2005-03-11 A | 100% | 2002-04-01 | 2005-03-11 | 770d? | finish no earlier than 2005-03-11 | N3 | 6160h | 6160h | PRESNC |  |  | Rel-6 | Gwiho |  |
| 1808 | 581.5 | Media Codecs and Formats for IMS Messaging and Presence | 650d? | 2003-06-12 A | 2005-12-07 A | 100% | 2003-06-12 | 2005-12-07 | 650d? | finish no earlier than 2005-12-07 | S4 | 5200h | 5200h | PRESNC-COFIMP | Nokia | harri.honko@nokia.com | Rel-6 | Paolo | 26.141, 26.936 |
| 1809 | 22.4 | Security issues | 79d | 2002-08-26 A | 2002-12-12 A | 100% | 2002-08-26 | 2002-12-12 | 79d | finish no earlier than 2002-12-12 | S3 | 632h | 632h | PRESNC |  |  | Rel-6 | Dionisio |  |
| 1810 | 581.7 | SIMPLE Presence | 326d? | 2004-01-01 A | 2005-03-31 A | 100% | 2004-01-01 | 2005-03-31 | 326d? | finish no earlier than 2004-12-30 | OMA | 2608h | 2608h | PRESNC |  | OMA-LIAISON@mail.openmobilealliance.org | Rel-6 |  |  |
| 1811 | 25 | **Enhanced A/Gb feasibility study** | 51d? | 2002-08-30 A | 2002-11-08 A | 100% | 2002-08-30 | 2002-11-08 | 51d? |  | GP | 3264h | 3264h | AGbEnFS | Vodafone | jose-luis.carrizo@vodafone.co.uk | Rel-6 | Paolo | None |
| 1812 | 25.1 | **Feasibility study on A/Gb enhancements** | 51d? | 2002-08-30 A | 2002-11-08 A | 100% | 2002-08-30 | 2002-11-08 | 51d? |  | G2 | 2856h | 2856h | AGbEnFS-FS | Vodafone | jose-luis.carrizo@vodafone.co.uk | Rel-6 | Gert | None |
| 1813 | 25.1.1 | Requirements for the support of conversational services | 51d | 2002-08-30 A | 2002-11-08 A | 100% | 2002-08-30 | 2002-11-08 | 51d | finish no earlier than 2002-11-08 | GP | 408h | 408h | AGbEnFS-FS |  |  | Rel-6 | Paolo | None |
| 1814 | 582.1.2 | Identification of the different building blocks for the provision of conversational services on the existing A/Gb protocol stack | 51d? | 2002-08-30 A | 2002-11-08 A | 100% | 2002-08-30 | 2002-11-08 | 51d? | finish no earlier than 2002-11-08 | GP | 408h | 408h | AGbEnFS-FS |  |  | Rel-6 | Paolo | None |
| 1815 | 582.1.3 | Outline of impact and feasibility of these building blocks and their different solutions | 51d? | 2002-08-30 A | 2002-11-08 A | 100% | 2002-08-30 | 2002-11-08 | 51d? | finish no earlier than 2002-11-08 | GP | 408h | 408h | AGbEnFS-FS |  |  | Rel-6 | Paolo | None |
| 1816 | 25.1.4 | Impact on 3GPP architecture and requirement to co-ordinatge with other TSGs (CN, SA) | 51d | 2002-08-30 A | 2002-11-08 A | 100% | 2002-08-30 | 2002-11-08 | 51d | finish no earlier than 2002-11-08 | GP | 408h | 408h | AGbEnFS-FS |  |  | Rel-6 | Paolo | None |
| 1817 | 25.1.5 | Standardisation effort | 51d | 2002-08-30 A | 2002-11-08 A | 100% | 2002-08-30 | 2002-11-08 | 51d | finish no earlier than 2002-11-08 | GP | 408h | 408h | AGbEnFS-FS |  |  | Rel-6 | Paolo | None |
| 1818 | 25.1.6 | Dependency to other features | 51d | 2002-08-30 A | 2002-11-08 A | 100% | 2002-08-30 | 2002-11-08 | 51d | finish no earlier than 2002-11-08 | GP | 408h | 408h | AGbEnFS-FS |  |  | Rel-6 | Paolo | None |
| 1819 | 26 | **Flexible Layer One for GERAN** | 1171d | 2000-01-03 A | 2004-06-25 A | 100% | 2000-01-03 | 2004-06-25 | 1171d |  | GP | 71551h | 71551h | FLOGER | Nokia | benoist.sebire@nokia.com | Rel-6 | Paolo |  |
| 1820 | 26.1 | **Realisation of a Flexible Layer One** | 1126d | 2000-01-03 A | 2004-04-23 A | 100% | 2000-01-03 | 2004-04-23 | 1126d |  | GP | 42816h | 42816h | FLOGER-Real | Nokia | benoist.sebire@nokia.com | Rel-6 | Paolo |  |
| 1821 | 26.1.1 | Technical Report | 471d | 2002-04-19 A | 2004-02-06 A | 100% | 2002-04-19 | 2004-02-06 | 471d | finish no earlier than 2004-02-06 | GP | 3768h | 3768h | FLOGER-Real |  |  | Rel-6 | Paolo |  |
| 1822 | 26.1.2 | Architecture in 45.001 and 43.051 | 526d | 2002-04-19 A | 2004-04-23 A | 100% | 2002-04-19 | 2004-04-23 | 526d | finish no earlier than 2004-04-23 | G1 | 4208h | 4208h | FLOGER-Real |  |  | Rel-6 | Paolo |  |
| 1823 | 26.1.3 | Multiplexing in 45.002 | 526d | 2002-04-19 A | 2004-04-23 A | 100% | 2002-04-19 | 2004-04-23 | 526d | finish no earlier than 2004-04-23 | G1 | 4208h | 4208h | FLOGER-Real |  |  | Rel-6 | Paolo |  |
| 1824 | 26.1.4 | Channel Coding in 45.003 | 526d | 2002-04-19 A | 2004-04-23 A | 100% | 2002-04-19 | 2004-04-23 | 526d | finish no earlier than 2004-04-23 | G1 | 4208h | 4208h | FLOGER-Real |  |  | Rel-6 | Paolo |  |
| 1825 | 26.1.5 | Performance Requirements in 45.005 | 1126d | 2000-01-03 A | 2004-04-23 A | 100% | 2000-01-03 | 2004-04-23 | 1126d | finish no earlier than 2004-04-23 | G1 | 9000h | 9000h | FLOGER-Real |  |  | Rel-6 | Paolo |  |
| 1826 | 26.1.6 | Radio subsystem link control in 45.008 | 526d | 2002-04-19 A | 2004-04-23 A | 100% | 2002-04-19 | 2004-04-23 | 526d | finish no earlier than 2004-04-23 | G1 | 4208h | 4208h | FLOGER-Real |  |  | Rel-6 | Paolo |  |
| 1827 | 26.1.7 | Requirements in 44.004 | 526d | 2002-04-19 A | 2004-04-23 A | 100% | 2002-04-19 | 2004-04-23 | 526d | finish no earlier than 2004-04-23 | G2 | 4208h | 4208h | FLOGER-Real |  |  | Rel-6 | Gert |  |

Notes:
- 1803: merged "Presence Service Enhancements" (UID31028, PRES1) to this feature as no answer was provided on why Presence and Presence Encmts had same target completion date
- 1804: -
- 1805: -
- 1806: Dependency to 2 IETF drafts, no known work at the moment
- 1807: No Contributions so far - only requires a little work
- 1808: -
- 1809: LSs handled in SA3. WID approved SP#17 Contribution at S3#25 & following e-mail discussion. Marked as closed 12/2008 (was marked 90% complete)
- 1810: Updated according to SP-040232
- 1811: -
- 1812: -
- 1813: -
- 1814: -
- 1815: -
- 1816: -
- 1817: -
- 1818: -
- 1819: -
- 1820: -
- 1821: -
- 1822: -
- 1823: -
- 1824: -
- 1825: -
- 1826: -
- 1827: -

| ID | WBS | Task | Type | Duration | Start | Finish | Complete | Baseline start | Baseline finish | Baseline duration | Constraint | Resources | Work | Actual work | Text1 | Text4 | Text5 | Text6 | Text8 | Text12 | Text3 |
| --- | --- | --- | --- | --- | --- | --- | --- | --- | --- | --- | --- | --- | --- | --- | --- | --- | --- | --- | --- | --- | --- |
| 1828 | 26.2 | **Signalling and protocol support for a Flexible Layer One** |  | 571d | 2002-04-19 A | 2004-06-25 A | 100% | 2002-04-19 | 2004-06-25 | 571d |  | G2 | 13704h | 13704h | FLOGER-SigPro | Nokia | benoist.sebire@nokia.com | Rel-6 | Gert |  |  |
| 1829 | 26.2.1 | Modifications to RLC/MAC in 44.060 and 44.160 |  | 571d | 2002-04-19 A | 2004-06-25 A | 100% | 2002-04-19 | 2004-06-25 | 571d | finish no earlier than 2004-06-25 | G2 | 4568h | 4568h | FLOGER-SigPro |  |  | Rel-6 | Gert |  |  |
| 1830 | 26.2.2 | Modifications to RRC in 44.118 and 44.018 |  | 571d | 2002-04-19 A | 2004-06-25 A | 100% | 2002-04-19 | 2004-06-25 | 571d | finish no earlier than 2004-06-25 | G2 | 4568h | 4568h | FLOGER-SigPro |  |  | Rel-6 | Gert |  |  |
| 1831 | 26.3 | **Security for a Flexible Layer One** |  | 356d | 2002-04-19 A | 2003-08-29 A | 100% | 2002-04-19 | 2003-08-29 | 356d |  | S3, G2 | 5663.03h | 5663.03h | FLOGER-SecFLO | Nokia | benoist.sebire@nokia.com | Rel-6 | Dionisio |  |  |
| 1832 | 26.3.1 | Ciphering in 44.160,44.118, 44.060 and 44.018 |  | 356d | 2002-04-19 A | 2003-08-29 A | 100% | 2002-04-19 | 2003-08-29 | 356d | finish no earlier than 2003-08-29 | S3, G2 | 2848h | 2848h | FLOGER-SecFLO |  |  | Rel-6 | Dionisio |  |  |
| 1833 | 26.4 | **Deleted - GERAN MS Conformance test for the Flexible Layer One - DELETE** |  | 0d | 2004-02-06 A | 2004-02-06 A | 100% | 2004-02-06 | 2004-02-06 | 0d |  | G4,G5 |  |  | FLOGER-Msconf | Nokia | benoist.sebire@nokia.com | Rel-6 | Paolo | GP-27 |  |
| 1834 | 26.4.1 | Deleted at TSG #27 - MS Test in 51.010 | milestone | 0d | 2004-02-06 A | 2004-02-06 A | 100% | 2004-02-06 | 2004-02-06 | 0d | finish no earlier than 2004-02-06 | G4,G5 |  |  | FLOGER-Msconf |  |  | Rel-6 | Paolo | GP-22 |  |
| 1835 | 26.5 | **Deleted - GERAN BTS Conformance test for the Flexible Layer One - DELETE** |  | 0d | 2004-02-06 A | 2004-02-06 A | 100% | 2004-02-06 | 2004-02-06 | 0d |  | G3new |  |  | FLOGER-BTSconf | Nokia | benoist.sebire@nokia.com | Rel-6 | Ingbert | GP-27 |  |
| 1836 | 26.5.1 | Deleted at TGS #27 - BTS Test in 51.021 - DELETE | milestone | 0d | 2004-02-06 A | 2004-02-06 A | 100% | 2004-02-06 | 2004-02-06 | 0d | finish no earlier than 2004-02-06 | G3new |  |  | FLOGER-BTSconf |  |  | Rel-6 | Ingbert | GP-22 |  |
| 1837 | 27 | Uplink TDOA feasibility study |  | 151d | 2001-11-30 A | 2002-06-28 A | 100% | 2001-11-30 | 2002-06-28 | 151d | finish no earlier than 2002-06-28 | GP | 1208h | 1208h | TDOAF | TruePosition | Bob Gross (rlgross@trueposition.com) | Rel-6 | Paolo |  | 45.811 |
| 1838 | 28 | **Multimedia Broadcast and Multicast Service** |  | 1781d? | 2001-05-11 A | 2008-03-07 A | 100% | 2001-05-11 | 2008-03-07 | 1781d? |  | S1,S2,S4,S5,RP,R5,GP | 158712h | 158712h | MBMS |  |  | Rel-6 | Alain |  |  |
| 1839 | 28.1 | Stage 1 |  | 232d | 2001-05-11 A | 2002-04-01 A | 100% | 2001-05-11 | 2002-04-01 | 232d | finish no earlier than 2002-04-01 | S1 | 1856h | 1856h | MBMS |  |  | Rel-6 | Alain |  | 22.146, 22.101 |
| 1840 | 28.2 | **Stage 2** |  | 648d | 2001-09-24 A | 2004-03-17 A | 100% | 2001-09-24 | 2004-03-17 | 648d |  | S2 | 10408h | 10408h | MBMS |  |  | Rel-6 | Maurice |  |  |
| 1841 | 28.2.1 | TR on Architectural Study |  | 240d | 2001-09-24 A | 2002-08-23 A | 100% | 2001-09-24 | 2002-08-23 | 240d | finish no earlier than 2002-08-23 | S2 | 1920h | 1920h | MBMS |  |  | Rel-6 | Maurice |  | 23.846 |
| 1842 | 28.2.2 | Stage 2 Specification Work |  | 413d | 2002-08-19 A | 2004-03-17 A | 100% | 2002-08-19 | 2004-03-17 | 413d | finish no earlier than 2004-03-17 | S2 | 3304h | 3304h | MBMS |  |  | Rel-6 | Maurice |  | 23.246 |
| 1843 | 28.3 | **Introduction of MBMS in RAN** |  | 967d? | 2002-01-01 A | 2005-09-14 A | 100% | 2002-01-01 | 2005-09-14 | 967d? |  | R2 | 15992h | 15992h | MBMS-RAN | Nokia | juho.pirskanen@nokia.com | Rel-6 | Joern |  | 25.346, 25.304, 25.321, 25.322, 25.323, 25.331 |
| 1844 | 585.3.1 | Introduction of MBMS in RAN (physical & upper layers, access network interfaces) |  | 771d? | 2002-01-01 A | 2004-12-14 A | 100% | 2002-01-01 | 2004-12-14 | 771d? | finish no earlier than 2004-12-14 | R2 | 6168h | 6168h | MBMS-RAN | Nokia | juho.pirskanen@nokia.com | Rel-6 | Joern |  | 25.346, 25.304, 25.321, 25.322, 25.323 |
| 1845 | 585.3.2 | UE Performance Requirements for MBMS |  | 261d? | 2004-09-15 A | 2005-09-14 A | 100% | 2004-09-15 | 2005-09-14 | 261d? | finish no earlier than 2005-09-15 | R4 | 2088h | 2088h | MBMS-RAN-RF | Ericsson | Torgny.Palenius@ericsson.com | Rel-6 | Issam |  | 25.101, 25.133 |
| 1846 | 28.4 | Support of the MBMS in CN protocols |  | 647d | 2002-06-18 A | 2004-12-08 A | 100% | 2002-06-18 | 2004-12-08 | 647d | finish no earlier than 2004-12-08 | N1 | 5176h | 5176h | MBMS |  |  | Rel-6 | Frederic |  |  |
| 1847 | 585.5 | Gmb interface for MBMS (CN3 part) |  | 334d | 2003-08-29 A | 2004-12-08 A | 100% | 2003-08-29 | 2004-12-08 | 334d | finish no earlier than 2004-12-08 | N3 | 2672h | 2672h | MBMS |  |  | Rel-6 | Gwiho |  | 29.061 |
| 1848 | 28.5 | Security Aspects of MBMS |  | 710d | 2002-07-01 A | 2005-03-18 A | 100% | 2002-07-01 | 2005-03-18 | 710d | finish no earlier than 2005-03-18 | S3 | 5680h | 5680h | MBMS |  | adrian.escott@three.co.uk | Rel-6 | Dionisio |  |  |
| 1849 | 28.6 | **Support of MBMS in GERAN** |  | 892d? | 2001-08-30 A | 2005-01-28 A | 100% | 2001-08-30 | 2005-01-28 | 892d? |  | GP | 71040h | 71040h | MBMS-GERAN |  |  | Rel-6 | Paolo |  |  |
| 1850 | 28.6.1 | Impact on the logical and physical channels |  | 631d | 2002-08-30 A | 2005-01-28 A | 100% | 2002-08-30 | 2005-01-28 | 631d | finish no earlier than 2005-01-28 | GP | 5048h | 5048h | MBMS-GERAN |  |  | Rel-6 | Paolo |  |  |
| 1851 | 28.6.4 | Re-synchronisation at cell change |  | 631d | 2002-08-30 A | 2005-01-28 A | 100% | 2002-08-30 | 2005-01-28 | 631d | finish no earlier than 2005-01-28 | G2 | 5048h | 5048h | MBMS-GERAN |  |  | Rel-6 | Gert |  |  |
| 1852 | 585.7.3 | Simultaneous support of MBMS services |  | 631d? | 2002-08-30 A | 2005-01-28 A | 100% | 2002-08-30 | 2005-01-28 | 631d? | finish no earlier than 2005-01-28 | GP | 5048h | 5048h | MBMS-GERAN |  |  | Rel-6 | Paolo |  |  |
| 1853 | 585.7.4 | Simultaneous support of MBMS and non-MBMS services |  | 892d? | 2001-08-30 A | 2005-01-28 A | 100% | 2001-08-30 | 2005-01-28 | 892d? | finish no earlier than 2005-01-28 | GP | 7136h | 7136h | MBMS-GERAN |  |  | Rel-6 | Paolo |  |  |
| 1854 | 585.7.5 | Resynchronisation at cell change |  | 892d? | 2001-08-30 A | 2005-01-28 A | 100% | 2001-08-30 | 2005-01-28 | 892d? | finish no earlier than 2005-01-28 | GP | 7136h | 7136h | MBMS-GERAN |  |  | Rel-6 | Paolo |  |  |
| 1855 | 28.6.5 | Decision making process between point-to-point or pont-to-multipoint configurations |  | 631d | 2002-08-30 A | 2005-01-28 A | 100% | 2002-08-30 | 2005-01-28 | 631d | finish no earlier than 2005-01-28 | GP | 5048h | 5048h | MBMS-GERAN |  |  | Rel-6 | Paolo |  |  |
| 1856 | 28.6.6 | MBMS channel allocations procedures to multiple MSs |  | 631d | 2002-08-30 A | 2005-01-28 A | 100% | 2002-08-30 | 2005-01-28 | 631d | finish no earlier than 2005-01-28 | GP | 5048h | 5048h | MBMS-GERAN |  |  | Rel-6 | Paolo |  |  |
| 1857 | 28.6.7 | Changes to the Gb interface |  | 631d | 2002-08-30 A | 2005-01-28 A | 100% | 2002-08-30 | 2005-01-28 | 631d | finish no earlier than 2005-01-28 | GP | 5048h | 5048h | MBMS-GERAN |  |  | Rel-6 | Paolo |  |  |
| 1858 | 28.6.8 | GERAN specific changes to the Iu-ps interface |  | 631d | 2002-08-30 A | 2005-01-28 A | 100% | 2002-08-30 | 2005-01-28 | 631d | finish no earlier than 2005-01-28 | GP | 5048h | 5048h | MBMS-GERAN |  |  | Rel-6 | Paolo |  |  |
| 1859 | 28.6.9 | Interaction between MBMS and Iu-flex |  | 631d | 2002-08-30 A | 2005-01-28 A | 100% | 2002-08-30 | 2005-01-28 | 631d | finish no earlier than 2005-01-28 | GP | 5048h | 5048h | MBMS-GERAN |  |  | Rel-6 | Paolo |  |  |
| 1860 | 28.6.10 | Security aspects |  | 631d | 2002-08-30 A | 2005-01-28 A | 100% | 2002-08-30 | 2005-01-28 | 631d | finish no earlier than 2005-01-28 | GP | 5048h | 5048h | MBMS-GERAN |  |  | Rel-6 | Paolo |  |  |
| 1861 | 585.7.12 | MBMS-GERAN - MS conformance tests |  | 786d? | 2002-01-25 A | 2005-01-28 A | 100% | 2002-01-25 | 2005-01-28 | 786d? | finish no earlier than 2005-01-28 | G3new | 6288h | 6288h | MBMS-GERAN |  |  | Rel-6 | Ingbert |  |  |
| 1862 | 585.7.13 | Deleted - MS conformance tests - G5 | milestone | 0d? | 2003-06-27 A | 2003-06-27 A | 100% | 2003-06-27 | 2003-06-27 | 0d? | start no earlier than 2003-06-27 | G5 |  |  | MBMS-GERAN |  |  | Rel-6 | Paolo | GP-19 |  |

Notes:
- 1828: -
- 1829: -
- 1830: -
- 1831: -
- 1832: -
- 1833: -
- 1834: -
- 1835: -
- 1836: -
- 1837: -
- 1838: Title renamed at SP#13
- 1839: This may or may not be a separate stage 1. In the meantime, CRs are proposed for 22.101
- 1840: -
- 1841: -
- 1842: -
- 1843: -
- 1844: Was "Introduction of MBMS in RAN" before RP#25. Created w/o WIDS after RAN approved the WT for RF aspects.Take WIDS from the parent BB
- 1845: Approved at RP#25 as RP-040370
- 1846: -
- 1847: -
- 1848: WID approved SP#17. 2004-12: Expected completion March 2005
- 1849: -
- 1850: -
- 1851: -
- 1852: -
- 1853: -
- 1854: -
- 1855: -
- 1856: -
- 1857: -
- 1858: -
- 1859: -
- 1860: -
- 1861: -
- 1862: -

| ID | WBS | Task | Type | Duration | Start | Finish | Complete | Baseline start | Baseline finish | Baseline duration | Constraint | Deadline | Resources | Work | Actual work | Text1 | Text6 | Text8 | Text4 | Text5 | Text10 | Text12 |
| --- | --- | --- | --- | --- | --- | --- | --- | --- | --- | --- | --- | --- | --- | --- | --- | --- | --- | --- | --- | --- | --- | --- |
| 1863 | 28.1 | **MBMS User Services** |  | 743d? | 2003-05-13 A | 2006-03-16 A | 100% | 2003-05-13 | 2006-03-16 | 743d? |  |  | S1 | 13576h | 13576h | MBMS | Rel-6 | Alain |  |  |  |  |
| 1864 | 28.1 | MBMS User Services Stage 1 |  | 233d | 2003-05-13 A | 2004-04-01 A | 100% | 2003-05-13 | 2004-04-01 | 233d | start no earlier than 2003-05-13 |  | S1 | 1864h | 1864h | MBMS | Rel-6 | Alain |  |  |  |  |
| 1865 | 585.8.2 | Definition of MBMS user services, media codecs, formats and transport/application protocols using MBMS |  | 721d? | 2003-06-12 A | 2006-03-16 A | 100% | 2003-06-12 | 2006-03-16 | 721d? | finish no earlier than 2006-03-16 |  | S4 | 5768h | 5768h | MBMS-TSMBMS | Rel-6 | Paolo | Nokia | igor.curcio@nokia.com |  |  |
| 1866 | 585.9 | MBMS charging |  | 108d? | 2005-01-11 A | 2005-06-09 A | 100% | 2005-01-11 | 2005-06-09 | 108d? | start no earlier than 2005-01-11 |  | S5 | 864h | 864h | MBMS-CH | Rel-6 | Dionisio |  |  |  |  |
| 1867 | 585.10 | **MBMS UE Conformance Testing** |  | 521d? | 2006-03-10 A | 2008-03-07 A | 100% | 2006-03-10 | 2008-03-07 | 521d? |  |  | R5,T1 | 17200h | 17200h | MBMS-UEConTest | Rel-6 | Ingbert |  |  |  |  |
| 1868 | 16.5.1 | RF/RRM Conformance Test Aspects – MBMS (FDD) |  | 461d | 2006-06-02 A | 2008-03-07 A | 100% | 2006-06-02 | 2008-03-07 | 461d | finish no earlier than 2008-03-07 | 2006-06-02 | R5,T1 | 3688h | 3688h | MBMS-RAN-RF_Test | Rel-6 | Ingbert | Ericsson | leif.mattisson@ericsson.com | Fri 11/03/05 |  |
| 1869 | 585.10.2 | Conformance Test Aspects - MBMS for 3.84 Mcps and 7.68 Mcps TDD |  | 318d? | 2006-09-20 A | 2007-12-07 A | 100% | 2006-09-20 | 2007-12-07 | 318d? | finish no earlier than 2007-12-07 |  | R5,T1 | 2544h | 2544h | MBMS-UEConTest_TDH | Rel-6 | Ingbert | IPWireless | Timothy Speight (tspeight@ipwireless.com) |  |  |
| 1870 | 585.10.3 | Signalling Conformance Test Aspects – MBMS for LCR TDD |  | 318d? | 2006-09-20 A | 2007-12-07 A | 100% | 2006-09-20 | 2007-12-07 | 318d? | finish no earlier than 2007-12-07 |  | R5,T1 | 2544h | 2544h | MBMS-UEConTest_SIGTDL | Rel-6 | Ingbert | DATANG | zhaojian@datangmobile.cn |  |  |
| 1871 | 585.10.4 | Conformance Test Aspects – MBMS |  | 396d? | 2006-03-10 A | 2007-09-14 A | 100% | 2006-03-10 | 2007-09-14 | 396d? | finish no earlier than 2007-09-14 |  | R5,T1 | 3168h | 3168h | MBMS_Test | Rel-6 | Ingbert | Qualcomm | Shubhang Vora (svora@qualcomm.com) |  |  |
| 1872 | 16.5.1 | Conformance Test Aspects - 1.28 Mcps TDD MBMS RF/RRM |  | 136d | 2007-06-01 A | 2007-12-07 A | 100% | 2007-06-01 | 2007-12-07 | 136d | finish no earlier than 2007-12-07 | 2006-06-02 | R5,T1 | 1088h | 1088h | MBMS-UEConTest_RFTDL | Rel-6 | Ingbert | Datang Mobile | chenxiaozhong@datangmobile.cn | Fri 11/03/05 |  |
| 1873 | 29 | **Speech Recognition and Speech Enabled Services** |  | 1105d? | 2001-10-08 A | 2005-12-30 A | 100% | 2001-10-08 | 2005-12-30 | 1105d? |  |  | S1 | 20176h | 20176h | SRSES | Rel-6 | Alain |  |  |  |  |
| 1874 | 29.1 | Speech Enabled Services Based on Distributed Speech Recognition (DSR) |  | 115d | 2001-10-08 A | 2002-03-15 A | 100% | 2001-10-08 | 2002-03-15 | 115d | finish no earlier than 2002-03-15 |  | S1 | 920h | 920h | DSR | Rel-6 | Alain | Qualcomm | Dwilliams@qualcomm.com |  |  |
| 1875 | 29.2 | TR on Architectural impacts |  | 212d | 2003-05-12 A | 2004-03-02 A | 100% | 2003-05-12 | 2004-03-02 | 212d | finish no earlier than 2004-03-02 |  | S2 | 1696h | 1696h | SRSES | Rel-6 | Maurice |  |  |  |  |
| 1876 | 586.3 | Codec Work to Support Speech Recognition Framework for Automated Voice Services |  | 568d? | 2002-10-15 A | 2004-12-16 A | 100% | 2002-10-15 | 2004-12-16 | 568d? | finish no earlier than 2004-12-16 |  | S4 | 4544h | 4544h | SRSES-Codec | Rel-6 | Paolo | Motorola | David Pearce (bdp003@motorola.com) |  |  |
| 1877 | 586.4 | Multimodal support |  | 522d? | 2004-01-01 A | 2005-12-30 A | 100% | 2004-01-01 | 2005-12-30 | 522d? | finish no earlier than 2005-06-30 |  | OMA | 4176h | 4176h | SRSES | Rel-6 | Paolo |  | OMA-LIAISON@mail.openmobilealliance.org | SP-24 |  |
| 1878 | 586.5 | Deleted - SES codec negotiation at Session Description Protocol (SDP) | milestone | 0d? | 2003-06-04 A | 2003-06-04 A | 100% | 2003-06-04 | 2003-06-04 | 0d? | start no earlier than 2003-06-04 |  | N1 |  |  | SRSES | Rel-6 | Frederic |  |  |  | NP-23 |
| 1879 | 30 | **Generic User Profile Rel-6** |  | 889d | 2001-10-08 A | 2005-03-03 A | 100% | 2001-10-08 | 2005-03-03 | 889d |  |  | S1 | 24295.8h | 24295.8h | GUP | Rel-6 | Alain |  |  |  |  |
| 1880 | 30.1 | Stage 1 - Requirements |  | 430d | 2001-10-08 A | 2003-05-30 A | 100% | 2001-10-08 | 2003-05-30 | 430d | finish no earlier than 2002-12-09 |  | S1 | 3440h | 3440h | GUP | Rel-6 | Alain | T-Mobile | kurt.bischinger@t-mobile.at |  |  |
| 1881 | 30.3 | Stage 2 - Architecture |  | 355d | 2002-01-28 A | 2003-06-06 A | 100% | 2002-01-28 | 2003-06-06 | 355d | finish no earlier than 2003-06-06 |  | S2 | 2840h | 2840h | GUP | Rel-6 | Maurice | Nokia | harri.o.koskinen@nokia.com |  |  |
| 1882 | 30.2 | Stage 2 - Data Description Method |  | 586d | 2002-12-05 A | 2005-03-03 A | 100% | 2002-12-05 | 2005-03-03 | 586d | finish no earlier than 2005-03-03 |  | N4 | 4688h | 4688h | GUP | Rel-6 | Kimmo | T-Mobile | kurt.bischinger@t-mobile.at |  |  |
| 1883 | 30.5 | Stage 3 - Network |  | 468.98d | 2003-05-19 A | 2005-03-03 A | 100% | 2003-05-19 | 2005-03-03 | 468.98d | finish no earlier than 2005-03-03 |  | N4 | 3751.83h | 3751.83h | GUP | Rel-6 | Kimmo |  |  |  |  |
| 1884 | 30.6 | Security Aspects |  | 308d | 2002-07-16 A | 2003-09-18 A | 100% | 2002-07-16 | 2003-09-18 | 308d | finish no earlier than 2003-09-18 |  | S3 | 2464h | 2464h | GUP | Rel-6 | Dionisio | Lucent | Owen, Bradley (bvowen@lucent.com) |  |  |
| 1885 | 31 | **Digital Rights Management** |  | 690d? | 2001-10-08 A | 2004-05-28 A | 100% | 2001-10-08 | 2004-05-28 | 690d? |  |  | S1 | 10152h | 10152h | DRM | Rel-6 | Alain |  |  |  |  |
| 1886 | 31.1 | Requirements |  | 179d | 2001-10-08 A | 2002-06-13 A | 100% | 2001-10-08 | 2002-06-13 | 179d | finish no earlier than 2002-06-13 |  | S1 | 1432h | 1432h | DRM | Rel-6 | Alain | Openwave | nicholas.wood@openwave.com |  |  |
| 1887 | 588.2 | Stage 2 |  | 107d? | 2004-01-01 A | 2004-05-28 A | 100% | 2004-01-01 | 2004-05-28 | 107d? | finish no earlier than 2004-05-28 |  | OMA | 856h | 856h | DRM | Rel-6 |  |  | OMA-LIAISON@mail.openmobilealliance.org | SP-24 |  |
| 1888 | 588.3 | Stage 3 |  | 107d? | 2004-01-01 A | 2004-05-28 A | 100% | 2004-01-01 | 2004-05-28 | 107d? | finish no earlier than 2004-05-28 |  | OMA | 856h | 856h | DRM | Rel-6 |  |  | OMA-LIAISON@mail.openmobilealliance.org | SP-24 |  |
| 1889 | 31.3 | Security |  | 186d | 2002-06-17 A | 2003-03-03 A | 100% | 2002-06-17 | 2003-03-03 | 186d | finish no earlier than 2003-03-03 |  | OMA | 1488h | 1488h | DRM | Rel-6 |  |  |  |  |  |
| 1890 | 588.5 | Deleted - Monitoring of Stages 2 and 3 progress (actual work to be done by OMA) | milestone | 0d? | 2003-03-21 A | 2003-03-21 A | 100% | 2003-03-21 | 2003-03-21 | 0d? | start no earlier than 2002-08-19 |  | S1 |  |  | DRM | Rel-6 | Alain |  |  |  | SP-19 |

Notes:
- 1863: - / Text3: 22.246
- 1864: - / Text3: 22.246
- 1865: TR26.946 tbc by March 06 / Text3: 26.346, 26.936, 26.946
- 1866: SP#28 06/2005 completed / Text3: 32.273
- 1867: BB place holder for a number of RAN5 Tasks. Moved in from the Stoyan/Testing WP / Text3: 34.108, 34.109, 34.121-1, 34.121-2, 34.122, 34.123-1, 34.123-2, 34.123-3
- 1868: TS 34.109 is under RAN2; RAN5 need to identify possible new requirements on UE test loop functionality to enable testing / Text3: 34.108, 34.109, 34.121-1, 34.121-2
- 1869: - / Text3: 34.108, 34.122, 34.123-1, 34.123-2, 34.123-3
- 1870: - / Text3: 34.108, 34.123-1, 34.123-2, 34.123-3
- 1871: - / Text3: 34.108, 34.123-1, 34.123-2, 34.123-3
- 1872: - / Text3: 34.108, 34.109, 34.122
- 1873: -
- 1874: - / Text3: 22.977, 22.941, 23.207, 22.243
- 1875: - / Text3: 23.877
- 1876: - / Text3: 26.235, 26.236, 26.243, 26.177, 26.943
- 1877: -
- 1878: Abandoned NP-23
- 1879: -
- 1880: - / Text3: 22.240, 22.228
- 1881: - / Text3: 23.240
- 1882: TR approved in CN#26 / Text3: 23.241
- 1883: - / Text3: 29.240
- 1884: WID approved SP#17. SA WG3 progress slow, depends on progress in other groups. / Text3: 33.102, 33.203, 33.210
- 1885: Foreseen start and completion dates introduced by MCC (no indication at all on the WID)
- 1886: -
- 1887: -
- 1888: -
- 1889: SA3 acknowledge role in WI at SA3#20. Active contribution S3#24, S3#25. S3 WID approved SP#17
- 1890: Replaced by UID 60005 and 60006

| ID | WBS | Task | Type | Duration | Start | Finish | Complete | Baseline start | Baseline finish | Baseline duration | Constraint | Deadline | Resources | Work | Actual work | Text1 | Text4 | Text5 | Text6 | Text8 | Text3 | Text10 |
| --- | --- | --- | --- | --- | --- | --- | --- | --- | --- | --- | --- | --- | --- | --- | --- | --- | --- | --- | --- | --- | --- | --- |
| 1891 | 32 | **WLAN-UMTS Interworking Rel-6** |  | 1495d? | 2000-01-03 A | 2005-09-22 A | 100% | 2000-01-03 | 2005-09-22 | 1495d? |  |  | S1 | 45472h | 45472h | WLAN | Telenor | frederic.paint@telenor.com | Rel-6 | Alain |  |  |
| 1892 | 32.1 | Technical Report |  | 901d? | 2000-01-03 A | 2003-06-13 A | 100% | 2000-01-03 | 2003-06-13 | 901d? | finish no earlier than 2003-06-13 |  | S1 | 7200h | 7200h | WLAN-TR | T-mobile | Mark.Younge@t-mobile.com | Rel-6 | Alain | 22.934 |  |
| 1893 | 589.2 | Stage 1 |  | 375d? | 2003-01-06 A | 2004-06-11 A | 100% | 2003-01-06 | 2004-06-11 | 375d? |  |  | S1 | 920h | 920h | WLAN-TS | Telenor | frederic.paint@telenor.com | Rel-6 | Alain | 22.101, 22.105 | SP-24 |
| 1894 | 32.2 | Architecture Definition for scenarii 2 and 3 |  | 571d | 2002-03-25 A | 2004-05-31 A | 100% | 2002-03-25 | 2004-05-31 | 571d | finish no earlier than 2004-05-31 |  | S2 | 4568h | 4568h | WLAN |  |  | Rel-6 | Maurice | 23.234 |  |
| 1895 | 32.3 | Security |  | 125d | 2002-09-30 A | 2003-03-21 A | 100% | 2002-09-30 | 2003-03-21 | 125d | finish no earlier than 2003-03-21 |  | S3 | 1000h | 1000h | WLAN | Ericsson | luis.lopez-soria@ece.ericsson.se | Rel-6 | Dionisio | 21.133, 33.106, 33.107, 33.108, 33.200, 33.203, 33.210 |  |
| 1896 | 589.5 | Stage 3 - CN4 aspects |  | 334d? | 2003-05-23 A | 2004-09-01 A | 100% | 2003-05-23 | 2004-09-01 | 334d? | finish no earlier than 2004-09-01 |  | N4 | 2672h | 2672h | WLAN-IW | Nokia | raquel.rodriguez@nokia.com | Rel-6 | Kimmo | 29.234, 29.061 |  |
| 1897 | 589.6 | Stage 3 - CN3 aspects (Wi Interface for Scenario 3) |  | 355d? | 2003-05-23 A | 2004-09-30 A | 100% | 2003-05-23 | 2004-09-30 | 355d? | start no earlier than 2003-05-23 |  | N3 | 2840h | 2840h | WLAN |  |  | Rel-6 | Gwiho | 29.161 | SP-24 |
| 1898 | 589.7 | Stage 3 for scenario 2 |  | 339d? | 2003-05-23 A | 2004-09-08 A | 100% | 2003-05-23 | 2004-09-08 | 339d? | finish no earlier than 2004-09-08 |  | N1 | 2712h | 2712h | WLAN |  |  | Rel-6 | Frederic |  |  |
| 1899 | 589.8 | Stage 3 for scenario 3 |  | 404d? | 2003-05-23 A | 2004-12-08 A | 100% | 2003-05-23 | 2004-12-08 | 404d? | finish no earlier than 2004-12-08 |  | N1 | 3232h | 3232h | WLAN |  |  | Rel-6 | Frederic |  | SP-24 |
| 1900 | 589.9 | WLAN charging |  | 655d? | 2003-03-21 A | 2005-09-22 A | 100% | 2003-03-21 | 2005-09-22 | 655d? | finish no earlier than 2005-09-22 |  | S5 | 5240h | 5240h | WLAN-CH | Nokia | Benni ALEXANDER | Rel-6 | Dionisio | 32.252 |  |
| 1901 | 589.10 | USIM enhancements for WLAN Interworking |  | 391d? | 2003-09-05 A | 2005-03-04 A | 100% | 2003-09-05 | 2005-03-04 | 391d? | finish no earlier than 2005-03-04 |  | T3 | 3128h | 3128h | WLAN | Axalto | Jabellan@axalto.com | Rel-6 | Xavier |  |  |
| 1902 | 33 | **Priority Service** |  | 347d? | 2002-05-30 A | 2003-09-26 A | 100% | 2002-05-30 | 2003-09-26 | 347d? |  |  | S1 | 6464h | 6464h | PRIOR1 | Telcordia | James Garrahan (jgarraha@telcordia.com) | Rel-6 | Alain |  |  |
| 1903 | 33.1 | Feasibility Study |  | 1d | 2002-06-14 A | 2002-06-14 A | 100% | 2002-06-14 | 2002-06-14 | 1d | finish no earlier than 2002-06-14 |  | S1 | 8h | 8h | PRIOR-FS | Telcordia | James Garrahan (jgarraha@telcordia.com) | Rel-6 | Alain | 22.950 |  |
| 1904 | 33.2 | Stage 1 - Requirements |  | 340d | 2002-05-30 A | 2003-09-17 A | 100% | 2002-05-30 | 2003-09-17 | 340d | finish no earlier than 2003-09-17 |  | S1 | 2720h | 2720h | PRIOR-SR | Telcordia | James Garrahan (jgarraha@telcordia.com) | Rel-6 | Alain |  |  |
| 1905 | 590.3 | Priority service implementation guide |  | 131d? | 2003-03-28 A | 2003-09-26 A | 100% | 2003-03-28 | 2003-09-26 | 131d? | finish no earlier than 2003-09-26 |  | S1 | 1048h | 1048h | PRIOR1 | Telcordia | James Garrahan (jgarraha@telcordia.com) | Rel-6 | Alain | 22.952 |  |
| 1906 | 34 | **Network Sharing** |  | 820d? | 2003-01-20 A | 2006-03-10 A | 100% | 2003-01-20 | 2006-03-10 | 820d? |  |  | S1,S2,N1,R2,R5 | 18696h | 18696h | NTShar | T-Mobile | michele.zarri@t-mobile.co.uk | Rel-6 | Alain |  |  |
| 1907 | 34.1 | Technical Report |  | 240d? | 2003-01-20 A | 2003-12-19 A | 100% | 2003-01-20 | 2003-12-19 | 240d? |  |  | S1 | 1920h | 1920h | NTShar-TR | T-Mobile | michele.zarri@t-mobile.co.uk | Rel-6 | Alain | 22.951 |  |
| 1908 | 591.2 | Stage 1 - CRs to implement Network Sharing |  | 240d? | 2003-01-20 A | 2003-12-19 A | 100% | 2003-01-20 | 2003-12-19 | 240d? | finish no earlier than 2003-12-19 |  | S1 | 1920h | 1920h | NTSharCR | T-Mobile | michele.zarri@t-mobile.co.uk | Rel-6 | Alain | 22.011, 22.101, 22.115, 22.129 |  |
| 1909 | 591.3 | Stage 2 |  | 372d? | 2003-02-27 A | 2004-07-30 A | 100% | 2003-02-27 | 2004-07-30 | 372d? | finish no earlier than 2004-07-30 |  | S2 | 2976h | 2976h | NTShar | T-Mobile | michele.zarri@t-mobile.co.uk | Rel-6 | Maurice | 23.002, 23.060, 23.221, 23.236, new 23.251 |  |
| 1910 | 591.4 | Network sharing - stage 3 |  | 404d? | 2003-05-23 A | 2004-12-08 A | 100% | 2003-05-23 | 2004-12-08 | 404d? | finish no earlier than 2004-12-08 |  | N1 | 3232h | 3232h | NTShar | T-Mobile | michele.zarri@t-mobile.co.uk | Rel-6 | Frederic | 23.008, 23.122, 24.007, 24.008, 29.018 |  |
| 1911 | 591.5 | Enhancement of the support of network sharing in the UTRAN | milestone | 0d | 2003-09-19 A | 2003-09-19 A | 100% | 2003-09-19 | 2003-09-19 | 0d |  |  | R2 |  |  | NTShar-UTRANEnh | TeliaSonera | Anders.Dahlen@TeliaSonera.com | Rel-6 | Joern | 25.401, 25.413, 25.331, 25.304 |  |
| 1912 | 16.5.1 | Conformance Test Aspects – Network Sharing |  | 261d | 2005-03-11 A | 2006-03-10 A | 100% | 2005-03-11 | 2006-03-10 | 261d | finish no earlier than 2006-03-10 | 2006-03-10 | R5 | 2088h | 2088h | NTShar-UTRANEnh_Test | TeliaSonera | Niklas.Wiren@TeliaSonera.com | Rel-6 | Ingbert | 34.108, 34.123-1, 34.123-2, 34.123-3 | Fri 11/03/05 |
| 1913 | 35 | **QoS Improvements** |  | 628d? | 2002-07-15 A | 2004-12-08 A | 100% | 2002-07-15 | 2004-12-08 | 628d? |  |  | S2,N3 | 13128h | 13128h | QoS1 | Nokia |  | Rel-6 | Maurice | 23.107, 23.207, 23.221 |  |
| 1914 | 35.1 | FS on Dynamic Policy control enhancements for end-to-end QoS |  | 465d | 2002-07-15 A | 2004-04-23 A | 100% | 2002-07-15 | 2004-04-23 | 465d | finish no earlier than 2004-04-23 |  | S2 | 3720h | 3720h | QoS1 | Nortel | Claire Mousset | Rel-6 | Maurice | 23.917 withdrawn (Contents all in 23.207) |  |
| 1915 | 592.2 | Definition of the Gq interface |  | 214d? | 2003-07-01 A | 2004-04-23 A | 100% | 2003-07-01 | 2004-04-23 | 214d? | finish no earlier than 2004-04-23 |  | S2 | 1712h | 1712h | QoS1 |  | Janne Rinne | Rel-6 | Maurice | 23.207 |  |
| 1916 | 592.3 | Gq interface specification for Dynamic Policy control enhancements – Stage 3 |  | 334d | 2003-08-29 A | 2004-12-08 A | 100% | 2003-08-29 | 2004-12-08 | 334d | finish no earlier than 2004-12-08 |  | N3 | 2672h | 2672h | QoS1 | Nokia | Anna.Sillanpaai@nokia.com | Rel-6 | Gwiho | 29.207, 29.208, 29.209 |  |

Notes:
- 1891: -
- 1892: -
- 1893: -
- 1894: -
- 1895: Active contribution S3#24, S3#25. WID approved SP#17
- 1896: WID approved at CN#19
- 1897: -
- 1898: -
- 1899: -
- 1900: SP#28: delayed 09/2005. WT also under SA5 BB 35017 Charging Management for Bearer level
- 1901: -
- 1902: -
- 1903: -
- 1904: -
- 1905: -
- 1906: -
- 1907: -
- 1908: -
- 1909: -
- 1910: -
- 1911: -
- 1912: -
- 1913: -
- 1914: -
- 1915: -
- 1916: [DAB - 25.05.04] - Delayed to Sept - possibly Dec 2004

| ID | WBS | Task | Type | Duration | Start | Finish | Complete | Baseline start | Baseline finish | Baseline duration | Constraint | Resources | Work | Actual work | Text1 | Text4 | Text5 | Text6 | Text8 | Text10 | Text12 |
| --- | --- | --- | --- | --- | --- | --- | --- | --- | --- | --- | --- | --- | --- | --- | --- | --- | --- | --- | --- | --- | --- |
| 1917 | 36 | **Subscriber certificates** |  | 728d? | 2002-02-25 A | 2004-12-08 A | 100% | 2002-02-25 | 2004-12-08 | 728d? |  | S3,S2,N1,N4,T3,OMA | 12888h | 12888h | SEC1-SC | Nokia | valtteri.niemi@nokia.com | Rel-6 | Dionisio |  |  |
| 1918 | 36.1 | Stage 1 |  | 144d | 2002-02-25 A | 2002-09-12 A | 100% | 2002-02-25 | 2002-09-12 | 144d | finish no earlier than 2002-09-12 | S3 | 1152h | 1152h | SEC1-SC | Nokia | valtteri.niemi@nokia.com | Rel-6 | Dionisio |  |  |
| 1919 | 36.2 | Architecture review |  | 24d | 2002-10-14 A | 2002-11-14 A | 100% | 2002-10-14 | 2002-11-14 | 24d | finish no earlier than 2002-11-14 | S2 | 192h | 192h | SEC1-SC | Nokia |  | Rel-6 | Maurice |  |  |
| 1920 | 593.3 | Stage 3 |  | 313d? | 2003-09-19 A | 2004-11-30 A | 100% | 2003-09-19 | 2004-11-30 | 313d? | finish no earlier than 2004-11-30 | N4,T3 | 2504h | 2504h | SEC1-SC | Nokia | Lauri Laitinen | Rel-6 | Kimmo |  |  |
| 1921 | 593.4 | Stage 3 Ua & Ub interfaces |  | 288d? | 2003-11-03 A | 2004-12-08 A | 100% | 2003-11-03 | 2004-12-08 | 288d? | finish no earlier than 2004-12-08 | N1 | 2304h | 2304h | SEC1-SC | Nokia |  | Rel-6 | Frederic |  |  |
| 1922 | 593.5 | OMA dependencies on Subscriber certificates |  | 114d? | 2004-01-01 A | 2004-06-08 A | 100% | 2004-01-01 | 2004-06-08 | 114d? | finish no earlier than 2004-06-08 | OMA | 912h | 912h | SEC1-SC | Nokia | OMA-LIAISON@mail.openmobilealliance.org | Rel-6 |  | SP-24 |  |
| 1923 | 594 | **Rel-6 OSA enhancements** |  | 616d? | 2002-10-31 A | 2005-03-10 A | 100% | 2002-10-31 | 2005-03-10 | 616d? |  | N5 | 22576h | 22576h | OSA3 | Alcatel | Chelo.Abarca@alcatel.fr | Rel-6 | Kimmo |  |  |
| 1924 | 594.1 | Scope of the Open Service Access Release 6 |  | 66d? | 2003-03-28 A | 2003-06-27 A | 100% | 2003-03-28 | 2003-06-27 | 66d? | finish no earlier than 2003-06-27 | S1 | 528h | 528h | OSA3 |  |  | Rel-6 | Alain |  |  |
| 1925 | 594.2 | OSA Stage 2 |  | 150d? | 2004-08-13 A | 2005-03-10 A | 100% | 2004-08-13 | 2005-03-10 | 150d? | finish no earlier than 2005-03-10 | N5 | 1200h | 1200h | OSA3 |  |  | Rel-6 | Kimmo |  |  |
| 1926 | 594.3 | Multi Media Messaging function |  | 487d? | 2002-10-31 A | 2004-09-10 A | 100% | 2002-10-31 | 2004-09-10 | 487d? | finish no earlier than 2004-09-10 | N5 | 3896h | 3896h | OSA3 |  |  | Rel-6 | Kimmo |  |  |
| 1927 | 594.4 | Policy management extensions |  | 292d? | 2002-10-31 A | 2003-12-12 A | 100% | 2002-10-31 | 2003-12-12 | 292d? | finish no earlier than 2003-12-12 | N5 | 2336h | 2336h | OSA3 |  |  | Rel-6 | Kimmo |  |  |
| 1928 | 594.5 | TS on Presence and Availability Management (from the PRESNC WI) |  | 367d? | 2002-10-31 A | 2004-03-26 A | 100% | 2002-10-31 | 2004-03-26 | 367d? | finish no earlier than 2004-03-26 | N5 | 2936h | 2936h | OSA3 |  |  | Rel-6 | Kimmo |  |  |
| 1929 | 594.6 | OSA interfaces at different levels of abstractions (Parlay X, Web services) |  | 305d? | 2003-07-14 A | 2004-09-10 A | 100% | 2003-07-14 | 2004-09-10 | 305d? | finish no earlier than 2004-09-10 | N5 | 2440h | 2440h | OSA3 |  |  | Rel-6 | Kimmo |  |  |
| 1930 | 594.7 | Introduction of migration support mechanism |  | 290d? | 2002-10-31 A | 2003-12-10 A | 100% | 2002-10-31 | 2003-12-10 | 290d? | finish no earlier than 2003-12-12 | N5 | 2320h | 2320h | OSA3 |  |  | Rel-6 | Kimmo |  |  |
| 1931 | 594.8 | Framework Function for Federation |  | 225d? | 2003-02-03 A | 2003-12-12 A | 100% | 2003-02-03 | 2003-12-12 | 225d? | finish no earlier than 2003-12-12 | N5 | 1800h | 1800h | OSA3 |  |  | Rel-6 | Kimmo |  |  |
| 1932 | 594.9 | OMA potential overlaps with 3GPP OSA Stage 3 (Web services) |  | 196d? | 2003-12-18 A | 2004-09-16 A | 100% | 2003-12-18 | 2004-09-16 | 196d? | start no earlier than 2003-12-18 | OMA | 1568h | 1568h | OSA3 |  |  | Rel-6 |  | SP-24 |  |
| 1933 | 594.10 | Deleted - TR on Presence and Availability Management (from the PRESNC WI) | milestone | 0d? | 2004-09-17 A | 2004-09-17 A | 100% | 2004-09-17 | 2004-09-17 | 0d? | start no earlier than 2004-09-17 | N5 |  |  | OSA3 |  |  | Rel-6 | Kimmo |  | NP-24 |
| 1934 | 39 | **Addition of frequency bands to GSM (TAPS)** |  | 676d | 2002-06-28 A | 2005-01-28 A | 100% | 2002-06-28 | 2005-01-28 | 676d |  | GP | 16640h | 16640h | TAPS | Nokia | Torben Themsen | Rel-6 | Paolo |  |  |
| 1935 | 39.1 | **Addition of frequency bands to GSM – Changes to core specs** |  | 26d | 2002-11-15 A | 2002-12-20 A | 100% | 2002-11-15 | 2002-12-20 | 26d |  | G1 | 416h | 416h | TAPS-Specs | Nokia | Torben Themsen | Rel-6 | Paolo |  |  |
| 1936 | 39.1.1 | Changes to core specs |  | 26d | 2002-11-15 A | 2002-12-20 A | 100% | 2002-11-15 | 2002-12-20 | 26d | finish no earlier than 2002-12-20 | G1 | 208h | 208h | TAPS-Specs | Nokia | Torben Themsen | Rel-6 | Paolo |  |  |
| 1937 | 39.2 | **Deleted - Addition of frequency bands to GSM – Changes for conformance tests** |  | 676d | 2002-06-28 A | 2005-01-28 A | 100% | 2002-06-28 | 2005-01-28 | 676d |  | G4 | 10816h | 10816h | TAPS-Conf | Nokia | Torben Themsen | Rel-6 | Paolo |  | GP-23 |
| 1938 | 39.2.1 | Deleted - 51.010-1 Add testing |  | 676d | 2002-06-28 A | 2005-01-28 A | 100% | 2002-06-28 | 2005-01-28 | 676d | finish no earlier than 2005-01-28 | G4 | 5408h | 5408h | TAPS-Conf | Nokia | Torben Themsen | Rel-6 | Paolo |  | GP-23 |
| 1939 | 40 | **Seamless support of streaming services in A/Gb mode** |  | 1426d? | 2000-01-03 A | 2005-06-17 A | 100% | 2000-01-03 | 2005-06-17 | 1426d? |  | GP | 53096h | 53096h | SSStrea | Vodafone | José Luis Carrizo Martínez | Rel-6 | Paolo |  |  |
| 1940 | 40.1 | **Identification of requirements for streaming** |  | 46d? | 2003-06-27 A | 2003-08-29 A | 100% | 2003-06-27 | 2003-08-29 | 46d? |  | G1 | 736h | 736h | SSStrea | Vodafone | José Luis Carrizo Martínez | Rel-6 | Paolo |  |  |
| 1941 | 596.1.1 | Requirements |  | 46d? | 2003-06-27 A | 2003-08-29 A | 100% | 2003-06-27 | 2003-08-29 | 46d? | finish no earlier than 2003-08-29 | G1 | 368h | 368h | SSStrea | Vodafone | José Luis Carrizo Martínez | Rel-6 | Paolo |  |  |

Notes:
- 1917: Approved at SP#14. May require BBs from CN1, CN4, SA5 and T3
- 1918: Contribution received S3#24, S3#25 / Text3: 33.220, 33.221, 33.222, 33.246, new TR 33.919
- 1919: -
- 1920: Finished in CN4#26 / Text3: 23.003, 23.008, 29.109, 29.230, T3 31.102, 31.103, 31.111
- 1921: - / Text3: 24.109
- 1922: Updated according to SP-040420
- 1923: CN#25: Updated WID NP-040351 replaces NP-040144. / Text3: 22.127, 23.198, 29.198, 29.199, 29.998
- 1924: -
- 1925: Inherited by CN5 from SA2 at TSG#25 Sep 2004. SA2's 23.127 (OSA/VHE Stage 2) replaced from Rel-6 onwards by a new CN5 TS 23.198 (Stage 2 OSA-only). / Text3: 23.198 OSA Stage 2-ONLY replaces 23.127 (OSA/VHE) from Rel-6 onwards
- 1926: - / Text3: 29.198-15
- 1927: - / Text3: 29.198, 29.998
- 1928: N5#26: Split WI into TS & TR. / Text3: 29.198-14
- 1929: - / Text3: 29.199
- 1930: - / Text3: 29.198, 29.998
- 1931: - / Text3: 29.198, 29.998
- 1932: TSG#25 Approved CN5 29.199 Parlay X Web services. Ongoing 3GPP/OMA co-ordination to avoid OMA producing conflicting/OVERLAPING specs (NP-040283/SP-040493).
- 1933: N5#26:TR Completion 09/04; consistent with CN1 delayed Rel-6 completion.
- 1934: -
- 1935: -
- 1936: -
- 1937: -
- 1938: -
- 1939: -
- 1940: -
- 1941: -

| ID | WBS | Task | Duration | Start | Finish | Complete | Baseline start | Baseline finish | Baseline duration | Constraint | Resources | Work | Actual work | Text1 | Text4 | Text5 | Text6 | Text8 | Text12 |
| --- | --- | --- | --- | --- | --- | --- | --- | --- | --- | --- | --- | --- | --- | --- | --- | --- | --- | --- | --- |
| 1942 | 40.2 | **Performance study of cell change mechanisms** | 956d? | 2000-01-03 A | 2003-08-29 A | 100% | 2000-01-03 | 2003-08-29 | 956d? |  | G1 | 30568h | 30568h | SSStrea | Vodafone | José Luis Carrizo Martínez | Rel-6 | Paolo |  |
| 1943 | 596.2.1 | Performance of NACC | 956d? | 2000-01-03 A | 2003-08-29 A | 100% | 2000-01-03 | 2003-08-29 | 956d? | finish no earlier than 2003-08-29 | G1 | 7640h | 7640h | SSStrea | Vodafone | José Luis Carrizo Martínez | Rel-6 | Paolo |  |
| 1944 | 596.2.2 | Performance of cell change in DTM for the PS domain | 956d? | 2000-01-03 A | 2003-08-29 A | 100% | 2000-01-03 | 2003-08-29 | 956d? | finish no earlier than 2003-08-29 | G1 | 7640h | 7640h | SSStrea | Vodafone | José Luis Carrizo Martínez | Rel-6 | Paolo |  |
| 1945 | 596.2.3 | Handover | 956d? | 2000-01-03 A | 2003-08-29 A | 100% | 2000-01-03 | 2003-08-29 | 956d? | finish no earlier than 2003-08-29 | G1 | 7640h | 7640h | SSStrea | Vodafone | José Luis Carrizo Martínez | Rel-6 | Paolo |  |
| 1946 | 40.3 | **Reduction of service interruption times and packet loss during mobility procedures** | 516d? | 2003-06-27 A | 2005-06-17 A | 100% | 2003-06-27 | 2005-06-17 | 516d? |  | G2 | 10800h | 10800h | SSStrea | Vodafone | José Luis Carrizo Martínez | Rel-6 | Gert |  |
| 1947 | 596.3.1 | optimizations of existing mechanisms/procedures | 106d? | 2003-06-27 A | 2003-11-21 A | 100% | 2003-06-27 | 2003-11-21 | 106d? | finish no earlier than 2003-11-21 | G2 | 848h | 848h | SSStrea | Vodafone | José Luis Carrizo Martínez | Rel-6 | Gert |  |
| 1948 | 596.3.2 | Inter-system NACC | 106d? | 2003-06-27 A | 2003-11-21 A | 100% | 2003-06-27 | 2003-11-21 | 106d? | finish no earlier than 2003-11-21 | G2 | 848h | 848h | SSStrea | Vodafone | José Luis Carrizo Martínez | Rel-6 | Gert |  |
| 1949 | 596.3.3 | PS Handover (within GERAN and between GERAN and UTRAN) | 516d? | 2003-06-27 A | 2005-06-17 A | 100% | 2003-06-27 | 2005-06-17 | 516d? | finish no earlier than 2003-11-21 | G2 | 4128h | 4128h | SSStrea | Vodafone | José Luis Carrizo Martínez | Rel-6 | Gert |  |
| 1950 | 596.3.4 | Dependency to other features | 106d? | 2003-06-27 A | 2003-11-21 A | 100% | 2003-06-27 | 2003-11-21 | 106d? | finish no earlier than 2003-11-21 | G2 | 848h | 848h | SSStrea | Vodafone | José Luis Carrizo Martínez | Rel-6 | Gert |  |
| 1951 | 40.5 | **Deleted - MS conformance testing** | 31d? | 2003-12-19 A | 2004-01-30 A | 100% | 2003-12-19 | 2004-01-30 | 31d? |  | G3new | 248h | 248h | SSStrea | Vodafone | José Luis Carrizo Martínez | Rel-6 | Ingbert | GP-27 |
| 1952 | 596.4.1 | Deleted - MS conformance tests | 31d? | 2003-12-19 A | 2004-01-30 A | 100% | 2003-12-19 | 2004-01-30 | 31d? | finish no earlier than 2004-01-30 | G4,G5 | 248h | 248h | SSStrea | Vodafone | José Luis Carrizo Martínez | Rel-6 | Ingbert | GP-27 |
| 1953 | 596.5 | GERAN A/Gb mode security enhancements | 612d? | 2002-09-26 A | 2005-01-28 A | 100% | 2002-09-26 | 2005-01-28 | 612d? | finish no earlier than 2005-01-28 | S3 | 4896h | 4896h | SSStrea | Vodafone | peter.howard@vodafone.com | Rel-6 | Dionisio |  |
| 1954 | 41 | Performance characterisation of default codecs for PS conversational multimedia application | 455d | 2002-09-13 A | 2004-06-10 A | 100% | 2002-09-13 | 2004-06-10 | 455d | finish no earlier than 2004-06-10 | S4 | 3640h | 3640h | CODCAR | Nokia | pasi.s.ojala@nokia.com | Rel-6 | Paolo |  |
| 1955 | 43 | Study on Privacy Capability | 83d | 2003-11-10 A | 2004-03-03 A | 100% | 2003-11-10 | 2004-03-03 | 83d | start no earlier than 2003-11-10 | S1 | 664h | 664h | PrivCap | Lucent | Michael Boote (mboote@alcatel-lucent.com) | Rel-6 | Alain |  |
| 1956 | 44 | **OAM&P Rel-6** | 652d? | 2002-09-12 A | 2005-03-11 A | 100% | 2002-09-12 | 2005-03-11 | 652d? |  | S5 | 30819.5h | 30819.5h | OAM | Motorola |  | Rel-6 | Dionisio |  |
| 1957 | 44.1 | Principles, high level Requirements and Architecture | 526d | 2002-09-12 A | 2004-09-16 A | 100% | 2002-09-12 | 2004-09-16 | 526d | finish no earlier than 2004-09-16 | S5 | 4208h | 4208h | OAM-AR | Motorola |  | Rel-6 | Dionisio |  |
| 1958 | 44.2 | Performance Management | 591d | 2002-09-12 A | 2004-12-16 A | 100% | 2002-09-12 | 2004-12-16 | 591d | finish no earlier than 2004-12-16 | S5 | 4728h | 4728h | OAM-PM | Nortel |  | Rel-6 | Dionisio |  |
| 1959 | 44.4 | Network Infrastructure Management | 591d | 2002-09-12 A | 2004-12-16 A | 100% | 2002-09-12 | 2004-12-16 | 591d | finish no earlier than 2004-12-16 | S5 | 4728h | 4728h | OAM-NIM | Ericsson | thomas.tovinger@ericsson.com | Rel-6 | Dionisio |  |
| 1960 | 44.5 | **Trace Management Rel-6** | 646d? | 2002-09-20 A | 2005-03-11 A | 100% | 2002-09-20 | 2005-03-11 | 646d? |  | S5 | 12061.9h | 12061.9h | OAM-Trace | Nokia | kari.t.ronka@nokia.com | Rel-6 | Dionisio |  |
| 1961 | 599.4.1 | Subscriber and UE trace management | 585d | 2002-09-20 A | 2004-12-16 A | 100% | 2002-09-20 | 2004-12-16 | 585d | finish no earlier than 2004-12-16 | S5 | 4680h | 4680h | OAM-Trace | Nokia | kari.t.ronka@nokia.com | Rel-6 | Dionisio |  |
| 1962 | 599.4.2 | Subscriber and equipment trace in UTRAN | 268d? | 2003-06-06 A | 2004-06-15 A | 100% | 2003-06-06 | 2004-06-15 | 268d? | finish no earlier than 2004-06-15 | R3 | 2144h | 2144h | OAM-Trace-RAN | Nortel | Yann Sehedi (sehedic@nortelnetworks.com) | Rel-6 | Juha |  |
| 1963 | 599.4.3 | Trace Management, Stage3 | 193.74d? | 2004-06-09 A | 2005-03-11 A | 100% | 2004-06-09 | 2005-03-11 | 193.74d? | finish no earlier than 2005-03-11 | N4 | 1549.92h | 1549.92h | OAM-Trace | Nokia | seppo.kauntola@nokia.com | Rel-6 | Kimmo |  |
| 1964 | 600 | **Charging Management** | 666d? | 2002-11-21 A | 2005-06-09 A | 100% | 2002-11-21 | 2005-06-09 | 666d? |  | S5 | 55320h | 55320h | CH | T-Mobile | karl-heinz.nenner@t-mobile.de | Rel-6 | Dionisio |  |
| 1965 | 600.1 | Charging architecture and principles | 390d? | 2003-03-21 A | 2004-09-16 A | 100% | 2003-03-21 | 2004-09-16 | 390d? | start no earlier than 2003-03-21 | S5 | 3120h | 3120h | CH |  |  | Rel-6 | Dionisio |  |
| 1966 | 600.2 | Charging Data Record (CDR) file format and transfer | 260d? | 2003-03-21 A | 2004-03-18 A | 100% | 2003-03-21 | 2004-03-18 | 260d? | start no earlier than 2003-03-21 | S5 | 2080h | 2080h | CH |  |  | Rel-6 | Dionisio |  |
| 1967 | 600.3 | CDR parameter description | 580d? | 2003-03-21 A | 2005-06-09 A | 100% | 2003-03-21 | 2005-06-09 | 580d? | finish no earlier than 2005-06-09 | S5 | 4640h | 4640h | CH |  |  | Rel-6 | Dionisio |  |
| 1968 | 600.4 | Diameter charging applications | 390d? | 2003-03-21 A | 2004-09-16 A | 100% | 2003-03-21 | 2004-09-16 | 390d? | start no earlier than 2003-03-21 | S5 | 3120h | 3120h | CH |  |  | Rel-6 | Dionisio |  |
| 1969 | 600.5 | Online Charging System (OCS) architecture study | 130d? | 2003-03-21 A | 2003-09-18 A | 100% | 2003-03-21 | 2003-09-18 | 130d? | start no earlier than 2003-03-21 | S5 | 1040h | 1040h | CH |  |  | Rel-6 | Dionisio |  |
| 1970 | 600.6 | OCS: Applications and interfaces | 455d? | 2003-03-21 A | 2004-12-16 A | 100% | 2003-03-21 | 2004-12-16 | 455d? | start no earlier than 2003-03-21 | S5 | 3640h | 3640h | CH |  |  | Rel-6 | Dionisio |  |

Notes:
- 1942: -
- 1943: -
- 1944: -
- 1945: -
- 1946: Completed at GERP#17
- 1947: -
- 1948: -
- 1949: -
- 1950: -
- 1951: Marked as stopped 10/2009
- 1952: Marked as stopped 10/2009
- 1953: Possible changes to 33.102 or new specification needed / Text3: 33.102
- 1954: - / Text3: 26.935
- 1955: - / Text3: 22.949
- 1956: SP#26: Updated WID SP-040766 was SP-020445. Completion delayed 12/04->03/05 due to OAM-Trace in CN1/4.
- 1957: SP#25 09/2004 completed / Text3: 32.101, 32.102
- 1958: SP#26 12/2004 completed / Text3: 32.401, 32.403, 52.402, 32.411, 32.412, 32.413, 32.432, 32.435, 32.436
- 1959: SP#26 12/2004 completed / Text3: 32.150/1/2, 32.805, 32.111-5, 32.313/4, 32.331/2/3/4/5, 32.341/2/3/4, 32.351/2/3/4, 32.361/2/3/4, 32.371/2/3/4, 32.804, 32.675, 32.690, 32.695, 32.71/2/3/4/5, 32.741/2/3/4/5
- 1960: SP#26 12/2004 SA5 completed 12/04. Signalling Based Trace Activation for IMS (SIP) moved to Rel-7. Reason: CN1 cannot complete 24.229 trace without IETF dependency => estimate 05/2005.
- 1961: SP#26 12/2004 completed / Text3: 32.421, 32.422, 32.423, 52.008
- 1962: - / Text3: 25.413, 25.420, 25.423
- 1963: - / Text3: 23.205, 29.232, 29.060, 29.002, 29.228
- 1964: SP#28 Target 09/2005 for WLAN Charging 32.252 / Text3: 32.2xy
- 1965: SP#25 09/2004 completed / Text3: 32.240
- 1966: SP#23 03/2004 completed / Text3: 32.297
- 1967: SP#28 06/2005 completed / Text3: 32.298
- 1968: SP#25 09/2004 completed / Text3: 32.299
- 1969: SP#21 09/2003 completed / Text3: 32.815
- 1970: SP#26 12/2004 completed / Text3: 32.296

| ID | WBS | Task | Duration | Start | Finish | Complete | Baseline start | Baseline finish | Baseline duration | Constraint | Resources | Work | Actual work | Text1 | Text4 | Text5 | Text6 | Text8 | Text10 | Text12 |
| --- | --- | --- | --- | --- | --- | --- | --- | --- | --- | --- | --- | --- | --- | --- | --- | --- | --- | --- | --- | --- |
| 1971 | 600.7 | **Charging Management for Bearer level** | 390d? | 2003-03-21 A | 2004-09-16 A | 100% | 2003-03-21 | 2004-09-16 | 390d? |  | S5 | 11440h | 11440h | CH-BC | Nokia | Benni ALEXANDER | Rel-6 | Dionisio |  |  |
| 1972 | 600.7.1 | CS domain charging | 260d? | 2003-03-21 A | 2004-03-18 A | 100% | 2003-03-21 | 2004-03-18 | 260d? | start no earlier than 2003-03-21 | S5 | 2080h | 2080h | CH |  |  | Rel-6 | Dionisio |  |  |
| 1973 | 600.7.2 | PS domain charging | 390d? | 2003-03-21 A | 2004-09-16 A | 100% | 2003-03-21 | 2004-09-16 | 390d? | start no earlier than 2003-03-21 | S5 | 3120h | 3120h | CH |  |  | Rel-6 | Dionisio |  |  |
| 1974 | 600.7.3 | CDR transfer | 390d? | 2003-03-21 A | 2004-09-16 A | 100% | 2003-03-21 | 2004-09-16 | 390d? | start no earlier than 2003-03-21 | S5 | 3120h | 3120h | CH |  |  | Rel-6 | Dionisio |  |  |
| 1975 | 600.8 | Charging Management for the IMS | 455d? | 2003-03-21 A | 2004-12-16 A | 100% | 2003-03-21 | 2004-12-16 | 455d? | finish no earlier than 2004-12-16 | S5 | 3640h | 3640h | IMS2-CH | Ericsson | Patrik TEPPO | Rel-6 | Dionisio |  |  |
| 1976 | 600.9 | Charging Management for the Service domain | 580d? | 2003-03-21 A | 2005-06-09 A | 100% | 2003-03-21 | 2005-06-09 | 580d? | finish no earlier than 2005-06-09 | S5 | 4640h | 4640h | CH | Siemens | Gerald.Goermer@nsn.com | Rel-6 | Dionisio |  |  |
| 1977 | 600.10 | **Overall architectural aspects of IP flow based bearer level charging** | 602d? | 2002-11-21 A | 2005-03-11 A | 100% | 2002-11-21 | 2005-03-11 | 602d? |  | S2 | 12632h | 12632h | CH-FBC |  |  | Rel-6 | Maurice |  |  |
| 1978 | 600.10.1 | Overall definition of FBC architecture | 334d? | 2002-11-21 A | 2004-03-02 A | 100% | 2002-11-21 | 2004-03-02 | 334d? | start no earlier than 2002-11-21 | S2 | 2672h | 2672h | CH-FBC |  |  | Rel-6 | Maurice | SP-24 |  |
| 1979 | 600.10.2 | Study on providing policy control with FBC | 130d? | 2004-02-02 A | 2004-07-30 A | 100% | 2004-02-02 | 2004-07-30 | 130d? | start no earlier than 2004-02-01 | S2 | 1040h | 1040h | CH-FBC |  |  | Rel-6 | Maurice | SP-24 |  |
| 1980 | 600.10.3 | Gx interface for flow based charging | 223d? | 2004-02-02 A | 2004-12-08 A | 100% | 2004-02-02 | 2004-12-08 | 223d? | start no earlier than 2004-02-01 | N3 | 1784h | 1784h | CH-FBC | Nokia | juha.a.rasanen@nokia.com | Rel-6 | Gwiho | SP-25 |  |
| 1981 | 600.10.4 | Rx interface for flow based charging | 290d? | 2004-02-02 A | 2005-03-11 A | 100% | 2004-02-02 | 2005-03-11 | 290d? | finish no earlier than 2005-03-11 | N3 | 2320h | 2320h | CH-FBC | Nortel | Javier Gonzalez Gallego | Rel-6 | Gwiho | SP-25 |  |
| 1982 | 13 | **Rel-6 UICC/USIM enhancements and interworking** | 1164d? | 2000-09-25 A | 2005-03-10 A | 100% | 2000-09-25 | 2005-03-10 | 1164d? |  | T3 | 43088h | 43088h | USAT1 |  |  | Rel-6 | Xavier |  |  |
| 1983 | 13.1 | **UICC API** | 777d | 2002-03-20 A | 2005-03-10 A | 100% | 2002-03-20 | 2005-03-10 | 777d |  | T3 | 15024h | 15024h | USAT1-API |  |  | Rel-6 | Xavier |  |  |
| 1984 | 13.1.1 | Java API Test specification | 59d | 2002-03-20 A | 2002-06-10 A | 100% | 2002-03-20 | 2002-06-10 | 59d | finish no earlier than 2002-09-20 | T3 | 472h | 472h | USAT1-API | Microelectrónica Española | Mario Pérez | Rel-6 | Xavier |  |  |
| 1985 | 601.1.2 | 2G/3G Java Card™ API based applet interworking | 255d | 2003-03-17 A | 2004-03-05 A | 100% | 2003-03-17 | 2004-03-05 | 255d | finish no earlier than 2004-02-19 | T3 | 2040h | 2040h | USAT1-API | Oberthur Card Systems | Stéphane Andrau | Rel-6 | Xavier |  |  |
| 1986 | 601.1.3 | (U)SIM API for Java Card Testing | 519d | 2003-03-17 A | 2005-03-10 A | 100% | 2003-03-17 | 2005-03-10 | 519d | finish no earlier than 2005-03-10 | T3 | 4152h | 4152h | USAT1-API | Axalto | Christophe Begassat (cbegassat@axalto.com) | Rel-6 | Xavier |  |  |
| 1987 | 13.1.2 | Deleted - Java API Test specification (TS 43.019 Rel-5) | 268d | 2002-05-30 A | 2003-06-09 A | 100% | 2002-05-30 | 2003-06-09 | 268d | finish no earlier than 2003-09-17 | T3 | 2144h | 2144h | USAT1-API | Microelectrónica Española | Mario Pérez | Rel-6 | Xavier |  | TP-20 |
| 1988 | 601.2 | **Rel-6 USIM toolkit enhancements** | 1160d? | 2000-09-25 A | 2005-03-04 A | 100% | 2000-09-25 | 2005-03-04 | 1160d? |  | T3 | 21848h | 21848h | USAT1-API-MULTOS | Aspects Software | Neil Livingston | Rel-6 | Xavier |  |  |
| 1989 | 601.2.1 | **C SIM API** | 525d | 2000-09-25 A | 2002-09-27 A | 100% | 2000-09-25 | 2002-09-27 | 525d |  | T3 | 9960h | 9960h | USAT1-API-MULTOS | Aspects Software | Neil Livingston | Rel-6 | Xavier |  |  |
| 1990 | 601.2.1.1 | Specification | 525d | 2000-09-25 A | 2002-09-27 A | 100% | 2000-09-25 | 2002-09-27 | 525d | finish no earlier than 2002-09-27 | T3 | 4200h | 4200h | USAT1-API-MULTOS | Aspects Software | Neil Livingston | Rel-6 | Xavier |  |  |
| 1991 | 601.2.1.2 | Test specification | 195d | 2001-01-01 A | 2001-09-28 A | 100% | 2001-01-01 | 2001-09-28 | 195d | finish no earlier than 2001-09-28 | T3 | 1560h | 1560h | USAT1-API-MULTOS | Aspects Software | Neil Livingston | Rel-6 | Xavier |  |  |
| 1992 | 601.2.2 | USIM application toolkit Conformance Test Specification for Mobile Equipments | 326d? | 2003-12-05 A | 2005-03-04 A | 100% | 2003-12-05 | 2005-03-04 | 326d? | start no earlier than 2003-12-05 | T3 | 2608h | 2608h | USAT1-API-MULTOS | Gemplus | Eric.laffont@gemplus.com | Rel-6 | Xavier |  |  |
| 1993 | 602 | **Packet Switched Streaming Services Rel-6** | 798d? | 2002-11-18 A | 2005-12-07 A | 100% | 2002-11-18 | 2005-12-07 | 798d? |  | S4,S1 | 13304h | 13304h | PSSrel6 | Ericsson | olle.franceschi@ericsson.com | Rel-6 | Paolo |  |  |
| 1994 | 602.1 | Stage 1 | 86d? | 2002-11-18 A | 2003-03-17 A | 100% | 2002-11-18 | 2003-03-17 | 86d? | finish no earlier than 2003-03-17 | S1 | 688h | 688h | PSSrel6 | Ericsson |  | Rel-6 | Alain |  |  |
| 1995 | 602.2 | Stage 3 | 779d? | 2002-12-13 A | 2005-12-07 A | 100% | 2002-12-13 | 2005-12-07 | 779d? | finish no earlier than 2005-12-07 | S4 | 6232h | 6232h | PSSrel6-Stage3 | Ericsson | olle.franceschi@ericsson.com | Rel-6 | Paolo |  |  |
| 1996 | 603 | AMR-WB extension for high audio quality | 779d | 2002-12-13 A | 2005-12-07 A | 100% | 2002-12-13 | 2005-12-07 | 779d | finish no earlier than 2005-12-07 | S4 | 6232h | 6232h | AMRWB+ | Nokia | janne.m.vainio@nokia.com | Rel-6 | Paolo |  |  |
| 1997 | 604 | Codec Enhancements for Packet Switched Conversational Multimedia Applications | 198d? | 2004-03-16 A | 2004-12-16 A | 100% | 2004-03-16 | 2004-12-16 | 198d? | finish no earlier than 2004-12-16 | S4 | 1584h | 1584h | CEPSCM | Nokia | miska.hannuksela@nokia.com | Rel-6 | Paolo |  |  |
| 1998 | 605 | 3G-324M Improvements | 198d? | 2004-03-16 A | 2004-12-16 A | 100% | 2004-03-16 | 2004-12-16 | 198d? | finish no earlier than 2004-12-16 | S4 | 1584h | 1584h | 3G-324MI | Ericsson | bo.burman@ericsson.com | Rel-6 | Paolo |  |  |
| 1999 | 606 | Single Antenna Receiver Interference Cancellation (SAIC) | 420.92d? | 2002-11-15 A | 2004-06-25 A | 100% | 2002-11-15 | 2004-06-25 | 420.92d? | finish no earlier than 2004-08-27 | GP,G1 | 3367.36h | 3367.36h | SAIC | Cingular | Marc Grant | Rel-6 | Paolo |  |  |

Notes:
- 1971: SP#28 Target 09/2005 for WLAN Charging 32.252
- 1972: SP#23 03/2004 completed / Text3: 32.250
- 1973: SP#25 09/2004 completed / Text3: 32.251
- 1974: SP#25 09/2004 completed / Text3: 32.295
- 1975: SP#26 12/2004 completed / Text3: 32.260
- 1976: SP#26: Updated WID SP-040778 was SP-030050. Target completion 06/2005. Consisting of MMS-CH, LCS-CH, WLAN-CH, POC-CH, MBMS-CH / Text3: 32.252, 32.270, 32.271, 32.272
- 1977: - / Text3: 23.125
- 1978: -
- 1979: -
- 1980: - / Text3: 29.210
- 1981: - / Text3: 29.209
- 1982: -
- 1983: 8/3/2001: test spec is based on R99 core spec, so deleted from Workplan
- 1984: -
- 1985: -
- 1986: - / Text3: 31.213
- 1987: MOVED to Rel-5 WP
- 1988: -
- 1989: - / Text3: 31.101, 31.102, 31.103, 31.111, 31.113, new 31.115, 31.116
- 1990: -
- 1991: -
- 1992: - / Text3: 31.124
- 1993: -
- 1994: 2nd resp SA4 / Text3: 22.233
- 1995: TR tbc by Sept. 05 / Text3: 26.233, 26.234, 26.244, 26.245, 26.246, 26.401, 26.402, 26.403, 26.404, 26.405, 26.406, 26.410, 26.411, 26.412, 26.273, 26.290, 26.304, 26.412, 26.274, 26.936
- 1996: TR tbc by Sept. 05 / Text3: 26.290, 26.304, 26.273, 26.274, 26.412, 26.936
- 1997: - / Text3: 26.235, 26.236
- 1998: - / Text3: 26.111, 26.911
- 1999: - / Text3: 45.903

| ID | WBS | Task | Type | Duration | Start | Finish | Complete | Baseline start | Baseline finish | Baseline duration | Constraint | Resources | Work | Actual work | Text1 | Text3 | Text4 | Text5 | Text6 | Text8 | Text12 |
| --- | --- | --- | --- | --- | --- | --- | --- | --- | --- | --- | --- | --- | --- | --- | --- | --- | --- | --- | --- | --- | --- |
| 2000 | 607 | **Enhancement of dialled service for CAMEL** |  | 199d | 2003-03-28 A | 2003-12-31 A | 100% | 2003-03-28 | 2003-12-31 | 199d |  | S1,N2,N4 | 3184h | 3184h | EDCAMEL | 22.078 | Samsung | craig.bishop@samsung.com | Rel-6 | Alain |  |
| 2001 | 607.1 | Stages 2 and 3 |  | 199d | 2003-03-28 A | 2003-12-31 A | 100% | 2003-03-28 | 2003-12-31 | 199d | finish no earlier than 2003-09-19 | N2,N4 | 1592h | 1592h | EDCAMEL | 23.008, 23.016, 23.018, 23.078, 29.002, 29.078 | Samsung | Richard Brook | Rel-6 | Kimmo |  |
| 2002 | 608 | Study on Bandwidth and resource savings in CS networks |  | 273d? | 2003-06-01 A | 2004-06-16 A | 100% | 2003-06-01 | 2004-06-16 | 273d? | finish no earlier than 2004-06-16 | S2 | 2184h | 2184h | BARS | 23.977 |  |  | Rel-6 | Maurice |  |
| 2003 | 609 | FS on (U)SIM Security Reuse by Peripheral Devices on Local Interfaces |  | 127d? | 2003-07-03 A | 2003-12-26 A | 100% | 2003-07-03 | 2003-12-26 | 127d? | finish no earlier than 2003-12-26 | S3 | 1016h | 1016h |  | 33.817 | Toshiba | Raziq Yaqub (ryaqub@tari.toshiba.com) | Rel-6 | Dionisio |  |
| 2004 | 610 | **Multiple TBF in A/Gb mode** |  | 736d? | 2002-04-05 A | 2005-01-28 A | 100% | 2002-04-05 | 2005-01-28 | 736d? |  | GP,G2 | 17600h | 17600h | MULTBF |  | Ericsson | gunnar.mildh@era.ericsson.se | Rel-6 | Paolo |  |
| 2005 | 610.1 | **Multiple TBF in A/Gb mode** |  | 366d? | 2002-04-05 A | 2003-08-29 A | 100% | 2002-04-05 | 2003-08-29 | 366d? |  | GP,G2 | 11712h | 11712h | MULTBF-Agbmode |  | Ericsson | gunnar.mildh@era.ericsson.se | Rel-6 | Paolo |  |
| 2006 | 610.1.1 | Multiple TBF Concept paper |  | 366d? | 2002-04-05 A | 2003-08-29 A | 100% | 2002-04-05 | 2003-08-29 | 366d? | finish no earlier than 2003-08-29 | GP,G2 | 2928h | 2928h | MULTBF-Agbmode |  |  |  | Rel-6 | Paolo |  |
| 2007 | 610.1.2 | Multiple TBF Stage 2 (43.064) CRs |  | 366d? | 2002-04-05 A | 2003-08-29 A | 100% | 2002-04-05 | 2003-08-29 | 366d? | finish no earlier than 2003-08-29 | GP,G2 | 2928h | 2928h | MULTBF-Agbmode |  |  |  | Rel-6 | Paolo |  |
| 2008 | 610.1.3 | Multiple TBF Stage 3 (44.060) CRs |  | 366d? | 2002-04-05 A | 2003-08-29 A | 100% | 2002-04-05 | 2003-08-29 | 366d? | finish no earlier than 2003-08-29 | GP,G2 | 2928h | 2928h | MULTBF-Agbmode |  |  |  | Rel-6 | Paolo |  |
| 2009 | 610.2 | Deleted - Multiple TBF in A/Gb mode – MS testing | milestone | 0d? | 2005-01-28 A | 2005-01-28 A | 100% | 2005-01-28 | 2005-01-28 | 0d? | start no earlier than 2005-01-28 | G3new |  |  | MULTBF-Testing |  | Ericsson | gunnar.mildh@era.ericsson.se | Rel-6 | Paolo | GP-27 |
| 2010 | 611 | **Alignment between the test-regimes for GERAN capable MS** |  | 526d? | 2003-08-29 A | 2005-09-02 A | 100% | 2003-08-29 | 2005-09-02 | 526d? |  | G3new | 4208h | 4208h | ALTERE |  | Ericsson | anthony.toubassi@sonyericsson.com | Rel-6 | Ingbert |  |
| 2011 | 611.1 | Determine the controversial test cases in the different test regimes and align them with 3GPP GERAN test specifications. Such test cases to be added to TS 51.010. |  | 526d? | 2003-08-29 A | 2005-09-02 A | 100% | 2003-08-29 | 2005-09-02 | 526d? | finish no earlier than 2005-09-02 | G3new | 4208h | 4208h | ALTERE-TC |  |  |  | Rel-6 | Ingbert |  |
| 2012 | 612 | Addition of U-TDOA in the CS domain |  | 111d? | 2003-11-21 A | 2004-04-23 A | 100% | 2003-11-21 | 2004-04-23 | 111d? | finish no earlier than 2004-04-23 | GP | 888h | 888h | UTDOACS |  | TruePosition | Bob Gross, Rhys Robinson (rlgross@trueposition.com) | Rel-6 | Paolo |  |
| 2013 | 613 | Addition of U-TDOA in the PS domain |  | 361d? | 2003-06-27 A | 2004-11-12 A | 100% | 2003-06-27 | 2004-11-12 | 361d? | finish no earlier than 2004-11-12 | GP | 2888h | 2888h | UTDOAPS |  | TruePosition | Bob Gross, Rhys Robinson (rlgross@trueposition.com) | Rel-6 | Paolo |  |
| 2014 | 614 | **Downlink Advanced Receiver Performance** |  | 466d? | 2003-11-21 A | 2005-09-02 A | 100% | 2003-11-21 | 2005-09-02 | 466d? |  | GP | 19160h | 19160h | DARP |  | Nokia | tommy.bysted@nokia.com | Rel-6 | Paolo |  |
| 2015 | 614.1 | DARP test scenarios |  | 201d? | 2003-11-21 A | 2004-08-27 A | 100% | 2003-11-21 | 2004-08-27 | 201d? | finish no earlier than 2004-08-27 | GP | 1608h | 1608h | DARP-TS |  | Nokia | tommy.bysted@nokia.com | Rel-6 | Paolo |  |
| 2016 | 614.2 | **DARP for GMSK modulated voice services** |  | 201d? | 2004-02-06 A | 2004-11-12 A | 100% | 2004-02-06 | 2004-11-12 | 201d? |  | GP | 4824h | 4824h | DARP-GMSK |  | Nokia | tommy.bysted@nokia.com | Rel-6 | Paolo |  |
| 2017 | 614.2.1 | Performance requirements in 45.005 |  | 201d? | 2004-02-06 A | 2004-11-12 A | 100% | 2004-02-06 | 2004-11-12 | 201d? | finish no earlier than 2004-11-12 | GP | 1608h | 1608h | DARP-GMSK-Perf |  |  |  | Rel-6 | Paolo |  |
| 2018 | 614.2.2 | Radio subsystem link control in 45.008 |  | 201d? | 2004-02-06 A | 2004-11-12 A | 100% | 2004-02-06 | 2004-11-12 | 201d? | finish no earlier than 2004-11-12 | GP | 1608h | 1608h | DARP-GMSK-LC |  |  |  | Rel-6 | Paolo |  |
| 2019 | 614.3 | **DARP for GPRS and EGPRS MCS1-MCS4** |  | 201d? | 2004-02-06 A | 2004-11-12 A | 100% | 2004-02-06 | 2004-11-12 | 201d? |  | GP | 4824h | 4824h | DARP-GPRSE |  | Nokia | tommy.bysted@nokia.com | Rel-6 | Paolo |  |
| 2020 | 614.3.1 | Performance requirements in 45.005 |  | 201d? | 2004-02-06 A | 2004-11-12 A | 100% | 2004-02-06 | 2004-11-12 | 201d? | finish no earlier than 2004-11-12 | GP | 1608h | 1608h | DARP-GPRSE-Perf |  |  |  | Rel-6 | Paolo |  |
| 2021 | 614.3.2 | Radio subsystem link control in 45.008 |  | 201d? | 2004-02-06 A | 2004-11-12 A | 100% | 2004-02-06 | 2004-11-12 | 201d? | finish no earlier than 2004-11-12 | GP | 1608h | 1608h | DARP-GPRSE-LC |  |  |  | Rel-6 | Paolo |  |
| 2022 | 614.4 | DARP Capability signalling |  | 256d? | 2003-11-21 A | 2004-11-12 A | 100% | 2003-11-21 | 2004-11-12 | 256d? | finish no earlier than 2004-11-12 | GP | 2048h | 2048h | DARP-CAPSIG |  | Nokia | tommy.bysted@nokia.com | Rel-6 | Paolo |  |
| 2023 | 614.5 | GERAN MS Conformance test for DARP |  | 266d? | 2004-08-27 A | 2005-09-02 A | 100% | 2004-08-27 | 2005-09-02 | 266d? | finish no earlier than 2005-06-24 | G3new | 2128h | 2128h | ARP-ConfTest |  | Nokia | tommy.bysted@nokia.com | Rel-6 | Ingbert |  |

Notes:
- 2000: -
- 2001: -
- 2002: -
- 2003: Approved TSG#20
- 2004: GP#17 Nov 2003 Moved from Rel-5 UID_50058 MULTBF (Only Multiple TBF Concept paper produced in Rel-5)
- 2005: -
- 2006: -
- 2007: -
- 2008: -
- 2009: -
- 2010: -
- 2011: -
- 2012: Completed, except for potential LMU performance specs
- 2013: -
- 2014: -
- 2015: -
- 2016: -
- 2017: -
- 2018: -
- 2019: -
- 2020: -
- 2021: -
- 2022: -
- 2023: -

| ID | WBS | Task | Type | Duration | Start | Finish | Complete | Baseline start | Baseline finish | Baseline duration | Constraint | Resources | Work | Actual work | Text1 | Text4 | Text5 | Text6 | Text8 | Text12 | Text3 | Text10 |
| --- | --- | --- | --- | --- | --- | --- | --- | --- | --- | --- | --- | --- | --- | --- | --- | --- | --- | --- | --- | --- | --- | --- |
| 2024 | 615 | **Reduction of PS service interruption in Dual Transfer Mode** |  | 416d? | 2003-11-21 A | 2005-06-24 A | 100% | 2003-11-21 | 2005-06-24 | 416d? |  | G2 | 8360h | 8360h | PSintDTM | Siemens | toby.proctor@roke.co.uk | Rel-6 | Gert |  |  |  |
| 2025 | 615.1 | Use case and requirement definition |  | 111d? | 2003-11-21 A | 2004-04-23 A | 100% | 2003-11-21 | 2004-04-23 | 111d? | finish no earlier than 2004-04-23 | G2 | 888h | 888h | PSintDTM-Req | Siemens | toby.proctor@roke.co.uk | Rel-6 | Gert |  |  |  |
| 2026 | 615.2 | Performance Study of Current Procedures |  | 111d? | 2003-11-21 A | 2004-04-23 A | 100% | 2003-11-21 | 2004-04-23 | 111d? | start no earlier than 2003-11-21 | G2 | 888h | 888h | PSintDTM-Perf | Siemens | toby.proctor@roke.co.uk | Rel-6 | Gert |  |  |  |
| 2027 | 615.3 | Reduction of service interruption times and packet loss during Dual Transfer Mode and mobility procedures |  | 146d? | 2004-04-23 A | 2004-11-12 A | 100% | 2004-04-23 | 2004-11-12 | 146d? | finish no earlier than 2004-11-12 | G2 | 1168h | 1168h | PSintDTM-Reduct | Siemens | toby.proctor@roke.co.uk | Rel-6 | Gert |  |  |  |
| 2028 | 615.4 | Deleted - MS Conformance testing - Reduction of PS service interruption in DTM |  | 261d? | 2004-06-25 A | 2005-06-24 A | 100% | 2004-06-25 | 2005-06-24 | 261d? | finish no earlier than 2005-06-24 | G3new | 2088h | 2088h | PSintDTM-ConfMS |  |  | Rel-6 | Ingbert | GP-25 |  |  |
| 2029 | 615.5 | Deleted - BTS Conformance testing - Reduction of PS service interruption in DTM | milestone | 0d? | 2005-06-24 A | 2005-06-24 A | 100% | 2005-06-24 | 2005-06-24 | 0d? | finish no earlier than 2005-06-24 | G3new |  |  | PSintDTM-ConfBTS |  |  | Rel-6 | Ingbert | GP-25 |  |  |
| 2030 | 616 | CAMEL prepay interworking with SCUDIF |  | 216.3d | 2003-12-08 A | 2004-10-05 A | 100% | 2003-12-08 | 2004-10-05 | 216.3d |  | N4,N3,S1 | 1730.4h | 1730.4h | SCCAMEL | Nokia | Keijo.Palviainen@Nokia.Com | Rel-6 | Kimmo |  | 22.078, 23.078, 29.078, 29.002, 23.172 |  |
| 2031 | 617 | **Circuit Switched Video and Voice Service Improvements** |  | 430d? | 2004-01-12 A | 2005-09-02 A | 100% | 2004-01-12 | 2005-09-02 | 430d? |  | S2,C1 | 9256h | 9256h | CS_VSS | Vodafone | John Watson | Rel-6 | Alain |  |  |  |
| 2032 | 617.1 | Deleted - Stage 1 - Requirements |  | 199d | 2004-01-12 A | 2004-10-14 A | 100% | 2004-01-12 | 2004-10-14 | 199d | finish no earlier than 2004-10-14 | S1 | 1592h | 1592h | CS_VSS | Vodafone | John Watson | Rel-6 | Alain | SP-26 | 22.101 |  |
| 2033 | 617.2 | Stage 2 Study on architecture alternatives |  | 244d? | 2004-01-12 A | 2004-12-16 A | 100% | 2004-01-12 | 2004-12-16 | 244d? | finish no earlier than 2004-08-13 | S2 | 1952h | 1952h | CS_VSS | Vodafone | Chris Pudney | Rel-6 | Maurice |  | 23.903 | SP-24 |
| 2034 | 617.3 | Deleted - Stage 2 description on Redial |  | 164d? | 2004-05-03 A | 2004-12-16 A | 100% | 2004-05-03 | 2004-12-16 | 164d? | finish no earlier than 2004-12-16 | S2 | 1312h | 1312h | CS_VSS | Vodafone | Chris Pudney | Rel-6 | Maurice | SP-26 |  | SP-24 |
| 2035 | 617.4 | Switching between voice and video call - Redial solution |  | 120d? | 2005-01-03 A | 2005-06-17 A | 100% | 2005-01-03 | 2005-06-17 | 120d? | start no earlier than 2005-01-03 | C1 | 960h | 960h | CS_VSS | Vodafone |  | Rel-6 | Frederic |  | 23.009, 24.008 |  |
| 2036 | 617.5 | Deleted - CS_VSS - GERAN2 Part | milestone | 0d | 2005-09-02 A | 2005-09-02 A | 100% | 2005-09-02 | 2005-09-02 | 0d | start no earlier than 2005-09-02 | G2 |  |  | CS_VSS | Vodafone |  | Rel-6 | Gert | GP-26 |  |  |
| 2037 | 617.6 | Deleted - CS_VSS - CN3 Part | milestone | 0d? | 2004-10-14 A | 2004-10-14 A | 100% | 2004-10-14 | 2004-10-14 | 0d? | start no earlier than 2004-10-14 | N3 |  |  | CS_VSS | Vodafone |  | Rel-6 | Gwiho | TP-26 |  |  |
| 2038 | 618 | Network Domain Security; MAP application layer security (NDS/MAPsec) |  | 127d? | 2004-07-06 A | 2004-12-29 A | 100% | 2004-07-06 | 2004-12-29 | 127d? | finish no earlier than 2003-12-26 | S3 | 1016h | 1016h | MAPSEC | Vodafone | Peter.Howard@vodafone.com | Rel-6 | Dionisio |  |  |  |
| 2039 | 619 | FS on Security for early IMS |  | 127d? | 2004-10-01 A | 2005-03-28 A | 100% | 2004-10-01 | 2005-03-28 | 127d? | finish no earlier than 2003-12-26 | S3 | 1016h | 1016h | SEC-IMS | Vodafone | Peter.Howard@vodafone.com | Rel-6 | Dionisio |  | 33.978 |  |
| 2040 | 620 | Reorganisation of CS Data Specifications |  | 14d? | 2004-11-19 A | 2004-12-08 A | 100% | 2004-11-19 | 2004-12-08 | 14d? | finish no earlier than 2004-12-24 | N3 | 112h | 112h | CS Data | Siemens | Thomas.Belling@nsn.com | Rel-6 | Gwiho |  | 23.910, 29.007, new 23.202 |  |
| 2041 | 621 | **Generic Access to A/Gb Interface (GAAI)** |  | 411d? | 2004-06-25 A | 2006-01-20 A | 100% | 2004-06-25 | 2006-01-20 | 411d? |  | GP | 9160h | 9160h | GAAI | Motorola |  | Rel-6 | Paolo |  |  |  |
| 2042 | 621.1 | FS on GAAI |  | 46d? | 2004-06-25 A | 2004-08-27 A | 100% | 2004-06-25 | 2004-08-27 | 46d? | finish no earlier than 2004-08-27 | GP | 368h | 368h | GAAG | Motorola |  | Rel-6 | Paolo |  | 43.901 |  |
| 2043 | 621.2 | GAAI – Stage 2 |  | 161d? | 2004-08-27 A | 2005-04-08 A | 100% | 2004-08-27 | 2005-04-08 | 161d? | finish no earlier than 2005-04-08 | GP | 1288h | 1288h | GAAI-Stage2 | Ericsson | jari.vikberg@ericsson.com | Rel-6 | Paolo |  | 43.318 |  |
| 2044 | 621.3 | GAAI – Stage 3 |  | 161d? | 2004-08-27 A | 2005-04-08 A | 100% | 2004-08-27 | 2005-04-08 | 161d? | finish no earlier than 2005-04-08 | GP | 1288h | 1288h | GAAI-Stage3 |  |  | Rel-6 | Paolo |  | 44.318 |  |
| 2045 | 621.4 | MS Conformance Test for GAAI |  | 366d? | 2004-08-27 A | 2006-01-20 A | 100% | 2004-08-27 | 2006-01-20 | 366d? | finish no earlier than 2006-01-20 | GP | 2928h | 2928h | GAAI-CT |  |  | Rel-6 | Ingbert |  |  |  |
| 2046 | 622 | **Support of PS Handover for GERAN A/Gb mode** |  | 473d? | 2003-11-03 A | 2005-08-24 A | 100% | 2003-11-03 | 2005-08-24 | 473d? |  | GP,G2 | 11352h | 11352h | SPSHAGB | Ericsson | gunnar.hedby@ericsson.com | Rel-6 | Paolo |  |  |  |
| 2047 | 622.1 | Stage 2 |  | 473d? | 2003-11-03 A | 2005-08-24 A | 100% | 2003-11-03 | 2005-08-24 | 473d? | finish no earlier than 2005-09-02 | GP,G2 | 3784h | 3784h | SPSHAGB-Stage2 | Ericsson | gunnar.hedby@ericsson.com | Rel-6 | Paolo |  | 43.129 |  |
| 2048 | 622.2 | PS handover |  | 473d? | 2003-11-03 A | 2005-08-24 A | 100% | 2003-11-03 | 2005-08-24 | 473d? | finish no earlier than 2005-09-02 | GP,G2 | 3784h | 3784h | SPSHAGB-PSHO | Ericsson | gunnar.hedby@ericsson.com | Rel-6 | Paolo |  |  |  |
| 2049 | 622.3 | Definition of radio resource management functionality |  | 473d? | 2003-11-03 A | 2005-08-24 A | 100% | 2003-11-03 | 2005-08-24 | 473d? | finish no earlier than 2005-09-02 | GP,G2 | 3784h | 3784h | SPSHAGB-RRM | Ericsson | gunnar.hedby@ericsson.com | Rel-6 | Paolo |  |  |  |
| 2050 | 623 | (Small) Technical Enhancements and Improvements for Rel-6 |  | 503d? | 2006-06-02 A | 2008-05-06 A | 100% | 2006-06-02 | 2008-05-06 | 503d? |  | All |  |  | TEI6 |  |  | Rel-6 | all |  |  |  |
| 2051 | 624 | Test - (Small) Technical Enhancements and Improvements for Rel-6 |  | 503d? | 2006-06-02 A | 2008-05-06 A | 100% | 2006-06-02 | 2008-05-06 | 503d? | start no earlier than 2006-06-02 | R5,T1 | 4024h | 4024h | TEI6_Test |  |  | Rel-6 | Ingbert |  | 34.108,34.121-1/2,34.122,34.123-1/2/3 |  |
| 2052 | 625 | Deleted - Study of Feature Interactions Requirements | milestone | 0d? | 2004-09-16 A | 2004-09-16 A | 100% | 2004-09-16 | 2004-09-16 | 0d? | finish no earlier than 2004-10-01 | S1 |  |  | FINTER |  |  | Rel-6 | Alain | SP-25 |  |  |
| 2053 | 626 | Deleted - Enhancements of VGCS in public networks for communication of public authority officials |  | 7d? | 2005-08-24 A | 2005-09-02 A | 100% | 2005-08-24 | 2005-09-02 | 7d? | start no earlier than 2005-08-24 | GP,G2 | 56h | 56h | EVGCS | Siemens | kenneth.isaacs@roke.co.uk | Rel-6 | Paolo | GP-26 | 44.018, 44.068, 48.008 |  |

Notes:
- 2024: -
- 2025: -
- 2026: -
- 2027: -
- 2028: -
- 2029: -
- 2030: -
- 2031: -
- 2032: -
- 2033: -
- 2034: -
- 2035: -
- 2036: -
- 2037: -
- 2038: Approved TSG#24. Marked as closed 12/2008 (was marked 20% complete)
- 2039: SP#24 approved WID. SP#27 completed. SP#46 TR 33.978 withdrawn from Rel-8 onwards
- 2040: Created at TSG#27 as 100 % complete
- 2041: -
- 2042: Feasibility Study
- 2043: -
- 2044: -
- 2045: Marked as closed 12/2008 (was marked 90% complete)
- 2046: Replaces SCSAGB- Originally Started Nov 2003 as GP-030443
- 2047: Replaces SCSAGB-Stage2
- 2048: Replaces SCSAGB-PSH
- 2049: Replaces SCSAGB-RRM
- 2050: "Joker" WI, to be used for a Rel 6 CR not related to any feature and with very limited impact on the system. Moved in from Stoyan/Testing WP
- 2051: "Joker" WI, to be used for small modifications applicable to Rel 4 conformance testing
- 2052: SP#25 stopped
- 2053: GP#26 moved to Rel-7 as UID_11045 Enhancements of VGCS in public networks for communication of public authority officials

| ID | WBS | Task | Type | Duration | Start | Finish | Complete | Baseline start | Baseline finish | Baseline duration | Constraint | Resources | Work | Actual work | Text1 | Text4 | Text5 | Text6 | Text8 | Text12 | Text3 | Text7 | Text10 |
| --- | --- | --- | --- | --- | --- | --- | --- | --- | --- | --- | --- | --- | --- | --- | --- | --- | --- | --- | --- | --- | --- | --- | --- |
| 2054 | 627 | **Deleted - Support of Conversational Services in A/Gb mode via the PS domain** |  | 64d? | 2003-11-21 A | 2004-02-19 A | 100% | 2003-11-21 | 2004-02-19 | 64d? |  | GP,N1 | 1024h | 1024h | SCSAGB | Ericsson | David Bladsjö (david.bladsjo@ericsson.com) | Rel-6 | Paolo | GP-18 |  |  |  |
| 2055 | 627.1 | Deleted - Creation of a TR | milestone | 0d? | 2003-11-21 A | 2003-11-21 A | 100% | 2003-11-21 | 2003-11-21 | 0d? | start no earlier than 2003-11-21 | GP |  |  | SCSAGB-TR | Ericsson | David Bladsjö (david.bladsjo@ericsson.com) | Rel-6 | Paolo | GP-17 |  |  |  |
| 2056 | 627.2 | Deleted - Stage 2 | milestone | 0d? | 2003-11-21 A | 2003-11-21 A | 100% | 2003-11-21 | 2003-11-21 | 0d? | finish no earlier than 2003-11-21 | GP |  |  | SCSAGB-Stage2 | Ericsson | David Bladsjö (david.bladsjo@ericsson.com) | Rel-6 | Paolo | GP-17 |  |  |  |
| 2057 | 627.3 | Deleted - Radio Channel Support | milestone | 0d? | 2003-11-21 A | 2003-11-21 A | 100% | 2003-11-21 | 2003-11-21 | 0d? | finish no earlier than 2003-11-21 | GP |  |  | SCSAGB-RCS | Ericsson | David Bladsjö (david.bladsjo@ericsson.com) | Rel-6 | Paolo | GP-17 |  |  |  |
| 2058 | 627.4 | Deleted - Definition of radio resource management functionality | milestone | 0d? | 2003-11-21 A | 2003-11-21 A | 100% | 2003-11-21 | 2003-11-21 | 0d? | finish no earlier than 2003-11-21 | GP |  |  | SCSAGB-RRM | Ericsson | David Bladsjö (david.bladsjo@ericsson.com) | Rel-6 | Paolo | GP-17 |  |  |  |
| 2059 | 627.5 | Deleted - replaced by 50561 - PS Handover |  | 64d | 2003-11-21 A | 2004-02-19 A | 100% | 2003-11-21 | 2004-02-19 | 64d | start no earlier than 2003-11-21 | GP,N1 | 512h | 512h | SCSAGB-PSH | Ericsson | David Bladsjö (david.bladsjo@ericsson.com) | Rel-6 | Paolo | GP-18 |  |  |  |
| 2060 | 627.6 | Deleted - Modifications to FLO | milestone | 0d? | 2003-11-21 A | 2003-11-21 A | 100% | 2003-11-21 | 2003-11-21 | 0d? | finish no earlier than 2003-11-21 | GP |  |  | SCSAGB-FLO | Ericsson | David Bladsjö (david.bladsjo@ericsson.com) | Rel-6 | Paolo | RP-29 |  |  |  |
| 2061 | 628 | Deleted - Rel-6 Evolutions of the transport in the UTRAN | milestone | 0d | 2003-12-31 A | 2003-12-31 A | 100% | 2003-12-31 | 2003-12-31 | 0d | start no earlier than 2003-12-31 | RP |  |  | ETRAN | Alcatel | Francois Courau | Rel-6 | Issam | RP-22 |  |  |  |
| 2062 | 629 | Release 5 Features |  | 325d? | 2001-03-30 A | 2002-06-28 A | 100% | 2001-03-30 | 2002-06-28 | 325d? |  | NP,GP, RP,SP,TP | 2600h | 2600h |  |  |  | Rel-5 | All |  |  |  |  |
| 2063 | 75 | IP transport in the UTRAN |  | 445d | 2000-07-17 A | 2002-03-29 A | 100% | 2000-07-17 | 2002-03-29 | 445d | finish no earlier than 2002-03-29 | R3 | 3560h | 3560h | ETRAN-IPtrans | Alcatel | Nicolas Drevon | Rel-5 | Juha |  |  |  |  |
| 2064 | 76 | FS on Usage of SUA |  | 205d | 2001-03-12 A | 2001-12-21 A | 100% | 2001-03-12 | 2001-12-21 | 205d | finish no earlier than 2001-12-21 | N4 | 1640h | 1640h | SS7IP |  |  | Rel-5 | Kimmo |  |  |  |  |
| 2065 | 77 | **High Speed Downlink Packet Access** |  | 1550d? | 2001-04-02 A | 2007-03-09 A | 100% | 2001-04-02 | 2007-03-09 | 1550d? |  | R2,R5 | 31488h | 31488h | HSDPA | Motorola | Ravi Kuchibhotla | Rel-5 | Joern |  |  |  |  |
| 2066 | 77.1 | Physical Layer |  | 257d | 2001-04-05 A | 2002-03-29 A | 100% | 2001-04-05 | 2002-03-29 | 257d | finish no earlier than 2002-03-29 | R1 | 2056h | 2056h | HSDPA-Phys | Motorola | Amitabha Ghosh (qa0047@email.mot.com) | Rel-5 | Patrick |  |  |  |  |
| 2067 | 77.2 | Layer 2 and 3 aspects |  | 257d | 2001-04-05 A | 2002-03-29 A | 100% | 2001-04-05 | 2002-03-29 | 257d | finish no earlier than 2002-03-29 | R2 | 2056h | 2056h | HSDPA-L23 | Motorola | Ravi Kuchibhotla | Rel-5 | Joern |  |  |  |  |
| 2068 | 77.3 | Iub/Iur protocol aspects |  | 260d | 2001-04-02 A | 2002-03-29 A | 100% | 2001-04-02 | 2002-03-29 | 260d | finish no earlier than 2002-03-29 | R3 | 2080h | 2080h | HSDPA-IubIur | Motorola | Mike Diesen | Rel-5 | Juha |  |  |  |  |
| 2069 | 77.4 | RF Radio Transmission/ Reception, System Performance Requirements and Conformance Testing |  | 565d | 2001-04-09 A | 2003-06-06 A | 100% | 2001-04-09 | 2003-06-06 | 565d | finish no earlier than 2003-06-06 | R4 | 4520h | 4520h | HSDPA-RF | Motorola | Howard Benn | Rel-5 | Issam |  |  |  |  |
| 2070 | 632.5 | Conformance Testing of HSDPA |  | 786d | 2003-09-19 A | 2006-09-22 A | 100% | 2003-09-19 | 2006-09-22 | 786d | finish no earlier than 2006-09-22 | R5 | 6288h | 6288h | HSDPA_Test | Motorola | carolyn.taylor@motorola.com | Rel-5 | Ingbert |  | 34.108, 34.121, 34.122, 34.123-1, 34.123-2, 34.123-3 | TSG | 19/9/2003 |
| 2071 | 632.6 | Conformance Testing of HCR TDD HSDPA |  | 261d? | 2006-03-10 A | 2007-03-09 A | 100% | 2006-03-10 | 2007-03-09 | 261d? | finish no earlier than 2007-03-09 | R5 | 2088h | 2088h | HSDPA_HCRTDD_Test | IPWireless | drichards@ipwireless.com | Rel-5 | Ingbert |  | 34.108, 34.122, 34.123-1, 34.123-2, 34.123-3 |  |  |
| 2072 | 78 | **Rel-5 Improvements of Radio Interface** |  | 535d | 2000-08-14 A | 2002-08-30 A | 100% | 2000-08-14 | 2002-08-30 | 535d |  | RP | 30376h | 30376h | RInImp |  |  | Rel-5 |  |  |  |  |  |
| 2073 | 78.1 | **Base station classification** |  | 480d | 2000-08-14 A | 2002-06-14 A | 100% | 2000-08-14 | 2002-06-14 | 480d |  | R4 | 9208h | 9208h | RInImp-BSClass | Nokia | antti.toskala@nokia.com | Rel-5 | Issam |  |  |  |  |
| 2074 | 78.1.1 | TDD Base station classification |  | 410d | 2000-08-14 A | 2002-03-08 A | 100% | 2000-08-14 | 2002-03-08 | 410d | finish no earlier than 2002-03-08 | R4 | 3280h | 3280h | RInImp-BSClass-TDD | Nokia | antti.toskala@nokia.com | Rel-5 | Issam |  |  |  |  |
| 2075 | 78.1.2 | Base Station Classification for 1.28 Mcps TDD option |  | 261d | 2001-06-15 A | 2002-06-14 A | 100% | 2001-06-15 | 2002-06-14 | 261d | finish no earlier than 2002-06-14 | R4 | 2088h | 2088h | RInImp-BSClass-LCRTDD | Siemens | Meik.Kottkamp@siemens.com | Rel-5 | Issam |  |  |  |  |
| 2076 | 78.2 | Enhancement on the DSCH hard split mode |  | 271d | 2001-03-16 A | 2002-03-29 A | 100% | 2001-03-16 | 2002-03-29 | 271d | finish no earlier than 2002-03-29 | R1 | 2168h | 2168h | RInImp-DSCHhsp | Samsung | Jaeyoel KIM | Rel-5 | Patrick |  |  |  |  |
| 2077 | 78.3 | Hybrid ARQ II/III |  | 355d | 2000-08-21 A | 2001-12-28 A | 100% | 2000-08-21 | 2001-12-28 | 355d | finish no earlier than 2001-12-28 | R2 | 2840h | 2840h | RInImp-HARQ | Siemens | armin.sitte@siemens.com | Rel-5 | Joern | RP-14 |  |  |  |
| 2078 | 78.4 | FS on USTS |  | 355d | 2000-08-14 A | 2001-12-21 A | 100% | 2000-08-14 | 2001-12-21 | 355d | finish no earlier than 2001-12-21 | R1 | 2840h | 2840h | RInImp-USTS | SK Telecom | D. Kim | Rel-5 | Patrick |  |  |  |  |
| 2079 | 78.5 | FS on UE antenna efficiency test method performance requirements |  | 255d | 2000-09-25 A | 2001-09-14 A | 100% | 2000-09-25 | 2001-09-14 | 255d | finish no earlier than 2001-09-14 | R4 | 2040h | 2040h | RInImp-UEAnTM | Allgon | O. Edvardsson | Rel-5 | Issam |  |  |  |  |
| 2080 | 78.6 | FS on the re-introduction of the downlink SIR measurement |  | 200d | 2001-03-12 A | 2001-12-14 A | 100% | 2001-03-12 | 2001-12-14 | 200d | finish no earlier than 2001-12-14 | R4 | 1600h | 1600h | RInImp-SIR | Ericsson | Torgny.Palenius@ericsson.com | Rel-5 | Issam |  |  |  |  |
| 2081 | 78.7 | FS on mitigating the effect of CPICH interference at the UE |  | 255d | 2001-03-19 A | 2002-03-08 A | 100% | 2001-03-19 | 2002-03-08 | 255d | finish no earlier than 2002-03-08 | R4 | 2040h | 2040h | RInImp-CPICH_Intf | Intel | shimon.moshavi@INTEL.COM | Rel-5 | Issam |  |  |  |  |

Notes:
- 2054: -
- 2055: -
- 2056: Started
- 2057: Not started
- 2058: Not started
- 2059: Started
- 2060: Not started
- 2061: Generic feature
- 2062: -
- 2063: -
- 2064: -
- 2065: -
- 2066: -
- 2067: -
- 2068: -
- 2069: -
- 2070: -
- 2071: -
- 2072: -
- 2073: -
- 2074: -
- 2075: -
- 2076: -
- 2077: Stopped at RP#14; work on this task was performed as part of High Speed Downlink Packet Access feature
- 2078: -
- 2079: -
- 2080: -
- 2081: -

| ID | WBS | Task | Duration | Start | Finish | Complete | Baseline start | Baseline finish | Baseline duration | Constraint | Deadline | Resources | Work | Actual work | Text6 | Text8 | Text12 | Text1 | Text4 | Text5 | Text3 | Text10 |
| --- | --- | --- | --- | --- | --- | --- | --- | --- | --- | --- | --- | --- | --- | --- | --- | --- | --- | --- | --- | --- | --- | --- |
| 2082 | 78.8 | **Deleted - Conformance Test Spec. improvements in Radio Interface** | 140d | 2002-02-18 A | 2002-08-30 A | 100% | 2002-02-18 | 2002-08-30 | 140d |  |  | T1 | 3360h | 3360h | Rel-5 | Ingbert | TP-17 |  |  |  |  |  |
| 2083 | 78.8.1 | Deleted - Testing improvement of inter-frequency and inter-system measurement | 140d | 2002-02-18 A | 2002-08-30 A | 100% | 2002-02-18 | 2002-08-30 | 140d | finish no earlier than 2002-08-30 |  | T1 | 1120h | 1120h | Rel-5 | Ingbert | TP-17 |  |  |  |  |  |
| 2084 | 78.8.2 | Deleted - Testing Hybrid ARQ II/III | 140d | 2002-02-18 A | 2002-08-30 A | 100% | 2002-02-18 | 2002-08-30 | 140d | finish no earlier than 2002-08-30 |  | T1 | 1120h | 1120h | Rel-5 | Ingbert | TP-17 |  |  |  |  |  |
| 2085 | 79 | **Rel-5 RAN improvements** | 1561d? | 2001-03-16 A | 2007-03-09 A | 100% | 2001-03-16 | 2007-03-09 | 1561d? |  |  | RP | 49424h | 49424h | Rel-5 |  |  | RANimp |  |  |  |  |
| 2086 | 79.1 | **RRM optimization for Iur and Iub** | 318d | 2001-03-16 A | 2002-06-04 A | 100% | 2001-03-16 | 2002-06-04 | 318d |  |  | R3 | 8904h | 8904h | Rel-5 | Juha |  | RANimp-RRMopt | Ericsson | Gert-Jan.van.Lieshout@eln.ericsson.se |  |  |
| 2087 | 79.1.1 | Iur common transport channel efficiency optimization | 271d | 2001-03-16 A | 2002-03-29 A | 100% | 2001-03-16 | 2002-03-29 | 271d | finish no earlier than 2002-03-29 |  | R3 | 2168h | 2168h | Rel-5 | Juha |  | RANimp-RRMopt-ctc | Ericsson | Shahrokh Amirijoo |  |  |
| 2088 | 79.1.2 | Iur neighbouring cell reporting efficiency optimization | 271d | 2001-03-16 A | 2002-03-29 A | 100% | 2001-03-16 | 2002-03-29 | 271d | finish no earlier than 2002-03-29 |  | R3 | 2168h | 2168h | Rel-5 | Juha |  | RANimp-RRMopt-ncr | Ericsson | Shahrokh Amirijoo |  |  |
| 2089 | 79.1.3 | FS Introduction of direct transport bearers between SRNC and Node-B | 253d | 2001-06-15 A | 2002-06-04 A | 100% | 2001-06-15 | 2002-06-04 | 253d | finish no earlier than 2002-06-28 |  | R3 | 2024h | 2024h | Rel-5 | Juha |  | RAN-imp-RRMopt-DTB | Ericsson | Risto Sepponen |  |  |
| 2090 | 79.2 | RL Timing Adjustment | 271d | 2001-03-16 A | 2002-03-29 A | 100% | 2001-03-16 | 2002-03-29 | 271d | finish no earlier than 2002-03-29 |  | R3 | 2168h | 2168h | Rel-5 | Juha |  | RANimp-RLTA | Ericsson | Elena Voltolina |  |  |
| 2091 | 79.3 | Separation of resource reservation and radio link activation | 271d | 2001-03-16 A | 2002-03-29 A | 100% | 2001-03-16 | 2002-03-29 | 271d | finish no earlier than 2002-03-29 |  | R3 | 2168h | 2168h | Rel-5 | Juha |  | RANimp-SepRR | Ericsson | Gert-Jan.van.Lieshout@eln.ericsson.se |  |  |
| 2092 | 79.4 | FS SRNS Relocation Procedure Enhancement | 318d | 2001-06-15 A | 2002-09-03 A | 100% | 2001-06-15 | 2002-09-03 | 318d | finish no earlier than 2002-09-06 |  | R3 | 2544h | 2544h | Rel-5 | Juha |  | RANimp-SRNS | Nokia | Olivier Guyot |  |  |
| 2093 | 79.5 | FS Improvement of Radio Resource Management across RNS and RNS/PSS | 201d | 2001-03-16 A | 2001-12-21 A | 100% | 2001-03-16 | 2001-12-21 | 201d | finish no earlier than 2001-12-21 |  | R3 | 1608h | 1608h | Rel-5 | Juha |  | RANimp-ImpRRM | Nokia | antti.toskala@nokia.com |  |  |
| 2094 | 79.6 | Re-arrangements of Iub transport bearers | 271d | 2001-03-16 A | 2002-03-29 A | 100% | 2001-03-16 | 2002-03-29 | 271d | finish no earlier than 2002-03-29 |  | R3 | 2168h | 2168h | Rel-5 | Juha |  | RANimp-TTPS | Nokia | antti.toskala@nokia.com |  |  |
| 2095 | 79.7 | RAB support enhancement for Rel-5 | 325d | 2001-04-02 A | 2002-06-28 A | 100% | 2001-04-02 | 2002-06-28 | 325d |  |  | R2 | 2600h | 2600h | Rel-5 | Joern |  | RANimp-RABSE5 | Nokia | Juha Mikola |  |  |
| 2096 | 16.5.1 | Testing of ROHC performance | 391d | 2005-09-09 A | 2007-03-09 A | 100% | 2005-09-09 | 2007-03-09 | 391d | finish no earlier than 2007-03-09 | 2006-06-02 | R5 | 3128h | 3128h | Rel-5 | Ingbert |  | RANimp-RABSE5_Test | Nokia | jarkko.hellsten@nokia.com | 34.108, 34.123-1, 34.123-2, 34.123-3 | Fri 11/03/05 |
| 2097 | 79.8 | Beamforming requirements for UE | 61d | 2001-09-21 A | 2001-12-14 A | 100% | 2001-09-21 | 2001-12-14 | 61d | finish no earlier than 2001-12-14 |  | R1 | 488h | 488h | Rel-5 | Patrick |  | RANimp-BFR-UE | Nokia | Jussi Kähtävä (juha.mikola@nokia.com) |  |  |
| 2098 | 79.9 | Support of Site Selection Diversity Transmission in UTRAN | 123d | 2001-12-14 A | 2002-06-04 A | 100% | 2001-12-14 | 2002-06-04 | 123d | finish no earlier than 2002-06-04 |  | R1 | 984h | 984h | Rel-5 | Patrick |  | RANimp-SSDT | NEC |  |  |  |
| 2099 | 79.10 | Node B Synchronisation for 1.28 Mcps TDD | 271d | 2001-03-16 A | 2002-03-29 A | 100% | 2001-03-16 | 2002-03-29 | 271d | finish no earlier than 2002-03-29 |  | R1 | 2168h | 2168h | Rel-5 | Patrick |  | RANimp-NBSLCR | CATT | Jinling HU |  |  |
| 2100 | 79.12 | **Deleted - Conformance Test Aspects - RAN Improvements** | 565d? | 2002-01-01 A | 2004-03-01 A | 100% | 2002-01-01 | 2004-03-01 | 565d? |  |  | T1 | 8008h | 8008h | Rel-5 | Ingbert | TP-23 |  |  |  | 0% |  |
| 2101 | 79.12.1 | Deleted - Testing Radio access bearer support enhancements | 175d | 2002-01-01 A | 2002-09-02 A | 100% | 2002-01-01 | 2002-09-02 | 175d | finish no earlier than 2002-09-02 |  | T1 | 1400h | 1400h | Rel-5 | Ingbert | TP-17 |  |  |  |  |  |
| 2102 | 634.12.2 | Deleted - General changes to TS34.121 and TS34.122 corresponding to release 5 | 261d? | 2003-03-03 A | 2004-03-01 A | 100% | 2003-03-03 | 2004-03-01 | 261d? | finish no earlier than 2004-03-01 |  | T1 | 2088h | 2088h | Rel-5 | Ingbert | TP-23 | RANimp-test |  |  | 34.108, 34.121, 34.122 |  |
| 2103 | 80 | UTRAN Sharing in Connected Mode | 197d | 2001-12-03 A | 2002-09-03 A | 100% | 2001-12-03 | 2002-09-03 | 197d | finish no earlier than 2002-09-06 |  | R3 | 1576h | 1576h | Rel-5 | Juha |  | NETSHARE | Ericsson | Martin Israelsson |  |  |
| 2104 | 81 | **Provisioning of IP-based multimedia services** | 1806d | 2000-01-03 A | 2006-12-01 A | 100% | 2000-01-03 | 2006-12-01 | 1806d |  |  | S1,S2,S5,R5 | 205676h | 205676h | Rel-5 | Alain |  | IMS | Openwave | Mark Cataldo |  |  |
| 2105 | 81.1 | **Call control and roaming to support IMS in UMTS** | 1806d | 2000-01-03 A | 2006-12-01 A | 100% | 2000-01-03 | 2006-12-01 | 1806d |  |  | S2,R5 | 95312h | 95312h | Rel-5 | Maurice |  | IMS-CCR | Lucent | Liz Daniel |  |  |
| 2106 | 81.1.1 | Stage 1 | 215d | 2000-02-21 A | 2000-12-15 A | 100% | 2000-02-21 | 2000-12-15 | 215d | finish no earlier than 2000-09-21 |  | S1 | 1720h | 1720h | Rel-5 | Alain |  | IMS-CCR | Motorola | Mark Cataldo | 22.228 |  |
| 2107 | 81.1.2 | Stage 2 (Architecture and Main flows) | 246d | 2000-04-14 A | 2001-03-23 A | 100% | 2000-04-14 | 2001-03-23 | 246d | finish no earlier than 2001-03-23 |  | S2 | 1968h | 1968h | Rel-5 | Maurice |  | IMS-CCR | Lucent | Liz Daniel | 23.228 |  |
| 2108 | 81.1.3 | Impact on MM/CC/SM | 400d | 2000-08-28 A | 2002-03-08 A | 100% | 2000-08-28 | 2002-03-08 | 400d | finish no earlier than 2002-03-08 |  | N1 | 3200h | 3200h | Rel-5 | Frederic |  | IMS-CCR-IWMM | Lucent | Keith Drage (drage@alcatel-lucent.com) |  |  |

Notes:
- 2082: Marked as stopped 12/2008
- 2083: Marked as stopped 12/2008
- 2084: Marked as stopped 12/2008
- 2085: -
- 2086: -
- 2087: -
- 2088: -
- 2089: FS was closed and introduction of WI not agreed at RAN #16
- 2090: -
- 2091: -
- 2092: -
- 2093: FS was closed and WI was introduced at RAN #14
- 2094: -
- 2095: RFC 3095 context relocation
- 2096: -
- 2097: -
- 2098: RP-020356
- 2099: -
- 2100: Marked as stopped 12/2008
- 2101: Marked as stopped 12/2008
- 2102: Marked as stopped 12/2008
- 2103: Formerly 'Shared Network support in connected mode', renamed at RAN #16.
- 2104: -
- 2105: -
- 2106: Issues include e.g.: Roaming requirements, Requirements on supplementary services, Interworking requirements
- 2107: Issues include e.g.: Mobile IP, RAB selection principles, Optimized VoIP bearer mechanisms, SIP multimedia protocol
- 2108: Per 26/2-02: This is understood to be the PCO & TFT CRs which CN1 provides to TSGN #15 for approval. If this is correct understanding, then the task is 100 % complete.

| ID | WBS | Task | Duration | Start | Finish | Complete | Baseline start | Baseline finish | Baseline duration | Constraint | Deadline | Resources | Work | Actual work | Text1 | Text3 | Text4 | Text5 | Text6 | Text8 | Text10 |
| --- | --- | --- | --- | --- | --- | --- | --- | --- | --- | --- | --- | --- | --- | --- | --- | --- | --- | --- | --- | --- | --- |
| 2109 | 81.1.4 | **SIP Call Control protocol for the IMS** | 385d | 2000-10-02 A | 2002-03-22 A | 100% | 2000-10-02 | 2002-03-22 | 385d |  |  | N1 | 12320h | 12320h | IMS-CCR | 24.228, 24.229, 23.218 | Lucent | Keith Drage (drage@alcatel-lucent.com) | Rel-5 | Frederic |  |
| 2110 | 81.1.4.1 | IMS signalling flows | 385d | 2000-10-02 A | 2002-03-22 A | 100% | 2000-10-02 | 2002-03-22 | 385d | finish no earlier than 2002-03-22 |  | N1 | 3080h | 3080h | IMS-CCR | 24.228 |  |  | Rel-5 | Frederic |  |
| 2111 | 81.1.4.2 | IMS stage 3 | 385d | 2000-10-02 A | 2002-03-22 A | 100% | 2000-10-02 | 2002-03-22 | 385d | finish no earlier than 2002-03-22 |  | N1 | 3080h | 3080h | IMS-CCR | 24.229 |  |  | Rel-5 | Frederic |  |
| 2112 | 81.1.4.3 | IMS Session Handling; stage 2 | 385d | 2000-10-02 A | 2002-03-22 A | 100% | 2000-10-02 | 2002-03-22 | 385d | finish no earlier than 2002-03-22 |  | N1 | 3080h | 3080h | IMS-CCR | 23.218 |  |  | Rel-5 | Frederic |  |
| 2113 | 16.5.1 | Conformance Test Aspects – IMS Call Control | 451d | 2005-03-11 A | 2006-12-01 A | 100% | 2005-03-11 | 2006-12-01 | 451d |  | 2006-06-02 | R5 | 3608h | 3608h | IMS-CCR_Test | 34.108, 34.229-1, 34.229-2, 34.229-3 | Motorola | Jacob.John@motorola.com | Rel-5 | Ingbert | Fri 11/03/05 |
| 2114 | 81.1.4.4 | **Main IETF dependencies** | 641d | 2000-01-03 A | 2002-06-14 A | 100% | 2000-01-03 | 2002-06-14 | 641d |  |  | NP | 58048h | 58048h | IMS |  |  |  | Rel-5 | Kimmo |  |
| 2115 | 81.1.4.4.1 | IETF: RFC 3261 (Session Initiation Protocol) | 346d | 2000-11-24 A | 2002-03-22 A | 100% | 2000-11-24 | 2002-03-22 | 346d | finish no earlier than 2002-03-22 |  | N1 | 2768h | 2768h | IMS |  |  |  | Rel-5 | Frederic |  |
| 2116 | 81.1.4.4.2 | IETF: RFC 3262 (Reliability of provisional responses) | 346d | 2000-11-24 A | 2002-03-22 A | 100% | 2000-11-24 | 2002-03-22 | 346d | finish no earlier than 2002-03-22 |  | N1 | 2768h | 2768h | IMS |  |  |  | Rel-5 | Frederic |  |
| 2117 | 81.1.4.4.3 | IETF: RFC 3312 (Without COMET)(Integration of resource management and SIP) | 382d | 2000-11-24 A | 2002-05-13 A | 100% | 2000-11-24 | 2002-05-13 | 382d | finish no earlier than 2002-05-13 |  | N1 | 3056h | 3056h | IMS |  |  |  | Rel-5 | Frederic |  |
| 2118 | 81.1.4.4.4 | IETF: RFC 3323 (SIP extensions for caller identity and privacy) | 382d | 2000-11-24 A | 2002-05-13 A | 100% | 2000-11-24 | 2002-05-13 | 382d | finish no earlier than 2002-05-13 |  | N1 | 3056h | 3056h | IMS |  |  |  | Rel-5 | Frederic |  |
| 2119 | 81.1.4.4.5 | IETF: RFC 3313 (SIP extensions for media authorization) | 382d | 2000-11-24 A | 2002-05-13 A | 100% | 2000-11-24 | 2002-05-13 | 382d | finish no earlier than 2002-05-13 |  | N1 | 3056h | 3056h | IMS |  |  |  | Rel-5 | Frederic |  |
| 2120 | 81.1.4.4.6 | IETF: RFC 3265 (specific event notification) | 346d | 2000-11-24 A | 2002-03-22 A | 100% | 2000-11-24 | 2002-03-22 | 346d | finish no earlier than 2002-03-22 |  | N1 | 2768h | 2768h | IMS |  |  |  | Rel-5 | Frederic |  |
| 2121 | 81.1.4.4.7 | IETF: RFC editor Queue (refer method) | 401d | 2000-11-24 A | 2002-06-07 A | 100% | 2000-11-24 | 2002-06-07 | 401d | finish no earlier than 2002-06-07 |  | N1 | 3208h | 3208h | IMS |  |  |  | Rel-5 | Frederic |  |
| 2122 | 81.1.4.4.8 | IETF: RFC editor Queue (DHCP options for SIP servers) | 382d | 2000-11-24 A | 2002-05-13 A | 100% | 2000-11-24 | 2002-05-13 | 382d | finish no earlier than 2002-05-13 |  | N1 | 3056h | 3056h | IMS |  |  |  | Rel-5 | Frederic |  |
| 2123 | 81.1.4.4.10 | IETF: RFC 3267 (AMR and AMR WB RTP and SDP) | 346d | 2000-11-24 A | 2002-03-22 A | 100% | 2000-11-24 | 2002-03-22 | 346d | finish no earlier than 2002-03-22 |  | N1 | 2768h | 2768h | IMS |  |  |  | Rel-5 | Frederic |  |
| 2124 | 81.1.4.4.11 | IETF: RFC 3266 (IPv6 support within SDP) | 581d | 2000-01-03 A | 2002-03-22 A | 100% | 2000-01-03 | 2002-03-22 | 581d | finish no earlier than 2002-03-22 |  | N1 | 4640h | 4640h | IMS |  |  |  | Rel-5 | Frederic |  |
| 2125 | 81.1.4.4.12 | IETF: RFC 3311 (The Update method) | 382d | 2000-11-24 A | 2002-05-13 A | 100% | 2000-11-24 | 2002-05-13 | 382d | finish no earlier than 2002-05-13 |  | N1 | 3056h | 3056h | IMS |  |  |  | Rel-5 | Frederic |  |
| 2126 | 81.1.4.4.13 | IETF: RFC 3324 (Network Asserted Identity) | 382d | 2000-11-24 A | 2002-05-13 A | 100% | 2000-11-24 | 2002-05-13 | 382d | finish no earlier than 2002-05-13 |  | N1 | 3056h | 3056h | IMS |  |  |  | Rel-5 | Frederic |  |
| 2127 | 81.1.4.4.14 | IETF: RFC editor Queue (Various 3GPP Private Extensions) | 382d | 2000-11-24 A | 2002-05-13 A | 100% | 2000-11-24 | 2002-05-13 | 382d | finish no earlier than 2002-05-13 |  | N1 | 3056h | 3056h | IMS |  |  |  | Rel-5 | Frederic |  |
| 2128 | 81.1.4.5 | **Addressing** | 380d | 2000-10-09 A | 2002-03-22 A | 100% | 2000-10-09 | 2002-03-22 | 380d |  |  | S2 | 7744h | 7744h | IMS |  |  |  | Rel-5 | Maurice |  |
| 2129 | 81.1.4.5.1 | Architectural issues | 235d | 2000-10-09 A | 2001-08-31 A | 100% | 2000-10-09 | 2001-08-31 | 235d | finish no earlier than 2001-03-16 |  | S2 | 1880h | 1880h | IMS |  |  |  | Rel-5 | Maurice |  |
| 2130 | 81.1.4.5.2 | Impact on HSS | 353d | 2000-11-15 A | 2002-03-22 A | 100% | 2000-11-15 | 2002-03-22 | 353d | finish no earlier than 2002-03-22 |  | N4 | 2824h | 2824h | IMS |  |  |  | Rel-5 | Kimmo |  |
| 2131 | 81.1.4.6 | **Service Examples (Work stopped)** | 304d | 2001-04-17 A | 2002-06-14 A | 100% | 2001-04-17 | 2002-06-14 | 304d |  |  | S1 | 4864h | 4864h | IMS-Sex | 22.928 | Motorola | Mark Cataldo | Rel-5 | Alain |  |
| 2132 | 81.1.4.6.1 | IMS Framework Report (work stopped) | 304d | 2001-04-17 A | 2002-06-14 A | 100% | 2001-04-17 | 2002-06-14 | 304d | finish no earlier than 2002-06-14 |  | S1 | 2432h | 2432h | IMS-FrWk | 22.941 | SBC | Randolph Wohlert (rwohlert@tri.sbc.com) | Rel-5 | Alain |  |

Notes:
- 2109: TSGN_10 approved the change:CN1 - SA2 SIP joint meeting spotted one more place for improvement: work tasks with ID 1998 and 1278 are actually subtasks under of single CN1 WT. One WI has been approved for the CN1 WT with title "SIP Call Control protocol
- 2110: 24.228
- 2111: 24.229
- 2112: 23.218
- 2113: -
- 2114: -
- 2115: -
- 2116: -
- 2117: -
- 2118: -
- 2119: -
- 2120: -
- 2121: -
- 2122: -
- 2123: -
- 2124: -
- 2125: -
- 2126: -
- 2127: -
- 2128: -
- 2129: -
- 2130: Covered by 29.228 & 29228
- 2131: -
- 2132: -

| ID | WBS | Task | Duration | Start | Finish | Complete | Baseline start | Baseline finish | Baseline duration | Constraint | Resources | Work | Actual work | Text1 | Text4 | Text5 | Text6 | Text8 | Text3 |
| --- | --- | --- | --- | --- | --- | --- | --- | --- | --- | --- | --- | --- | --- | --- | --- | --- | --- | --- | --- |
| 2133 | 81.2 | **Access Security for IMS** | 190d | 2001-10-08 A | 2002-06-28 A | 100% | 2001-10-08 | 2002-06-28 | 190d |  | S3 | 4120h | 4120h | IMS-ASEC | Ericsson | krister.boman@emw.ericsson.se | Rel-5 | Dionisio |  |
| 2134 | 81.2.2 | IMS impacts on UICC (ISIM application) | 185d | 2001-10-08 A | 2002-06-21 A | 100% | 2001-10-08 | 2002-06-21 | 185d | finish no earlier than 2002-06-21 | T3 | 1480h | 1480h |  | Vodafone | Jeremy Norris | Rel-5 | Xavier |  |
| 2135 | 81.2.3 | SIP extensions for Integrity protection | 140d | 2001-12-17 A | 2002-06-28 A | 100% | 2001-12-17 | 2002-06-28 | 140d | finish no earlier than 2002-06-28 | N1 | 1120h | 1120h |  |  |  | Rel-5 | Frederic |  |
| 2136 | 81.3 | Security Aspects of Requirement for Network Configuration Independence | 130d | 2001-07-02 A | 2001-12-28 A | 100% | 2001-07-02 | 2001-12-28 | 130d | finish no earlier than 2001-12-28 | S3 | 1040h | 1040h | SEC1-NCI | AT&T Wireless | hugh.shieh@attws.com | Rel-5 | Dionisio |  |
| 2137 | 81.4 | Lawful interception | 410d | 2000-09-04 A | 2002-03-29 A | 100% | 2000-09-04 | 2002-03-29 | 410d | finish no earlier than 2002-03-29 | S3 | 3280h | 3280h | IMS-LI | Reg TP | berthold.wilhelm@regtp.de | Rel-5 | Dionisio | 33.106, 33.107, new 33.108 |
| 2138 | 81.5 | Charging and OAM&P for IMS | 383d | 2000-12-25 A | 2002-06-12 A | 100% | 2000-12-25 | 2002-06-12 | 383d | finish no earlier than 2002-06-12 | S5 | 3064h | 3064h | IMS-OAM | VoiceStream, Motorola |  | Rel-5 | Dionisio | 32-series |
| 2139 | 81.6 | **Multimedia codecs and protocols for conversational PS services** | 568d | 2000-07-26 A | 2002-09-27 A | 100% | 2000-07-26 | 2002-09-27 | 568d |  | S4 | 15640h | 15640h | IMS-CODEC | Toshiba, Nokia | B. Aronson (Toshiba), pasi.s.ojala@nokia.com | Rel-5 | Paolo | 26.235, 26.236 |
| 2140 | 81.6.1 | Codecs | 427d | 2000-07-26 A | 2002-03-14 A | 100% | 2000-07-26 | 2002-03-14 | 427d | finish no earlier than 2001-03-21 | S4 | 3416h | 3416h |  |  |  | Rel-5 | Paolo | 26.235, 26.236 |
| 2141 | 81.6.2 | Transport protocols | 1d | 2002-03-12 A | 2002-03-12 A | 100% | 2002-03-12 | 2002-03-12 | 1d | finish no earlier than 2002-03-12 | S4 | 8h | 8h | IMS-CODEC | Nokia | P. Ojala | Rel-5 | Paolo | 26.236 |
| 2142 | 81.6.4 | recommendation for QoS parameter values for various media types | 195d | 2001-12-31 A | 2002-09-27 A | 100% | 2001-12-31 | 2002-09-27 | 195d | finish no earlier than 2002-09-27 | S4 | 1560h | 1560h |  |  |  | Rel-5 | Paolo |  |
| 2143 | 81.6.5 | IETF: RFC 3310 (HTTP Digest Authentication using AKA) | 382d | 2000-11-24 A | 2002-05-13 A | 100% | 2000-11-24 | 2002-05-13 | 382d | finish no earlier than 2002-05-13 | N1 | 3056h | 3056h |  |  |  | Rel-5 | Frederic |  |
| 2144 | 81.6.6 | IETF: RFC 3329 (Security mechanism agreement for SIP connections) | 382d | 2000-11-24 A | 2002-05-13 A | 100% | 2000-11-24 | 2002-05-13 | 382d | finish no earlier than 2002-05-13 | N1 | 3056h | 3056h |  |  |  | Rel-5 | Frederic |  |
| 2145 | 81.7 | **SIP message compression** | 185d | 2001-09-24 A | 2002-06-07 A | 100% | 2001-09-24 | 2002-06-07 | 185d |  | S2 | 3128h | 3128h |  |  |  | Rel-5 | Maurice |  |
| 2146 | 81.7.1 | Stage 2 | 25d | 2001-09-24 A | 2001-10-26 A | 100% | 2001-09-24 | 2001-10-26 | 25d | finish no earlier than 2001-10-26 | S2 | 200h | 200h |  |  |  | Rel-5 | Maurice |  |
| 2147 | 81.7.2 | Compression signalling | 181d | 2001-09-28 A | 2002-06-07 A | 100% | 2001-09-28 | 2002-06-07 | 181d | finish no earlier than 2002-06-07 | N1 | 1448h | 1448h |  |  |  | Rel-5 | Frederic |  |
| 2148 | 81.8 | **Stage 3 description of IMS interfaces** | 383d | 2001-03-14 A | 2002-08-30 A | 100% | 2001-03-14 | 2002-08-30 | 383d |  | NP | 29531.6h | 29531.6h |  |  |  | Rel-5 | Kimmo |  |
| 2149 | 81.8.1 | Cx interface (HSS to CSCF) | 135.95d | 2001-03-14 A | 2002-06-07 A | 100% | 2001-03-14 | 2002-06-07 | 135.95d | finish no earlier than 2002-06-07 | N4 | 1087.58h | 1087.58h |  |  |  | Rel-5 | Kimmo |  |
| 2150 | 81.8.2 | Mp interface (MRFC - MRFP) enhancements | 258d | 2001-03-14 A | 2002-03-08 A | 100% | 2001-03-14 | 2002-03-08 | 258d | finish no earlier than 2002-06-07 | N4 | 2064h | 2064h |  |  |  | Rel-5 | Kimmo |  |
| 2151 | 81.8.3 | Mw interface (CSCF to P-CSCF) | 323d | 2001-03-14 A | 2002-06-07 A | 100% | 2001-03-14 | 2002-06-07 | 323d | finish no earlier than 2002-06-07 | N1 | 2584h | 2584h |  |  |  | Rel-5 | Frederic |  |
| 2152 | 81.8.4 | Mr interface (CSCF to MRF) | 273d | 2001-03-14 A | 2002-03-29 A | 100% | 2001-03-14 | 2002-03-29 | 273d | finish no earlier than 2002-03-29 | N1 | 2184h | 2184h |  |  |  | Rel-5 | Frederic |  |
| 2153 | 81.8.5 | Dx interface (I-CSCF to SLF) | 323d | 2001-03-14 A | 2002-06-07 A | 100% | 2001-03-14 | 2002-06-07 | 323d | finish no earlier than 2002-06-07 | N4 | 2584h | 2584h |  |  |  | Rel-5 | Kimmo |  |
| 2154 | 81.8.6 | Go interface (GGSN to PCF) | 323d | 2001-03-14 A | 2002-06-07 A | 100% | 2001-03-14 | 2002-06-07 | 323d | finish no earlier than 2002-06-07 | N3 | 2584h | 2584h |  |  |  | Rel-5 | Gwiho |  |
| 2155 | 81.8.7 | ISC (IMS Service Control) Interface | 323d | 2001-03-14 A | 2002-06-07 A | 100% | 2001-03-14 | 2002-06-07 | 323d | finish no earlier than 2002-06-07 | N1 | 2584h | 2584h |  |  |  | Rel-5 | Frederic |  |
| 2156 | 81.8.8 | Sh interface (HSS to AS) | 82d | 2002-02-14 A | 2002-06-07 A | 100% | 2002-02-14 | 2002-06-07 | 82d | finish no earlier than 2002-06-07 | N4 | 656h | 656h |  |  |  | Rel-5 | Kimmo |  |
| 2157 | 81.8.9 | Si interface (HSS to IM-SSF) | 162.5d | 2002-01-16 A | 2002-08-30 A | 100% | 2002-01-16 | 2002-08-30 | 162.5d | finish no earlier than 2002-06-07 | N4 | 1300h | 1300h |  |  |  | Rel-5 | Kimmo |  |
| 2158 | 81.8.10 | Gm interface (UE to CSCF) | 323d | 2001-03-14 A | 2002-06-07 A | 100% | 2001-03-14 | 2002-06-07 | 323d | finish no earlier than 2002-06-07 | N1 | 2584h | 2584h |  |  |  | Rel-5 | Frederic |  |
| 2159 | 81.8.11 | Mi interface (CSCF to BGCF) | 323d | 2001-03-14 A | 2002-06-07 A | 100% | 2001-03-14 | 2002-06-07 | 323d | finish no earlier than 2002-06-07 | N1 | 2584h | 2584h |  |  |  | Rel-5 | Frederic |  |
| 2160 | 81.8.12 | Mj interface (BGCF to MGCF) | 323d | 2001-03-14 A | 2002-06-07 A | 100% | 2001-03-14 | 2002-06-07 | 323d | finish no earlier than 2002-06-07 | N1 | 2584h | 2584h |  |  |  | Rel-5 | Frederic |  |
| 2161 | 81.8.13 | Mk interface (BGCF to BGCF) | 323d | 2001-03-14 A | 2002-06-07 A | 100% | 2001-03-14 | 2002-06-07 | 323d | finish no earlier than 2002-06-07 | N1 | 2584h | 2584h |  |  |  | Rel-5 | Frederic |  |
| 2162 | 81.9 | Support of VHE/OSA by entities and protocols of the IMS (e.g. CSCF) | 186d | 2001-09-21 A | 2002-06-07 A | 100% | 2001-09-21 | 2002-06-07 | 186d | finish no earlier than 2002-06-07 | N5 | 1488h | 1488h | IMS-ONOSA | Ericsson | Ard.Jan.Moerdijk@eln.ericsson.se | Rel-5 | Kimmo | 29.198, 29.998 |

Notes:
- 2133: TS33.203 will be presented for info at SP#14 and is scheduled for approval at SP#15. Dependencies on IETF exist. Approved SP#15
- 2134: -
- 2135: Per 26/2-02: CN1 is not aware of any requirements and is not doing anything on this task.
- 2136: Incorporated into IMS access security TS (33.203) which will be presented for info at SP#14 and is scheduled for approval at SP#15.Editors notes removed SP#16&17
- 2137: SA#17 completed
- 2138: -
- 2139: -
- 2140: -
- 2141: -
- 2142: -
- 2143: -
- 2144: -
- 2145: -
- 2146: -
- 2147: -
- 2148: -
- 2149: -
- 2150: [DAB 08-03-02] - No work required in CN4
- 2151: -
- 2152: -
- 2153: CN4#11 30/11/01: No inputs received in CN4 / 14/02/02 Completed(introduced in 29.228)
- 2154: [DAB - 23/05/03] - 100 % complete
- 2155: -
- 2156: CN4#11 30/11/01: No inputs received in CN4 / CN4#12bis 14/02/02: WID approved / 17th May 100% complete. 3GPP TS 29.329 will be sent for approval in CN#16
- 2157: SA16: Part of Rel5 only if completed in September 02. Marked as closed 12/2008 (was marked 72% complete)
- 2158: -
- 2159: -
- 2160: -
- 2161: -
- 2162: -

| ID | WBS | Task | Duration | Start | Finish | Predecessors | Complete | Baseline start | Baseline finish | Baseline duration | Constraint | Resources | Work | Actual work | Text1 | Text4 | Text5 | Text6 | Text8 | Text12 | Text3 |
| --- | --- | --- | --- | --- | --- | --- | --- | --- | --- | --- | --- | --- | --- | --- | --- | --- | --- | --- | --- | --- | --- |
| 2163 | 81.10 | **CAMEL control of IMS services** | 365d | 2001-04-16 A | 2002-09-06 A |  | 100% | 2001-04-16 | 2002-09-06 | 365d |  | N2 | 9952h | 9952h | IMS-CAMEL | Lucent | Angelica Remoquillo | Rel-5 | Kimmo |  |  |
| 2164 | 81.10.1 | Stage2 work 'general' | 365d | 2001-04-16 A | 2002-09-06 A |  | 100% | 2001-04-16 | 2002-09-06 | 365d | finish no earlier than 2002-09-06 | N2 | 2920h | 2920h |  |  |  | Rel-5 | Kimmo |  |  |
| 2165 | 81.10.2 | Stage3 work 'CAP' | 175d | 2002-01-07 A | 2002-09-06 A |  | 100% | 2002-01-07 | 2002-09-06 | 175d | finish no earlier than 2002-09-06 | N2 | 1400h | 1400h |  |  |  | Rel-5 | Kimmo |  |  |
| 2166 | 81.10.3 | Stage2 work 'Si interface' | 175d | 2002-01-07 A | 2002-09-06 A |  | 100% | 2002-01-07 | 2002-09-06 | 175d | finish no earlier than 2002-09-06 | N2 | 1400h | 1400h |  |  |  | Rel-5 | Kimmo |  |  |
| 2167 | 81.10.4 | Stage3 work 'Si interface' | 82d | 2002-02-14 A | 2002-06-07 A |  | 100% | 2002-02-14 | 2002-06-07 | 82d | finish no earlier than 2002-06-07 | N4 | 656h | 656h |  |  |  | Rel-5 | Kimmo |  |  |
| 2168 | 81.10.5 | Deleted - SDM issues for CAMEL control of IMS | 82d | 2002-02-14 A | 2002-06-07 A |  | 100% | 2002-02-14 | 2002-06-07 | 82d | finish no earlier than 2002-06-07 | N4 | 656h | 656h |  |  |  | Rel-5 | Kimmo | NP-17 |  |
| 2169 | 81.11 | Pre-pay/real-time charging in IMS | 196d | 2001-06-15 A | 2002-03-15 A |  | 100% | 2001-06-15 | 2002-03-15 | 196d | finish no earlier than 2002-03-15 | S1 | 1568h | 1568h |  |  |  | Rel-5 | Alain |  |  |
| 2170 | 81.12 | **Charging** | 289d | 2001-08-06 A | 2002-09-12 A |  | 100% | 2001-08-06 | 2002-09-12 | 289d |  | S2,S5 | 6632h | 6632h | OAM-CH | T-Mobile | karl-heinz.nenner@t-mobile.de | Rel-5 | Dionisio |  | 32.225 |
| 2171 | 81.12.1 | Charging Implications of IMS architecture | 75d | 2001-08-06 A | 2001-11-16 A |  | 100% | 2001-08-06 | 2001-11-16 | 75d | finish no earlier than 2001-11-16 | S2 | 600h | 600h |  |  |  | Rel-5 | Maurice |  |  |
| 2172 | 81.12.2 | Charging management for IMS (off-line & on-line) | 214d | 2001-11-19 A | 2002-09-12 A | 2171 | 100% | 2001-11-19 | 2002-09-12 | 214d | finish no earlier than 2002-09-12 | S5 | 1712h | 1712h | OAM-CH |  |  | Rel-5 | Dionisio |  | 32.225 |
| 2173 | 86.1.6.10 | Billing, accounting and call detail record aspects | 251d | 2001-09-27 A | 2002-09-12 A |  | 100% | 2001-09-27 | 2002-09-12 | 251d | finish no earlier than 2002-09-12 | S5 | 2008h | 2008h | OAM-CH | T-Mobile | Karl-Heinz.Nenner@T-MOBILE.DE | Rel-5 | Dionisio |  | 32.225 |
| 2174 | 81.13 | **Other IETF dependencies** | 401d | 2000-11-24 A | 2002-06-07 A |  | 100% | 2000-11-24 | 2002-06-07 | 401d |  | NP | 9624h | 9624h |  |  |  | Rel-5 |  |  |  |
| 2175 | 81.13.1 | IETF: draft-ietf-aaa-diameter - should be CN4 | 401d | 2000-11-24 A | 2002-06-07 A |  | 100% | 2000-11-24 | 2002-06-07 | 401d | finish no earlier than 2002-06-07 | NP | 3208h | 3208h |  |  |  | Rel-5 |  |  |  |
| 2176 | 81.13.2 | IETF: draft-johansson-aaa-diameter-mm-app - should be CN4 | 401d | 2000-11-24 A | 2002-06-07 A |  | 100% | 2000-11-24 | 2002-06-07 | 401d | finish no earlier than 2002-06-07 | NP | 3208h | 3208h |  |  |  | Rel-5 |  |  |  |
| 2177 | 81.15 | Conformance Test Aspects - Provisioning of IMS | 205d | 2002-03-18 A | 2002-12-27 A |  | 100% | 2002-03-18 | 2002-12-27 | 205d | finish no earlier than 2002-12-27 | T1 | 1640h | 1640h | IMS-TEST |  |  | Rel-5 | Ingbert |  |  |
| 2178 | 81.16 | Testing of support for IMS - prose | 270d | 2002-09-18 A | 2003-09-30 A |  | 100% | 2002-09-18 | 2003-09-30 | 270d | finish no earlier than 2003-09-30 | T1 | 2160h | 2160h |  | Anritsu | dan.fox@eu.anritsu.com | Rel-5 | Ingbert |  | 34.108, 34.123 |
| 2179 | 81.17 | Testing of support for IMS - TTCN | 381d | 2002-09-18 A | 2004-03-03 A |  | 100% | 2002-09-18 | 2004-03-03 | 381d | finish no earlier than 2004-03-03 | T1 | 3048h | 3048h |  | Anritsu | dan.fox@eu.anritsu.com | Rel-5 | Ingbert |  | 34.108, 34.123 |
| 2180 | 82 | **Extended Transparent End-to-End PS Streaming Service** | 313d? | 2002-01-03 A | 2003-03-17 A |  | 100% | 2002-01-03 | 2003-03-17 | 313d? |  | S4 | 6224h | 6224h | PSS-E | Ericsson | olle.franceschi@ericsson.com | Rel-5 | Paolo |  | 26.233, 26.234 |
| 2181 | 82.1 | **Stage 1** | 86d? | 2002-11-18 A | 2003-03-17 A |  | 100% | 2002-11-18 | 2003-03-17 | 86d? |  | S1 | 1376h | 1376h |  | Vodafone | stephen.wolak@vodafone.com | Rel-5 | Alain |  | 22.233 |
| 2182 | 637.1.1 | Interaction with other services | 86d? | 2002-11-18 A | 2003-03-17 A |  | 100% | 2002-11-18 | 2003-03-17 | 86d? | finish no earlier than 2003-03-17 | S1 | 688h | 688h |  | Vodafone | stephen.wolak@vodafone.com | Rel-5 | Alain |  | 22.233 |
| 2183 | 82.2 | Stage 2 (version Rel5 of TS 26.234) | 51d | 2002-01-03 A | 2002-03-14 A |  | 100% | 2002-01-03 | 2002-03-14 | 51d | finish no earlier than 2002-03-26 | S4 | 408h | 408h |  |  |  | Rel-5 | Paolo |  | 26.234 |
| 2184 | 82.3 | RTP usage model | 242d | 2002-01-03 A | 2002-12-06 A |  | 100% | 2002-01-03 | 2002-12-06 | 242d | finish no earlier than 2002-12-06 | S4 | 1936h | 1936h |  |  |  | Rel-5 | Paolo |  | 26.937 |
| 2185 | 83 | **Rel-5 OSA enhancements** | 955d | 1999-04-27 A | 2002-12-20 A |  | 100% | 1999-04-27 | 2002-12-20 | 955d |  | S1 | 62480h | 62480h | OSA1 | Siemens | Joerg Swetina (joerg.swetina@nw.neclab.eu) | Rel-5 | Alain |  | 22.127, 23.127, 29.198-x, 29.998-x |
| 2186 | 83.1 | General Stage 2 for Rel5 | 194d | 2001-09-11 A | 2002-06-07 A |  | 100% | 2001-09-11 | 2002-06-07 | 194d |  | S2 | 1232h | 1232h |  |  |  | Rel-5 | Maurice |  |  |

Notes:
- 2163: -
- 2164: DAB 12.12.01 split into cn4 and cn2 parts
- 2165: DAB 12.12.01 split into cn4 and cn2 parts
- 2166: DAB 12.12.01 split into cn4 and cn2 parts
- 2167: [DAB 08-03-02] - UID 12004 is MASTER of UID 14998 / 17 May need to be recearch possible impact on 23.008 & 23.016, changes to 29.002 are done.
- 2168: Marked as stopped 12/2008
- 2169: Marked as closed 12/2008 (was marked 60% complete)
- 2170: -
- 2171: -
- 2172: -
- 2173: -
- 2174: Was introduced at SP#13 by Ileana Leuca (exact position in the WP and related WG have to be defined)
- 2175: Marked as closed 12/2008 (was marked 90% complete)
- 2176: Marked as closed 12/2008 (was marked 50% complete)
- 2177: The task is a building block, individual work items are being considered but are constrained by lack of supporting companies. Marked as stopped 12/2008
- 2178: Marked as stopped 12/2008
- 2179: Marked as stopped 12/2008
- 2180: -
- 2181: 2nd resp SA4
- 2182: 2nd resp SA4. Marked as closed 12/2008 (was marked 65% complete)
- 2183: 2nd resp SA2
- 2184: Marked as closed 12/2008 (was marked 90% complete)
- 2185: -
- 2186: Marked as closed 12/2008 (was marked 47% complete)

| ID | WBS | Task | Duration | Start | Finish | Predecessors | Complete | Baseline start | Baseline finish | Baseline duration | Constraint | Resources | Work | Actual work | Text1 | Text6 | Text8 | Text3 | Text4 | Text5 |
| --- | --- | --- | --- | --- | --- | --- | --- | --- | --- | --- | --- | --- | --- | --- | --- | --- | --- | --- | --- | --- |
| 2187 | 83.2 | **OSA APIs for Multimedia Call Control** | 499d | 2000-07-11 A | 2002-06-07 A |  | 100% | 2000-07-11 | 2002-06-07 | 499d |  | S2 | 5960h | 5960h | OSA1-CSCF | Rel-5 | Maurice |  |  |  |
| 2188 | 83.2.1 | Stage 1 | 438d | 2000-07-11 A | 2002-03-14 A |  | 100% | 2000-07-11 | 2002-03-14 | 438d | finish no earlier than 2002-03-14 | S1 | 3504h | 3504h |  | Rel-5 | Alain | 22.127 | Siemens | Manfred.leitgeb@siemens.at |
| 2189 | 83.2.2 | Multimedia Call Control - Stages 2 and 3 | 194d | 2001-09-11 A | 2002-06-07 A |  | 100% | 2001-09-11 | 2002-06-07 | 194d | finish no earlier than 2002-06-07 | N5 | 1552h | 1552h |  | Rel-5 | Kimmo | 29.198-04 |  |  |
| 2190 | 83.3 | Generic user interaction - Stage 3 | 194d | 2001-09-11 A | 2002-06-07 A |  | 100% | 2001-09-11 | 2002-06-07 | 194d | finish no earlier than 2002-06-07 | N5 | 1552h | 1552h |  | Rel-5 | Kimmo | 29.198-05 |  |  |
| 2191 | 83.4 | Charging - Stage 3 | 194d | 2001-09-11 A | 2002-06-07 A |  | 100% | 2001-09-11 | 2002-06-07 | 194d | finish no earlier than 2002-06-07 | N5 | 1552h | 1552h |  | Rel-5 | Kimmo | 29.198-12 |  |  |
| 2192 | 83.5 | Call Control Service Mapping; Multiparty Call Control SIP - Stage 3 | 194d | 2001-09-11 A | 2002-06-07 A |  | 100% | 2001-09-11 | 2002-06-07 | 194d | finish no earlier than 2002-06-07 | N5 | 1552h | 1552h |  | Rel-5 | Kimmo | 29.998-04-4 |  |  |
| 2193 | 83.6 | WSDL APIs for SOAP/HTTP - Stage 3 | 455d | 2000-09-11 A | 2002-06-07 A |  | 100% | 2000-09-11 | 2002-06-07 | 455d | finish no earlier than 2002-06-07 | N5 | 3640h | 3640h |  | Rel-5 | Kimmo | 29.198, 29.998 |  |  |
| 2194 | 83.7 | **OSA security** | 639d | 2000-07-11 A | 2002-12-20 A |  | 100% | 2000-07-11 | 2002-12-20 | 639d |  | S3 | 15000h | 15000h | OSA1-SEC | Rel-5 | Dionisio |  | BT | colin.blanchard@bt.com |
| 2195 | 83.7.1 | Stage 1 | 349d | 2000-07-11 A | 2001-11-09 A |  | 100% | 2000-07-11 | 2001-11-09 | 349d | finish no earlier than 2001-11-09 | S1 | 2792h | 2792h |  | Rel-5 | Alain | 22.127 | Siemens | Manfred.leitgeb@siemens.at |
| 2196 | 83.7.2 | Stage 3 | 430d | 2000-10-23 A | 2002-06-14 A |  | 100% | 2000-10-23 | 2002-06-14 | 430d | finish no earlier than 2002-06-14 | S3 | 3440h | 3440h |  | Rel-5 | Dionisio |  |  |  |
| 2197 | 83.7.3 | security related SCF(s) definition | 186d | 2001-09-21 A | 2002-06-07 A |  | 100% | 2001-09-21 | 2002-06-07 | 186d | finish no earlier than 2002-06-07 | N5 | 1488h | 1488h |  | Rel-5 | Kimmo | 29.198, 29.998 | Ericsson | Ard.Jan.Moerdijk@eln.ericsson.se |
| 2198 | 83.7.4 | changes required from supporting platforms, e.g. gsmSCF, HLR | 69d | 2000-09-11 A | 2000-12-14 A |  | 100% | 2000-09-11 | 2000-12-14 | 69d | finish no earlier than 2000-12-14 | S3 | 552h | 552h |  | Rel-5 | Dionisio |  |  |  |
| 2199 | 638.7.5 | Security (moved from Rel-6) | 202d | 2002-03-14 A | 2002-12-20 A |  | 100% | 2002-03-14 | 2002-12-20 | 202d | finish no earlier than 2002-12-20 | S3 | 1616h | 1616h |  | Rel-5 | Dionisio |  |  |  |
| 2200 | 83.8 | **Interactions OSA - e-commerce** | 815d | 1999-04-27 A | 2002-06-07 A |  | 100% | 1999-04-27 | 2002-06-07 | 815d |  | S2 | 6152h | 6152h | OSA1-ECOM | Rel-5 | Maurice |  |  |  |
| 2201 | 83.8.1 | Stage 1 | 439d | 1999-04-27 A | 2000-12-28 A |  | 100% | 1999-04-27 | 2000-12-28 | 439d | finish no earlier than 2000-12-28 | S1 | 3504h | 3504h |  | Rel-5 | Alain | 22.127 | Siemens | Joerg Swetina (joerg.swetina@nw.neclab.eu) |
| 2202 | 83.8.2 | Stages 2 and 3 | 186d | 2001-09-21 A | 2002-06-07 A |  | 100% | 2001-09-21 | 2002-06-07 | 186d | finish no earlier than 2002-06-07 | N5 | 1488h | 1488h |  | Rel-5 | Kimmo | 29.198, 29.998 | Ericsson | Ard.Jan.Moerdijk@eln.ericsson.se |
| 2203 | 83.9 | Policy Management - Stage 3 | 194d | 2001-09-11 A | 2002-06-07 A |  | 100% | 2001-09-11 | 2002-06-07 | 194d | finish no earlier than 2002-06-07 | N5 | 1552h | 1552h |  | Rel-5 | Kimmo | 29.198-13 |  |  |
| 2204 | 83.10 | Presence and Availability Management (PAM) - Stage 3 | 194d | 2001-09-11 A | 2002-06-07 A |  | 100% | 2001-09-11 | 2002-06-07 | 194d | finish no earlier than 2002-06-07 | N5 | 1552h | 1552h |  | Rel-5 | Kimmo | 29.198-14 |  |  |
| 2205 | 83.11 | **CHECK STATUS - LCS - OSA interfaces** | 455d | 2000-09-11 A | 2002-06-07 A |  | 100% | 2000-09-11 | 2002-06-07 | 455d |  | S1 | 5656h | 5656h | OSA1-LCSI | Rel-5 | Alain |  | Siemens | Joerg Swetina (joerg.swetina@nw.neclab.eu) |
| 2206 | 83.11.1 | Stage 1 | 65d | 2000-09-11 A | 2000-12-08 A |  | 100% | 2000-09-11 | 2000-12-08 | 65d | finish no earlier than 2000-12-08 | S1 | 520h | 520h |  | Rel-5 | Alain | 22.127 | Siemens | Joerg Swetina (joerg.swetina@nw.neclab.eu) |
| 2207 | 83.11.2 | Stage 2 | 1d | 2000-12-11 A | 2000-12-11 A | 2206 | 100% | 2000-12-11 | 2000-12-11 | 1d | finish no earlier than 2000-12-11 | S2 | 8h | 8h |  | Rel-5 | Maurice | 23.127 | Ericsson | Christophe GOURRAUD |
| 2208 | 83.11.3 | Stage 3 | 186d | 2001-09-21 A | 2002-06-07 A | 2207 | 100% | 2001-09-21 | 2002-06-07 | 186d | finish no earlier than 2002-06-07 | N5 | 1488h | 1488h |  | Rel-5 | Kimmo | 29.198, 29.998 | Ericsson | Ard.Jan.Moerdijk@eln.ericsson.se |
| 2209 | 638.12 | Access to User Profile | 145d | 2001-06-01 A | 2001-12-20 A |  | 100% | 2001-06-01 | 2001-12-20 | 145d | finish no earlier than 2001-12-20 | S1 | 1160h | 1160h | OSA2-UP | Rel-5 | Alain |  |  |  |
| 2210 | 638.13 | **Retrieval of Terminal capabilities** | 634d | 2000-07-11 A | 2002-12-13 A |  | 100% | 2000-07-11 | 2002-12-13 | 634d |  | S2 | 10808h | 10808h | OSA2-TC | Rel-5 | Maurice |  |  |  |
| 2211 | 638.13.1 | Stage 1 | 132d | 2000-07-11 A | 2001-01-10 A |  | 100% | 2000-07-11 | 2001-01-10 | 132d | finish no earlier than 2001-01-10 | S1 | 1056h | 1056h |  | Rel-5 | Alain | 22.127 | Siemens | Joerg Swetina (joerg.swetina@nw.neclab.eu) |
| 2212 | 638.13.2 | Stages 2 and 3 | 321d | 2001-09-21 A | 2002-12-13 A | 2211 | 100% | 2001-09-21 | 2002-12-13 | 321d | finish no earlier than 2002-12-13 | N5 | 2568h | 2568h |  | Rel-5 | Kimmo | 29.198, 29.998 | Ericsson | Ard.Jan.Moerdijk@eln.ericsson.se |
| 2213 | 638.13.3 | Provisioning of the terminal capabilities | 445d | 2001-04-02 A | 2002-12-13 A |  | 100% | 2001-04-02 | 2002-12-13 | 445d | finish no earlier than 2002-12-13 | T2 | 3560h | 3560h |  | Rel-5 |  | 23.057 |  |  |

Notes:
- 2187: For Rel5 even if completed by March
- 2188: -
- 2189: -
- 2190: -
- 2191: -
- 2192: -
- 2193: -
- 2194: CR to correct security specifications in 29.198 scheduled for approval at CN#15
- 2195: -
- 2196: Marked as closed 12/2008 (was marked 80% complete)
- 2197: -
- 2198: -
- 2199: Contribution at S3#25
- 2200: -
- 2201: Marked as closed 12/2008 (was marked 95% complete)
- 2202: -
- 2203: -
- 2204: -
- 2205: az: CN#13 - changed to Rel5
- 2206: -
- 2207: az 24/05/01: Rel4 completion 90->100%.
- 2208: -
- 2209: -
- 2210: -
- 2211: -
- 2212: -
- 2213: According to T2 SWG1 M. Cataldo this is automatically supported by the MExE support of UAProf therefore 100% complete

| ID | WBS | Task | Duration | Start | Finish | Predecessors | Complete | Baseline start | Baseline finish | Baseline duration | Constraint | Resources | Work | Actual work | Text1 | Text4 | Text5 | Text6 | Text8 | Text3 |
| --- | --- | --- | --- | --- | --- | --- | --- | --- | --- | --- | --- | --- | --- | --- | --- | --- | --- | --- | --- | --- |
| 2214 | 84 | **CAMEL phase 4** | 625d | 2000-04-17 A | 2002-09-06 A |  | 100% | 2000-04-17 | 2002-09-06 | 625d |  | S1 | 41104h | 41104h | CAMEL4 | Nokia | keijo.palviainen@nokia.com | Rel-5 | Alain |  |
| 2215 | 84.1 | Service requirements | 565d | 2000-04-17 A | 2002-06-14 A |  | 100% | 2000-04-17 | 2002-06-14 | 565d | finish no earlier than 2002-06-14 | S1 | 4520h | 4520h |  |  |  | Rel-5 | Alain |  |
| 2216 | 84.2 | Call Party Handling | 500d | 2000-07-10 A | 2002-06-07 A |  | 100% | 2000-07-10 | 2002-06-07 | 500d | finish no earlier than 2002-06-07 | N2 | 4000h | 4000h | CAMEL4-CPH |  |  | Rel-5 | Kimmo |  |
| 2217 | 84.3 | Mid call procedure for MO and MT calls | 495d | 2000-07-17 A | 2002-06-07 A |  | 100% | 2000-07-17 | 2002-06-07 | 495d | finish no earlier than 2002-06-07 | N2 | 3960h | 3960h | CAMEL4-MCP |  |  | Rel-5 | Kimmo |  |
| 2218 | 84.4 | Interactions with Optimal Routing | 430d | 2000-07-17 A | 2002-03-08 A |  | 100% | 2000-07-17 | 2002-03-08 | 430d | finish no earlier than 2002-03-08 | N2 | 3440h | 3440h | CAMEL4-IOR |  |  | Rel-5 | Kimmo |  |
| 2219 | 84.5 | Inclusion of flexible tone injection | 430d | 2000-07-17 A | 2002-03-08 A |  | 100% | 2000-07-17 | 2002-03-08 | 430d | finish no earlier than 2002-03-08 | N2 | 3440h | 3440h | CAMEL4-IFTI |  |  | Rel-5 | Kimmo |  |
| 2220 | 84.6 | CSE control over MT SMS | 430d | 2000-07-17 A | 2002-03-08 A |  | 100% | 2000-07-17 | 2002-03-08 | 430d | finish no earlier than 2002-03-08 | N2 | 3440h | 3440h | CAMEL4-CCSMS |  |  | Rel-5 | Kimmo |  |
| 2221 | 84.7 | Notification of GPRS mobility management to CSE | 331d | 2001-03-02 A | 2002-06-07 A |  | 100% | 2001-03-02 | 2002-06-07 | 331d | finish no earlier than 2002-06-07 | N2 | 2648h | 2648h | CAMEL4-NMM |  |  | Rel-5 | Kimmo |  |
| 2222 | 84.8 | Provision of location information of called subscriber | 266d | 2001-03-02 A | 2002-03-08 A |  | 100% | 2001-03-02 | 2002-03-08 | 266d | finish no earlier than 2002-03-08 | N2 | 2128h | 2128h | CAMEL4-LOCB |  |  | Rel-5 | Kimmo |  |
| 2223 | 84.9 | Inclusion of ODB data in the CSE_HLR interface | 175d | 2001-07-09 A | 2002-03-08 A |  | 100% | 2001-07-09 | 2002-03-08 | 175d | finish no earlier than 2002-03-08 | N2 | 1400h | 1400h | CAMEL4-ODB |  |  | Rel-5 | Kimmo |  |
| 2224 | 84.10 | Location information during an ongoing call (Handover DP) | 280d | 2001-05-14 A | 2002-06-07 A |  | 100% | 2001-05-14 | 2002-06-07 | 280d | finish no earlier than 2002-06-07 | N2 | 2240h | 2240h | CAMEL4-HODP |  |  | Rel-5 | Kimmo |  |
| 2225 | 84.11 | GPRS Any Time Interrogation | 240d | 2001-07-09 A | 2002-06-07 A |  | 100% | 2001-07-09 | 2002-06-07 | 240d | finish no earlier than 2002-06-07 | N2 | 1920h | 1920h | CAMEL4-ATI |  |  | Rel-5 | Kimmo |  |
| 2226 | 84.12 | Transfer of IMEI (with SW version) to CSE | 240d | 2001-07-09 A | 2002-06-07 A |  | 100% | 2001-07-09 | 2002-06-07 | 240d | finish no earlier than 2002-06-07 | N2 | 1920h | 1920h | CAMEL4-ATI |  |  | Rel-5 | Kimmo |  |
| 2227 | 84.13 | Handling of partial implementations of CAMEL4 | 131d | 2002-03-08 A | 2002-09-06 A |  | 100% | 2002-03-08 | 2002-09-06 | 131d | finish no earlier than 2002-06-07 | N2 | 1048h | 1048h | CAMEL4-SUB |  |  | Rel-5 | Kimmo |  |
| 2228 | 85 | **Rel-5 MExE enhancements** | 250d | 2001-03-26 A | 2002-03-08 A |  | 100% | 2001-03-26 | 2002-03-08 | 250d |  | T2 | 2880h | 2880h | MEXE5 |  |  | Rel-5 | Kimmo |  |
| 2229 | 85.1 | MExE Rel-5 Improvements and Investigations | 110d | 2001-03-26 A | 2002-03-08 A |  | 100% | 2001-03-26 | 2002-03-08 | 110d | finish no earlier than 2001-12-17 | T2 | 880h | 880h | MEXE5-ENHANC | Motorola | Mark Cataldo | Rel-5 | Kimmo | 22.057, 23.057 |
| 2230 | 86 | **Wideband Telephony Service - AMR** | 1036d | 2000-01-01 A | 2003-12-19 A |  | 100% | 2000-01-01 | 2003-12-19 | 1036d |  | S4 | 81496h | 81496h | AMRWB | Siemens | Imre.Varga@mch.siemens.de | Rel-5 | Paolo |  |
| 2231 | 86.1 | **Specification** | 636d | 2000-01-01 A | 2002-06-07 A |  | 100% | 2000-01-01 | 2002-06-07 | 636d |  | S4 | 19984h | 19984h |  |  |  | Rel-5 | Paolo |  |
| 2232 | 86.1.1 | Stage 1 | 125d | 2001-10-01 A | 2002-03-22 A |  | 100% | 2001-10-01 | 2002-03-22 | 125d | finish no earlier than 2002-03-22 | S1 | 1000h | 1000h |  |  |  | Rel-5 | Alain |  |
| 2233 | 86.1.2 | **Stage 2** | 77d | 2000-01-03 A | 2000-04-17 A |  | 100% | 2000-01-03 | 2000-04-17 | 77d |  | S4 | 1232h | 1232h |  |  |  | Rel-5 | Paolo |  |
| 2234 | 86.1.2.1 | Design Constraints | 27d | 2000-01-03 A | 2000-02-07 A |  | 100% | 2000-01-03 | 2000-02-07 | 27d |  | S4 [96.3%] | 208h | 208h |  |  |  | Rel-5 | Paolo |  |
| 2235 | 86.1.2.2 | General Description | 51d | 2000-02-07 A | 2000-04-17 A | 2234 | 100% | 2000-02-07 | 2000-04-17 | 51d | start no earlier than 2000-09-25 | S4 | 408h | 408h |  |  |  | Rel-5 | Paolo |  |
| 2236 | 86.1.3 | Feasibility Study | 26d | 2000-04-28 A | 2000-06-02 A | 2235 | 100% | 2000-04-28 | 2000-06-02 | 26d | finish no earlier than 2000-06-02 | S4 | 208h | 208h |  |  |  | Rel-5 | Paolo | 26.901 |
| 2237 | 86.1.4 | N1 Aspects | 66d | 2001-09-21 A | 2001-12-21 A |  | 100% | 2001-09-21 | 2001-12-21 | 66d | finish no earlier than 2001-12-21 | N1 | 528h | 528h |  |  |  | Rel-5 | Frederic |  |
| 2238 | 86.1.5 | N4 work | 83d | 2002-02-13 A | 2002-06-07 A |  | 100% | 2002-02-13 | 2002-06-07 | 83d | finish no earlier than 2002-06-07 | N4 | 664h | 664h |  |  |  | Rel-5 | Kimmo |  |

Notes:
- 2214: -
- 2215: -
- 2216: -
- 2217: -
- 2218: -
- 2219: -
- 2220: -
- 2221: -
- 2222: -
- 2223: Added on May 29, 2001
- 2224: -
- 2225: -
- 2226: -
- 2227: stage2 and stage3 CRs for approval at CN#17
- 2228: -
- 2229: -
- 2230: -
- 2231: -
- 2232: -
- 2233: -
- 2234: -
- 2235: -
- 2236: S4,TD SP-000024: TR 26.901 v.4.0.0
- 2237: Some of N1 tasks: Indication of supported codecs by the MS, Bearer cap negociation, codec indication to MS... / One common set of codec negotiation procedures will be specified as in ID1657.
- 2238: CN4#11 30/11/01: No inputs to CN4 at this meeting / 14/02/02 work started 50% reached / 17 May work is done 100%

| ID | WBS | Task | Duration | Start | Finish | Predecessors | Complete | Baseline start | Baseline finish | Baseline duration | Constraint | Resources | Work | Actual work | Text6 | Text8 | Text1 | Text3 | Text12 | Text4 | Text5 |
| --- | --- | --- | --- | --- | --- | --- | --- | --- | --- | --- | --- | --- | --- | --- | --- | --- | --- | --- | --- | --- | --- |
| 2239 | 86.1.6 | **Codec issues** | 636d | 2000-01-03 A | 2002-06-07 A |  | 100% | 2000-01-03 | 2002-06-07 | 636d |  | S4 | 9496h | 9496h | Rel-5 | Paolo |  |  |  |  |  |
| 2240 | 86.1.6.1 | Codec qualification | 86d | 2000-02-02 A | 2000-05-31 A |  | 100% | 2000-02-02 | 2000-05-31 | 86d | finish no earlier than 2000-05-31 | S4 | 688h | 688h | Rel-5 | Paolo |  |  |  |  |  |
| 2241 | 86.1.6.2 | Codec selection tests | 102d | 2000-06-01 A | 2000-10-20 A | 2240 | 100% | 2000-06-01 | 2000-10-20 | 102d | finish no earlier than 2000-10-20 | S4 | 816h | 816h | Rel-5 | Paolo |  |  |  |  |  |
| 2242 | 86.1.6.3 | Codec selection | 5d | 2000-10-23 A | 2000-10-27 A | 2241 | 100% | 2000-10-23 | 2000-10-27 | 5d | finish no earlier than 2000-10-27 | S4 | 40h | 40h | Rel-5 | Paolo |  |  |  |  |  |
| 2243 | 86.1.6.4 | TFO AMR-WB | 63d | 2001-12-18 A | 2002-03-14 A |  | 100% | 2001-12-18 | 2002-03-14 | 63d | finish no earlier than 2002-03-14 | S4 | 504h | 504h | Rel-5 | Paolo | AMRWB-TFO |  |  |  |  |
| 2244 | 86.1.6.5 | Other codec issues (verif., characterization) | 441d | 2000-09-29 A | 2002-06-07 A |  | 100% | 2000-09-29 | 2002-06-07 | 441d | finish no earlier than 2002-06-07 | S4 | 3528h | 3528h | Rel-5 | Paolo |  | 26.976 |  |  |  |
| 2245 | 86.1.6.6 | AMR-WB and narrrowband interworking | 121d | 2001-09-27 A | 2002-03-14 A |  | 100% | 2001-09-27 | 2002-03-14 | 121d | finish no earlier than 2002-03-14 | S4 | 968h | 968h | Rel-5 | Paolo | AMRWB-IWG |  |  |  |  |
| 2246 | 86.1.6.7 | Interworking with fixed broadband networks | 121d | 2001-09-27 A | 2002-03-14 A |  | 100% | 2001-09-27 | 2002-03-14 | 121d | finish no earlier than 2002-03-14 | S4 | 968h | 968h | Rel-5 | Paolo |  |  |  |  |  |
| 2247 | 86.1.6.8 | Tones and announcements | 121d | 2001-09-27 A | 2002-03-14 A |  | 100% | 2001-09-27 | 2002-03-14 | 121d | finish no earlier than 2002-03-14 | S4 | 968h | 968h | Rel-5 | Paolo |  |  |  |  |  |
| 2248 | 86.1.6.9 | Deleted - WB Conferencing and WB Voice Group calls | 1d | 2000-01-03 A | 2000-01-03 A |  | 100% | 2000-01-03 | 2000-01-03 | 1d | finish no earlier than 2000-01-03 | S1 | 8h | 8h | Rel-5 | Alain |  |  | SP-07 |  |  |
| 2249 | 86.1.8 | **Conformance tests (CRs to 34 series)** | 74d | 2000-01-01 A | 2000-04-12 A |  | 100% | 2000-01-01 | 2000-04-12 | 74d |  | T1 | 1768h | 1768h | Rel-5 | Ingbert |  |  |  |  |  |
| 2250 | 86.1.8.1 | **Terminal Acoustic Characteristics** | 74d | 2000-01-01 A | 2000-04-12 A |  | 100% | 2000-01-01 | 2000-04-12 | 74d |  | S4 | 1176h | 1176h | Rel-5 | Paolo |  |  |  |  |  |
| 2251 | 86.1.8.1.1 | Definition | 22d | 2000-01-01 A | 2000-01-31 A |  | 100% | 2000-01-01 | 2000-01-31 | 22d | finish no earlier than 2000-01-28 | S4 | 168h | 168h | Rel-5 | Paolo |  | 26.131 |  |  |  |
| 2252 | 86.1.8.1.2 | Test specification | 52d | 2000-02-01 A | 2000-04-12 A | 2251 | 100% | 2000-02-01 | 2000-04-12 | 52d | finish no earlier than 2000-03-13 | S4 | 416h | 416h | Rel-5 | Paolo |  | 26.132 |  |  |  |
| 2253 | 86.2 | Floating-point ANSI-C code for the AMR-WB speech codec | 123d | 2001-09-25 A | 2002-03-14 A |  | 100% | 2001-09-25 | 2002-03-14 | 123d | finish no earlier than 2002-03-14 | S4 | 984h | 984h | Rel-5 | Paolo | AMRWB-FP | 26.204 |  | Nokia | janne.m.vainio@nokia.com |
| 2254 | 86.3 | **Support of AMR-WB in GERAN: GMSK and 8PSK WB FR / HR** | 651d | 2000-01-03 A | 2002-06-28 A |  | 100% | 2000-01-03 | 2002-06-28 | 651d |  | GP | 23488h | 23488h | Rel-5 | Paolo | GAMRWB |  |  |  |  |
| 2255 | 86.3.1 | Channel coding in 45.003 | 591d | 2000-01-03 A | 2002-04-05 A |  | 100% | 2000-01-03 | 2002-04-05 | 591d |  | GP | 4720h | 4720h | Rel-5 | Paolo |  |  |  |  |  |
| 2256 | 86.3.2 | Signalling for the A interface | 391d | 2000-01-03 A | 2001-06-29 A |  | 100% | 2000-01-03 | 2001-06-29 | 391d | finish no earlier than 2001-06-29 | GP | 3120h | 3120h | Rel-5 | Paolo |  |  |  |  |  |
| 2257 | 86.3.3 | Signalling for Iu | 651d | 2000-01-03 A | 2002-06-28 A |  | 100% | 2000-01-03 | 2002-06-28 | 651d | finish no earlier than 2002-06-28 | GP | 5200h | 5200h | Rel-5 | Paolo |  |  |  |  |  |
| 2258 | 86.3.4 | Receiver performance in TS 45.005 | 325d | 2001-04-02 A | 2002-06-28 A |  | 100% | 2001-04-02 | 2002-06-28 | 325d | finish no earlier than 2002-06-28 | GP | 2600h | 2600h | Rel-5 | Paolo |  |  |  |  |  |
| 2259 | 86.3.5 | Link Adaptation in 45.009 | 330d | 2001-03-26 A | 2002-06-28 A |  | 100% | 2001-03-26 | 2002-06-28 | 330d | finish no earlier than 2002-06-28 | GP | 2640h | 2640h | Rel-5 | Paolo |  |  |  |  |  |
| 2260 | 86.4 | **Deleted - GERAN MS conformance test for AMR-WB** | 1036d | 2000-01-03 A | 2003-12-19 A |  | 100% | 2000-01-03 | 2003-12-19 | 1036d |  | GP | 16568h | 16568h | Rel-5 | Paolo |  |  |  |  |  |
| 2261 | 86.4.1 | Deleted - MS test for AMR-WB | 1036d | 2000-01-03 A | 2003-12-19 A |  | 100% | 2000-01-03 | 2003-12-19 | 1036d | finish no earlier than 2003-12-19 | GP | 8280h | 8280h | Rel-5 | Paolo |  |  | GP-17 |  |  |
| 2262 | 86.5 | **GERAN BTS conformance test for AMR-WB** | 762d | 2000-01-03 A | 2002-12-02 A |  | 100% | 2000-01-03 | 2002-12-02 | 762d |  | GP | 12184h | 12184h | Rel-5 | Paolo |  |  |  |  |  |
| 2263 | 86.5.1 | BTS test | 762d | 2000-01-03 A | 2002-12-02 A |  | 100% | 2000-01-03 | 2002-12-02 | 762d | finish no earlier than 2002-12-02 | GP | 6088h | 6088h | Rel-5 | Paolo |  |  |  |  |  |

Notes:
- 2239: -
- 2240: -
- 2241: -
- 2242: -
- 2243: -
- 2244: ANSI C-Code , Test Sequences, Speech Transcoding Functions, Error Concealment of lost frames, Source Controlled Bit-Rate Operation, Voice Activity Detector, Frame Structure
- 2245: -
- 2246: -
- 2247: -
- 2248: -
- 2249: -
- 2250: -
- 2251: -
- 2252: -
- 2253: -
- 2254: -
- 2255: 50098 -> 50298
- 2256: -
- 2257: -
- 2258: -
- 2259: -
- 2260: Not started 02/2003. Marked as stopped 12/2008
- 2261: Marked as stopped 12/2008
- 2262: -
- 2263: -

| ID | WBS | Task | Duration | Start | Finish | Complete | Baseline start | Baseline finish | Baseline duration | Constraint | Resources | Work | Actual work | Text1 | Text6 | Text8 | Text3 | Text4 | Text5 |
| --- | --- | --- | --- | --- | --- | --- | --- | --- | --- | --- | --- | --- | --- | --- | --- | --- | --- | --- | --- |
| 2264 | 11 | **Terminal interfaces** | 223d | 2001-05-14 A | 2002-03-20 A | 100% | 2001-05-14 | 2002-03-20 | 223d |  | T2 | 3568h | 3568h | TI | Rel-5 | Kimmo |  |  |  |
| 2265 | 87 | Terminal local model enhancements | 223d | 2001-05-14 A | 2002-03-20 A | 100% | 2001-05-14 | 2002-03-20 | 223d | finish no earlier than 2002-03-20 | T2 | 1784h | 1784h | TLM5 | Rel-5 |  | 23.227 |  |  |
| 2266 | 88 | **Rel-5 Location Services enhancements** | 845d | 2000-04-03 A | 2003-06-27 A | 100% | 2000-04-03 | 2003-06-27 | 845d |  | S2,S5 | 86804h | 86804h | LCS1 | Rel-5 | Maurice |  | Nokia | Jan Kall |
| 2267 | 88.1 | **UE positioning** | 315d | 2001-01-15 A | 2002-03-29 A | 100% | 2001-01-15 | 2002-03-29 | 315d |  | RP | 5560h | 5560h | LCS1-UEpos | Rel-5 | Issam |  |  |  |
| 2268 | 88.1.1 | UE positioning enhancements for 1.28 Mcps TDD | 255d | 2001-04-09 A | 2002-03-29 A | 100% | 2001-04-09 | 2002-03-29 | 255d | finish no earlier than 2002-03-29 | R2 | 2040h | 2040h | LCS-128Pos | Rel-5 | Joern |  | CATT | Xiaohua Mei |
| 2269 | 88.1.2 | Open SMLC-SRNC Interface within the UTRAN to support A-GPS Positioning | 195d | 2001-01-15 A | 2001-10-12 A | 100% | 2001-01-15 | 2001-10-12 | 195d |  | R2 | 1560h | 1560h | LCS-INTF | Rel-5 | Joern |  | Qualcomm | Kirk Burroughs |
| 2270 | 88.2 | **Event based and Periodic LCS** | 535d | 2000-05-22 A | 2002-06-07 A | 100% | 2000-05-22 | 2002-06-07 | 535d |  | S1 | 6288h | 6288h | LCS1-EBP | Rel-5 | Alain |  |  |  |
| 2271 | 88.2.1 | Stage 1 | 130d | 2000-05-22 A | 2000-11-17 A | 100% | 2000-05-22 | 2000-11-17 | 130d | finish no earlier than 2000-07-21 | S1 | 1040h | 1040h |  | Rel-5 | Alain | 22.071 | Pacific Bell Wireless | Randolph Wohlert (rwohlert@tri.sbc.com) |
| 2272 | 88.2.2 | Stage 2 specification | 60d | 2000-11-06 A | 2001-01-26 A | 100% | 2000-11-06 | 2001-01-26 | 60d | finish no earlier than 2001-01-26 | S2 | 480h | 480h |  | Rel-5 | Maurice |  |  |  |
| 2273 | 88.2.3 | Impact on MAP | 61d | 2002-03-15 A | 2002-06-07 A | 100% | 2002-03-15 | 2002-06-07 | 61d | finish no earlier than 2002-06-07 | N4 | 488h | 488h |  | Rel-5 | Kimmo |  |  |  |
| 2274 | 88.3 | **Location Services for GERAN in A/Gb Mode** | 485d | 2000-04-03 A | 2002-02-08 A | 100% | 2000-04-03 | 2002-02-08 | 485d |  | GP | 14760h | 14760h | LCS-GERAN | Rel-5 | Paolo |  |  |  |
| 2275 | 88.3.1 | GERAN LCS Stage 2 (first release) | 485d | 2000-04-03 A | 2002-02-08 A | 100% | 2000-04-03 | 2002-02-08 | 485d | finish no earlier than 2002-02-08 | GP,S2,G1,G2 | 3880h | 3880h |  | Rel-5 | Paolo |  |  |  |
| 2276 | 88.3.2 | Gb interface support for LCS | 370d | 2000-04-03 A | 2001-08-31 A | 100% | 2000-04-03 | 2001-08-31 | 370d | finish no earlier than 2001-08-31 | GP | 2960h | 2960h |  | Rel-5 | Paolo |  |  |  |
| 2277 | 88.3.3 | L3 protocol support for LCS | 305d | 2000-04-03 A | 2001-06-01 A | 100% | 2000-04-03 | 2001-06-01 | 305d | finish no earlier than 2001-06-01 | GP | 2440h | 2440h |  | Rel-5 | Paolo |  |  |  |
| 2278 | 88.3.4 | Stage 3 specifications | 305d | 2000-04-03 A | 2001-06-01 A | 100% | 2000-04-03 | 2001-06-01 | 305d | finish no earlier than 2001-06-01 | GP | 2440h | 2440h |  | Rel-5 | Paolo |  |  |  |
| 2279 | 88.4 | **Location Services for GERAN in Iu Mode** | 585d | 2000-04-03 A | 2002-06-28 A | 100% | 2000-04-03 | 2002-06-28 | 585d |  | S2,G1,G2,R2,R3 | 20996h | 20996h |  | Rel-5 | Paolo |  |  |  |
| 2280 | 88.4.1 | GERAN LCS Stage 2 | 585d | 2000-04-03 A | 2002-06-28 A | 100% | 2000-04-03 | 2002-06-28 | 585d | finish no earlier than 2002-06-28 | S2,G1,G2 | 4680h | 4680h |  | Rel-5 | Paolo |  |  |  |
| 2281 | 88.4.2 | Iu-ps interface support for LCS | 585d | 2000-04-03 A | 2002-06-28 A | 100% | 2000-04-03 | 2002-06-28 | 585d | finish no earlier than 2002-06-28 | R2,R3 | 4680h | 4680h |  | Rel-5 | Paolo |  |  |  |
| 2282 | 88.4.3 | Iu-cs interface support for LCS | 585d | 2000-04-03 A | 2002-06-28 A | 100% | 2000-04-03 | 2002-06-28 | 585d | finish no earlier than 2002-06-28 | R2,R3 | 4680h | 4680h |  | Rel-5 | Paolo |  |  |  |
| 2283 | 88.4.4 | Iur-g interface support for LCS | 62.5d | 2002-01-23 A | 2002-04-19 A | 100% | 2002-01-23 | 2002-04-19 | 62.5d | finish no earlier than 2002-04-19 | G1,G2 | 500h | 500h |  | Rel-5 | Paolo |  |  |  |
| 2284 | 88.4.5 | RRC protocol support for LCS | 75d | 2001-08-20 A | 2001-11-30 A | 100% | 2001-08-20 | 2001-11-30 | 75d | finish no earlier than 2001-11-30 | G1,G2,R2,R3 | 600h | 600h |  | Rel-5 | Paolo |  |  |  |
| 2285 | 88.4.6 | Additional impacts on Broadcast of LCS data on packet channels | 77.5d | 2001-08-20 A | 2001-12-05 A | 100% | 2001-08-20 | 2001-12-05 | 77.5d | finish no earlier than 2001-12-05 | G1,G2,R2,R3 | 620h | 620h |  | Rel-5 | Paolo |  |  |  |
| 2286 | 88.4.7 | Stage 3 specifications | 69.5d | 2002-03-25 A | 2002-06-28 A | 100% | 2002-03-25 | 2002-06-28 | 69.5d | finish no earlier than 2002-06-28 | G1,G2,R2,R3 | 556h | 556h |  | Rel-5 | Paolo |  |  |  |
| 2287 | 88.5 | **GERAN MS Conformance test for LCS** | 280d | 2002-06-03 A | 2003-06-27 A | 100% | 2002-06-03 | 2003-06-27 | 280d |  | GP | 6720h | 6720h | LCS-GERAN-MSconf | Rel-5 | Paolo |  |  |  |
| 2288 | 88.5.1 | Develop LCS MS test case work plan (Release 98/99/4) | 280d | 2002-06-03 A | 2003-06-27 A | 100% | 2002-06-03 | 2003-06-27 | 280d | finish no earlier than 2003-06-27 | G4,G5 | 2240h | 2240h |  | Rel-5 | Paolo |  |  |  |
| 2289 | 88.5.2 | Develop LCS MS test cases | 280d | 2002-06-03 A | 2003-06-27 A | 100% | 2002-06-03 | 2003-06-27 | 280d | finish no earlier than 2003-06-27 | G4,G5 | 2240h | 2240h |  | Rel-5 | Paolo |  |  |  |

Notes:
- 2264: -
- 2265: -
- 2266: -
- 2267: -
- 2268: -
- 2269: Finished at RP#13
- 2270: -
- 2271: Evaluate Event based and Periodic LCS to be included in R00, corresponding Stage 1 description
- 2272: Marked as closed 12/2008 (was marked 51% complete)
- 2273: Possible impact on UTRAN of LCS quality level request / 17 May No stage 2 for event-based & periodic LCS. Work 100% completefor current stage 2
- 2274: -
- 2275: -
- 2276: -
- 2277: -
- 2278: -
- 2279: -
- 2280: -
- 2281: -
- 2282: -
- 2283: FFS
- 2284: -
- 2285: -
- 2286: -
- 2287: -
- 2288: Marked as closed 12/2008 (was marked 60% complete)
- 2289: Marked as closed 12/2008 (was marked 60% complete)

| ID | WBS | Task | Duration | Start | Finish | Predecessors | Complete | Baseline start | Baseline finish | Baseline duration | Constraint | Resources | Work | Actual work | Text1 | Text6 | Text8 | Text12 | Text3 | Text4 | Text5 |
| --- | --- | --- | --- | --- | --- | --- | --- | --- | --- | --- | --- | --- | --- | --- | --- | --- | --- | --- | --- | --- | --- |
| 2290 | 88.6 | **Deleted - GERAN BTS Conformance test for LCS** | 280d | 2002-06-03 A | 2003-06-27 A |  | 100% | 2002-06-03 | 2003-06-27 | 280d |  | GP | 6720h | 6720h | LCS-GERAN-BTSconf | Rel-5 | Paolo | GP-15 |  |  |  |
| 2291 | 88.6.1 | Deleted - Develop LCS BTS test case work plan (Release 98/99/4) | 280d | 2002-06-03 A | 2003-06-27 A |  | 100% | 2002-06-03 | 2003-06-27 | 280d | finish no earlier than 2003-06-27 | G4,G5 | 2240h | 2240h |  | Rel-5 | Paolo | GP-15 |  |  |  |
| 2292 | 88.6.2 | Deleted - Develop LCS BTS test cases | 280d | 2002-06-03 A | 2003-06-27 A |  | 100% | 2002-06-03 | 2003-06-27 | 280d | finish no earlier than 2003-06-27 | G4,G5 | 2240h | 2240h |  | Rel-5 | Paolo | GP-15 |  |  |  |
| 2293 | 88.7 | LCS interoperation stage 2 aspects | 480d | 2000-08-28 A | 2002-06-28 A |  | 100% | 2000-08-28 | 2002-06-28 | 480d |  | S2 | 3840h | 3840h |  | Rel-5 | Maurice |  |  |  |  |
| 2294 | 88.8 | **LCS interoperability aspects to GERAN** | 480d | 2000-08-28 A | 2002-06-28 A |  | 100% | 2000-08-28 | 2002-06-28 | 480d |  | GP,S5 | 7680h | 7680h | LCS-GERAN | Rel-5 | Paolo |  |  |  |  |
| 2295 | 88.8.1 | Co-ordinated development of GSM LCS Phase 2 and UMTS LCS, S2 and GERAN | 480d | 2000-08-28 A | 2002-06-28 A |  | 100% | 2000-08-28 | 2002-06-28 | 480d | finish no earlier than 2002-06-28 | GP,S2,S5,R2,R3,G2,G1 | 3840h | 3840h | LCS-GERAN | Rel-5 | Paolo |  |  |  |  |
| 2296 | 88.9 | FS on LCS support in the IMS | 90d | 2001-02-12 A | 2002-01-18 A |  | 100% | 2001-02-12 | 2002-01-18 | 90d | start no earlier than 2001-02-12 | S1 | 720h | 720h |  | Rel-5 | Alain |  |  |  |  |
| 2297 | 88.10 | Charging and OAM&P for LCS enhancements | 201d | 2001-09-21 A | 2002-06-28 A |  | 100% | 2001-09-21 | 2002-06-28 | 201d | finish no earlier than 2002-06-28 | S5 | 1608h | 1608h | LCS1-OAM | Rel-5 | Dionisio |  | 32-series | VoiceStream, Motorola |  |
| 2298 | 88.11 | New security aspects of LCS (not identified) | 446d | 2000-04-14 A | 2001-12-28 A |  | 100% | 2000-04-14 | 2001-12-28 | 446d | finish no earlier than 2001-12-28 | S3 | 3568h | 3568h | LCS1-SEC | Rel-5 | Dionisio |  |  | Nokia | valtteri.niemi@nokia.com |
| 2299 | 88.12 | Specification for the Le Interface | 45d | 2002-01-14 A | 2002-03-15 A |  | 100% | 2002-01-14 | 2002-03-15 | 45d | start no earlier than 2002-01-14 | S2 | 360h | 360h | LCS1-Le | Rel-5 | Maurice |  |  |  |  |
| 2300 | 88.13 | Deleted - CHECK STATUS - Inter-GMLC interface | 153d | 2002-05-30 A | 2002-12-30 A |  | 100% | 2002-05-30 | 2002-12-30 | 153d | finish no earlier than 2002-12-30 | S2 | 1224h | 1224h |  | Rel-5 | Maurice | SP-10 |  |  |  |
| 2301 | 89 | **Rel-5 Security enhancements** | 615d | 2000-02-21 A | 2002-06-28 A |  | 100% | 2000-02-21 | 2002-06-28 | 615d |  | S3 | 29974.9h | 29974.9h |  | Rel-5 | Dionisio |  |  | Vodafone | Peter.Howard@vodafone.com |
| 2302 | 89.1 | **Network domain security** | 615d | 2000-02-21 A | 2002-06-28 A |  | 100% | 2000-02-21 | 2002-06-28 | 615d |  | S3 | 25054.9h | 25054.9h | SEC1-NDS | Rel-5 | Dionisio |  |  | Telenor | Geir-myrdahl.koien@telenor.com |
| 2303 | 89.1.1 | **Deleted -Control plane protection in core network (e.g., GTP, CAP, MAP/IP, provided by IPsec)** | 541d | 2000-05-12 A | 2002-06-07 A |  | 100% | 2000-05-12 | 2002-06-07 | 541d |  | S3 | 7118.9h | 7118.9h |  | Rel-5 | Dionisio | SP-16 |  |  |  |
| 2304 | 89.1.1.1 | Deleted - Main aspects | 290d | 2000-05-12 A | 2001-06-21 A |  | 100% | 2000-05-12 | 2001-06-21 | 290d | finish no earlier than 2001-06-21 | S3 | 2320h | 2320h |  | Rel-5 | Dionisio | SP-12 |  |  |  |
| 2305 | 89.1.1.2 | Deleted -Integration of GTP signalling security architecture | 191d | 2001-09-14 A | 2002-06-07 A |  | 100% | 2001-09-14 | 2002-06-07 | 191d | finish no earlier than 2002-06-07 | N4 | 1528h | 1528h |  | Rel-5 | Kimmo | NP-16 |  |  |  |
| 2306 | 89.1.2 | **Deleted -User plane protection in core network (e.g., provided by IPsec)** | 615d | 2000-02-21 A | 2002-06-28 A |  | 100% | 2000-02-21 | 2002-06-28 | 615d |  | S3 | 9360h | 9360h |  | Rel-5 | Dionisio | SP-16 |  |  |  |
| 2307 | 89.1.2.1 | Deleted -Main aspects | 349d | 2000-02-21 A | 2001-06-21 A |  | 100% | 2000-02-21 | 2001-06-21 | 349d | finish no earlier than 2001-06-21 | S3 | 2792h | 2792h |  | Rel-5 | Dionisio | SP-12 |  |  |  |
| 2308 | 89.1.2.2 | Deleted -Integration of GTP signalling security architecture | 206d | 2001-09-14 A | 2002-06-28 A |  | 100% | 2001-09-14 | 2002-06-28 | 206d | finish no earlier than 2002-06-28 | N4 | 1648h | 1648h |  | Rel-5 | Kimmo | NP-16 |  |  |  |
| 2309 | 89.1.3 | IP network layer security (NDS/IP) | 457d | 2000-06-15 A | 2002-03-15 A |  | 100% | 2000-06-15 | 2002-03-15 | 457d | finish no earlier than 2002-03-15 | S3 | 3656h | 3656h | SEC1-NDS-IP | Rel-5 | Dionisio |  | 33.210 | Telenor | Geir-myrdahl.koien@telenor.com |
| 2310 | 90 | **Intra Domain Connection of RAN Nodes to Multiple CN Nodes** | 455d | 2000-10-02 A | 2002-06-28 A |  | 100% | 2000-10-02 | 2002-06-28 | 455d |  | S2 | 15136h | 15136h | IUFLEX | Rel-5 | Alain |  | 23.236 | Ericsson | stephen.terrill@ericsson.com |
| 2311 | 90.1 | Overall System Architecture | 188d | 2001-01-03 A | 2001-09-21 A |  | 100% | 2001-01-03 | 2001-09-21 | 188d | finish no earlier than 2001-06-01 | S2 | 1504h | 1504h |  | Rel-5 | Maurice |  |  |  |  |
| 2312 | 90.2 | Stage 3: RAN node selecting CN node | 130d | 2001-09-24 A | 2002-03-22 A | 2311 | 100% | 2001-09-24 | 2002-03-22 | 130d | finish no earlier than 2002-03-22 | R3 | 1040h | 1040h |  | Rel-5 | Juha |  |  | Vodafone | Brendan.McWilliams@gb.vodafone.co.uk |
| 2313 | 90.3 | N1 work | 205d | 2001-09-17 A | 2002-06-28 A |  | 100% | 2001-09-17 | 2002-06-28 | 205d | start no earlier than 2001-09-17 | N1 | 1640h | 1640h |  | Rel-5 | Frederic |  | 24.008 and check 29.018 |  |  |
| 2314 | 90.4 | N4 work | 375d | 2000-10-02 A | 2002-03-08 A |  | 100% | 2000-10-02 | 2002-03-08 | 375d | finish no earlier than 2002-03-15 | N4 | 3000h | 3000h |  | Rel-5 | Kimmo |  |  |  |  |

Notes:
- 2290: Not started 02/3003. Marked as stopped 12/2008
- 2291: Marked as stopped 12/2008
- 2292: Marked as stopped 12/2008
- 2293: Marked as closed 12/2008 (was marked 17% complete)
- 2294: -
- 2295: -
- 2296: Marked as closed 12/2008 (was marked 75% complete)
- 2297: -
- 2298: 14/09/00: WI may need to be split to improve on this date. S3#17 15% complete. No progress since S3#17
- 2299: -
- 2300: Marked as stopped 12/2008
- 2301: Added BB UE authentication and rapporteur added. TO BE DELETED
- 2302: S3#17: All due in Rel5. (WI Update at S3#18). Replaced by NDS-IP and NDS-MAP. TO BE DELETED OR MOVED TO HISTORY FILE
- 2303: Marked as stopped 12/2008
- 2304: TO BE DELETED. Marked as stopped 12/2008
- 2305: Waiting for input from SA3!.... Marked as stopped 12/2008
- 2306: TO BE DELETED. Marked as stopped 12/2008
- 2307: -
- 2308: 14/02/2002 requirements are not clear/not received...Marked as closed 12/2008 (was marked 95 complete)
- 2309: 2002/12: All IPsec RFCs are stable STD Track RFCs. WID updated SP#17
- 2310: No clear indication on the end date. Put to Rel5 by AS.
- 2311: -
- 2312: Not identified
- 2313: -
- 2314: DAB 12.12.01 - % complete to 66% / 14/02/02 Work completed

| ID | WBS | Task | Duration | Start | Finish | Complete | Baseline start | Baseline finish | Baseline duration | Constraint | Resources | Work | Actual work | Text1 | Text4 | Text5 | Text6 | Text8 | Text12 | Text3 |
| --- | --- | --- | --- | --- | --- | --- | --- | --- | --- | --- | --- | --- | --- | --- | --- | --- | --- | --- | --- | --- |
| 2315 | 90.5 | **GERAN work for Intra Domain Connection of RAN Nodes to Multiple CN Nodes** | 101d | 2002-02-08 A | 2002-06-28 A | 100% | 2002-02-08 | 2002-06-28 | 101d |  | GP | 4848h | 4848h | IDCRAN-GERAN | Ericsson | ingemar.backlund@era.ericsson.se | Rel-5 | Paolo |  |  |
| 2316 | 90.5.1 | Stage 2 (changes to ) | 101d | 2002-02-08 A | 2002-06-28 A | 100% | 2002-02-08 | 2002-06-28 | 101d | finish no earlier than 2002-06-28 | G1 | 808h | 808h |  |  |  | Rel-5 | Paolo |  |  |
| 2317 | 90.5.2 | 43.051 Introduction of support for IDNNS in GERAN Iu mode | 101d | 2002-02-08 A | 2002-06-28 A | 100% | 2002-02-08 | 2002-06-28 | 101d | finish no earlier than 2002-06-28 | G1 | 808h | 808h |  |  |  | Rel-5 | Paolo |  |  |
| 2318 | 90.5.3 | Stage 3 (changes to ) | 101d | 2002-02-08 A | 2002-06-28 A | 100% | 2002-02-08 | 2002-06-28 | 101d | finish no earlier than 2002-06-28 | G2 | 808h | 808h |  |  |  | Rel-5 | Gert |  |  |
| 2319 | 90.5.4 | 48.016 Use of Gb interface concepts when a network applies IDNNS | 101d | 2002-02-08 A | 2002-06-28 A | 100% | 2002-02-08 | 2002-06-28 | 101d | finish no earlier than 2002-06-28 | G2 | 808h | 808h |  |  |  | Rel-5 | Gert |  |  |
| 2320 | 90.5.5 | 48.018 Include MSC/VLR identity in CS IMSI paging | 101d | 2002-02-08 A | 2002-06-28 A | 100% | 2002-02-08 | 2002-06-28 | 101d | finish no earlier than 2002-06-28 | G2 | 808h | 808h |  |  |  | Rel-5 | Gert |  |  |
| 2321 | 91 | **Deleted - GERAN improvements 3 (new transport layer on interface A)** | 446d | 2001-04-06 A | 2002-12-20 A | 100% | 2001-04-06 | 2002-12-20 | 446d |  | GP | 14272h | 14272h | GEIMP3 |  |  | Rel-5 | Paolo |  |  |
| 2322 | 91.1 | **Deleted - Evolution of the transport for A** | 446d | 2001-04-06 A | 2002-12-20 A | 100% | 2001-04-06 | 2002-12-20 | 446d |  | GP | 10704h | 10704h | GEIMP3-EtA |  |  | Rel-5 | Paolo | GP-12 |  |
| 2323 | 91.1.1 | Deleted - Definition of a new A/Ater interface Transport Layer option based on the Iu Interface Transport Layer | 446d | 2001-04-06 A | 2002-12-20 A | 100% | 2001-04-06 | 2002-12-20 | 446d | finish no earlier than 2002-12-20 | GP | 3568h | 3568h |  |  |  | Rel-5 | Paolo | GP-12 |  |
| 2324 | 91.1.2 | Deleted - Adaptation of the Layer 3 BSSMAP procedures as required | 446d | 2001-04-06 A | 2002-12-20 A | 100% | 2001-04-06 | 2002-12-20 | 446d | finish no earlier than 2002-12-20 | GP | 3568h | 3568h |  |  |  | Rel-5 | Paolo | GP-12 |  |
| 2325 | 92 | **Rel-5 Charging and OAM&P** | 264d | 2001-09-10 A | 2002-09-12 A | 100% | 2001-09-10 | 2002-09-12 | 264d |  | S5 | 9976h | 9976h | OAM | VoiceStream, Motorola |  | Rel-5 | Dionisio |  |  |
| 2326 | 92.1 | Rel5 Principles, high level Requirements and Architecture | 205d | 2001-09-17 A | 2002-06-28 A | 100% | 2001-09-17 | 2002-06-28 | 205d | finish no earlier than 2002-06-28 | S5 | 1640h | 1640h | OAM-AR/PR | Motorola |  | Rel-5 | Dionisio |  | 32.101, 32.102 |
| 2327 | 92.2 | Rel5 Performance Management | 259d | 2001-09-17 A | 2002-09-12 A | 100% | 2001-09-17 | 2002-09-12 | 259d | finish no earlier than 2002-09-12 | S5 | 2072h | 2072h | OAM-PM | Nortel |  | Rel-5 | Dionisio |  | 32.4xy, 52.402 |
| 2328 | 92.3 | Rel5 Charging Management | 264d | 2001-09-10 A | 2002-09-12 A | 100% | 2001-09-10 | 2002-09-12 | 264d | finish no earlier than 2002-09-12 | S5 | 2112h | 2112h | OAM-CH | T-Mobile | Karl-Heinz.Nenner@T-MOBILE.DE | Rel-5 | Dionisio |  | 32.200, 32.205, 32.215, 32.225, 32.235 |
| 2329 | 92.4 | Rel5 Network Infrastructure Management | 255d | 2001-09-21 A | 2002-09-12 A | 100% | 2001-09-21 | 2002-09-12 | 255d | finish no earlier than 2002-09-12 | S5 | 2040h | 2040h | OAM-NIM | Ericsson | thomas.tovinger@ericsson.com | Rel-5 | Dionisio |  | 32.6xy, 32.3xy |
| 2330 | 93 | **GERAN enhancements for streaming services 1 (RLC enhancements)** | 430d | 2000-11-06 A | 2002-06-28 A | 100% | 2000-11-06 | 2002-06-28 | 430d |  | GP | 8944h | 8944h |  |  |  | Rel-5 | Paolo |  |  |
| 2331 | 93.1 | Concept | 258d | 2000-11-06 A | 2001-10-31 A | 100% | 2000-11-06 | 2001-10-31 | 258d | finish no earlier than 2001-10-31 | GP | 2064h | 2064h |  |  |  | Rel-5 | Paolo |  |  |
| 2332 | 93.2 | RLC protocol enhancement (SDU Discard) | 430d | 2000-11-06 A | 2002-06-28 A | 100% | 2000-11-06 | 2002-06-28 | 430d | finish no earlier than 2002-06-28 | GP | 3440h | 3440h |  |  |  | Rel-5 | Paolo |  |  |
| 2333 | 94 | **GERAN enhancements for streaming services 2 (usage of ECSD)** | 430d | 2000-11-06 A | 2002-06-28 A | 100% | 2000-11-06 | 2002-06-28 | 430d |  | GP | 19840h | 19840h |  | Ericsson | Frank Muller | Rel-5 | Paolo |  |  |
| 2334 | 94.1 | Usage of ECSD Concept | 380d | 2000-11-06 A | 2002-04-19 A | 100% | 2000-11-06 | 2002-04-19 | 380d | finish no earlier than 2002-04-19 | GP | 3040h | 3040h |  |  |  | Rel-5 | Paolo |  |  |
| 2335 | 94.2 | Stage 2 | 380d | 2000-11-06 A | 2002-04-19 A | 100% | 2000-11-06 | 2002-04-19 | 380d | finish no earlier than 2002-04-19 | GP | 3040h | 3040h |  |  |  | Rel-5 | Paolo |  |  |
| 2336 | 94.3 | Stage 3 | 430d | 2000-11-06 A | 2002-06-28 A | 100% | 2000-11-06 | 2002-06-28 | 430d | finish no earlier than 2002-06-28 | GP | 3440h | 3440h |  |  |  | Rel-5 | Paolo |  |  |
| 2337 | 94.4 | RLC PDU formats | 430d | 2000-11-06 A | 2002-06-28 A | 100% | 2000-11-06 | 2002-06-28 | 430d | finish no earlier than 2002-06-28 | GP | 3440h | 3440h |  |  |  | Rel-5 | Paolo |  |  |
| 2338 | 94.5 | MAC header | 430d | 2000-11-06 A | 2002-06-28 A | 100% | 2000-11-06 | 2002-06-28 | 430d | finish no earlier than 2002-06-28 | GP | 3440h | 3440h |  |  |  | Rel-5 | Paolo |  |  |

Notes:
- 2315: Accept changes Gb over IP
- 2316: -
- 2317: -
- 2318: -
- 2319: Closed, accept changes for Gb over IP
- 2320: -
- 2321: Terminated - not standardized. Marked as stopped 12/2008
- 2322: TERMINATED - NOT STANDARDIZED. Marked as stopped 12/2008
- 2323: TERMINATED - NOT STANDARDIZED. Marked as stopped 12/2008
- 2324: TERMINATED - NOT STANDARDIZED. Marked as stopped 12/2008
- 2325: -
- 2326: -
- 2327: -
- 2328: -
- 2329: -
- 2330: -
- 2331: -
- 2332: -
- 2333: AWS, Nokia, Ericsson, Nortel, Siemens, Motorola, Vodafone
- 2334: -
- 2335: -
- 2336: -
- 2337: -
- 2338: -

| ID | WBS | Task | Duration | Start | Finish | Predecessors | Complete | Baseline start | Baseline finish | Baseline duration | Constraint | Resources | Work | Actual work | Text1 | Text4 | Text5 | Text6 | Text8 |
| --- | --- | --- | --- | --- | --- | --- | --- | --- | --- | --- | --- | --- | --- | --- | --- | --- | --- | --- | --- |
| 2339 | 95 | **GERAN/UTRAN interface evolution 1 (evolution of Iu PS)** | 476d | 2000-09-01 A | 2002-06-28 A |  | 100% | 2000-09-01 | 2002-06-28 | 476d |  | GP,R3 | 10688h | 10688h | GERUEV1 | SBC | Marc Grant | Rel-5 | Paolo |
| 2340 | 95.1 | **Evolution of Iu ps** | 476d | 2000-09-01 A | 2002-06-28 A |  | 100% | 2000-09-01 | 2002-06-28 | 476d |  | GP,R3 | 7248h | 7248h | GERUEV1-IuPS |  |  | Rel-5 | Paolo |
| 2341 | 95.1.1 | Identification of GERAN requirements on Iu ps | 326d | 2000-09-01 A | 2001-11-30 A |  | 100% | 2000-09-01 | 2001-11-30 | 326d | finish no earlier than 2001-11-30 | GP,R3 | 2608h | 2608h |  |  |  | Rel-5 | Paolo |
| 2342 | 95.1.2 | Update of specifications | 150d | 2001-12-03 A | 2002-06-28 A | 2341 | 100% | 2001-12-03 | 2002-06-28 | 150d | finish no earlier than 2002-06-28 | GP,R3 | 1200h | 1200h |  |  |  | Rel-5 | Paolo |
| 2343 | 96 | **GERAN/UTRAN interface evolution 2 (evolution of Iu CS)** | 476d | 2000-09-01 A | 2002-06-28 A |  | 100% | 2000-09-01 | 2002-06-28 | 476d |  | GP,R3 | 12816h | 12816h | GERUEV2 |  |  | Rel-5 | Paolo |
| 2344 | 96.1 | **Evolution of Iu cs** | 476d | 2000-09-01 A | 2002-06-28 A |  | 100% | 2000-09-01 | 2002-06-28 | 476d |  | GP,R3 | 10016h | 10016h | GERUEV2-IuCS | Lucent | Krishna Balachandran | Rel-5 | Paolo |
| 2345 | 96.1.1 | Identification of GERAN requirements on Iu cs | 426d | 2000-09-01 A | 2002-06-24 A |  | 100% | 2000-09-01 | 2002-06-24 | 426d | finish no earlier than 2002-04-19 | GP,R3 | 3408h | 3408h |  |  |  | Rel-5 | Paolo |
| 2346 | 96.1.2 | Update of specifications | 476d | 2000-09-01 A | 2002-06-28 A |  | 100% | 2000-09-01 | 2002-06-28 | 476d | finish no earlier than 2002-06-28 | GP,R3 | 3808h | 3808h |  |  |  | Rel-5 | Paolo |
| 2347 | 97 | **End to End QoS for PS Domain including IMS** | 480d | 2000-08-28 A | 2002-06-28 A |  | 100% | 2000-08-28 | 2002-06-28 | 480d |  | S2 | 9856h | 9856h | E2EQoS | Ericsson | Johnson.oyama@era.ericcson.se | Rel-5 | Maurice |
| 2348 | 97.1 | E2E QoSConcept and Architecture | 178d | 2001-01-03 A | 2001-09-07 A |  | 100% | 2001-01-03 | 2001-09-07 | 178d | finish no earlier than 2001-09-07 | S2 | 1424h | 1424h |  |  |  | Rel-5 | Maurice |
| 2349 | 97.2 | E2E QoS interworking | 465d | 2000-08-28 A | 2002-06-07 A |  | 100% | 2000-08-28 | 2002-06-07 | 465d | finish no earlier than 2002-06-07 | N3 | 3720h | 3720h | E2EQoS-IW | Lucent | Daisuke Yokota (yokota@lucent.com) | Rel-5 | Gwiho |
| 2350 | 97.3 | QoS Management (Provisioning and Monitoring) | 201d | 2001-09-21 A | 2002-06-28 A |  | 100% | 2001-09-21 | 2002-06-28 | 201d | finish no earlier than 2002-06-28 | S5 | 1608h | 1608h | E2EQoS-OAM | VoiceStream, Motorola |  | Rel-5 | Dionisio |
| 2351 | 98 | **Messaging enhancements Rel-5** | 467d | 2001-06-15 A | 2003-03-31 A |  | 100% | 2001-06-15 | 2003-03-31 | 467d |  | T2 | 19000h | 19000h | MESS5 |  |  | Rel-5 | Kimmo |
| 2352 | 98.1 | **Multimedia Messaging (MMS) enhancements** | 467d | 2001-06-15 A | 2003-03-31 A |  | 100% | 2001-06-15 | 2003-03-31 | 467d |  | T2 | 11688h | 11688h | MESS5-MMS | Siemens | Josef.Laumen@SAL.SIEMENS.DE | Rel-5 | Alain |
| 2353 | 98.1.1 | Definition of service requirements | 196d | 2001-06-15 A | 2002-03-15 A |  | 100% | 2001-06-15 | 2002-03-15 | 196d | finish no earlier than 2002-03-15 | S1 | 1568h | 1568h | MESS5-SR | Siemens | Josef.Laumen@SAL.SIEMENS.DE | Rel-5 | Alain |
| 2354 | 98.1.2 | Technical realization | 256d | 2001-06-15 A | 2002-06-07 A |  | 100% | 2001-06-15 | 2002-06-07 | 256d | finish no earlier than 2002-06-07 | T2 | 2048h | 2048h |  | Siemens | Josef.Laumen@SAL.SIEMENS.DE | Rel-5 |  |
| 2355 | 98.1.3 | WAP Forum dependency: MM1 stage 3 | 467d | 2001-06-15 A | 2003-03-31 A |  | 100% | 2001-06-15 | 2003-03-31 | 467d | finish no earlier than 2003-03-31 | T2 | 3736h | 3736h |  |  |  | Rel-5 |  |
| 2356 | 98.1.4 | MMS formats and codecs | 75d | 2001-12-03 A | 2002-03-15 A |  | 100% | 2001-12-03 | 2002-03-15 | 75d | finish no earlier than 2002-03-15 | S4 | 600h | 600h |  |  |  | Rel-5 | Paolo |
| 2357 | 98.2 | **Enhanced Messaging Service (EMS) enhancements** | 191d | 2001-06-15 A | 2002-03-08 A |  | 100% | 2001-06-15 | 2002-03-08 | 191d |  | T2 | 3584h | 3584h | MESS5-EMS | Ericsson | Alan.Baldwin@EML.ERICSSON.SE | Rel-5 | Kimmo |
| 2358 | 98.2.1 | Definition of service requirements | 66d | 2001-06-15 A | 2001-09-14 A |  | 100% | 2001-06-15 | 2001-09-14 | 66d | finish no earlier than 2001-09-14 | S1 | 528h | 528h |  | Ericsson | Alan.Baldwin@EML.ERICSSON.SE | Rel-5 | Alain |
| 2359 | 98.2.2 | Technical realization | 191d | 2001-06-15 A | 2002-03-08 A |  | 100% | 2001-06-15 | 2002-03-08 | 191d | finish no earlier than 2002-03-08 | T2 | 1528h | 1528h |  | Ericsson | Alan.Baldwin@EML.ERICSSON.SE | Rel-5 | Kimmo |
| 2360 | 99 | **GERAN Inter BSC NACC improvements over the Gb Interface** | 215d | 2001-09-03 A | 2002-06-28 A |  | 100% | 2001-09-03 | 2002-06-28 | 215d |  | GP | 8200h | 8200h | GERNACC |  |  | Rel-5 | Paolo |
| 2361 | 99.1 | **Modification of core network protocols for GERAN Inter BSC NACC over Gb Interface** | 165d | 2001-09-03 A | 2002-04-19 A |  | 100% | 2001-09-03 | 2002-04-19 | 165d |  | N4,S2 | 4064h | 4064h | GERNACC-Cnmod |  |  | Rel-5 | Kimmo |
| 2362 | 99.1.1 | Stage 2 - Concept | 43d | 2001-09-03 A | 2001-10-31 A |  | 100% | 2001-09-03 | 2001-10-31 | 43d | finish no earlier than 2001-10-31 | N4,S2 | 344h | 344h |  |  |  | Rel-5 | Kimmo |
| 2363 | 99.1.2 | Stage 2 - 23.060 change - Definition of Inter BSC NACC | 165d | 2001-09-03 A | 2002-04-19 A |  | 100% | 2001-09-03 | 2002-04-19 | 165d | finish no earlier than 2002-04-19 | N4,S2 | 1320h | 1320h |  |  |  | Rel-5 | Kimmo |
| 2364 | 99.1.3 | Stage 3 (changes to TS 29.060) | 135d | 2001-09-03 A | 2002-03-08 A |  | 100% | 2001-09-03 | 2002-03-08 | 135d | finish no earlier than 2002-03-08 | N4 | 1080h | 1080h |  |  |  | Rel-5 | Kimmo |

Notes:
- 2339: SBC, Motorola, Nokia, Ericsson, Nortel
- 2340: -
- 2341: -
- 2342: -
- 2343: -
- 2344: Lucent, Ericsson, AWS, Nortel
- 2345: -
- 2346: -
- 2347: -
- 2348: - / Text3: 23.207
- 2349: [DAB - 30/07/02] - % complete to 95% (if we exclude Diffserv). Marked as closed 12/2008 (was marked 95% complete) / Text3: 29.208, 29.207, 27.060, 29.061, 24.008, 24.228, , 24.229, 29.060, 29.163
- 2350: - / Text3: 32-series
- 2351: support of UAProf, so this in my opinion is 100% complete
- 2352: -
- 2353: - / Text3: 22.140
- 2354: stage 3 MM7 is missing / Text3: 23.140
- 2355: Marked as closed 12/2008 (was marked 80% complete)
- 2356: - / Text3: 26.140
- 2357: - / Text3: 23.040
- 2358: -
- 2359: - / Text3: 23.040
- 2360: -
- 2361: -
- 2362: -
- 2363: -
- 2364: IP 30/11/01: Input awaited from GERAN2 to CN4 / 17 May Work complete 100%

| ID | WBS | Task | Duration | Start | Finish | Complete | Baseline start | Baseline finish | Baseline duration | Constraint | Resources | Work | Actual work | Text1 | Text6 | Text8 | Text12 | Text3 | Text4 | Text5 |
| --- | --- | --- | --- | --- | --- | --- | --- | --- | --- | --- | --- | --- | --- | --- | --- | --- | --- | --- | --- | --- |
| 2365 | 99.2 | **Modification of Gb protocols for GERAN Inter BSC NACC over Gb Interface** | 151d | 2001-11-30 A | 2002-06-28 A | 100% | 2001-11-30 | 2002-06-28 | 151d |  | GP | 2416h | 2416h | GERNACC-Gbmod | Rel-5 | Paolo |  |  |  |  |
| 2366 | 99.2.1 | Stage 3 (changes to TS 48.018) | 151d | 2001-11-30 A | 2002-06-28 A | 100% | 2001-11-30 | 2002-06-28 | 151d | finish no earlier than 2002-06-28 | GP | 1208h | 1208h |  | Rel-5 | Paolo |  |  |  |  |
| 2367 | 100 | **Enhanced Power Control** | 540d | 2001-11-26 A | 2003-12-19 A | 100% | 2001-11-26 | 2003-12-19 | 540d |  | GP | 12840h | 12840h | EPC | Rel-5 | Paolo |  |  |  |  |
| 2368 | 100.1 | Realization of Enhanced power control and signalling support | 5d | 2001-11-26 A | 2001-11-30 A | 100% | 2001-11-26 | 2001-11-30 | 5d | finish no earlier than 2001-11-30 | GP | 40h | 40h |  | Rel-5 | Paolo |  |  |  |  |
| 2369 | 100.2 | Deleted - GERAN MS Conformance test for Enhanced Power Control | 530d | 2001-12-10 A | 2003-12-19 A | 100% | 2001-12-10 | 2003-12-19 | 530d | finish no earlier than 2003-12-19 | GP | 4240h | 4240h |  | Rel-5 | Paolo | GP-17 |  |  |  |
| 2370 | 100.3 | Deleted - GERAN BTS Conformance test for Enhanced Power Control | 530d | 2001-12-10 A | 2003-12-19 A | 100% | 2001-12-10 | 2003-12-19 | 530d | finish no earlier than 2003-12-19 | GP | 4240h | 4240h |  | Rel-5 | Paolo | GP-17 |  |  |  |
| 2371 | 101 | **8PSK AMR HR** | 530d | 2001-12-10 A | 2003-12-19 A | 100% | 2001-12-10 | 2003-12-19 | 530d |  | GP | 21080h | 21080h | 8PSK-AH | Rel-5 | Paolo |  |  |  |  |
| 2372 | 101.1 | **Definition of channel coding, performance requirements and signalling support** | 145d | 2001-12-10 A | 2002-06-28 A | 100% | 2001-12-10 | 2002-06-28 | 145d |  | GP | 10440h | 10440h |  | Rel-5 | Paolo |  |  |  |  |
| 2373 | 101.1.1 | Concept | 145d | 2001-12-10 A | 2002-06-28 A | 100% | 2001-12-10 | 2002-06-28 | 145d | finish no earlier than 2002-06-28 | GP | 1160h | 1160h |  | Rel-5 | Paolo |  |  |  |  |
| 2374 | 101.1.2 | Changes to 44.018 | 145d | 2001-12-10 A | 2002-06-28 A | 100% | 2001-12-10 | 2002-06-28 | 145d | finish no earlier than 2002-06-28 | G2 | 1160h | 1160h |  | Rel-5 | Gert |  |  |  |  |
| 2375 | 101.1.3 | Changes to 45.001 | 145d | 2001-12-10 A | 2002-06-28 A | 100% | 2001-12-10 | 2002-06-28 | 145d | finish no earlier than 2002-06-28 | G1 | 1160h | 1160h |  | Rel-5 | Paolo |  |  |  |  |
| 2376 | 101.1.4 | Changes to 45.002 | 145d | 2001-12-10 A | 2002-06-28 A | 100% | 2001-12-10 | 2002-06-28 | 145d | finish no earlier than 2002-06-28 | G1 | 1160h | 1160h |  | Rel-5 | Paolo |  |  |  |  |
| 2377 | 101.1.5 | Changes to 45.003 | 145d | 2001-12-10 A | 2002-06-28 A | 100% | 2001-12-10 | 2002-06-28 | 145d | finish no earlier than 2002-06-28 | G1 | 1160h | 1160h |  | Rel-5 | Paolo |  |  |  |  |
| 2378 | 101.1.6 | Changes to 45.005 | 145d | 2001-12-10 A | 2002-06-28 A | 100% | 2001-12-10 | 2002-06-28 | 145d | finish no earlier than 2002-06-28 | G1 | 1160h | 1160h |  | Rel-5 | Paolo |  |  |  |  |
| 2379 | 101.1.7 | Changes to 24.008 | 145d | 2001-12-10 A | 2002-06-28 A | 100% | 2001-12-10 | 2002-06-28 | 145d | finish no earlier than 2002-06-28 | G2 | 1160h | 1160h |  | Rel-5 | Gert |  |  |  |  |
| 2380 | 101.1.8 | Changes to 48.058 | 145d | 2001-12-10 A | 2002-06-28 A | 100% | 2001-12-10 | 2002-06-28 | 145d | finish no earlier than 2002-06-28 | G2 | 1160h | 1160h |  | Rel-5 | Gert |  |  |  |  |
| 2381 | 101.2 | Deleted - GERAN MS Conformance test for 8PSK HR | 530d | 2001-12-10 A | 2003-12-19 A | 100% | 2001-12-10 | 2003-12-19 | 530d | finish no earlier than 2003-12-19 | GP | 4240h | 4240h |  | Rel-5 | Paolo | GP-17 |  |  |  |
| 2382 | 101.3 | GERAN BTS Conformance test for 8PSK HR | 270d | 2001-12-10 A | 2002-12-20 A | 100% | 2001-12-10 | 2002-12-20 | 270d | finish no earlier than 2002-12-20 | GP | 2160h | 2160h |  | Rel-5 | Paolo |  |  |  |  |
| 2383 | 102 | Service Change and UDI Fallback | 175d | 2001-10-08 A | 2002-06-07 A | 100% | 2001-10-08 | 2002-06-07 | 175d | finish no earlier than 2002-06-07 | N3 | 1400h | 1400h | SCUDIF | Rel-5 | Gwiho |  | 29.007, 27.001, 24.008 | Ericsson | Rune.Werner.Wiik@ericsson.no |
| 2384 | 103 | **Rel-5 USIM toolkit enhancements** | 865d | 2000-06-05 A | 2003-09-26 A | 100% | 2000-06-05 | 2003-09-26 | 865d |  | T3 | 24352h | 24352h | USAT1-Interpr | Rel-5 | Xavier |  |  | G & D | Michael Meyer |
| 2385 | 103.1 | Deleted - Test specification for USIM toolkit security mechanisms | 349d | 2002-05-28 A | 2003-09-26 A | 100% | 2002-05-28 | 2003-09-26 | 349d | finish no earlier than 2003-09-26 | T3 | 2792h | 2792h |  | Rel-5 | Xavier | TP-21 |  | Gemplus | Sophie Viallet |
| 2386 | 103.2 | **Protocol Standardisation of a SIM Toolkit Interpreter** | 688d | 2000-06-05 A | 2003-01-22 A | 100% | 2000-06-05 | 2003-01-22 | 688d |  | T3 | 12512h | 12512h | USAT1-Interpr | Rel-5 | Xavier |  | 27.103 | G & D | Michael Meyer |
| 2387 | 103.2.1 | Stage 1 | 205d | 2000-06-05 A | 2001-03-16 A | 100% | 2000-06-05 | 2001-03-16 | 205d | finish no earlier than 2001-03-16 | T3 | 1640h | 1640h | USAT1-Interpr | Rel-5 | Xavier |  |  |  |  |
| 2388 | 103.2.2 | Stage 2 and 3 | 308d | 2001-01-03 A | 2002-03-08 A | 100% | 2001-01-03 | 2002-03-08 | 308d | finish no earlier than 2002-03-08 | T3 | 2464h | 2464h | USAT1-Interpr | Rel-5 | Xavier |  |  |  |  |
| 2389 | 103.2.3 | Test specification | 363d | 2001-09-03 A | 2003-01-22 A | 100% | 2001-09-03 | 2003-01-22 | 363d | finish no earlier than 2003-01-22 | T3 | 2904h | 2904h | USAT1-Interpr | Rel-5 | Xavier |  |  | Gemplus | Gérald MAUNIER |

Notes:
- 2365: -
- 2366: -
- 2367: -
- 2368: Completed 11/2001
- 2369: Not started. Marked as stopped 12/2008
- 2370: Not started. Marked as stopped 12/2008
- 2371: Completed for Rel-5
- 2372: -
- 2373: -
- 2374: -
- 2375: -
- 2376: -
- 2377: -
- 2378: -
- 2379: -
- 2380: -
- 2381: Marked as stopped 12/2008
- 2382: -
- 2383: -
- 2384: -
- 2385: Marked as stopped 12/2008
- 2386: 28/5/2001: T3-19 proposed that since the stage 2 and 3 will not be presented to TP-12 for approval as expected, the WI will be moved to rel-5, with completion expected at TP-13.
- 2387: 5/10/2001: Stage one comepeted at TP-12.
- 2388: 5/10/2001: TS 31.112 and 31.113 approved at TP-13. TS 31.114 to be presented to TP-14.
- 2389: 5/10/2001: Work started on test specification. Marked as closed 12/2008 (was marked 12% complete)

| ID | WBS | Task | Duration | Start | Finish | Complete | Baseline start | Baseline finish | Baseline duration | Constraint | Resources | Work | Actual work | Text1 | Text4 | Text5 | Text6 | Text8 | Text12 |
| --- | --- | --- | --- | --- | --- | --- | --- | --- | --- | --- | --- | --- | --- | --- | --- | --- | --- | --- | --- |
| 2390 | 103.4 | **(U)SIM API** | 133d | 2002-03-20 A | 2002-09-20 A | 100% | 2002-03-20 | 2002-09-20 | 133d |  | T3 | 2128h | 2128h | USAT1-API | Microelectrónica Española | Mario Pérez | Rel-5 | Xavier |  |
| 2391 | 103.4.1 | Java API Test specification | 133d | 2002-03-20 A | 2002-09-20 A | 100% | 2002-03-20 | 2002-09-20 | 133d | finish no earlier than 2002-09-20 | T3 | 1064h | 1064h | USAT1-API | Microelectrónica Española | Mario Pérez | Rel-5 | Xavier |  |
| 2392 | 104 | (Small) Technical Enhancements and Improvements for Rel-5 | 2349d? | 2000-01-03 A | 2008-12-31 A | 100% | 2000-01-03 | 2008-12-31 | 2349d? |  | All |  |  | TEI5 |  |  | Rel-5 | all |  |
| 2393 | 660 | Test - (Small) Technical Enhancements and Improvements for Rel-5 | 2349d? | 2000-01-03 A | 2008-12-31 A | 100% | 2000-01-03 | 2008-12-31 | 2349d? | finish no earlier than 2008-12-31 | R5,T1 | 18792h | 18792h | TEI5_Test |  |  | Rel-5 | Ingbert |  |
| 2394 | 105 | Technical Report on UE Functionality Split | 87d | 2000-01-03 A | 2000-05-01 A | 100% | 2000-01-03 | 2000-05-01 | 87d |  | S1 | 688h | 688h | UESPLIT | Motorola | jian.j.wu@motorola.com | Rel-5 | Alain |  |
| 2395 | 106 | **User Equipment Management** | 267d | 2001-06-21 A | 2002-06-28 A | 100% | 2001-06-21 | 2002-06-28 | 267d |  | S5 | 3752h | 3752h | UEM | Vodafone | john.mudge@vf.vodafone.co.uk | Rel-5 | Dionisio |  |
| 2396 | 106.1 | FS on User Equipment (UE) Management | 267d | 2001-06-21 A | 2002-06-28 A | 100% | 2001-06-21 | 2002-06-28 | 267d | finish no earlier than 2002-06-28 | S5 | 2136h | 2136h | OAM-UEM | Vodafone | john.mudge@vf.vodafone.co.uk | Rel-5 | Dionisio |  |
| 2397 | 107 | **Flow control supporting an MS with multiple data flows with different QoS over the Gb interface** | 50d | 2002-06-24 A | 2002-08-30 A | 100% | 2002-06-24 | 2002-08-30 | 50d |  | GP | 1288h | 1288h | FlowCon | Ericsson | ingemar.backlund@era.ericsson.se | Rel-5 | Paolo |  |
| 2398 | 107.1 | **Update of stage 2 specifications** | 50d | 2002-06-24 A | 2002-08-30 A | 100% | 2002-06-24 | 2002-08-30 | 50d |  | GP | 808h | 808h |  |  |  | Rel-5 | Paolo |  |
| 2399 | 107.1.1 | Concept document 23.060 (changes to) | 46d | 2002-06-28 A | 2002-08-30 A | 100% | 2002-06-28 | 2002-08-30 | 46d | finish no earlier than 2002-08-30 | S2 | 368h | 368h |  |  |  | Rel-5 | Maurice |  |
| 2400 | 107.1.2 | Flow Control | 5d | 2002-06-24 A | 2002-06-28 A | 100% | 2002-06-24 | 2002-06-28 | 5d | finish no earlier than 2002-06-28 | GP | 40h | 40h |  |  |  | Rel-5 | Paolo |  |
| 2401 | 107.2 | **Modification of BSSGP protocol** | 5d | 2002-06-24 A | 2002-06-28 A | 100% | 2002-06-24 | 2002-06-28 | 5d |  | GP | 80h | 80h |  | Ericsson | ingemar.backlund@era.ericsson.se | Rel-5 | Paolo |  |
| 2402 | 107.2.1 | Stage 3 (changes to 48.018) | 5d | 2002-06-24 A | 2002-06-28 A | 100% | 2002-06-24 | 2002-06-28 | 5d | finish no earlier than 2002-06-28 | G2 | 40h | 40h |  |  |  | Rel-5 | Gert |  |
| 2403 | 108 | **Deleted - Multiple TBF in A/Gb mode - Phase 1** | 421d | 2002-04-19 A | 2003-11-28 A | 100% | 2002-04-19 | 2003-11-28 | 421d |  | GP | 17480h | 17480h | MULTBF | Ericsson | gunnar.mildh@era.ericsson.se | Rel-5 | Paolo | GP-17 |
| 2404 | 108.1 | **Deleted - Multiple TBF in A/Gb mode - Phase 1** | 351d | 2002-04-19 A | 2003-08-22 A | 100% | 2002-04-19 | 2003-08-22 | 351d |  | GP | 8112h | 8112h | MULTBF-Agbmode |  |  | Rel-5 | Paolo | GP-17 |
| 2405 | 108.1.1 | Deleted - Multiple TBF Concept paper | 351d | 2002-04-19 A | 2003-08-22 A | 100% | 2002-04-19 | 2003-08-22 | 351d | finish no earlier than 2003-08-22 | GP | 2808h | 2808h | MULTBF-Agbmode |  |  | Rel-5 | Paolo | GP-17 |
| 2406 | 108.1.2 | Deleted - Multiple TBF Stage 2 (43.064) CRs | 156d | 2002-04-19 A | 2002-11-22 A | 100% | 2002-04-19 | 2002-11-22 | 156d | finish no earlier than 2002-11-22 | G1 | 1248h | 1248h | MULTBF-Agbmode |  |  | Rel-5 | Paolo | GP-12 |
| 2407 | 108.1.3 | Deleted - Multiple TBF Stage 3 (44.060) CRs | 156d | 2002-04-19 A | 2002-11-22 A | 100% | 2002-04-19 | 2002-11-22 | 156d | finish no earlier than 2002-11-22 | G2 | 1248h | 1248h | MULTBF-Agbmode |  |  | Rel-5 | Gert | GP-12 |
| 2408 | 108.2 | **Deleted - Multiple TBF in A/Gb mode – MS testing** | 375d | 2002-06-24 A | 2003-11-28 A | 100% | 2002-06-24 | 2003-11-28 | 375d |  | GP | 6000h | 6000h |  | Ericsson | ingemar.backlund@era.ericsson.se | Rel-5 | Paolo | GP-17 |
| 2409 | 108.2.1 | Deleted - MS conformance tests | 375d | 2002-06-24 A | 2003-11-28 A | 100% | 2002-06-24 | 2003-11-28 | 375d | finish no earlier than 2003-11-28 | G4 | 3000h | 3000h |  |  |  | Rel-5 | Paolo | GP-17 |
| 2410 | 109 | **Alignment of 3G functional split and Iu** | 922d | 2000-06-08 A | 2003-12-19 A | 100% | 2000-06-08 | 2003-12-19 | 922d |  | GP | 126664h | 126664h | GER3GAL | Ericsson | Frank Muller | Rel-5 | Paolo |  |
| 2411 | 109.1 | **GERAN user / control plane** | 540d | 2000-08-07 A | 2002-08-30 A | 100% | 2000-08-07 | 2002-08-30 | 540d |  | GP | 36232h | 36232h | GER3GAL-GUCOPL | Ericsson | Frank Muller | Rel-5 | Paolo |  |
| 2412 | 109.1.1 | **Alignment with UMTS bearer concept** | 540d | 2000-08-07 A | 2002-08-30 A | 100% | 2000-08-07 | 2002-08-30 | 540d |  | GP | 24952h | 24952h |  |  |  | Rel-5 | Paolo |  |
| 2413 | 109.1.1.1 | Enhanced power control | 1d | 2001-08-31 A | 2001-08-31 A | 100% | 2001-08-31 | 2001-08-31 | 1d | finish no earlier than 2001-08-31 | GP | 8h | 8h |  |  |  | Rel-5 | Paolo |  |
| 2414 | 109.1.1.2 | Stage 2 | 235d | 2000-08-07 A | 2001-06-29 A | 100% | 2000-08-07 | 2001-06-29 | 235d | finish no earlier than 2001-06-29 | GP | 1880h | 1880h |  |  |  | Rel-5 | Paolo |  |
| 2415 | 109.1.1.3 | Adoption of the UTRAN PDCP | 295d | 2000-11-06 A | 2001-12-21 A | 100% | 2000-11-06 | 2001-12-21 | 295d | finish no earlier than 2001-12-21 | GP | 2360h | 2360h |  |  |  | Rel-5 | Paolo |  |
| 2416 | 109.1.1.4 | Development of RLC / MAC | 261d | 2001-08-31 A | 2002-08-30 A | 100% | 2001-08-31 | 2002-08-30 | 261d | finish no earlier than 2002-08-30 | GP | 2088h | 2088h |  |  |  | Rel-5 | Paolo |  |
| 2417 | 109.1.1.5 | Development of GERAN RRC | 266d | 2001-06-22 A | 2002-06-28 A | 100% | 2001-06-22 | 2002-06-28 | 266d | finish no earlier than 2002-06-28 | GP | 2128h | 2128h |  |  |  | Rel-5 | Paolo |  |
| 2418 | 109.1.1.6 | Ciphering and integrity protection concept paper | 166d | 2001-08-31 A | 2002-04-19 A | 100% | 2001-08-31 | 2002-04-19 | 166d | finish no earlier than 2002-04-19 | GP | 1328h | 1328h |  |  |  | Rel-5 | Paolo |  |
| 2419 | 109.1.1.7 | Multiple TBF or equivalent Concept paper | 116d | 2001-08-31 A | 2002-02-08 A | 100% | 2001-08-31 | 2002-02-08 | 116d | finish no earlier than 2002-02-08 | GP | 928h | 928h |  |  |  | Rel-5 | Paolo |  |
| 2420 | 109.1.1.8 | Paging concept | 166d | 2001-08-31 A | 2002-04-19 A | 100% | 2001-08-31 | 2002-04-19 | 166d | finish no earlier than 2002-04-19 | GP | 1328h | 1328h |  |  |  | Rel-5 | Paolo |  |
| 2421 | 109.1.1.9 | Dedicated Physical subchannels, includes traffic and control channels | 66d | 2001-08-31 A | 2001-11-30 A | 100% | 2001-08-31 | 2001-11-30 | 66d | finish no earlier than 2001-11-30 | GP | 528h | 528h |  |  |  | Rel-5 | Paolo |  |
| 2422 | 109.1.1.10 | Iu support and broadcast concept | 166d | 2001-08-31 A | 2002-04-19 A | 100% | 2001-08-31 | 2002-04-19 | 166d | finish no earlier than 2002-04-19 | GP | 1328h | 1328h |  |  |  | Rel-5 | Paolo |  |
| 2423 | 109.1.1.11 | Impact of using RLC instead of LAPDm concept | 116d | 2001-08-31 A | 2002-02-08 A | 100% | 2001-08-31 | 2002-02-08 | 116d | finish no earlier than 2002-02-08 | GP | 928h | 928h |  |  |  | Rel-5 | Paolo |  |
| 2424 | 109.1.1.12 | Contention resolution, mobile station identity, and access concept | 66d | 2001-08-31 A | 2001-11-30 A | 100% | 2001-08-31 | 2001-11-30 | 66d | finish no earlier than 2001-11-30 | GP | 528h | 528h |  |  |  | Rel-5 | Paolo |  |
| 2425 | 109.1.1.13 | PDCP concept | 166d | 2001-08-31 A | 2002-04-19 A | 100% | 2001-08-31 | 2002-04-19 | 166d | finish no earlier than 2002-04-19 | GP | 1328h | 1328h |  |  |  | Rel-5 | Paolo |  |
| 2426 | 109.1.1.14 | Downlink delayed TBF release | 261d | 2001-08-31 A | 2002-08-30 A | 100% | 2001-08-31 | 2002-08-30 | 261d | finish no earlier than 2002-08-30 | GP | 2088h | 2088h |  |  |  | Rel-5 | Paolo |  |
| 2427 | 109.1.1.15 | Add transparent RLC Concept | 116d | 2001-08-31 A | 2002-02-08 A | 100% | 2001-08-31 | 2002-02-08 | 116d | finish no earlier than 2002-02-08 | GP | 928h | 928h |  |  |  | Rel-5 | Paolo |  |
| 2428 | 109.1.1.16 | Handover concept | 116d | 2001-08-31 A | 2002-02-08 A | 100% | 2001-08-31 | 2002-02-08 | 116d | finish no earlier than 2002-02-08 | GP | 928h | 928h |  |  |  | Rel-5 | Paolo |  |

Notes:
- 2390: 8/3/2001: test spec is based on R99 core spec, so deleted from Workplan
- 2391: -
- 2392: "Joker" WI, to be used for a Rel 5 CR not related to any feature and with very limited impact on the system
- 2393: "Joker" WI, to be used for small modifications applicable to Rel 5 conformance testing. Moved in from Stoyan/testing WP. / Text3: 34.108, 34.109, 34.121-1, 34.121-2, 34.122, 34.123-1, 34.123-2, 34.123-3, 34.171, 34.229-1, 34.229-2, 34.229-3
- 2394: - / Text3: new TR 22.944
- 2395: - / Text3: 32.802
- 2396: - / Text3: 32.802
- 2397: 50101 -> 50201
- 2398: 50102 -> 50202
- 2399: -
- 2400: 50103 -> 50203
- 2401: -
- 2402: -
- 2403: GP#17 Nov 2003 Moved to Rel-6 as UID_50600 MULTBF (Only Multiple TBF Concept paper produced in Rel-5)
- 2404: Marked as closed 12/2008 (was marked 26% complete)
- 2405: Marked as closed 12/2008 (was marked 50% complete)
- 2406: Marked as stopped 12/2008
- 2407: Marked as stopped 12/2008
- 2408: 08/08: duplicate UID_50106=-> 50206. Marked as stopped 12/2008
- 2409: Not started. Marked as stopped 12/2008
- 2410: AWS, Nokia, Ericsson, Nortel, Siemens, Vodafone
- 2411: AWS, Nokia, Ericsson, Nortel, Siemens, Vodafone
- 2412: -
- 2413: -
- 2414: -
- 2415: Responsible is GERAN; RAN WG2 help may be needed.
- 2416: -
- 2417: -
- 2418: -
- 2419: -
- 2420: -
- 2421: -
- 2422: -
- 2423: -
- 2424: -
- 2425: -
- 2426: -
- 2427: -
- 2428: -

| ID | WBS | Task | Duration | Start | Finish | Complete | Baseline start | Baseline finish | Baseline duration | Constraint | Resources | Work | Actual work | Text6 | Text8 | Text1 | Text4 | Text5 |
| --- | --- | --- | --- | --- | --- | --- | --- | --- | --- | --- | --- | --- | --- | --- | --- | --- | --- | --- |
| 2429 | 109.1.2 | **Physical layer alignment with UMTS bearer concept** | 280d | 2000-11-06 A | 2001-11-30 A | 100% | 2000-11-06 | 2001-11-30 | 280d |  | GP | 6960h | 6960h | Rel-5 | Paolo |  |  |  |
| 2430 | 109.1.2.1 | PDTCH/TCH in 45.003 | 155d | 2000-11-06 A | 2001-06-08 A | 100% | 2000-11-06 | 2001-06-08 | 155d | finish no earlier than 2001-06-08 | GP | 1240h | 1240h | Rel-5 | Paolo |  |  |  |
| 2431 | 109.1.2.2 | Control channels in 45.003 | 155d | 2000-11-06 A | 2001-06-08 A | 100% | 2000-11-06 | 2001-06-08 | 155d | finish no earlier than 2001-06-08 | GP | 1240h | 1240h | Rel-5 | Paolo |  |  |  |
| 2432 | 109.1.2.3 | Receiver performance in 45.005 for PDTCH/TCH and control channels | 280d | 2000-11-06 A | 2001-11-30 A | 100% | 2000-11-06 | 2001-11-30 | 280d | finish no earlier than 2001-11-30 | GP | 2240h | 2240h | Rel-5 | Paolo |  |  |  |
| 2433 | 109.2 | **Iu rg interface** | 430d | 2000-11-06 A | 2002-06-28 A | 100% | 2000-11-06 | 2002-06-28 | 430d |  | GP,RP | 39560h | 39560h | Rel-5 | Paolo | GER3GAL-Iurg | Ericsson | Frank Muller |
| 2434 | 109.2.1 | **Inter BSS interface** | 430d | 2000-11-06 A | 2002-06-28 A | 100% | 2000-11-06 | 2002-06-28 | 430d |  | GP,RP | 20640h | 20640h | Rel-5 | Paolo |  |  |  |
| 2435 | 109.2.1.1 | Identification of requirements | 430d | 2000-11-06 A | 2002-06-28 A | 100% | 2000-11-06 | 2002-06-28 | 430d | finish no earlier than 2002-06-28 | GP | 3440h | 3440h | Rel-5 | Paolo |  |  |  |
| 2436 | 109.2.1.2 | Stage 2 | 430d | 2000-11-06 A | 2002-06-28 A | 100% | 2000-11-06 | 2002-06-28 | 430d | finish no earlier than 2002-06-28 | GP | 3440h | 3440h | Rel-5 | Paolo |  |  |  |
| 2437 | 109.2.1.3 | Adoption of relevant parts from Iur | 430d | 2000-11-06 A | 2002-06-28 A | 100% | 2000-11-06 | 2002-06-28 | 430d | finish no earlier than 2002-06-28 | GP | 3440h | 3440h | Rel-5 | Paolo |  |  |  |
| 2438 | 109.2.1.4 | Complementation with GERAN specifics | 430d | 2000-11-06 A | 2002-06-28 A | 100% | 2000-11-06 | 2002-06-28 | 430d | finish no earlier than 2002-06-28 | GP | 3440h | 3440h | Rel-5 | Paolo |  |  |  |
| 2439 | 109.2.1.5 | Stage 3 | 430d | 2000-11-06 A | 2002-06-28 A | 100% | 2000-11-06 | 2002-06-28 | 430d | finish no earlier than 2002-06-28 | GP | 3440h | 3440h | Rel-5 | Paolo |  |  |  |
| 2440 | 109.2.2 | **Inter BSS-RNS interface** | 430d | 2000-11-06 A | 2002-06-28 A | 100% | 2000-11-06 | 2002-06-28 | 430d |  | GP,RP | 15480h | 15480h | Rel-5 | Paolo |  |  |  |
| 2441 | 109.2.2.1 | Identification of requirements | 430d | 2000-11-06 A | 2002-06-28 A | 100% | 2000-11-06 | 2002-06-28 | 430d | start no earlier than 2000-11-06 | GP,R3 | 3440h | 3440h | Rel-5 | Paolo |  |  |  |
| 2442 | 109.2.2.2 | Stage 2 | 430d | 2000-11-06 A | 2002-06-28 A | 100% | 2000-11-06 | 2002-06-28 | 430d | finish no earlier than 2002-06-28 | GP,R3 | 3440h | 3440h | Rel-5 | Paolo |  |  |  |
| 2443 | 109.2.2.3 | Adoption of relevant parts from Iur | 430d | 2000-11-06 A | 2002-06-28 A | 100% | 2000-11-06 | 2002-06-28 | 430d | finish no earlier than 2002-06-28 | GP,R3 | 3440h | 3440h | Rel-5 | Paolo |  |  |  |
| 2444 | 109.2.2.4 | Complementation with GERAN specifics | 107.5d | 2002-01-30 A | 2002-06-28 A | 100% | 2002-01-30 | 2002-06-28 | 107.5d | finish no earlier than 2002-06-28 | GP,R3 | 860h | 860h | Rel-5 | Paolo |  |  |  |
| 2445 | 109.2.2.5 | Stage 3 | 107.5d | 2002-01-30 A | 2002-06-28 A | 100% | 2002-01-30 | 2002-06-28 | 107.5d | finish no earlier than 2002-06-28 | GP,R3 | 860h | 860h | Rel-5 | Paolo |  |  |  |
| 2446 | 109.3 | **Voice over GERAN PS and CS concept** | 430d | 2000-11-06 A | 2002-06-28 A | 100% | 2000-11-06 | 2002-06-28 | 430d |  | GP,R3 | 18520h | 18520h | Rel-5 | Paolo |  |  |  |
| 2447 | 109.3.1 | Architecture for A, Iu cs and Iu ps | 430d | 2000-11-06 A | 2002-06-28 A | 100% | 2000-11-06 | 2002-06-28 | 430d | finish no earlier than 2002-06-28 | GP,R3 | 3440h | 3440h | Rel-5 | Paolo |  |  |  |
| 2448 | 109.3.2 | Transcoder position/operation | 115d | 2000-11-06 A | 2001-04-13 A | 100% | 2000-11-06 | 2001-04-13 | 115d | finish no earlier than 2001-04-13 | GP | 920h | 920h | Rel-5 | Paolo |  |  |  |
| 2449 | 109.3.3 | Handover | 430d | 2000-11-06 A | 2002-06-28 A | 100% | 2000-11-06 | 2002-06-28 | 430d | finish no earlier than 2002-06-28 | GP,R3 | 3440h | 3440h | Rel-5 | Paolo |  |  |  |
| 2450 | 109.3.4 | RTP payload | 430d | 2000-11-06 A | 2002-06-28 A | 100% | 2000-11-06 | 2002-06-28 | 430d | finish no earlier than 2002-06-28 | GP,R3 | 3440h | 3440h | Rel-5 | Paolo |  |  |  |
| 2451 | 109.3.5 | Codec renegotiation concept | 365d | 2000-11-06 A | 2002-03-29 A | 100% | 2000-11-06 | 2002-03-29 | 365d | finish no earlier than 2002-03-29 | GP,R3 | 2920h | 2920h | Rel-5 | Paolo |  |  |  |
| 2452 | 109.3.6 | LA | 115d | 2000-11-06 A | 2001-04-13 A | 100% | 2000-11-06 | 2001-04-13 | 115d | finish no earlier than 2001-04-13 | GP | 920h | 920h | Rel-5 | Paolo |  |  |  |

Notes:
- 2429: -
- 2430: -
- 2431: -
- 2432: -
- 2433: AWS, Nokia, Ericsson, Nortel, Siemens, Vodafone
- 2434: -
- 2435: -
- 2436: -
- 2437: -
- 2438: -
- 2439: -
- 2440: -
- 2441: -
- 2442: -
- 2443: -
- 2444: -
- 2445: -
- 2446: -
- 2447: -
- 2448: -
- 2449: -
- 2450: -
- 2451: -
- 2452: -

| ID | WBS | Task | Duration | Start | Finish | Complete | Baseline start | Baseline finish | Baseline duration | Constraint | Resources | Work | Actual work | Text6 | Text8 | Text12 | Text1 | Text4 | Text5 |
| --- | --- | --- | --- | --- | --- | --- | --- | --- | --- | --- | --- | --- | --- | --- | --- | --- | --- | --- | --- |
| 2453 | 109.4 | **Deleted - GERAN MS Conformance test for GERAN interface evolution** | 660d | 2001-06-11 A | 2003-12-19 A | 100% | 2001-06-11 | 2003-12-19 | 660d |  | GP | 10560h | 10560h | Rel-5 | Paolo | GP-17 |  |  |  |
| 2454 | 109.4.1 | Deleted - MS test | 660d | 2001-06-11 A | 2003-12-19 A | 100% | 2001-06-11 | 2003-12-19 | 660d | finish no earlier than 2003-12-19 | GP | 5280h | 5280h | Rel-5 | Paolo | GP-17 |  |  |  |
| 2455 | 109.5 | **GERAN BSS Conformance test for GERAN interface evolution** | 922d | 2000-06-08 A | 2003-12-19 A | 100% | 2000-06-08 | 2003-12-19 | 922d |  | GP | 14752h | 14752h | Rel-5 | Paolo |  |  |  |  |
| 2456 | 109.5.1 | Deleted - BSS test | 922d | 2000-06-08 A | 2003-12-19 A | 100% | 2000-06-08 | 2003-12-19 | 922d | finish no earlier than 2003-12-19 | GP | 7376h | 7376h | Rel-5 | Paolo | GP-17 |  |  |  |
| 2457 | 110 | **GERAN support for IMS** | 690d | 2000-05-01 A | 2002-12-20 A | 100% | 2000-05-01 | 2002-12-20 | 690d |  | GP | 39198.4h | 39198.4h | Rel-5 | Paolo |  | GERIMS | Nokia | Shkumbin Hamiti |
| 2458 | 110.1 | **GERAN Header adaptation** | 690d | 2000-05-01 A | 2002-12-20 A | 100% | 2000-05-01 | 2002-12-20 | 690d |  | GP,S2,RP | 12302.8h | 12302.8h | Rel-5 | Paolo |  | GERIMS-HEADAPT | Nokia | Shkumbin Hamiti |
| 2459 | 110.1.1 | Definition of compression and removal modes for PDCP protocol | 15.05d | 2000-05-01 A | 2000-06-09 A | 100% | 2000-05-01 | 2000-06-09 | 15.05d | finish no earlier than 2000-09-01 | GP,S2,RP | 120.4h | 120.4h | Rel-5 | Paolo |  |  |  |  |
| 2460 | 110.1.2 | Conceptual description in stage 2 | 393d | 2000-05-01 A | 2001-10-31 A | 100% | 2000-05-01 | 2001-10-31 | 393d | finish no earlier than 2001-10-31 | GP,S2,RP | 3144h | 3144h | Rel-5 | Paolo |  |  |  |  |
| 2461 | 110.1.3 | Necessary changes on stage 3 regarding header removal | 439.8d | 2000-11-06 A | 2002-12-20 A | 100% | 2000-11-06 | 2002-12-20 | 439.8d | finish no earlier than 2002-12-20 | GP,S2,RP | 3518.4h | 3518.4h | Rel-5 | Paolo |  |  |  |  |
| 2462 | 110.2 | **Deleted - GERAN Radio access bearer design for IMS** | 430d | 2000-11-06 A | 2002-06-28 A | 100% | 2000-11-06 | 2002-06-28 | 430d |  | GP,S2,RP | 9287.6h | 9287.6h | Rel-5 | Paolo | GP-10 | GERIMS-RABDES | Nokia | Shkumbin Hamiti |
| 2463 | 110.2.1 | **Deleted - MuM control signalling for conversational multimedia services** | 430d | 2000-11-06 A | 2002-06-28 A | 100% | 2000-11-06 | 2002-06-28 | 430d |  | GP,S2,RP | 5847.6h | 5847.6h | Rel-5 | Paolo | GP-10 |  |  |  |
| 2464 | 110.2.1.1 | Deleted - Identification of requirements | 330d | 2000-11-06 A | 2002-02-08 A | 100% | 2000-11-06 | 2002-02-08 | 330d | finish no earlier than 2002-02-08 | GP,S2,RP | 2640h | 2640h | Rel-5 | Paolo | GP-08 |  |  |  |
| 2465 | 110.2.1.2 | Deleted - Necessary modifications due to SIP | 40d | 2002-05-06 A | 2002-06-28 A | 100% | 2002-05-06 | 2002-06-28 | 40d | finish no earlier than 2002-06-28 | GP,S2,RP | 320h | 320h | Rel-5 | Paolo | GP-10 |  |  |  |
| 2466 | 110.3 | **Deleted - GERAN MS Conformance test for support of IMS** | 400d | 2001-06-11 A | 2002-12-20 A | 100% | 2001-06-11 | 2002-12-20 | 400d |  | GP | 6400h | 6400h | Rel-5 | Paolo | GP-12 | GERIMS-MSconf | Nokia | Shkumbin Hamiti |
| 2467 | 110.3.1 | Deleted - MS test | 400d | 2001-06-11 A | 2002-12-20 A | 100% | 2001-06-11 | 2002-12-20 | 400d | finish no earlier than 2002-12-20 | G4 | 3200h | 3200h | Rel-5 | Paolo | GP-12 |  |  |  |
| 2468 | 110.4 | **Deleted - GERAN BTS Conformance test for support of IMS** | 400d | 2001-06-11 A | 2002-12-20 A | 100% | 2001-06-11 | 2002-12-20 | 400d |  | GP | 6400h | 6400h | Rel-5 | Paolo | GP-12 | GERIMS-BTSconf | Nokia | Shkumbin Hamiti |
| 2469 | 110.4.1 | Deleted - BTS test | 400d | 2001-06-11 A | 2002-12-20 A | 100% | 2001-06-11 | 2002-12-20 | 400d | finish no earlier than 2002-12-20 | G3new | 3200h | 3200h | Rel-5 | Ingbert | GP-12 |  |  |  |
| 2470 | 667 | MS Conformance Testing of Dual Transfer Mode | 65d? | 2002-11-11 A | 2003-02-07 A | 100% | 2002-11-11 | 2003-02-07 | 65d? | finish no earlier than 2003-02-07 | G4,G5 | 520h | 520h | Rel-5 | Paolo |  | MSCTDTM | Vodafone | Dave Fox |
| 2471 | 668 | **Handling of early UEs** | 911d? | 2000-01-03 A | 2003-06-27 A | 100% | 2000-01-03 | 2003-06-27 | 911d? |  | S2 | 4488h | 4488h | Rel-5 | Maurice |  | LATE_UE |  |  |
| 2472 | 668.1 | Feasibility Study | 50d? | 2002-10-07 A | 2002-12-13 A | 100% | 2002-10-07 | 2002-12-13 | 50d? | finish no earlier than 2002-12-13 | S2 | 400h | 400h | Rel-5 | Maurice |  |  |  |  |
| 2473 | 668.2 | Stage 2 | 125d? | 2003-01-06 A | 2003-06-27 A | 100% | 2003-01-06 | 2003-06-27 | 125d? | start no earlier than 2003-01-06 | S2 | 1000h | 1000h | Rel-5 | Maurice |  |  |  |  |
| 2474 | 668.3 | FS for the Early Mobile Handling in UTRAN | 195d | 2002-09-09 A | 2003-06-06 A | 100% | 2002-09-09 | 2003-06-06 | 195d | finish no earlier than 2003-06-06 | R2 | 1560h | 1560h | Rel-5 | Joern |  | FSEarlyUE | Vodafone | alan.law@vodafone.com |
| 2475 | 668.4 | Note: Stage 3 RAN part not shown | 1d | 2000-01-03 A | 2000-01-03 A | 100% | 2000-01-03 | 2000-01-03 | 1d |  | RP | 8h | 8h | Rel-5 |  |  |  |  |  |
| 2476 | 669 | Release 4 Features | 326d? | 2000-01-03 A | 2001-03-30 A | 100% | 2000-01-03 | 2001-03-30 | 326d? |  | NP,GP, RP,SP,TP | 2608h | 2608h | Rel-4 | All |  |  |  |  |

Notes:
- 2453: Not started. Marked as stopped 12/2008
- 2454: Not started. Marked as stopped 12/2008
- 2455: Not started. Marked as stopped 12/2008
- 2456: Not started. Marked as stopped 12/2008
- 2457: AWS, Nokia, Ericsson, Nortel, Siemens, Motorola
- 2458: AWS, Nokia, Ericsson, Nortel, Siemens, Motorola
- 2459: -
- 2460: -
- 2461: -
- 2462: TERMINATED - NOT STANDARDIZED. Marked as stopped 12/2008
- 2463: TERMINATED - NOT STANDARDIZED. Marked as stopped 12/2008
- 2464: TERMINATED - NOT STANDARDIZED
- 2465: TERMINATED - NOT STANDARDIZED
- 2466: TERMINATED - NOT STANDARDIZED. Marked as stopped 12/2008
- 2467: TERMINATED - NOT STANDARDIZED. Marked as stopped 12/2008
- 2468: TERMINATED - NOT STANDARDIZED. Marked as stopped 12/2008
- 2469: TERMINATED - NOT STANDARDIZED. Marked as stopped 12/2008
- 2470: Needed to complete DTM (R99)
- 2471: -
- 2472: -
- 2473: -
- 2474: -
- 2475: -
- 2476: -

| ID | WBS | Task | Duration | Start | Finish | Predecessors | Complete | Baseline start | Baseline finish | Baseline duration | Constraint | Resources | Work | Actual work | Text1 | Text6 | Text8 | Text3 | Text12 | Text4 | Text5 |
| --- | --- | --- | --- | --- | --- | --- | --- | --- | --- | --- | --- | --- | --- | --- | --- | --- | --- | --- | --- | --- | --- |
| 2477 | 15 | **Miscellaneous UE Conformance Testing Activities** | 958d | 2001-04-02 A | 2004-12-01 A |  | 100% | 2001-04-02 | 2004-12-01 | 958d |  | T1 | 36360h | 36360h | MISTST1 | Rel-4 | Ingbert |  |  |  |  |
| 2478 | 15.1 | Optimization of Test Time, RF Aspects (FDD) | 508d | 2001-09-24 A | 2003-09-03 A |  | 100% | 2001-09-24 | 2003-09-03 | 508d | finish no earlier than 2003-09-03 | T1 | 4064h | 4064h | MISTST1-OpFDD | Rel-4 | Ingbert | 34.121 |  |  |  |
| 2479 | 15.2 | Optimization of Test Time, RF Aspects (TDD) | 508d | 2001-09-24 A | 2003-09-03 A |  | 100% | 2001-09-24 | 2003-09-03 | 508d | finish no earlier than 2003-09-03 | T1 | 4064h | 4064h | MISTST1-OpTDD | Rel-4 | Ingbert | 34.122 |  |  |  |
| 2480 | 15.3 | Extensions to R99 Test cases | 139.4w | 2001-04-02 A | 2003-12-02 A |  | 100% | 2001-04-02 | 2003-12-02 | 139.4w | finish no earlier than 2003-12-02 | T1 | 5576h | 5576h | MISTST1-Ext | Rel-4 | Ingbert | 34.123 p 1,2 |  |  |  |
| 2481 | 15.4 | Extension to R99 Test cases - TTCN | 439d | 2002-06-28 A | 2004-03-03 A |  | 100% | 2002-06-28 | 2004-03-03 | 439d | finish no earlier than 2004-03-03 | T1 | 3512h | 3512h |  | Rel-4 | Ingbert |  |  |  |  |
| 2482 | 15.5 | Creation of R99 TCs for TDD - prose | 719d | 2001-10-01 A | 2004-07-01 A |  | 100% | 2001-10-01 | 2004-07-01 | 719d | finish no earlier than 2004-07-01 | T1 | 5752h | 5752h | MISTST1-TDD | Rel-4 | Ingbert | 34.123-1 |  |  |  |
| 2483 | 15.6 | Deleted - Creation of R99 TCs for TDD - TTCN | 587d | 2002-09-03 A | 2004-12-01 A |  | 100% | 2002-09-03 | 2004-12-01 | 587d | finish no earlier than 2004-12-01 | T1 | 4696h | 4696h |  | Rel-4 | Ingbert |  | TP-26 |  |  |
| 2484 | 15.7 | Deleted - Review all other work items for impact on new or exiting 34 series specs. | 25.8w | 2002-07-02 A | 2002-12-27 A |  | 100% | 2002-07-02 | 2002-12-27 | 25.8w | finish no earlier than 2002-12-27 | T1 | 1032h | 1032h | MISTST1 | Rel-4 | Ingbert | 34.121,122,123,125 | TP-18 |  |  |
| 2485 | 46 | **Facsimile** | 89d | 2000-02-22 A | 2000-06-23 A |  | 100% | 2000-02-22 | 2000-06-23 | 89d |  | S1 | 4376h | 4376h | FAX | Rel-4 | Alain |  |  |  |  |
| 2486 | 46.1 | **Real Time Fax** | 89d | 2000-02-22 A | 2000-06-23 A |  | 100% | 2000-02-22 | 2000-06-23 | 89d |  | S2 | 3664h | 3664h | FAX-RT | Rel-4 | Maurice |  |  |  |  |
| 2487 | 46.1.1 | Terminal capabilities, AT commands | 89d | 2000-02-22 A | 2000-06-23 A |  | 100% | 2000-02-22 | 2000-06-23 | 89d | finish no earlier than 2000-06-23 | T2 | 712h | 712h |  | Rel-4 |  | 21.904, 27.007 |  |  |  |
| 2488 | 46.1.2 | Signalling aspects (e.g. ICM) | 89d | 2000-02-22 A | 2000-06-23 A |  | 100% | 2000-02-22 | 2000-06-23 | 89d | start no earlier than 2000-02-22 | N1 | 712h | 712h |  | Rel-4 | Frederic |  |  |  |  |
| 2489 | 46.1.3 | Service provision | 89d | 2000-02-22 A | 2000-06-23 A |  | 100% | 2000-02-22 | 2000-06-23 | 89d | finish no earlier than 2000-06-23 | N3 | 712h | 712h |  | Rel-4 | Gwiho | 23.146 |  |  |  |
| 2490 | 46.1.4 | Review whether service/stage 1 aspects need to be aligned | 51d | 2000-04-14 A | 2000-06-23 A |  | 100% | 2000-04-14 | 2000-06-23 | 51d | finish no earlier than 2000-12-14 | S1 | 408h | 408h |  | Rel-4 | Alain |  |  |  |  |
| 2491 | 46.1.5 | Review whether architecture/stage 2 aspects need to be aligned | 51d | 2000-04-14 A | 2000-06-23 A |  | 100% | 2000-04-14 | 2000-06-23 | 51d | finish no earlier than 2000-12-14 | S2 | 408h | 408h |  | Rel-4 | Maurice |  |  |  |  |
| 2492 | 47 | Transparent End-to-End PS mobile streaming application | 253d | 2000-04-03 A | 2001-03-21 A |  | 100% | 2000-04-03 | 2001-03-21 | 253d | finish no earlier than 2000-12-29 | S4 | 2024h | 2024h | PSTREAM | Rel-4 | Paolo | 26.233, 26.234 |  |  |  |
| 2493 | 48 | **Multimedia Messaging** | 277d | 2000-02-22 A | 2001-03-14 A |  | 100% | 2000-02-22 | 2001-03-14 | 277d |  | T2,S1 | 9992h | 9992h | MMS | Rel-4 | Kimmo | 22.140, 23.140 |  | Siemens | Josef.Laumen@SAL.SIEMENS.DE |
| 2494 | 48.1 | Definition of service requirements | 72d | 2000-02-22 A | 2000-05-31 A |  | 100% | 2000-02-22 | 2000-05-31 | 72d | start no earlier than 2000-02-22 | S1 | 576h | 576h | MMS | Rel-4 | Alain |  |  |  |  |
| 2495 | 48.2 | Review of definition of service requirements | 205d | 2000-06-01 A | 2001-03-14 A | 2494 | 100% | 2000-06-01 | 2001-03-14 | 205d | finish no earlier than 2000-09-08 | T2 | 1640h | 1640h | MMS | Rel-4 | Kimmo | 22.140, 23.140 |  | Siemens |  |
| 2496 | 48.3 | **Technical Realisation** | 243d | 2000-04-10 A | 2001-03-14 A |  | 100% | 2000-04-10 | 2001-03-14 | 243d |  | T2 | 7776h | 7776h | MMS | Rel-4 | Kimmo | 22.140, 23.140 |  | Siemens | Josef.Laumen@SAL.SIEMENS.DE |
| 2497 | 48.3.1 | Review of definition of reference Achitecture model | 243d | 2000-04-10 A | 2001-03-14 A |  | 100% | 2000-04-10 | 2001-03-14 | 243d | finish no earlier than 2001-03-14 | T2 | 1944h | 1944h | MMS | Rel-4 | Kimmo | 22.140, 23.140 |  | Siemens | Josef.Laumen@SAL.SIEMENS.DE |
| 2498 | 48.3.2 | Fulfill Requirements of Stage 1 | 243d | 2000-04-10 A | 2001-03-14 A |  | 100% | 2000-04-10 | 2001-03-14 | 243d | finish no earlier than 2001-03-14 | T2 | 1944h | 1944h | MMS | Rel-4 | Kimmo | 22.140, 23.140 |  | Siemens | Josef.Laumen@SAL.SIEMENS.DE |
| 2499 | 48.3.3 | Definition of MMS primitives in Stage 2 | 243d | 2000-04-10 A | 2001-03-14 A |  | 100% | 2000-04-10 | 2001-03-14 | 243d | finish no earlier than 2001-03-14 | T2 | 1944h | 1944h | MMS | Rel-4 | Kimmo | 22.140, 23.140 |  | Siemens | Josef.Laumen@SAL.SIEMENS.DE |
| 2500 | 49 | **Transcoder-Free Operation** | 326d | 2000-01-03 A | 2001-03-30 A |  | 100% | 2000-01-03 | 2001-03-30 | 326d |  | N4,S2,N1 | 10448h | 10448h | TrFO | Rel-4 | Kimmo |  |  |  |  |
| 2501 | 49.1 | **Out-of-Band Transcoder Control solution** | 326d | 2000-01-03 A | 2001-03-30 A |  | 100% | 2000-01-03 | 2001-03-30 | 326d |  | N4 | 8448h | 8448h | TrFO-OoBTC | Rel-4 | Kimmo |  |  | NEC | Toshiyuki Tamura (tamurato@aj.jp.nec.com) |
| 2502 | 49.1.1 | implementation in UTRAN | 145d | 2000-09-11 A | 2001-03-30 A |  | 100% | 2000-09-11 | 2001-03-30 | 145d | finish no earlier than 2001-03-30 | R3 | 1160h | 1160h | TrFO-OoBTC-UTRAN | Rel-4 | Juha | 25.401, 25.410, 25.413, 25.415, 23.153 |  | Siemens | Alexander Vesely |
| 2503 | 49.1.2 | Impact on architecture, Principles and Terminology | 211d | 2000-01-03 A | 2000-10-20 A |  | 100% | 2000-01-03 | 2000-10-20 | 211d | finish no earlier than 2000-10-20 | S2 | 1680h | 1680h | TrFO-OoBTC | Rel-4 | Maurice |  |  |  |  |
| 2504 | 49.1.3 | Codec Negotiation between UE and MSC | 125d | 2000-08-14 A | 2001-02-02 A |  | 100% | 2000-08-14 | 2001-02-02 | 125d | finish no earlier than 2001-02-02 | N1 | 1000h | 1000h | TrFO-OoBTC | Rel-4 | Frederic | 24.008, 23.009, 23.108, (29.002) |  | Motorola | Andrew Howell |
| 2505 | 49.1.4 | Codec Negotiation inter MSC | 125d | 2000-07-03 A | 2000-12-22 A |  | 100% | 2000-07-03 | 2000-12-22 | 125d | finish no earlier than 2000-12-22 | N4 | 1000h | 1000h | TrFO-OoBTC | Rel-4 | Kimmo |  |  |  |  |
| 2506 | 49.1.5 | Bearer establishment inter MSC | 125d | 2000-07-03 A | 2000-12-22 A |  | 100% | 2000-07-03 | 2000-12-22 | 125d | finish no earlier than 2000-12-22 | N4 | 1000h | 1000h | TrFO-OoBTC | Rel-4 | Kimmo | 23.153 |  |  |  |

Notes:
- 2477: -
- 2478: It is believed that the current R99 test spec. can be optimised for faster overall test times. Marked as stopped 12/2008 (was 70% complete)
- 2479: It is believed that the current R99 test spec. can be optimised for faster overall test times
- 2480: Further test coverage of the R99 specification to cover supplementry services. Marked as stopped 12/2008 (was 70% complete)
- 2481: Marked as closed 12/2008 (was marked 50% complete)
- 2482: Marked as closed 12/2008 (was marked 50% complete)
- 2483: Marked as stopped 12/2008
- 2484: Marked as stopped 12/2008
- 2485: -
- 2486: postponed from R99 to R00, SP-000169
- 2487: -
- 2488: -
- 2489: -
- 2490: -
- 2491: -
- 2492: -
- 2493: -
- 2494: -
- 2495: -
- 2496: -
- 2497: -
- 2498: e.g. minimum set of media formats, media format conversion, personalization of MMS.
- 2499: -
- 2500: Lead given to CN4 from CN / [DAB 28/11/00]
- 2501: -
- 2502: moved according to NP-000575
- 2503: e.g. study cascading TrFO/TFO/TrFO
- 2504: the link to NP-000085has been deleted because refering to a R99 status sheet / One common set of codec negotiation procedures will be specified as in ID1656.
- 2505: Bearer establishment inter MSC. TS 23.153 R99 part complete. capabilities moved to annex + list of open issues
- 2506: Bearer establishment inter MSC. TS 23.153 R99 part complete. capabilities moved to annex. / See NP-000127 / Open issues: / Handling of Conference Calls; / Handling of Multi Party Supplementary Services; / Handling of Handover UMTS to GSM; / Handling of Sending a ...

| ID | WBS | Task | Duration | Start | Finish | Complete | Baseline start | Baseline finish | Baseline duration | Constraint | Resources | Work | Actual work | Text1 | Text6 | Text8 | Text4 | Text5 |
| --- | --- | --- | --- | --- | --- | --- | --- | --- | --- | --- | --- | --- | --- | --- | --- | --- | --- | --- |
| 2507 | 49.2 | **Speech Transcoder: Location and Control at the UMTS Core Network Border** | 125d | 2000-04-10 A | 2000-09-29 A | 100% | 2000-04-10 | 2000-09-29 | 125d |  | S2 | 2000h | 2000h | TrFO-STLC | Rel-4 | Maurice |  |  |
| 2508 | 49.2.1 | Transcoder at Edge | 125d | 2000-04-10 A | 2000-09-29 A | 100% | 2000-04-10 | 2000-09-29 | 125d | finish no earlier than 2000-09-29 | NP | 1000h | 1000h | TrFO-STLC | Rel-4 | Kimmo |  |  |
| 2509 | 50 | **GERAN improvements 1 (Gb over IP)** | 225d | 2000-05-09 A | 2001-03-19 A | 100% | 2000-05-09 | 2001-03-19 | 225d |  | GP | 6472h | 6472h | GEIMP1 | Rel-4 | Paolo |  |  |
| 2510 | 50.1 | **Gb over IP (Ip-fication of Gb)** | 225d | 2000-05-09 A | 2001-03-19 A | 100% | 2000-05-09 | 2001-03-19 | 225d |  | GP | 4672h | 4672h | GbIP | Rel-4 | Paolo |  |  |
| 2511 | 50.1.1 | Concept of Gb over IP (Ip-fication of Gb) | 134d | 2000-05-09 A | 2000-11-10 A | 100% | 2000-05-09 | 2000-11-10 | 134d |  | GP | 1072h | 1072h |  | Rel-4 | Paolo |  |  |
| 2512 | 50.1.2 | Changes to 08.16, 08.18 | 225d | 2000-05-09 A | 2001-03-19 A | 100% | 2000-05-09 | 2001-03-19 | 225d |  | GP | 1800h | 1800h |  | Rel-4 | Paolo |  |  |
| 2513 | 51 | **GERAN improvements 2 (NACC)** | 677d | 2000-11-06 A | 2003-06-10 A | 100% | 2000-11-06 | 2003-06-10 | 677d |  | GP | 19224h | 19224h | GEIMP2 | Rel-4 | Paolo |  |  |
| 2514 | 51.1 | **Gb enhancements** | 155d | 2000-11-06 A | 2001-06-08 A | 100% | 2000-11-06 | 2001-06-08 | 155d |  | GP | 7440h | 7440h | Gben | Rel-4 | Paolo |  |  |
| 2515 | 51.1.1 | **Intra BSC NACC (Network Assisted Cell Change)** | 155d | 2000-11-06 A | 2001-06-08 A | 100% | 2000-11-06 | 2001-06-08 | 155d |  | GP | 6200h | 6200h |  | Rel-4 | Paolo |  |  |
| 2516 | 51.1.1.1 | Concept | 155d | 2000-11-06 A | 2001-06-08 A | 100% | 2000-11-06 | 2001-06-08 | 155d | finish no earlier than 2001-06-08 | GP | 1240h | 1240h |  | Rel-4 | Paolo |  |  |
| 2517 | 51.1.1.2 | Changes in 03.64 | 155d | 2000-11-06 A | 2001-06-08 A | 100% | 2000-11-06 | 2001-06-08 | 155d | finish no earlier than 2001-06-08 | GP | 1240h | 1240h |  | Rel-4 | Paolo |  |  |
| 2518 | 51.1.1.3 | Changes in 04.60 | 155d | 2000-11-06 A | 2001-06-08 A | 100% | 2000-11-06 | 2001-06-08 | 155d | finish no earlier than 2001-06-08 | GP | 1240h | 1240h |  | Rel-4 | Paolo |  |  |
| 2519 | 51.1.1.4 | Changes in 44.008 | 155d | 2000-11-06 A | 2001-06-08 A | 100% | 2000-11-06 | 2001-06-08 | 155d | finish no earlier than 2001-06-08 | GP | 1240h | 1240h |  | Rel-4 | Paolo |  |  |
| 2520 | 51.3 | **MS conformance test for Intra BSC NACC** | 398d | 2001-11-30 A | 2003-06-10 A | 100% | 2001-11-30 | 2003-06-10 | 398d |  | GP | 6368h | 6368h | GEIMP2-Msconf | Rel-4 | Paolo |  |  |
| 2521 | 51.3.1 | Changes in 51.010 | 398d | 2001-11-30 A | 2003-06-10 A | 100% | 2001-11-30 | 2003-06-10 | 398d | finish no earlier than 2003-12-19 | G5,G4 | 3184h | 3184h |  | Rel-4 | Paolo |  |  |
| 2522 | 52 | **GERAN improvements 4 (Delayed TBF)** | 105d | 2001-01-15 A | 2001-06-08 A | 100% | 2001-01-15 | 2001-06-08 | 105d |  | GP | 3960h | 3960h | GEIMP4 | Rel-4 | Paolo |  |  |
| 2523 | 52.1 | **Gb enhancements 2** | 105d | 2001-01-15 A | 2001-06-08 A | 100% | 2001-01-15 | 2001-06-08 | 105d |  | GP | 3120h | 3120h | GEIMP4-Gben2 | Rel-4 | Paolo |  |  |
| 2524 | 52.1.1 | stage 2 | 105d | 2001-01-15 A | 2001-06-08 A | 100% | 2001-01-15 | 2001-06-08 | 105d | finish no earlier than 2001-06-08 | GP | 840h | 840h |  | Rel-4 | Paolo |  |  |
| 2525 | 52.1.2 | **Stage 3 (changes in 44.060)** | 60d | 2001-01-15 A | 2001-04-06 A | 100% | 2001-01-15 | 2001-04-06 | 60d |  | G2 | 1440h | 1440h |  | Rel-4 | Gert |  |  |
| 2526 | 52.1.2.1 | Definition of enhanced countdown procedure | 60d | 2001-01-15 A | 2001-04-06 A | 100% | 2001-01-15 | 2001-04-06 | 60d | finish no earlier than 2001-04-06 | G2 | 480h | 480h |  | Rel-4 | Gert |  |  |
| 2527 | 52.1.2.2 | Definition of enhanced TBF release procedure | 60d | 2001-01-15 A | 2001-04-06 A | 100% | 2001-01-15 | 2001-04-06 | 60d | finish no earlier than 2001-04-06 | G2 | 480h | 480h |  | Rel-4 | Gert |  |  |
| 2528 | 52.1.2.3 | Definition of USF=FREE type polling mechanism on PDCH | 60d | 2001-01-15 A | 2001-04-06 A | 100% | 2001-01-15 | 2001-04-06 | 60d | finish no earlier than 2001-04-06 | G2 | 480h | 480h |  | Rel-4 | Gert |  |  |
| 2529 | 53 | **Low Chip Rate TDD option** | 880d | 2000-07-19 A | 2003-12-02 A | 100% | 2000-07-19 | 2003-12-02 | 880d |  | R1 | 27488h | 27488h | LCRTDD | Rel-4 | Patrick | CWTS | G. Yang |
| 2530 | 53.1 | Physical layer | 183d | 2000-07-19 A | 2001-03-30 A | 100% | 2000-07-19 | 2001-03-30 | 183d | finish no earlier than 2001-03-30 | R1 | 1464h | 1464h | LCRTDD-Phys | Rel-4 | Patrick | CWTS | G. Yang |
| 2531 | 53.2 | Layer 2 and layer 3 protocol aspects | 183d | 2000-07-19 A | 2001-03-30 A | 100% | 2000-07-19 | 2001-03-30 | 183d | finish no earlier than 2001-03-30 | R2 | 1464h | 1464h | LCRTDD-L23 | Rel-4 | Joern | CWTS | Y. Liu |
| 2532 | 53.3 | RF radio transmission/reception, system performance requirements and conformance testing | 165d | 2000-08-14 A | 2001-03-30 A | 100% | 2000-08-14 | 2001-03-30 | 165d | finish no earlier than 2001-03-30 | R4 | 1320h | 1320h | LCRTDD-RF | Rel-4 | Issam | CWTS | D. Zhang |
| 2533 | 53.4 | UE radio access capability | 165d | 2000-08-14 A | 2001-03-30 A | 100% | 2000-08-14 | 2001-03-30 | 165d | finish no earlier than 2001-03-30 | R2 | 1320h | 1320h | LCRTDD-UErac | Rel-4 | Joern | CWTS | Y. Liu |
| 2534 | 53.5 | Iub/Iur protocol aspects | 165d | 2000-08-14 A | 2001-03-30 A | 100% | 2000-08-14 | 2001-03-30 | 165d | finish no earlier than 2001-03-30 | R3 | 1320h | 1320h | LCRTDD-IubIur | Rel-4 | Juha | CWTS | Y. Liu |

Notes:
- 2507: WI description and Tdoc S2-99352 / Speech Transcoder: Location and Control at the UMTS Core Network Border
- 2508: WI description and Tdoc S2-99352...
- 2509: -
- 2510: -
- 2511: -
- 2512: -
- 2513: -
- 2514: -
- 2515: -
- 2516: -
- 2517: -
- 2518: -
- 2519: -
- 2520: -
- 2521: az 05/08: duplicated UID_50099 => 50299. Marked as closed 12/2008 (was marked 50% complete)
- 2522: -
- 2523: -
- 2524: -
- 2525: -
- 2526: -
- 2527: -
- 2528: -
- 2529: -
- 2530: -
- 2531: -
- 2532: -
- 2533: -
- 2534: -

| ID | WBS | Task | Duration | Start | Finish | Predecessors | Complete | Baseline start | Baseline finish | Baseline duration | Constraint | Resources | Work | Actual work | Text6 | Text8 | Text3 | Text12 | Text1 | Text4 | Text5 |
| --- | --- | --- | --- | --- | --- | --- | --- | --- | --- | --- | --- | --- | --- | --- | --- | --- | --- | --- | --- | --- | --- |
| 2535 | 53.6 | **Low chiprate TDD interworking with GERAN** | 101d | 2000-09-01 A | 2001-01-19 A | 2534 | 100% | 2000-09-01 | 2001-01-19 | 101d |  | GP | 1616h | 1616h | Rel-4 | Paolo |  |  |  |  |  |
| 2536 | 53.6.1 | Handover and Cell Selection / Reselection to UTRA 1.28 Mcps TDD | 101d | 2000-09-01 A | 2001-01-19 A |  | 100% | 2000-09-01 | 2001-01-19 | 101d | finish no earlier than 2001-01-19 | GP | 808h | 808h | Rel-4 | Paolo |  |  |  |  |  |
| 2537 | 53.8 | **Conformance Test Aspects - Low Chip Rate TDD** | 577d | 2001-09-17 A | 2003-12-02 A | 2535 | 100% | 2001-09-17 | 2003-12-02 | 577d |  | T1 | 12088h | 12088h | Rel-4 | Ingbert |  |  |  |  |  |
| 2538 | 53.8.1 | Testing Layer 2 and layer 3 protocol aspects | 468d | 2001-09-17 A | 2003-07-02 A |  | 100% | 2001-09-17 | 2003-07-02 | 468d | finish no earlier than 2003-07-02 | T1 | 3744h | 3744h | Rel-4 | Ingbert | 34.123-1, 34.123-2 |  |  |  |  |
| 2539 | 53.8.2 | Deleted - Testing Layer 2 and layer 3 protocol aspects - TTCN | 261d | 2002-12-03 A | 2003-12-02 A |  | 100% | 2002-12-03 | 2003-12-02 | 261d | finish no earlier than 2003-12-02 | T1 | 2088h | 2088h | Rel-4 | Ingbert | 34.123-3 | TP-22 |  |  |  |
| 2540 | 53.8.3 | Testing RF Radio Transmission and Reception | 205d | 2001-09-17 A | 2002-06-28 A |  | 100% | 2001-09-17 | 2002-06-28 | 205d | finish no earlier than 2002-06-28 | T1 | 1640h | 1640h | Rel-4 | Ingbert |  |  |  |  |  |
| 2541 | 54 | **Enable bearer independent CS architecture** | 566d | 2000-01-03 A | 2002-03-01 A |  | 100% | 2000-01-03 | 2002-03-01 | 566d |  | S2 | 20192h | 20192h | Rel-4 | Maurice |  |  | CSSPLIT | Siemens | Alexander Milinski |
| 2542 | 54.1 | **Enable bearer-independent call control** | 425d | 2000-01-03 A | 2001-08-16 A |  | 100% | 2000-01-03 | 2001-08-16 | 425d |  | N4 | 12344h | 12344h | Rel-4 | Kimmo |  |  |  | Ericsson | Heinz-Peter.Keutmann@eed.ericsson.se |
| 2543 | 54.1.1 | Architecture and Stage 2 description | 181d | 2000-01-03 A | 2000-09-08 A |  | 100% | 2000-01-03 | 2000-09-08 | 181d | finish no earlier than 2000-09-08 | S2 | 1440h | 1440h | Rel-4 | Maurice | 23.002 |  |  |  |  |
| 2544 | 54.1.2 | Standardisation of protocols (control & user planes) over Nb interface | 64d | 2001-01-02 A | 2001-03-30 A |  | 100% | 2001-01-02 | 2001-03-30 | 64d | finish no earlier than 2001-03-30 | N3 | 512h | 512h | Rel-4 | Gwiho |  |  |  |  |  |
| 2545 | 54.1.3 | Standardisation of protocols over reference points between MSC server and Gateway MSC server | 130d | 2000-09-25 A | 2001-03-23 A |  | 100% | 2000-09-25 | 2001-03-23 | 130d | finish no earlier than 2001-03-23 | N4 | 1040h | 1040h | Rel-4 | Kimmo |  |  |  |  |  |
| 2546 | 54.1.4 | Standardisation of detailed stage 2 description | 180d | 2000-07-17 A | 2001-03-23 A |  | 100% | 2000-07-17 | 2001-03-23 | 180d | finish no earlier than 2001-03-23 | N4 | 1440h | 1440h | Rel-4 | Kimmo |  |  |  |  |  |
| 2547 | 54.1.5 | **Bearer control between MSC server and MGW** | 250d | 2000-09-01 A | 2001-08-16 A |  | 100% | 2000-09-01 | 2001-08-16 | 250d |  | N4 | 4512h | 4512h | Rel-4 | Kimmo |  |  |  |  |  |
| 2548 | 54.1.5.1 | stage 3 - protocol issues | 250d | 2000-09-01 A | 2001-08-16 A |  | 100% | 2000-09-01 | 2001-08-16 | 250d | finish no earlier than 2001-08-16 | N4 | 2000h | 2000h | Rel-4 | Kimmo |  |  |  |  |  |
| 2549 | 54.1.5.2 | stage 3 - parameter value issues | 64d | 2001-01-02 A | 2001-03-30 A |  | 100% | 2001-01-02 | 2001-03-30 | 64d | finish no earlier than 2001-03-30 | N3 | 512h | 512h | Rel-4 | Gwiho |  |  |  |  |  |
| 2550 | 54.2 | Lawful interception | 155d | 2000-08-21 A | 2001-03-23 A |  | 100% | 2000-08-21 | 2001-03-23 | 155d | finish no earlier than 2001-03-23 | S3 | 1240h | 1240h | Rel-4 | Dionisio |  |  |  |  |  |
| 2551 | 54.4 | Deleted - Conformance Test Aspects - Enable bearer independent CS architecture | 260d | 2001-03-05 A | 2002-03-01 A |  | 100% | 2001-03-05 | 2002-03-01 | 260d |  | T1 | 2080h | 2080h | Rel-4 | Ingbert |  | TP-15 | CSSPLIT-TEST |  |  |
| 2552 | 55 | **MExE enhancements Rel-4** | 511d | 2000-01-03 A | 2001-12-14 A |  | 100% | 2000-01-03 | 2001-12-14 | 511d |  | T2 | 19032h | 19032h | Rel-4 | Kimmo |  |  | MEXE |  |  |
| 2553 | 55.1 | **MExE Security Analysis Activity** | 474d | 2000-02-22 A | 2001-12-14 A |  | 100% | 2000-02-22 | 2001-12-14 | 474d |  | S3 | 8464h | 8464h | Rel-4 | Dionisio |  |  | MEXE-SEC | BT | colin.blanchard@bt.com |
| 2554 | 55.1.1 | Stage 3 | 370d | 2000-07-17 A | 2001-12-14 A |  | 100% | 2000-07-17 | 2001-12-14 | 370d | finish no earlier than 2001-12-14 | S3 | 2960h | 2960h | Rel-4 | Dionisio |  |  | MEXE1-SEC |  |  |
| 2555 | 55.1.2 | Terminal aspects | 214d | 2000-02-22 A | 2000-12-15 A |  | 100% | 2000-02-22 | 2000-12-15 | 214d | finish no earlier than 2000-12-15 | T2 | 1712h | 1712h | Rel-4 |  |  |  |  |  |  |
| 2556 | 55.2 | **MExE Rel4 Improvements and Investigations** | 251d | 2000-01-03 A | 2000-12-15 A |  | 100% | 2000-01-03 | 2000-12-15 | 251d |  | T2 | 6480h | 6480h | Rel-4 | Kimmo | 22.057, 23.057 |  | MEXE-ENHANC | Motorola | Mark Cataldo |
| 2557 | 55.2.1 | 3rd MExE classmark | 251d | 2000-01-03 A | 2000-12-15 A |  | 100% | 2000-01-03 | 2000-12-15 | 251d | finish no earlier than 2000-12-15 | T2 | 2000h | 2000h | Rel-4 | Kimmo | 22.057, 23.057 |  |  | Motorola | Mark Cataldo |
| 2558 | 55.2.2 | FS on Secure download mechanism and capabilities to support SDR concepts | 225d | 2000-02-07 A | 2000-12-15 A |  | 100% | 2000-02-07 | 2000-12-15 | 225d | finish no earlier than 2000-12-15 | T2 | 1800h | 1800h | Rel-4 | Kimmo | 22.057, 23.057 |  |  | Motorola | Mark Cataldo |
| 2559 | 55.2.3 | FS on Support of MP3/MPEG4 content | 225d | 2000-02-07 A | 2000-12-15 A |  | 100% | 2000-02-07 | 2000-12-15 | 225d | finish no earlier than 2000-12-15 | T2 | 1800h | 1800h | Rel-4 | Kimmo | 22.057, 23.057 |  |  | Motorola | Mark Cataldo |

Notes:
- 2535: -
- 2536: -
- 2537: -
- 2538: Marked as closed 12/2008 (was marked 60% complete)
- 2539: Marked as stopped 12/2008
- 2540: duration set to 6 months (was 0), finish date set
- 2541: -
- 2542: DAB 12.12.01 should be 100% hence closed
- 2543: R00 stage 2 at least 80 % complete in TSGS #8 21.-23.6.2000
- 2544: -
- 2545: -
- 2546: -
- 2547: -
- 2548: -
- 2549: -
- 2550: Requirements capture: S3#14 (Aug 00), Feature specification: S3#15 (Sep 00), Definition of architecture. Should be included in general LI work mentioned above.
- 2551: Marked as stopped 12/2008
- 2552: -
- 2553: Presentation to S3 of threats and countermeasures analysis: S3#15, Feature specification: S3#16. S3#18: WID updated
- 2554: Analysis undertaken by T2. No additional analysis needed for Rel-4
- 2555: -
- 2556: -
- 2557: Additional features for MExE R2000
- 2558: -
- 2559: -

| ID | WBS | Task | Duration | Start | Finish | Complete | Baseline start | Baseline finish | Baseline duration | Constraint | Resources | Work | Actual work | Text1 | Text6 | Text8 | Text3 | Text4 | Text5 |
| --- | --- | --- | --- | --- | --- | --- | --- | --- | --- | --- | --- | --- | --- | --- | --- | --- | --- | --- | --- |
| 2560 | 56 | **Tandem Free aspects for 3G and between 2G and 3G systems** | 344d | 2000-02-22 A | 2001-06-15 A | 100% | 2000-02-22 | 2001-06-15 | 344d |  | S4 | 9696h | 9696h | TFO | Rel-4 | Paolo |  |  |  |
| 2561 | 56.1 | **Tandem Free AMR** | 344d | 2000-02-22 A | 2001-06-15 A | 100% | 2000-02-22 | 2001-06-15 | 344d |  | S4 | 6944h | 6944h | TFO-AMR | Rel-4 | Paolo |  |  |  |
| 2562 | 56.1.1 | Specification | 284d | 2000-02-22 A | 2001-03-23 A | 100% | 2000-02-22 | 2001-03-23 | 284d | start no earlier than 2000-02-22 | S4 | 2272h | 2272h |  | Rel-4 | Paolo | 28.062 |  |  |
| 2563 | 56.1.2 | **Impact on:** | 115d | 2001-01-08 A | 2001-06-15 A | 100% | 2001-01-08 | 2001-06-15 | 115d |  | NP | 1920h | 1920h |  | Rel-4 | Kimmo |  |  |  |
| 2564 | 56.1.2.1 | CN | 60d | 2001-03-26 A | 2001-06-15 A | 100% | 2001-03-26 | 2001-06-15 | 60d | finish no earlier than 2001-06-15 | NP | 480h | 480h |  | Rel-4 | Kimmo |  |  |  |
| 2565 | 56.1.2.2 | GERAN | 65d | 2001-01-08 A | 2001-04-06 A | 100% | 2001-01-08 | 2001-04-06 | 65d | finish no earlier than 2001-04-06 | GP | 520h | 520h |  | Rel-4 | Paolo |  |  |  |
| 2566 | 57 | **Advanced Speech Call Items enhancements_REL-4** | 334d | 2000-12-03 A | 2002-03-14 A | 100% | 2000-12-03 | 2002-03-14 | 334d |  | N1 | 5925.6h | 5925.6h | ASCI | Rel-4 | Frederic |  | Nortel | sonia.garapaty@nortelnetworks.com |
| 2567 | 57.1 | Stage 2 | 326.7d | 2000-12-03 A | 2002-03-14 A | 100% | 2000-12-03 | 2002-03-14 | 326.7d | finish no earlier than 2002-03-14 | N4 | 2613.6h | 2613.6h |  | Rel-4 | Kimmo | 23.067, 24.067 | Sagem | Vivien Perlic |
| 2568 | 57.2 | Stages 2 and 3 on A interface | 80d | 2000-12-03 A | 2001-03-23 A | 100% | 2000-12-03 | 2001-03-23 | 80d | finish no earlier than 2001-03-23 | N1 | 640h | 640h |  | Rel-4 | Frederic | 44.068, 44.069, 24.008 | Nortel | sonia.garapaty@nortelnetworks.com |
| 2569 | 58 | **700 MHz spectrum support** | 776d | 2000-01-03 A | 2002-12-20 A | 100% | 2000-01-03 | 2002-12-20 | 776d |  | GP | 25016h | 25016h | 700SS | Rel-4 | Paolo |  |  |  |
| 2570 | 58.1 | **GERAN support for the 700 MHz band** | 276d | 2000-01-03 A | 2001-01-19 A | 100% | 2000-01-03 | 2001-01-19 | 276d |  | GP | 8808h | 8808h |  | Rel-4 | Paolo |  |  |  |
| 2571 | 58.1.1 | Signalling support | 276d | 2000-01-03 A | 2001-01-19 A | 100% | 2000-01-03 | 2001-01-19 | 276d | finish no earlier than 2001-01-19 | GP | 2200h | 2200h |  | Rel-4 | Paolo |  |  |  |
| 2572 | 58.1.2 | Physical layer definitions | 276d | 2000-01-03 A | 2001-01-19 A | 100% | 2000-01-03 | 2001-01-19 | 276d | finish no earlier than 2001-01-19 | GP | 2200h | 2200h |  | Rel-4 | Paolo |  |  |  |
| 2573 | 58.1.3 | Receiver performance and RF budget | 276d | 2000-01-03 A | 2001-01-19 A | 100% | 2000-01-03 | 2001-01-19 | 276d | finish no earlier than 2001-01-19 | GP | 2200h | 2200h |  | Rel-4 | Paolo |  |  |  |
| 2574 | 58.2 | **GERAN MS Conformance test for 700 MHz band** | 175d | 2001-04-02 A | 2001-11-30 A | 100% | 2001-04-02 | 2001-11-30 | 175d |  | GP | 2800h | 2800h |  | Rel-4 | Paolo |  |  |  |
| 2575 | 58.2.1 | MS test | 175d | 2001-04-02 A | 2001-11-30 A | 100% | 2001-04-02 | 2001-11-30 | 175d | finish no earlier than 2001-11-30 | GP | 1400h | 1400h |  | Rel-4 | Paolo |  |  |  |
| 2576 | 58.3 | **GERAN BTS Conformance test for 700 MHz band** | 450d | 2001-04-02 A | 2002-12-20 A | 100% | 2001-04-02 | 2002-12-20 | 450d |  | GP | 7200h | 7200h |  | Rel-4 | Paolo |  |  |  |
| 2577 | 58.3.1 | BTS test | 450d | 2001-04-02 A | 2002-12-20 A | 100% | 2001-04-02 | 2002-12-20 | 450d | finish no earlier than 2002-12-20 | GP | 3600h | 3600h |  | Rel-4 | Paolo |  |  |  |
| 2578 | 59 | Operator Determined Barring for Packet Oriented Services | 208d | 2000-06-01 A | 2001-03-19 A | 100% | 2000-06-01 | 2001-03-19 | 208d | finish no earlier than 2001-03-19 | NP | 1664h | 1664h | ODB | Rel-4 | Kimmo |  | NEC | Toshiyuki Tamura (tamurato@aj.jp.nec.com) |
| 2579 | 60 | **UMTS QoS Architecture for PS Domain** | 759d | 2000-01-03 A | 2002-11-27 A | 100% | 2000-01-03 | 2002-11-27 | 759d |  | S2 | 41312h | 41312h | QoSPS | Rel-4 | Maurice |  | Ericsson | Ina.widegren@era.ericsson.se |
| 2580 | 60.1 | Architecture | 153d | 2000-06-05 A | 2001-01-03 A | 100% | 2000-06-05 | 2001-01-03 | 153d | finish no earlier than 2001-01-03 | S2 | 1224h | 1224h |  | Rel-4 | Maurice | 23.107 |  |  |
| 2581 | 60.2 | Charging and OAM&P for QoS Management | 201d | 2001-09-21 A | 2002-06-28 A | 100% | 2001-09-21 | 2002-06-28 | 201d | finish no earlier than 2002-06-28 | S5 | 1608h | 1608h | QoSPS-OAM | Rel-4 | Dionisio | 32-series | VoiceStream, Motorola |  |
| 2582 | 60.3 | **RAB Quality of Service (re)Negotiation over Iu** | 155d | 2000-08-21 A | 2001-03-23 A | 100% | 2000-08-21 | 2001-03-23 | 155d |  | R3 | 3648h | 3648h | QoSPS-MAPEND-RABQoS | Rel-4 | Juha | 25.413 | Ericsson | anders.molander@ericsson.com |
| 2583 | 60.3.1 | RAB Quality of Service Negotiation over Iu | 155d | 2000-08-21 A | 2001-03-23 A | 100% | 2000-08-21 | 2001-03-23 | 155d | finish no earlier than 2001-03-23 | R3 | 1240h | 1240h | QoSPS-MAPEND-RABQoS-Negot | Rel-4 | Juha |  | Ericsson | anders.molander@ericsson.com |
| 2584 | 60.3.2 | RAB Quality of Service Negotiation over Iu during relocation | 16d | 2001-03-02 A | 2001-03-23 A | 100% | 2001-03-02 | 2001-03-23 | 16d | start no earlier than 2001-03-02 | R3 | 128h | 128h | QoSPS-MAPEND-RABQoS-NegotReloc | Rel-4 | Juha |  |  |  |
| 2585 | 60.3.3 | RAB Quality of Service Re-Negotiation over Iu | 130d | 2000-09-25 A | 2001-03-23 A | 100% | 2000-09-25 | 2001-03-23 | 130d | finish no earlier than 2001-03-23 | R3 | 1040h | 1040h | QoSPS-MAPEND-RABQoS-ReNegot | Rel-4 | Juha |  | Motorola | S. Irwin |

Notes:
- 2560: RAN and CN to verify no problems for GSM terminals roaming in 3G R99
- 2561: RAN and CN to verify UMTS_AMR_2 support
- 2562: -
- 2563: "Implementation" changed to "Impact on:" by A. Sultan (for better wording)
- 2564: RAN and CN to verify UMTS_AMR_2 support
- 2565: End date Modified from June to March to have it in Rel4
- 2566: Approved at CN#10
- 2567: CN4#11 30/11/02: no inputs received in CN4
- 2568: -
- 2569: -
- 2570: -
- 2571: -
- 2572: -
- 2573: -
- 2574: -
- 2575: -
- 2576: -
- 2577: -
- 2578: Completed WI missing from the P-plan Added for tracking
- 2579: -
- 2580: -
- 2581: -
- 2582: -
- 2583: -
- 2584: -
- 2585: -

| ID | WBS | Task | Duration | Start | Finish | Complete | Baseline start | Baseline finish | Baseline duration | Constraint | Resources | Work | Actual work | Text1 | Text6 | Text8 | Text12 | Text4 | Text5 | Text3 |
| --- | --- | --- | --- | --- | --- | --- | --- | --- | --- | --- | --- | --- | --- | --- | --- | --- | --- | --- | --- | --- |
| 2586 | 60.4 | **GERAN QoS Aspects - Handovers: maintenance of real-time QoS while moving between cells in the PLMN including inter-SGSN and SRNS relocation or possibly other mechanisms** | 501d | 2000-01-03 A | 2001-11-30 A | 100% | 2000-01-03 | 2001-11-30 | 501d |  | GP | 14456h | 14456h | GERQoS | Rel-4 | Paolo |  |  |  |  |
| 2587 | 60.4.1 | **Handover Concept for the PS domain** | 501d | 2000-01-03 A | 2001-11-30 A | 100% | 2000-01-03 | 2001-11-30 | 501d |  | GP | 10448h | 10448h |  | Rel-4 | Paolo |  |  |  |  |
| 2588 | 60.4.1.1 | Stable RT handover report 25.936 including header removal | 14d | 2000-01-03 A | 2000-01-19 A | 100% | 2000-01-03 | 2000-01-19 | 14d | start no earlier than 2000-01-03 | GP [92.9%] | 104h | 104h |  | Rel-4 | Paolo |  |  |  |  |
| 2589 | 60.4.1.2 | Update of stage 2 | 293d | 2000-01-03 A | 2001-02-13 A | 100% | 2000-01-03 | 2001-02-13 | 293d | finish no earlier than 2001-02-13 | GP | 2336h | 2336h |  | Rel-4 | Paolo |  |  |  |  |
| 2590 | 60.4.1.3 | Update of relevant stage 3 specs -> RRC | 501d | 2000-01-03 A | 2001-11-30 A | 100% | 2000-01-03 | 2001-11-30 | 501d | finish no earlier than 2001-11-30 | G2 | 4000h | 4000h |  | Rel-4 | Gert |  |  |  |  |
| 2591 | 60.5 | **Deleted - GERAN MS Conformance test for inter-system and intra-system Packet data real-time Handover** | 324d | 2001-08-31 A | 2002-11-27 A | 100% | 2001-08-31 | 2002-11-27 | 324d |  | G4,R3 | 12960h | 12960h | GERQoS-Mstest | Rel-4 | Paolo | GP-12 |  |  |  |
| 2592 | 60.5.1 | **Deleted - Handover for the PS domain** | 324d | 2001-08-31 A | 2002-11-27 A | 100% | 2001-08-31 | 2002-11-27 | 324d |  | G4,R3 | 10368h | 10368h |  | Rel-4 | Paolo | GP-12 |  |  |  |
| 2593 | 60.5.1.1 | Deleted - Stable RT handover report 25.936 including header removal | 324d | 2001-08-31 A | 2002-11-27 A | 100% | 2001-08-31 | 2002-11-27 | 324d | finish no earlier than 2002-11-27 | G4,R3 | 2592h | 2592h |  | Rel-4 | Paolo | GP-12 |  |  |  |
| 2594 | 60.5.1.2 | Deleted - Update of stage 2 | 324d | 2001-08-31 A | 2002-11-27 A | 100% | 2001-08-31 | 2002-11-27 | 324d | finish no earlier than 2002-11-27 | G4,R3 | 2592h | 2592h |  | Rel-4 | Paolo | GP-12 |  |  |  |
| 2595 | 60.5.1.3 | Deleted - Update of relevant stage 3 specs | 324d | 2001-08-31 A | 2002-11-27 A | 100% | 2001-08-31 | 2002-11-27 | 324d | finish no earlier than 2002-11-27 | G4,R3 | 2592h | 2592h |  | Rel-4 | Paolo | GP-12 |  |  |  |
| 2596 | 60.6 | PS-domain handover for real-time services | 155d | 2000-08-28 A | 2001-03-30 A | 100% | 2000-08-28 | 2001-03-30 | 155d | finish no earlier than 2001-03-30 | R3 | 1240h | 1240h | QoSPS-PSdoRTS | Rel-4 | Juha |  | Nokia | atte.lansisalmi@nokia.com |  |
| 2597 | 60.7 | Deleted - RAB QoS Renegotiation at Relocation | 58d | 2001-01-03 A | 2001-03-23 A | 100% | 2001-01-03 | 2001-03-23 | 58d | finish no earlier than 2001-03-23 | R3 | 464h | 464h |  | Rel-4 | Juha | RP-11 |  |  | 25.851, 25.946 |
| 2598 | 61 | (Small) Technical Enhancements and Improvements for Rel-4 | 326d? | 2000-01-03 A | 2001-03-30 A | 100% | 2000-01-03 | 2001-03-30 | 326d? |  | All | 2608h | 2608h | TEI4 | Rel-4 | all |  |  |  |  |
| 2599 | 687 | Test - (Small) Technical Enhancements and Improvements for Rel-4 | 326d? | 2000-01-03 A | 2001-03-30 A | 100% | 2000-01-03 | 2001-03-30 | 326d? | finish no earlier than 2008-12-31 | R5,T1 | 2608h | 2608h | TEI4_Test | Rel-4 | Ingbert |  |  |  |  |
| 2600 | 62 | **Rel-4 Evolutions of the transport in the UTRAN** | 525d | 2000-08-21 A | 2002-08-23 A | 100% | 2000-08-21 | 2002-08-23 | 525d |  | RP | 8600h | 8600h | ETRAN | Rel-4 | Issam |  | Alcatel | Francois Courau |  |
| 2601 | 62.1 | QoS optimization for AAL2 connections over Iub and Iur interfaces | 160d | 2000-08-21 A | 2001-03-30 A | 100% | 2000-08-21 | 2001-03-30 | 160d | finish no earlier than 2001-03-30 | R3 | 1280h | 1280h | ETRAN-QoSAAL2 | Rel-4 | Juha |  | Japan Telecom | T. Yoshimura |  |
| 2602 | 62.2 | Transport bearer modification procedure on Iub, Iur, and Iu | 130d | 2000-10-02 A | 2001-03-30 A | 100% | 2000-10-02 | 2001-03-30 | 130d | finish no earlier than 2001-03-30 | R3 | 1040h | 1040h | ETRAN-MigrMod | Rel-4 | Juha |  | Japan Telecom | T. Yoshimura |  |
| 2603 | 62.3 | **Deleted - Conformance Test Aspects of Rel-4 evolutions of the transport in UTRAN** | 130d | 2002-02-25 A | 2002-08-23 A | 100% | 2002-02-25 | 2002-08-23 | 130d |  | T1 | 2080h | 2080h |  | Rel-4 | Ingbert | TP-17 |  |  |  |
| 2604 | 62.3.1 | Deleted - Testing RAB support enhancements | 130d | 2002-02-25 A | 2002-08-23 A | 100% | 2002-02-25 | 2002-08-23 | 130d | finish no earlier than 2002-08-23 | T1 | 1040h | 1040h | CT-RABS? | Rel-4 | Ingbert | TP-17 |  |  | 34.108, 34. 121, 34.122, 34.123 p 1,2, 34.123 pt 3 |
| 2605 | 63 | **Rel-4 Evolutions of the transport in the CN** | 215d | 2000-05-29 A | 2001-03-23 A | 100% | 2000-05-29 | 2001-03-23 | 215d |  | N4,N1,N2,S2 | 7968h | 7968h | CNTRSP | Rel-4 | Kimmo |  |  |  |  |
| 2606 | 63.1 | **IP Transport of CN protocols (e.g., CAP, MAP)** | 77d | 2000-12-07 A | 2001-03-23 A | 100% | 2000-12-07 | 2001-03-23 | 77d |  | N4 | 2808h | 2808h | SS7IP | Rel-4 | Kimmo |  |  |  |  |
| 2607 | 63.1.1 | **Stage 3** | 77d | 2000-12-07 A | 2001-03-23 A | 100% | 2000-12-07 | 2001-03-23 | 77d |  | N4 | 2192h | 2192h |  | Rel-4 | Kimmo |  |  |  |  |
| 2608 | 63.1.1.1 | CAP | 77d | 2000-12-07 A | 2001-03-23 A | 100% | 2000-12-07 | 2001-03-23 | 77d | finish no earlier than 2001-03-23 | N2 | 616h | 616h |  | Rel-4 | Kimmo |  |  |  |  |
| 2609 | 63.1.1.2 | MAP | 77d | 2000-12-07 A | 2001-03-23 A | 100% | 2000-12-07 | 2001-03-23 | 77d | finish no earlier than 2001-03-23 | N4 | 616h | 616h |  | Rel-4 | Kimmo |  |  |  |  |
| 2610 | 63.1.1.3 | BSSAP+ | 43d | 2001-01-15 A | 2001-03-14 A | 100% | 2001-01-15 | 2001-03-14 | 43d | finish no earlier than 2001-03-14 | N1 | 344h | 344h | SS7IP-BSSAP+ | Rel-4 | Frederic |  |  |  |  |

Notes:
- 2586: -
- 2587: -
- 2588: -
- 2589: -
- 2590: -
- 2591: Still exist? To be clarified by GERAN4/5. Marked as stopped 12/2008
- 2592: Marked as stopped 12/2008
- 2593: Marked as stopped 12/2008
- 2594: Marked as stopped 12/2008
- 2595: Marked as stopped 12/2008
- 2596: -
- 2597: Marked as stopped 12/2008
- 2598: "Joker" WI, to be used for a Rel 4 CR not related to any feature and with very limited impact on the system
- 2599: "Joker" WI, to be used for small modifications applicable to Rel 4 conformance testing. Moved in from the Stoyan/Testing WP
- 2600: -
- 2601: -
- 2602: -
- 2603: Marked as stopped 12/2008
- 2604: Marked as stopped 12/2008
- 2605: -
- 2606: -
- 2607: -
- 2608: -
- 2609: -
- 2610: -

| ID | WBS | Task | Duration | Start | Finish | Complete | Baseline start | Baseline finish | Baseline duration | Constraint | Resources | Work | Actual work | Text4 | Text5 | Text6 | Text8 | Text1 | Text3 | Text12 |
| --- | --- | --- | --- | --- | --- | --- | --- | --- | --- | --- | --- | --- | --- | --- | --- | --- | --- | --- | --- | --- |
| 2611 | 63.2 | **FS on Transport and control separation in the PS CN domain** | 215d | 2000-05-29 A | 2001-03-23 A | 100% | 2000-05-29 | 2001-03-23 | 215d |  | S2 | 3440h | 3440h | Ericsson | Juan-Antonio.Ibanez@eed.ericsson.se | Rel-4 | Maurice |  |  |  |
| 2612 | 63.2.1 | Architectural impacts | 215d | 2000-05-29 A | 2001-03-23 A | 100% | 2000-05-29 | 2001-03-23 | 215d | finish no earlier than 2001-03-23 | S2 | 1720h | 1720h |  |  | Rel-4 | Maurice |  |  |  |
| 2613 | 64 | **Rel-4 Improvements of Radio Interface** | 700d | 2000-07-10 A | 2003-03-14 A | 100% | 2000-07-10 | 2003-03-14 | 700d |  | RP | 28624h | 28624h |  |  | Rel-4 |  | RInImp |  |  |
| 2614 | 64.1 | UTRA repeater specification (master) | 183d | 2000-07-10 A | 2001-03-21 A | 100% | 2000-07-10 | 2001-03-21 | 183d | finish no earlier than 2001-03-21 | R4 | 1464h | 1464h | Mikom, Allgon | T. Kummetz, Mikom; Alf Ahlström, Allgon | Rel-4 | Issam | RInImp-REP |  |  |
| 2615 | 64.2 | DSCH power control improvement in soft handover | 140d | 2000-09-11 A | 2001-03-23 A | 100% | 2000-09-11 | 2001-03-23 | 140d | finish no earlier than 2001-03-23 | R1 | 1120h | 1120h | Nokia | antti.toskala@nokia.com | Rel-4 | Patrick | RInImp-DSCHsho |  |  |
| 2616 | 64.3 | UMTS 1800 | 320d | 2000-09-25 A | 2001-12-14 A | 100% | 2000-09-25 | 2001-12-14 | 320d | finish no earlier than 2001-12-14 | R4 | 2560h | 2560h | Motorola | Howard Benn | Rel-4 | Issam | RInImp-UMTS18 |  |  |
| 2617 | 64.4 | UMTS 1900 | 195d | 2001-03-19 A | 2001-12-14 A | 100% | 2001-03-19 | 2001-12-14 | 195d | finish no earlier than 2001-12-14 | R4 | 1560h | 1560h | Motorola | Howard Benn | Rel-4 | Issam | RInImp-UMTS19 | 25.101 |  |
| 2618 | 64.5 | FS on High Speed downlink packet access | 155d | 2000-08-21 A | 2001-03-23 A | 100% | 2000-08-21 | 2001-03-23 | 155d | finish no earlier than 2001-03-23 | R2 | 1240h | 1240h | Motorola | Amitabha Ghosh (qa0047@email.mot.com) | Rel-4 | Joern | RInImp-HSDPA |  |  |
| 2619 | 64.6 | Deleted - FS on improved common DL channel for Cell-FACH state | 340d | 2000-09-11 A | 2001-12-28 A | 100% | 2000-09-11 | 2001-12-28 | 340d | finish no earlier than 2001-12-28 | R2 | 2720h | 2720h | GBT | J. Kwak | Rel-4 | Joern | RInImp-DLCFACH |  | RP-14 |
| 2620 | 64.7 | **Conformance Test Spec. Rel-4 improvements in Radio Interface** | 375d | 2001-10-08 A | 2003-03-14 A | 100% | 2001-10-08 | 2003-03-14 | 375d |  | T1 | 12360h | 12360h |  |  | Rel-4 | Ingbert |  |  |  |
| 2621 | 64.7.1 | Deleted - Testing Improved usage of downlink resource in FDD for CCTrCHs of dedicated type | 140d | 2002-02-18 A | 2002-08-30 A | 100% | 2002-02-18 | 2002-08-30 | 140d | finish no earlier than 2002-08-30 | T1 | 1120h | 1120h |  |  | Rel-4 | Ingbert |  |  | TP-17 |
| 2622 | 64.7.2 | Deleted - Testing Terminal Power saving features | 140d | 2002-02-18 A | 2002-08-30 A | 100% | 2002-02-18 | 2002-08-30 | 140d | finish no earlier than 2002-08-30 | T1 | 1120h | 1120h |  |  | Rel-4 | Ingbert |  |  | TP-17 |
| 2623 | 64.7.3 | Deleted - Testing DSCH power control improvement in soft handover | 140d | 2002-02-18 A | 2002-08-30 A | 100% | 2002-02-18 | 2002-08-30 | 140d | finish no earlier than 2002-08-30 | T1 | 1120h | 1120h |  |  | Rel-4 | Ingbert |  |  | TP-17 |
| 2624 | 64.7.4 | Testing UMTS 1800 | 180d | 2001-10-08 A | 2002-06-14 A | 100% | 2001-10-08 | 2002-06-14 | 180d | finish no earlier than 2002-06-14 | T1 | 1440h | 1440h |  |  | Rel-4 | Ingbert |  | 34.108, 34,121, 34.122, 34.123-1 |  |
| 2625 | 64.7.5 | Testing UMTS 1900 | 180d | 2001-10-08 A | 2002-06-14 A | 100% | 2001-10-08 | 2002-06-14 | 180d | finish no earlier than 2002-06-14 | T1 | 1440h | 1440h |  |  | Rel-4 | Ingbert |  | 34.108, 34,121, 34.122, 34.123-1 |  |
| 2626 | 64.7.6 | Testing UMTS 1800 - TTCN | 195d | 2002-06-17 A | 2003-03-14 A | 100% | 2002-06-17 | 2003-03-14 | 195d | finish no earlier than 2003-03-14 | T1 | 1560h | 1560h |  |  | Rel-4 | Ingbert |  | 34.123-3 |  |
| 2627 | 64.7.7 | Testing UMTS 1900 - TTCN | 195d | 2002-06-17 A | 2003-03-14 A | 100% | 2002-06-17 | 2003-03-14 | 195d | finish no earlier than 2003-03-14 | T1 | 1560h | 1560h |  |  | Rel-4 | Ingbert |  | 34.123-3 |  |
| 2628 | 65 | **Rel-4 RAN improvements** | 938d? | 2000-08-14 A | 2004-03-17 A | 100% | 2000-08-14 | 2004-03-17 | 938d? |  | RP | 29336h | 29336h |  |  | Rel-4 |  | RANimp |  |  |
| 2629 | 65.1 | Node B synchronization for TDD | 160d | 2000-08-14 A | 2001-03-23 A | 100% | 2000-08-14 | 2001-03-23 | 160d | finish no earlier than 2001-03-23 | R1 | 1280h | 1280h | Siemens | S. Oestreich | Rel-4 | Patrick | RANimp-NBsync |  |  |
| 2630 | 65.2 | RAB support enhancement for Rel-4 | 155d | 2000-08-21 A | 2001-03-23 A | 100% | 2000-08-21 | 2001-03-23 | 155d | finish no earlier than 2001-03-23 | R2 | 1240h | 1240h | Ericsson | M. Israelsson, A. Krishnarajah | Rel-4 | Joern | RANimp-RABSE |  |  |
| 2631 | 65.4 | **Deleted - Conformance Test Aspects - Rel-4 RAN Improvements** | 577d? | 2002-01-01 A | 2004-03-17 A | 100% | 2002-01-01 | 2004-03-17 | 577d? |  | T1 | 19312h | 19312h |  |  | Rel-4 | Ingbert |  |  | TP-23 |
| 2632 | 65.4.1 | Deleted - Testing Radio access bearer support enhancments | 175d | 2002-01-01 A | 2002-09-02 A | 100% | 2002-01-01 | 2002-09-02 | 175d | finish no earlier than 2002-09-02 | T1 | 1400h | 1400h |  |  | Rel-4 | Ingbert |  |  | TP-17 |
| 2633 | 65.4.2 | Deleted - Testing RAB support enhancements-Robust Header Compression | 332d | 2002-05-28 A | 2003-09-03 A | 100% | 2002-05-28 | 2003-09-03 | 332d | finish no earlier than 2003-09-03 | T1 | 2656h | 2656h |  |  | Rel-4 | Ingbert | RABimp-RoCH | 34.123-1, -2 | TP-21 |
| 2634 | 65.4.3 | Deleted - Testing RAB support enhancements-Robust Header Compression - TTCN | 472d | 2002-05-28 A | 2004-03-17 A | 100% | 2002-05-28 | 2004-03-17 | 472d | finish no earlier than 2004-03-17 | T1 | 3776h | 3776h |  |  | Rel-4 | Ingbert |  | 34.123-3 | TP-23 |
| 2635 | 65.4.4 | Testing of Extended Robut Header Compression | 270d | 2002-09-18 A | 2003-09-30 A | 100% | 2002-09-18 | 2003-09-30 | 270d | finish no earlier than 2003-09-30 | T1 | 2160h | 2160h |  |  | Rel-4 | Ingbert | Ext-RoHC | 34.123-1, -2 |  |
| 2636 | 65.4.5 | Deleted - Testing of Extended Robut Header Compression - TTCN | 325d | 2002-09-18 A | 2003-12-16 A | 100% | 2002-09-18 | 2003-12-16 | 325d | finish no earlier than 2003-12-16 | T1 | 2600h | 2600h |  |  | Rel-4 | Ingbert |  | 34.123-3 | TP-22 |
| 2637 | 691.3.6 | Deleted - General changes to TS34.121 corresponding to release 4 | 263d? | 2003-03-03 A | 2004-03-03 A | 100% | 2003-03-03 | 2004-03-03 | 263d? | finish no earlier than 2004-03-03 | T1 | 2104h | 2104h |  |  | Rel-4 | Ingbert | RANimp-test | 34.108, 34.121 | TP-23 |

Notes:
- 2611: -
- 2612: -
- 2613: -
- 2614: -
- 2615: -
- 2616: -
- 2617: -
- 2618: -
- 2619: Stopped at RP#14
- 2620: -
- 2621: Marked as stopped 12/2008
- 2622: Marked as stopped 12/2008
- 2623: Marked as stopped 12/2008
- 2624: -
- 2625: -
- 2626: -
- 2627: -
- 2628: -
- 2629: -
- 2630: 29 Nov 2000: split into ROHC and non-ROHC part; 5 Mar 2001: splitting off of ROHC for Rel-4 agreed by R2
- 2631: Marked as stopped 12/2008
- 2632: Marked as stopped 12/2008
- 2633: UID changed. Marked as stopped 12/2008
- 2634: UID changed. Marked as stopped 12/2008
- 2635: Marked as closed 12/2008 (was marked 15% complete)
- 2636: Marked as stopped 12/2008
- 2637: Marked as stopped 12/2008

| ID | WBS | Task | Duration | Start | Finish | Complete | Baseline start | Baseline finish | Baseline duration | Constraint | Resources | Work | Actual work | Text1 | Text4 | Text6 | Text8 | Text12 | Text3 | Text5 |
| --- | --- | --- | --- | --- | --- | --- | --- | --- | --- | --- | --- | --- | --- | --- | --- | --- | --- | --- | --- | --- |
| 2638 | 66 | **Rel-4 Emergency call enhancements** | 628d | 2000-01-03 A | 2002-05-28 A | 100% | 2000-01-03 | 2002-05-28 | 628d |  | N1,S1,T1 | 3600h | 3600h | EMC1 | Ericsson | Rel-4 | Frederic |  |  |  |
| 2639 | 66.1 | **For CS based calls** | 628d | 2000-01-03 A | 2002-05-28 A | 100% | 2000-01-03 | 2002-05-28 | 628d |  | N1 | 3600h | 3600h | EMC1-CS | Ericsson | Rel-4 | Frederic |  |  |  |
| 2640 | 66.1.1 | Distinction in CS domain of emergency call types to different emergency services | 40d | 2000-05-01 A | 2000-06-23 A | 100% | 2000-05-01 | 2000-06-23 | 40d | finish no earlier than 2000-06-23 | S1 | 320h | 320h | EMC1-CS |  | Rel-4 | Alain |  |  |  |
| 2641 | 66.1.2 | Distinction in CS domain of emergency calls to different emergency types | 22d | 2000-08-24 A | 2000-09-22 A | 100% | 2000-08-24 | 2000-09-22 | 22d | finish no earlier than 2000-09-22 | N1 | 176h | 176h | EMC1-CS |  | Rel-4 | Frederic |  |  |  |
| 2642 | 66.1.3 | Deleted - Conformance Test Aspects - Emergency call enhancements | 151d | 2000-01-03 A | 2000-07-28 A | 100% | 2000-01-03 | 2000-07-28 | 151d |  | T1 | 1200h | 1200h | EMC1-CS |  | Rel-4 | Ingbert | TP-08 |  |  |
| 2643 | 66.1.4 | Testing CS based emergency calls | 67d | 2002-02-25 A | 2002-05-28 A | 100% | 2002-02-25 | 2002-05-28 | 67d | finish no earlier than 2002-05-28 | T1 | 536h | 536h | EMC1-CS |  | Rel-4 | Ingbert |  | 34.123-1 |  |
| 2644 | 66.1.5 | Testing CS based emergency calls - TTCN | 134d | 2001-11-22 A | 2002-05-28 A | 100% | 2001-11-22 | 2002-05-28 | 134d | finish no earlier than 2002-05-28 | T1 | 1072h | 1072h | EMC1-CS |  | Rel-4 | Ingbert |  | 34.123-3 |  |
| 2645 | 67 | **Rel-4 Terminal interfaces** | 315d | 2000-01-03 A | 2001-03-15 A | 100% | 2000-01-03 | 2001-03-15 | 315d |  | T2 | 14296h | 14296h | TI |  | Rel-4 | Kimmo |  |  |  |
| 2646 | 67.1 | **AT commands enhancements** | 314d | 2000-01-03 A | 2001-03-14 A | 100% | 2000-01-03 | 2001-03-14 | 314d |  | T2 | 5016h | 5016h | TI-ATC |  | Rel-4 | Kimmo |  | 27.007 |  |
| 2647 | 67.1.1 | Specification of AT commands for new services | 314d | 2000-01-03 A | 2001-03-14 A | 100% | 2000-01-03 | 2001-03-14 | 314d | finish no earlier than 2001-03-14 | T2 | 2504h | 2504h |  |  | Rel-4 | Kimmo |  | 27.007 |  |
| 2648 | 67.2 | **Wide Area Data Synchronization** | 314d | 2000-01-03 A | 2001-03-14 A | 100% | 2000-01-03 | 2001-03-14 | 314d |  | T2 | 5016h | 5016h | TI-WADS |  | Rel-4 | Kimmo |  |  |  |
| 2649 | 67.2.1 | Continues evolution of Synchronization protocol | 314d | 2000-01-03 A | 2001-03-14 A | 100% | 2000-01-03 | 2001-03-14 | 314d | finish no earlier than 2001-03-14 | T2 | 2504h | 2504h | TI-SYNC-EVOL |  | Rel-4 | Kimmo |  | 27.903, 27.103 |  |
| 2650 | 67.3 | Terminal local model | 218d | 2000-05-16 A | 2001-03-15 A | 100% | 2000-05-16 | 2001-03-15 | 218d | finish no earlier than 2001-03-15 | T2 | 1744h | 1744h | TLM | Ericsson | Rel-4 | Kimmo |  | 23.227 | Olga.Tome@ECS.ERICSSON.SE |
| 2651 | 68 | **Rel-4 Location Services enhancements** | 455d | 2000-04-03 A | 2001-12-28 A | 100% | 2000-04-03 | 2001-12-28 | 455d |  | S2 | 26799.2h | 26799.2h | LCS1 | Nokia | Rel-4 | Maurice |  |  | Jan Kall |
| 2652 | 68.1 | CBS interactions | 455d | 2000-04-03 A | 2001-12-28 A | 100% | 2000-04-03 | 2001-12-28 | 455d | finish no earlier than 2001-12-28 | T2 | 3640h | 3640h | LCS1-CBS |  | Rel-4 |  |  | 23.041 |  |
| 2653 | 68.2 | LCS support in the CS domain | 180d | 2000-05-15 A | 2001-01-19 A | 100% | 2000-05-15 | 2001-01-19 | 180d | finish no earlier than 2001-01-19 | S2 | 1440h | 1440h | LCS1-CS |  | Rel-4 | Maurice |  |  |  |
| 2654 | 68.3 | **LCS support in the PS domain** | 435d | 2000-05-01 A | 2001-12-28 A | 100% | 2000-05-01 | 2001-12-28 | 435d |  | S2 | 13560h | 13560h | LCS1-PS |  | Rel-4 | Maurice |  |  |  |
| 2655 | 68.3.1 | Stage 1 | 40d | 2000-07-03 A | 2000-08-25 A | 100% | 2000-07-03 | 2000-08-25 | 40d | start no earlier than 2000-07-03 | S1 | 320h | 320h |  | Pacific Bell Wireless | Rel-4 | Alain |  | 22.071 | Randolph Wohlert (rwohlert@tri.sbc.com) |
| 2656 | 68.3.2 | Stage 2 | 190d | 2000-05-01 A | 2001-01-19 A | 100% | 2000-05-01 | 2001-01-19 | 190d | finish no earlier than 2001-01-19 | S2 | 1520h | 1520h |  |  | Rel-4 | Maurice |  | 23.271 |  |
| 2657 | 68.3.3 | **Stage 3** | 355d | 2000-08-21 A | 2001-12-28 A | 100% | 2000-08-21 | 2001-12-28 | 355d |  | N1 | 8240h | 8240h |  |  | Rel-4 | Frederic |  |  |  |
| 2658 | 68.3.3.1 | Layer 3 LCS signalling UE (MS) -SGSN (UMTS PS and and GSM-GPRS) | 355d | 2000-08-21 A | 2001-12-28 A | 100% | 2000-08-21 | 2001-12-28 | 355d | finish no earlier than 2001-12-28 | N1 | 2840h | 2840h |  | Nokia | Rel-4 | Frederic |  |  | Janne Muhonen |
| 2659 | 68.3.3.2 | MAP impacts of LCS | 160d | 2000-08-21 A | 2001-03-30 A | 100% | 2000-08-21 | 2001-03-30 | 160d | finish no earlier than 2001-03-30 | N4 | 1280h | 1280h |  |  | Rel-4 | Kimmo |  |  |  |
| 2660 | 68.3.3.3 | GTP signalling for LCS | 160d | 2000-08-21 A | 2001-03-30 A | 100% | 2000-08-21 | 2001-03-30 | 160d | finish no earlier than 2001-03-30 | N4 | 1280h | 1280h |  |  | Rel-4 | Kimmo |  |  |  |
| 2661 | 68.4 | **UE positioning Rel-4** | 260d | 2000-04-03 A | 2001-03-30 A | 100% | 2000-04-03 | 2001-03-30 | 260d |  | RP | 4591.2h | 4591.2h | LCS1-UEpos |  | Rel-4 | Issam |  |  |  |
| 2662 | 68.4.1 | Iub/Iur interfaces for methods Rel 99 | 233.9d | 2000-04-03 A | 2001-03-30 A | 100% | 2000-04-03 | 2001-03-30 | 233.9d | finish no earlier than 2001-03-30 | R3 | 1871.2h | 1871.2h | LCS1-UEpos-IubIur | Ericsson | Rel-4 | Juha |  |  | Yun-Chao Hu |
| 2663 | 68.4.2 | UE positioning enhancements - IPDL for TDD | 150d | 2000-08-28 A | 2001-03-23 A | 100% | 2000-08-28 | 2001-03-23 | 150d | finish no earlier than 2001-03-23 | R2 | 1200h | 1200h | LCS1-UEpos-enh | Siemens | Rel-4 | Joern |  |  | M. Beckmann |

Notes:
- 2638: -
- 2639: WI approved in TSG_10
- 2640: -
- 2641: Calls to different emergency services such as ambulance, fire brigade, police, etc. can be routed to respective different emergency centres. / NP-000447 is the stage 3 changes for CS call control protocol.
- 2642: UID changed. Marked as stopped 12/2008
- 2643: -
- 2644: -
- 2645: -
- 2646: -
- 2647: goal not completely achieved because of missing input
- 2648: AS: Rel5 changed to Rel4 according to SP#10 decision, milestone on testing added
- 2649: -
- 2650: -
- 2651: -
- 2652: -
- 2653: Only MAP impact foreseen so far. To be further split if needed.
- 2654: -
- 2655: To be also considered: External LCS client identity, and Privacy options when PDP-context and when no PDP-context is established
- 2656: AS: 23.271 completed at SP#10
- 2657: -
- 2658: -
- 2659: Missing work task
- 2660: -
- 2661: UID changed
- 2662: 27/11: WG corrected; rapporteur corrected
- 2663: 5 Mar 2001: splitting off of IPDL for TDD for Rel-4 agreed by R2

| ID | WBS | Task | Duration | Start | Finish | Complete | Baseline start | Baseline finish | Baseline duration | Constraint | Resources | Work | Actual work | Text1 | Text6 | Text8 | Text3 | Text4 | Text5 | Text12 |
| --- | --- | --- | --- | --- | --- | --- | --- | --- | --- | --- | --- | --- | --- | --- | --- | --- | --- | --- | --- | --- |
| 2664 | 69 | **Rel-4 UICC/(U)SIM enhancements and interworking** | 175d | 2000-07-24 A | 2001-03-23 A | 100% | 2000-07-24 | 2001-03-23 | 175d |  | T3 | 2800h | 2800h | UICC1 | Rel-4 | Xavier |  |  |  |  |
| 2665 | 69.1 | Common PCN Handset Specification (CPHS) | 175d | 2000-07-24 A | 2001-03-23 A | 100% | 2000-07-24 | 2001-03-23 | 175d | finish no earlier than 2001-03-23 | T3 | 1400h | 1400h | UICC1-CPHS | Rel-4 | Xavier | 27.103 | One2One |  |  |
| 2666 | 70 | **Rel-4 (U)SIM toolkit enhancements** | 210d | 2000-06-05 A | 2001-03-23 A | 100% | 2000-06-05 | 2001-03-23 | 210d |  | T3 | 3360h | 3360h | USAT1-LocLnk | Rel-4 | Xavier |  | Gemplus | Jean-Francois Rubon |  |
| 2667 | 70.1 | USAT local link | 210d | 2000-06-05 A | 2001-03-23 A | 100% | 2000-06-05 | 2001-03-23 | 210d | finish no earlier than 2001-03-23 | T3 | 1680h | 1680h | USAT1-LocLnk | Rel-4 | Xavier |  | Gemplus | Jean-Francois Rubon |  |
| 2668 | 71 | **Rel-4 Security enhancements** | 576d | 2000-01-03 A | 2002-03-15 A | 100% | 2000-01-03 | 2002-03-15 | 576d |  | S3 | 24152h | 24152h |  | Rel-4 | Dionisio |  | Vodafone | Peter.Howard@vodafone.com |  |
| 2669 | 71.1 | Evolution of GSM CS algorithms (e.g. A5/3 development and deployment) | 272d | 2000-01-03 A | 2001-01-15 A | 100% | 2000-01-03 | 2001-01-15 | 272d | finish no earlier than 2001-01-15 | S3 | 2168h | 2168h | SEC1-CSALGO1 | Rel-4 | Dionisio |  |  |  |  |
| 2670 | 71.2 | **Evolution of GSM PS algorithms (e.g. GEA 2 deployment)** | 219d | 2000-02-22 A | 2000-12-22 A | 100% | 2000-02-22 | 2000-12-22 | 219d |  | S3 | 6024h | 6024h | SEC1-PSALGO1 | Rel-4 | Dionisio |  |  |  |  |
| 2671 | 71.2.1 | Main aspects | 199d | 2000-02-22 A | 2000-11-24 A | 100% | 2000-02-22 | 2000-11-24 | 199d | finish no earlier than 2000-11-24 | S3 | 1592h | 1592h | SEC1-PSALGO1 | Rel-4 | Dionisio |  |  |  |  |
| 2672 | 71.2.2 | Impact on GTP | 200d | 2000-03-20 A | 2000-12-22 A | 100% | 2000-03-20 | 2000-12-22 | 200d | finish no earlier than 2000-12-22 | N4 | 1600h | 1600h | SEC1-PSALGO1 | Rel-4 | Kimmo |  |  |  |  |
| 2673 | 71.2.3 | GEA capability indication in MS CM | 135d | 2000-06-19 A | 2000-12-22 A | 100% | 2000-06-19 | 2000-12-22 | 135d | finish no earlier than 2000-12-22 | N1 | 1080h | 1080h | SEC1-PSALGO1-GEACAP | Rel-4 | Frederic |  | Vodafone Airtouch | Duncan Mills |  |
| 2674 | 71.3 | **Deleted - MAP application layer security** | 576d | 2000-01-03 A | 2002-03-15 A | 100% | 2000-01-03 | 2002-03-15 | 576d |  | S3 | 11352h | 11352h | SEC1-MAPAL | Rel-4 | Dionisio |  |  |  | SP-15 |
| 2675 | 71.3.1 | Deleted - Main aspects | 199d | 2000-02-21 A | 2001-03-29 A | 100% | 2000-02-21 | 2001-03-29 | 199d | start no earlier than 2000-02-21 | S3 | 1592h | 1592h |  | Rel-4 | Dionisio |  |  |  | SP-11 |
| 2676 | 71.3.2 | Deleted - Other stage 3 aspects | 199d | 2000-02-22 A | 2000-11-24 A | 100% | 2000-02-22 | 2000-11-24 | 199d | finish no earlier than 2000-11-24 | N4 | 1592h | 1592h |  | Rel-4 | Kimmo |  |  |  | CP-10 |
| 2677 | 71.3.3 | Deleted - Visibility and Configurability of security | 576d | 2000-01-03 A | 2002-03-15 A | 100% | 2000-01-03 | 2002-03-15 | 576d | finish no earlier than 2002-03-15 | S3 | 4600h | 4600h | SEC1-VCS | Rel-4 | Dionisio |  | France Telecom | Sebastien.nguyenngoc@rd.francetelecom.com | SP-15 |
| 2678 | 72 | **Rel-4 Charging and OAM&P** | 221d | 2000-12-01 A | 2001-10-05 A | 100% | 2000-12-01 | 2001-10-05 | 221d |  | S5 | 10472h | 10472h | OAM | Rel-4 | Dionisio |  | VoiceStream, Motorola |  |  |
| 2679 | 72.1 | Rel4 Principles, high level Requirements and Architecture | 145d | 2000-12-01 A | 2001-06-21 A | 100% | 2000-12-01 | 2001-06-21 | 145d | finish no earlier than 2001-06-21 | S5 | 1160h | 1160h | OAM-AR/PR | Rel-4 | Dionisio | 32.101, 32.102 | Motorola, Telia | Michael.Truss@motorola.com, Tommy.R.Berggren@TELIA.SE |  |
| 2680 | 72.2 | Rel4 Performance Management | 216d | 2000-12-01 A | 2001-09-28 A | 100% | 2000-12-01 | 2001-09-28 | 216d | finish no earlier than 2001-06-21 | S5 | 1728h | 1728h |  | Rel-4 | Dionisio | 32.4xy, 52.402 | T-Mobile | karl-heinz.nenner@t-mobile.de |  |
| 2681 | 72.3 | Fault Management | 221d | 2000-12-01 A | 2001-10-05 A | 100% | 2000-12-01 | 2001-10-05 | 221d | finish no earlier than 2001-06-21 | S5 | 1768h | 1768h |  | Rel-4 | Dionisio | 32.111-1/4 | Lucent |  |  |
| 2682 | 72.4 | Configuration Management | 145d | 2000-12-01 A | 2001-06-21 A | 100% | 2000-12-01 | 2001-06-21 | 145d | finish no earlier than 2001-06-21 | S5 | 1160h | 1160h | OAM-CM | Rel-4 | Dionisio | 32.106-1/8 | Ericsson | thomas.tovinger@ericsson.com |  |
| 2683 | 72.5 | Rel4 Charging Management | 216d | 2000-12-01 A | 2001-09-28 A | 100% | 2000-12-01 | 2001-09-28 | 216d | finish no earlier than 2001-06-21 | S5 | 1728h | 1728h | OAM-CH | Rel-4 | Dionisio | 32.200, 32.205, 32.215, 32.235 | T-Mobile | karl-heinz.nenner@t-mobile.de |  |
| 2684 | 72.6 | UTRAN Operations and Maintenance procedures | 145d | 2000-12-01 A | 2001-06-21 A | 100% | 2000-12-01 | 2001-06-21 | 145d | finish no earlier than 2001-06-21 | S5 | 1160h | 1160h | UOAM | Rel-4 | Dionisio | 32.800 | Mannesmann Mobilfunk | bert.boden@d2mannesmann.de |  |
| 2685 | 73 | **Global Text Telephony** | 2537d? | 2000-01-03 A | 2009-09-18 A | 100% | 2000-01-03 | 2009-09-18 | 2537d? |  | S1,S2,S4,T1,R5 | 44928h | 44928h | GTT | Rel-4 | Maurice |  | Ericsson | gunnar.hellstrom@omnitor.se |  |
| 2686 | 73.1 | Stage 1 | 188d | 2000-04-05 A | 2000-12-22 A | 100% | 2000-04-05 | 2000-12-22 | 188d | finish no earlier than 2000-12-22 | S1 | 1504h | 1504h | GTT | Rel-4 | Alain | 22.976, 22.226 |  |  |  |
| 2687 | 73.2 | Stage 2 | 206d | 2000-01-03 A | 2000-10-13 A | 100% | 2000-01-03 | 2000-10-13 | 206d |  | S2 | 1640h | 1640h | GTT | Rel-4 | Maurice | 23.226 |  |  |  |

Notes:
- 2664: -
- 2665: 28/5/2001: CRs approved at TP-11. WI complete.
- 2666: -
- 2667: 25/5/2001:CR was approved at TP-11. WI is complete
- 2668: Added BB UE authentication and rapporteur added. TO BE DELETED
- 2669: Approved SP#17
- 2670: A5/3 development will consider new GEA algorithm based on Kasumi
- 2671: Complete TSG#09 (09/2000). S3#17: Proposed for deletion. TO BE DELETED
- 2672: -
- 2673: -
- 2674: REPLACED BY NDS-MAP and NDS-IP. Completed Auto Key Management -> Rel-6. Marked as stopped 12/2008
- 2675: UID changed. Marked as stopped 12/2008
- 2676: UID changed. Marked as stopped 12/2008
- 2677: CR approved at SA3#21 awaiting comments from CN1. Marked as stopped 12/2008
- 2678: SP#13 approved WID
- 2679: -
- 2680: -
- 2681: -
- 2682: -
- 2683: -
- 2684: -
- 2685: SP#12 updated WID SP-000162=>SP-010340
- 2686: -
- 2687: -

| ID | WBS | Task | Duration | Start | Finish | Complete | Baseline start | Baseline finish | Baseline duration | Constraint | Resources | Work | Actual work | Text1 | Text6 | Text8 | Text9 | Text12 |
| --- | --- | --- | --- | --- | --- | --- | --- | --- | --- | --- | --- | --- | --- | --- | --- | --- | --- | --- |
| 2688 | 73.3 | **Specification of Cellular Text telephone Modem** | 136d | 2000-09-11 A | 2001-03-19 A | 100% | 2000-09-11 | 2001-03-19 | 136d |  | S4 | 2704h | 2704h | GTT-CTM | Rel-4 | Paolo |  |  |
| 2689 | 73.3.1 | General description and C-code | 66d | 2000-09-11 A | 2000-12-11 A | 100% | 2000-09-11 | 2000-12-11 | 66d | finish no earlier than 2000-12-11 | S4 | 528h | 528h | GTT-CTM | Rel-4 | Paolo |  |  |
| 2690 | 73.3.2 | Minimum Performance requirements | 136d | 2000-09-11 A | 2001-03-19 A | 100% | 2000-09-11 | 2001-03-19 | 136d | finish no earlier than 2001-03-19 | S4 | 1088h | 1088h | GTT-CTM | Rel-4 | Paolo |  |  |
| 2691 | 73.5 | Deleted - Conformance Test Aspects - Global Text Telephony | 2348d? | 2000-09-21 A | 2009-09-18 A | 100% | 2000-09-21 | 2009-09-18 | 2348d? | finish no earlier than 2009-09-18 | R5,T1 | 18784h | 18784h | GTT_Test | Rel-4 | Ingbert | PCG-23 | RP-45 |
| 2692 | 700 | Release 1999 Features | 261d? | 1999-01-01 A | 1999-12-31 A | 100% | 1999-01-01 | 1999-12-31 | 261d? |  | NP,SP,TP,SMG | 2088h | 2088h |  | R99 | All |  |  |
| 2693 | 701 | **UMTS Features** | 261d? | 1999-01-01 A | 1999-12-31 A | 100% | 1999-01-01 | 1999-12-31 | 261d? |  | S1,S2,S4,SMG,N3,N4,RP | 25056h | 25056h |  | R99 | Alain |  |  |
| 2694 | 701.1 | UMTS_SERVICES | 261d? | 1999-01-01 A | 1999-12-31 A | 100% | 1999-01-01 | 1999-12-31 | 261d? | start no earlier than 1999-01-01 | S1 | 2088h | 2088h | UMTS_SERVICES | R99 | Alain |  |  |
| 2695 | 701.2 | UMTS phase 1 | 261d? | 1999-01-01 A | 1999-12-31 A | 100% | 1999-01-01 | 1999-12-31 | 261d? | start no earlier than 1999-01-01 | S1 | 2088h | 2088h | UMTS1 | R99 | Alain |  |  |
| 2696 | 701.3 | UMTS Capabilities | 261d? | 1999-01-01 A | 1999-12-31 A | 100% | 1999-01-01 | 1999-12-31 | 261d? | start no earlier than 1999-01-01 | S1 | 2088h | 2088h | UMTS_Capabil | R99 | Alain |  |  |
| 2697 | 701.4 | Architecture of the GSM-UMTS platform | 261d? | 1999-01-01 A | 1999-12-31 A | 100% | 1999-01-01 | 1999-12-31 | 261d? | start no earlier than 1999-01-01 | S2,N4 | 2088h | 2088h |  | R99 | Maurice |  |  |
| 2698 | 701.5 | UMTS Terrestrial Radio Access Network | 261d? | 1999-01-01 A | 1999-12-31 A | 100% | 1999-01-01 | 1999-12-31 | 261d? | start no earlier than 1999-01-01 | RP | 2088h | 2088h | UTRAN | R99 | Joern |  |  |
| 2699 | 701.6 | UMTS 1800, UMTS 1900 | 261d? | 1999-01-01 A | 1999-12-31 A | 100% | 1999-01-01 | 1999-12-31 | 261d? | start no earlier than 1999-01-01 | R2 | 2088h | 2088h | Rlnlmp19, Rlnlmp18 | R99 | Joern |  |  |
| 2700 | 701.7 | Mandatory speech codec for narrowband telephony service | 261d? | 1999-01-01 A | 1999-12-31 A | 100% | 1999-01-01 | 1999-12-31 | 261d? | start no earlier than 1999-01-01 | S4 | 2088h | 2088h | Mandatory_Speech_Codec, AMR-NB, AMR | R99 | Paolo |  |  |
| 2701 | 701.8 | Codec for low bitrate multimedia telephony service | 261d? | 1999-01-01 A | 1999-12-31 A | 100% | 1999-01-01 | 1999-12-31 | 261d? | start no earlier than 1999-01-01 | S4 | 2088h | 2088h | Low_bit_rate_codec_for_MM_Tel., H.324M | R99 | Paolo |  |  |
| 2702 | 701.9 | 3G Audio-Visual Terminal characteristics | 261d? | 1999-01-01 A | 1999-12-31 A | 100% | 1999-01-01 | 1999-12-31 | 261d? | start no earlier than 1999-01-01 | S4 | 2088h | 2088h | WI5TAC, 3G-AVT, Terminal_Acoustic_Characteristics | R99 | Paolo |  |  |
| 2703 | 701.10 | Updates_for_UMTS | 261d? | 1999-01-01 A | 1999-12-31 A | 100% | 1999-01-01 | 1999-12-31 | 261d? | start no earlier than 1999-01-01 | N3 | 2088h | 2088h | Updates_for_UMTS | R99 | Gwiho |  |  |
| 2704 | 701.11 | UMTS | 261d? | 1999-01-01 A | 1999-12-31 A | 100% | 1999-01-01 | 1999-12-31 | 261d? | start no earlier than 1999-01-01 | N3 | 2088h | 2088h | UMTS | R99 | Gwiho |  |  |
| 2705 | 702 | **UMTS and GSM Features** | 261d? | 1999-01-01 A | 1999-12-31 A | 100% | 1999-01-01 | 1999-12-31 | 261d? |  | S1,S2,SMG,T2,N1,N2,N3,N4,R2,R3 | 114840h | 114840h |  | R99 | Alain |  |  |
| 2706 | 702.1 | Multimedia Messaging Service | 261d? | 1999-01-01 A | 1999-12-31 A | 100% | 1999-01-01 | 1999-12-31 | 261d? | start no earlier than 1999-01-01 | T2 | 2088h | 2088h | MMS | R99 |  |  |  |
| 2707 | 702.2 | Location Services | 261d? | 1999-01-01 A | 1999-12-31 A | 100% | 1999-01-01 | 1999-12-31 | 261d? | start no earlier than 1999-01-01 | S1,S2,S3,SMG1,SMG2,SMG12,N1,N2,N4,R2,R3 | 2088h | 2088h | LCS | R99 | Alain |  |  |
| 2708 | 702.3 | **Customised Application for Mobile network Enhanced Logic Phase 3** | 261d? | 1999-01-01 A | 1999-12-31 A | 100% | 1999-01-01 | 1999-12-31 | 261d? |  | S1,S2,N2,N4 | 6264h | 6264h | CAMEL3 | R99 | Alain |  |  |
| 2709 | 702.3.1 | Global view | 261d? | 1999-01-01 A | 1999-12-31 A | 100% | 1999-01-01 | 1999-12-31 | 261d? | start no earlier than 1999-01-01 | S1,S2,N2,N4 | 2088h | 2088h | CAMEL3 | R99 | Alain |  |  |
| 2710 | 702.3.2 | Multiple Subscriber Profile (MSP) based on CAMEL phase 3 | 261d? | 1999-01-01 A | 1999-12-31 A | 100% | 1999-01-01 | 1999-12-31 | 261d? | start no earlier than 1999-01-01 | S1 | 2088h | 2088h | CAMEL3 | R99 | Alain |  |  |
| 2711 | 702.4 | Short Message Service enhancements / Enhanced Messaging Service (EMS) | 261d? | 1999-01-01 A | 1999-12-31 A | 100% | 1999-01-01 | 1999-12-31 | 261d? | start no earlier than 1999-01-01 | T2 | 2088h | 2088h | EMS | R99 |  |  |  |
| 2712 | 702.5 | Mobile Station Execution Environment | 261d? | 1999-01-01 A | 1999-12-31 A | 100% | 1999-01-01 | 1999-12-31 | 261d? | start no earlier than 1999-01-01 | S1,SMG1,T2 | 2088h | 2088h | MExE | R99 | Alain |  |  |
| 2713 | 702.6 | MS_Classmark | 261d? | 1999-01-01 A | 1999-12-31 A | 100% | 1999-01-01 | 1999-12-31 | 261d? | start no earlier than 1999-01-01 | N1 | 2088h | 2088h | MS_Classmark | R99 | Frederic |  |  |

Notes:
- 2688: -
- 2689: - / Text3: 26.226, 26.230
- 2690: - / Text3: 26.231
- 2691: RP#45 work item abandoned/closed (it was never really started)
- 2692: -
- 2693: -
- 2694: - / Text3: 22.101
- 2695: - / Text3: 22.100
- 2696: Requirement for high quality speech in UMTS Phase 1 but not in R99 / Text3: 22.105
- 2697: wid Architecture overview of the GSM-UMTS System, Architecture the GSM-UMTS Platform and New Access Network to Core Network (BSS-NSS) interface / Text3: 23.002, 23.008, 23.060, 23.101, 23.110
- 2698: - / Text3: 22.011, 22.038, 22.060, 22.078, 22.100, 22.101, 22.105, 22.115, 22.129, 23.002, 23.060, 24.007, 24.008, 25.101, 25.102, 25.104, 25.105, 25.113, 25.123, 25.133, 25.141, 25.142, 25.201, 25.211, 25.212, 25.213, 25.214, 25.215, 25.221, 25.222, 25.223, 25.224,
- 2699: - / Text3: 25.307 CR#0002, 0003 Inclusion of release independent RF related information
- 2700: Define the default speech codec for UMTS (both for FDD and TDD). Definition limited to selection of one codec among several existing ones/proposed codecs: GSM AMR, IS127 EVRC, ITU G.729 and MPEG-4 speech codec. / Text3: 04.08, 05.01, 05.02, 05.03, 05.05, 05.08, 05.09, 05.09, 05.50, 08.60, 08.61, 11.21, 26.071, 26.073, 26.074, 26.090, 26.091, 26.092, 26.093, 26.094, 26.101, 26.102, 26.103, 26.104, 26.975
- 2701: - / Text3: 26.104, 26.110, 26.111, 26.911, 26.912, 26.915
- 2702: - / Text3: 26.131, 26.132
- 2703: - / Text3: 24.022, 27.001, 29.007
- 2704: - / Text3: 27.060, 29.061
- 2705: -
- 2706: MMS allows users to send/receive messages e.g. almost unlimited text length, images, audio and video clips and new content types. R99 only includes the concept. MMS stage 3 is not included in 23.140. Rel-4 adds detailed architecture and protocols. / Text3: 22.140, 23.040, 23.140
- 2707: LCS provide ability to localize a terminal. Location data is used to provide services to end-user (e.g. local map indicating closest restaurants), for emergency services or for a UMTS network entity (RNC to direct beam when space diversity is used) / Text3: 02.07, 03.71, 04.31, 04.35, 04.71, 05.05, 08.08, 08.31, 08.71, 09.31, 22.071, 23.002, 23.003, 23.007, 23.008, 23.016, 23.018, 23.032, 23.171, 24.007, 24.008, 24.030, 24.080, 25.305, 25.306, 25.331, 25.413, 25.423, 29.002, 29.010
- 2708: CAMEL is a network feature providing mechanisms to support services of operators which are not covered by standardised services, even when roaming outside the HPLMN. / Text3: 22.101, 23.008, 23.012, 23.016, 23.018, 23.060, 23.072, 23.078, 23.079, 23.082, 23.093, 29.002, 29.078
- 2709: - / Text3: 22.078, 23.078, 29.078
- 2710: MSP is an optional service enabling mobile subscribers to have several profiles associated with a single IMSI, with each profile being a subscription option. Each profile may be used for mobile originated and mobile terminated calls. / Text3: 22.097 (Advanced Addressing)
- 2711: SMS for 3G terminals compatible with GSM SMS. Added Enhanced Messaging Service (EMS) allowing small pictures, sounds, animations to be transferred via SMS. / Text3: 23.038, 23.039, 23.040, 23.042
- 2712: MExE provides a standardized MS execution environment and ability to negotiate its supported capabilities with a MExE SP. R99 enhances SIM MExE certificate management, security clarifications, QoS and defines two MExE classmarks WAP/Personal-Java based. / Text3: 02.57, 22.057, 22.101, 23.057
- 2713: MExE classmark identifies a category of MExE UE supporting MExE functionality with a minimum level of processing, memory, display, and interactive capabilities. Several MExE classmarks may be defined. / Text3: 24.008

| ID | WBS | Task | Duration | Start | Finish | Complete | Baseline start | Baseline finish | Baseline duration | Constraint | Resources | Work | Actual work | Text1 | Text6 | Text8 | Text12 |
| --- | --- | --- | --- | --- | --- | --- | --- | --- | --- | --- | --- | --- | --- | --- | --- | --- | --- |
| 2714 | 702.7 | **MultiCall** | 261d? | 1999-01-01 A | 1999-12-31 A | 100% | 1999-01-01 | 1999-12-31 | 261d? |  | S1,N1,N2,N4 | 4176h | 4176h | Multicall | R99 | Alain |  |
| 2715 | 702.7.1 | Multicall | 261d? | 1999-01-01 A | 1999-12-31 A | 100% | 1999-01-01 | 1999-12-31 | 261d? | start no earlier than 1999-01-01 | S1 | 2088h | 2088h | Multicall | R99 | Alain |  |
| 2716 | 702.8 | Virtual Home Environment | 261d? | 1999-01-01 A | 1999-12-31 A | 100% | 1999-01-01 | 1999-12-31 | 261d? | start no earlier than 1999-01-01 | S1,SMG1,S2 | 2088h | 2088h | VHE | R99 | Alain |  |
| 2717 | 702.9 | Open Service Access | 261d? | 1999-01-01 A | 1999-12-31 A | 100% | 1999-01-01 | 1999-12-31 | 261d? | start no earlier than 1999-01-01 | S1,S2,N5 | 2088h | 2088h | OSA | R99 | Alain |  |
| 2718 | 702.10 | Super Charger mechanism for signalling traffic associated with mobility | 261d? | 1999-01-01 A | 1999-12-31 A | 100% | 1999-01-01 | 1999-12-31 | 261d? | start no earlier than 1999-01-01 | N2,N4 | 2088h | 2088h | Super_Charger | R99 | Kimmo |  |
| 2719 | 702.11 | Follow_Me service | 261d? | 1999-01-01 A | 1999-12-31 A | 100% | 1999-01-01 | 1999-12-31 | 261d? | start no earlier than 1999-01-01 | S1,N2,N4 | 2088h | 2088h | Follow_Me | R99 | Alain |  |
| 2720 | 702.12 | Wide area network Synchronization and object exchange | 261d? | 1999-01-01 A | 1999-12-31 A | 100% | 1999-01-01 | 1999-12-31 | 261d? | start no earlier than 1999-01-01 | T2 | 2088h | 2088h | SYNC | R99 |  |  |
| 2721 | 702.13 | **Terminal Interfaces** | 261d? | 1999-01-01 A | 1999-12-31 A | 100% | 1999-01-01 | 1999-12-31 | 261d? |  | T2 | 8352h | 8352h |  | R99 |  |  |
| 2722 | 702.13.1 | AT commands for 3GPP | 261d? | 1999-01-01 A | 1999-12-31 A | 100% | 1999-01-01 | 1999-12-31 | 261d? | start no earlier than 1999-01-01 | T2 | 2088h | 2088h |  | R99 |  |  |
| 2723 | 702.13.2 | Physical interfaces | 261d? | 1999-01-01 A | 1999-12-31 A | 100% | 1999-01-01 | 1999-12-31 | 261d? | start no earlier than 1999-01-01 | T2 | 2088h | 2088h |  | R99 |  |  |
| 2724 | 702.13.3 | Multiplexer | 261d? | 1999-01-01 A | 1999-12-31 A | 100% | 1999-01-01 | 1999-12-31 | 261d? | start no earlier than 1999-01-01 | T2 | 2088h | 2088h | MUX MS-TE | R99 |  |  |
| 2725 | 702.14 | **Bearer Services** | 261d? | 1999-01-01 A | 1999-12-31 A | 100% | 1999-01-01 | 1999-12-31 | 261d? |  | S1,T2,N1,N3 | 27144h | 27144h |  | R99 | Alain |  |
| 2726 | 702.14.1 | **Circuit Switched Bearer Services** | 261d? | 1999-01-01 A | 1999-12-31 A | 100% | 1999-01-01 | 1999-12-31 | 261d? |  | S1,N3 | 14616h | 14616h | Circuit_switched_Bearer_Services | R99 | Alain |  |
| 2727 | 702.14.1.1 | Circuit Switched Bearer Services | 261d? | 1999-01-01 A | 1999-12-31 A | 100% | 1999-01-01 | 1999-12-31 | 261d? | start no earlier than 1999-01-01 | S1,N3 | 2088h | 2088h | CS_Bearerss_in_UMTS | R99 | Alain |  |
| 2728 | 702.14.1.2 | CS_Bearers | 261d? | 1999-01-01 A | 1999-12-31 A | 100% | 1999-01-01 | 1999-12-31 | 261d? | start no earlier than 1999-01-01 | N3 | 2088h | 2088h | CS_Bearers | R99 | Gwiho |  |
| 2729 | 702.14.1.3 | CS_Bearerss | 261d? | 1999-01-01 A | 1999-12-31 A | 100% | 1999-01-01 | 1999-12-31 | 261d? | start no earlier than 1999-01-01 | N3 | 2088h | 2088h | CS_Bearerss | R99 | Gwiho |  |
| 2730 | 702.14.1.4 | CS_Data | 261d? | 1999-01-01 A | 1999-12-31 A | 100% | 1999-01-01 | 1999-12-31 | 261d? | start no earlier than 1999-01-01 | N3 | 2088h | 2088h | CS_Data | R99 | Gwiho |  |
| 2731 | 702.14.1.5 | CS_Data_Bearers | 261d? | 1999-01-01 A | 1999-12-31 A | 100% | 1999-01-01 | 1999-12-31 | 261d? | start no earlier than 1999-01-01 | N3 | 2088h | 2088h | CS_Data_Bearers | R99 | Gwiho |  |
| 2732 | 702.14.1.6 | Deleted - Circuit Switched Bearer Services | 261d? | 1999-01-01 A | 1999-12-31 A | 100% | 1999-01-01 | 1999-12-31 | 261d? | start no earlier than 1999-01-01 | N3 | 2088h | 2088h | CSBS | R99 | Gwiho | NP-06 |
| 2733 | 702.14.2 | Frame Tunnelling Mode | 261d? | 1999-01-01 A | 1999-12-31 A | 100% | 1999-01-01 | 1999-12-31 | 261d? | start no earlier than 1999-01-01 | T2,N1,N3 | 2088h | 2088h | FTM | R99 | Gwiho |  |
| 2734 | 702.14.3 | Access to ISPs and Intranets – Wireless/Remote access to LANs | 261d? | 1999-01-01 A | 1999-12-31 A | 100% | 1999-01-01 | 1999-12-31 | 261d? | start no earlier than 1999-01-01 | N3 | 2088h | 2088h | Interworking with PDN (DHCP) | R99 | Gwiho |  |
| 2735 | 702.14.4 | **PHS Internet Access Forum Specification** | 261d? | 1999-01-01 A | 1999-12-31 A | 100% | 1999-01-01 | 1999-12-31 | 261d? |  | S1,N3 | 6264h | 6264h | PIAFS | R99 | Alain |  |
| 2736 | 702.14.4.1 | Personal Handyphone System Internet Access Forum Standard (PIAFS) | 261d? | 1999-01-01 A | 1999-12-31 A | 100% | 1999-01-01 | 1999-12-31 | 261d? | start no earlier than 1999-01-01 | S1 | 2088h | 2088h | PIAFS | R99 | Alain |  |
| 2737 | 702.14.4.2 | Support_of_PIAFS_in_UMTS | 261d? | 1999-01-01 A | 1999-12-31 A | 100% | 1999-01-01 | 1999-12-31 | 261d? | start no earlier than 1999-01-01 | N3 | 2088h | 2088h | Support_of_PIAFS_in_UMTS | R99 | Gwiho |  |

Notes:
- 2714: Multicall allows several simultaneous CS calls with dedicated bearers of independent traffic and performance characteristics. R99 Multicall was defined as a supplementary service limited to one CS bearer to be used for speech at any time. / Text3: 22.030, 22.083, 22.087, 23.008, 23.009, 23.016, 23.018, 23.108, 23.135, 24.008, 24.080, 24.135, 29.002, 29.010
- 2715: - / Text3: 22.030, 22.083, 22.087
- 2716: Information exists in SP#5-8 reports & in SP-99416,SP-000095,SP 000155. OSA allows service development by operators and 3rd parties by making use of network functionality through open, standardised, secure, extensible and scalable interfaces. / Text3: 02.01, 22.105, 22.121,23.127
- 2717: Open Service Architecture became in later Releases Open Service Access. Produced by Parlay, ETSI SPAN (TISPAN), 3GPP SA1 (Stage 1), SA2 (Stage 2) and CN5 (Stage 3), resulting in a single set of standard OSA APIs for the whole development community. / Text3: 22.121, 23.127, 29.198, 29.998
- 2718: Super Charger reduces mobility management cost by reducing the volume of location update signalling. It changes subscriber data management associated with inter-VLR and SGSN location updates. It also applies to packet services (SGSN replaces VLR and … / Text3: 21.905, 23.007, 23.008, 23.012, 23.016, 23.018, 23.040, 23.060, 23.116, 23.912, 29.002
- 2719: Follow Me enables a mobile subscriber A to manipulate the Follow Me data of a party B in such a way that - under certain conditions - subsequent calls directed to party B will be forwarded to subscriber A. It is PLMN-specific and control based on USSD / Text3: 21.905, 22.004, 22.030, 22.082, 22.090, 22.094, 23.090, 24.090, 22.094, 23.011, 23.015, 23.082, 29.002
- 2720: Allows data stored in ME/USIM to be synchronized with the outside world. TS 27.103 defines protocols based upon IrMC level 4 and will evaluate new technologies (XML) for inclusion. From Rel-4 IrMC was replaced by SyncML in 27.103. / Text3: 27.103, 27.903
- 2721: -
- 2722: AT commands to control a 3G ME via an external Terminal Equipment (TE), fully compatible with GSM AT commands. R99 adds new AT commands e.g. to control Advanced Speech Call Items (ASCI) services. / Text3: 27.005, 27.007
- 2723: Conclusion: 3GPP should not produce any technical specification for terminal interfaces other than radio interface and USIM interface. SDOs could develop own optional physical connector specification based on market requirements / Text3: 27.901
- 2724: Multiplexing protocol allowing a number of simultaneous sessions between a MS and a terminal; used to send any data (voice, SMS, USSD, fax etc.). 27.010 describes the protocol, but not the commands or data transported with it. / Text3: 27.010
- 2725: -
- 2726: CS and real-time data services provided for interworking with PSTN/ISDN so that user is unaware of access network used (UMTS, GSM or handover between ANs). Transparent(constant delay) & non-transparent(zero error with flow control) services are supported / Text3: 22.002, 23.910, 27.001, 29.007
- 2727: CS and real-time data services provided for interworking with PSTN/ISDN so that user is unaware of access network used (UMTS, GSM or handover between ANs). Transparent(constant delay) & non-transparent(zero error with flow control) services are supported / Text3: 22.002, 23.910, 27.001, 29.007
- 2728: - / Text3: 29.007
- 2729: - / Text3: 04.21, 23.910, 27.001, 29.007
- 2730: - / Text3: 27.001, 27.002, 27.003, 29.007
- 2731: - / Text3: 23.910, 27.001, 29.007
- 2732: No CR or new TS/TR approved under this WI / Text3: 29.007
- 2733: FTM is a type of async non-transparent CS bearer service (22.002). Generic term for HDLC and HDLC-related transmission protocols. Converts async non-transp data stream towards mobile side & sync data stream using X.31 flag stuffing on fixed network side. / Text3: 22.002, 27.001, 27.007, 29.007
- 2734: Access to an Intranet or ISP by running DHCP between the TE and a server in the Intranet/ISP domain. / Text3: 29.061
- 2735: PIAFS is one type of CS bearer data service (22.002). It refers to async CS tx protocol over ISDN 64 kbit/s unrestricted digital line. Facilitates interworking between PHS-MS and UMTS-UE & UMTS-UE and existing PIAFS TA (Terminal Adapter). / Text3: 22.002, 27.001, 27.007, 29.007
- 2736: PIAFS was originally standardised by the PHS Internet Access Forum in Japan. More information can be found at: http://www.infopro.or.jp/piaf / Text3: 22.002
- 2737: - / Text3: 27.001, 27.007, 29.007

| ID | WBS | Task | Duration | Start | Finish | Complete | Baseline start | Baseline finish | Baseline duration | Constraint | Resources | Work | Actual work | Text1 | Text6 | Text8 | Text12 |
| --- | --- | --- | --- | --- | --- | --- | --- | --- | --- | --- | --- | --- | --- | --- | --- | --- | --- |
| 2738 | 702.15 | **Universal Integrated Circuit Card (UICC) and Universal Subscriber Identity Module (USIM)** | 261d? | 1999-01-01 A | 1999-12-31 A | 100% | 1999-01-01 | 1999-12-31 | 261d? |  | T3 | 27144h | 27144h | UICC, USIM | R99 | Xavier |  |
| 2739 | 702.15.1 | UICC / Terminal interface; Physical and logical characteristics | 261d? | 1999-01-01 A | 1999-12-31 A | 100% | 1999-01-01 | 1999-12-31 | 261d? | start no earlier than 1999-01-01 | T3 | 2088h | 2088h | UICC | R99 | Xavier |  |
| 2740 | 702.15.2 | UICC/(U)SIM enhancements and interworking | 261d? | 1999-01-01 A | 1999-12-31 A | 100% | 1999-01-01 | 1999-12-31 | 261d? | start no earlier than 1999-01-01 | T3 | 2088h | 2088h | UICC1 | R99 | Xavier |  |
| 2741 | 702.15.3 | Characteristics of the USIM application | 261d? | 1999-01-01 A | 1999-12-31 A | 100% | 1999-01-01 | 1999-12-31 | 261d? | start no earlier than 1999-01-01 | T3 | 2088h | 2088h | USIM | R99 | Xavier |  |
| 2742 | 702.15.4 | UICC Application Identifiers | 261d? | 1999-01-01 A | 1999-12-31 A | 100% | 1999-01-01 | 1999-12-31 | 261d? | start no earlier than 1999-01-01 | T3 | 2088h | 2088h | AID, Application_Identifiers | R99 | Xavier |  |
| 2743 | 702.15.5 | SIM Application Toolkit | 261d? | 1999-01-01 A | 1999-12-31 A | 100% | 1999-01-01 | 1999-12-31 | 261d? | start no earlier than 1999-01-01 | S1,T3 | 2088h | 2088h | SAT | R99 | Alain |  |
| 2744 | 702.15.6 | USIM Application Toolkit | 261d? | 1999-01-01 A | 1999-12-31 A | 100% | 1999-01-01 | 1999-12-31 | 261d? | start no earlier than 1999-01-01 | T3 | 2088h | 2088h | USAT | R99 | Xavier |  |
| 2745 | 702.15.7 | Bearer Independent Protocol for SAT applications to exchange data over the GSM network | 261d? | 1999-01-01 A | 1999-12-31 A | 100% | 1999-01-01 | 1999-12-31 | 261d? | start no earlier than 1999-01-01 | T3 | 2088h | 2088h | BIP | R99 | Xavier |  |
| 2746 | 702.15.8 | Administrative commands and functions for IC cards | 261d? | 1999-01-01 A | 1999-12-31 A | 100% | 1999-01-01 | 1999-12-31 | 261d? | start no earlier than 1999-01-01 | T3 | 2088h | 2088h |  | R99 | Xavier |  |
| 2747 | 702.15.9 | USIM and UICC requirements | 261d? | 1999-01-01 A | 1999-12-31 A | 100% | 1999-01-01 | 1999-12-31 | 261d? | start no earlier than 1999-01-01 | T3 | 2088h | 2088h |  | R99 | Xavier |  |
| 2748 | 702.15.10 | SIM_API | 261d? | 1999-01-01 A | 1999-12-31 A | 100% | 1999-01-01 | 1999-12-31 | 261d? | start no earlier than 1999-01-01 | T3 | 2088h | 2088h | SIM_API | R99 | Xavier |  |
| 2749 | 702.15.11 | SIM_toolkit_API | 261d? | 1999-01-01 A | 1999-12-31 A | 100% | 1999-01-01 | 1999-12-31 | 261d? | start no earlier than 1999-01-01 | SMG9,T3 | 2088h | 2088h | SIM_toolkit | R99 | Xavier |  |
| 2750 | 702.15.12 | Deleted - 1.8 Volt SIM ME interface | 261d? | 1999-01-01 A | 1999-12-31 A | 100% | 1999-01-01 | 1999-12-31 | 261d? | start no earlier than 1999-01-01 | SMG9 | 2088h | 2088h | SMIME_1.8V | R99 | Xavier | TP-06 |
| 2751 | 702.16 | **USIM/UICC Testing** | 261d? | 1999-01-01 A | 1999-12-31 A | 100% | 1999-01-01 | 1999-12-31 | 261d? |  | T3 | 10440h | 10440h |  | R99 | Xavier |  |
| 2752 | 702.16.1 | Terminal tests for the UICC Interface | 261d? | 1999-01-01 A | 1999-12-31 A | 100% | 1999-01-01 | 1999-12-31 | 261d? | start no earlier than 1999-01-01 | T3 | 2088h | 2088h |  | R99 | Xavier |  |
| 2753 | 702.16.2 | USIM application test specification | 261d? | 1999-01-01 A | 1999-12-31 A | 100% | 1999-01-01 | 1999-12-31 | 261d? | start no earlier than 1999-01-01 | T3 | 2088h | 2088h |  | R99 | Xavier |  |
| 2754 | 702.16.3 | USIM conformance test specification | 261d? | 1999-01-01 A | 1999-12-31 A | 100% | 1999-01-01 | 1999-12-31 | 261d? | start no earlier than 1999-01-01 | T3 | 2088h | 2088h |  | R99 | Xavier |  |
| 2755 | 702.16.4 | SIM toolkit test specification | 261d? | 1999-01-01 A | 1999-12-31 A | 100% | 1999-01-01 | 1999-12-31 | 261d? | start no earlier than 1999-01-01 | T3 | 2088h | 2088h |  | R99 | Xavier |  |
| 2756 | 702.17 | **Security** | 261d? | 1999-01-01 A | 1999-12-31 A | 100% | 1999-01-01 | 1999-12-31 | 261d? |  | S3,N2,N4 | 8352h | 8352h | Security | R99 | Dionisio |  |
| 2757 | 702.17.1 | Fraud Information Gathering Service (for connection-orientated services) | 261d? | 1999-01-01 A | 1999-12-31 A | 100% | 1999-01-01 | 1999-12-31 | 261d? | start no earlier than 1999-01-01 | S3 | 2088h | 2088h | FIGS | R99 | Dionisio |  |
| 2758 | 702.17.2 | Immediate Service Termination / SECurity Immediate Service Termination | 261d? | 1999-01-01 A | 1999-12-31 A | 100% | 1999-01-01 | 1999-12-31 | 261d? | start no earlier than 1999-01-01 | S3,N2,N4 | 2088h | 2088h | IST, SECIST | R99 | Dionisio |  |
| 2759 | 702.17.3 | Core_Network_Security | 261d? | 1999-01-01 A | 1999-12-31 A | 100% | 1999-01-01 | 1999-12-31 | 261d? | start no earlier than 1999-01-01 | N4 | 2088h | 2088h | Core_Network_Security | R99 | Kimmo |  |
| 2760 | 703 | **GSM Features** | 261d? | 1999-01-01 A | 1999-12-31 A | 100% | 1999-01-01 | 1999-12-31 | 261d? |  | S1,S2,SMG,T2,N1,N2,N3,N4 | 50112h | 50112h |  | R99 | Alain |  |
| 2761 | 703.1 | **Dual Transfer Mode within GSM and GPRS** | 261d? | 1999-01-01 A | 1999-12-31 A | 100% | 1999-01-01 | 1999-12-31 | 261d? |  | SMG,N1 | 6264h | 6264h | DTM | R99 | Frederic |  |
| 2762 | 703.1.1 | Class A Dual Transfer Mode | 261d? | 1999-01-01 A | 1999-12-31 A | 100% | 1999-01-01 | 1999-12-31 | 261d? | start no earlier than 1999-01-01 | SMG | 2088h | 2088h | Class_A_Dual_Transfer_Mode_(DTM) | R99 | Frederic |  |
| 2763 | 703.1.2 | Dual Transfer Mode | 261d? | 1999-01-01 A | 1999-12-31 A | 100% | 1999-01-01 | 1999-12-31 | 261d? | start no earlier than 1999-01-01 | SMG,N1 | 2088h | 2088h | DTM | R99 | Frederic |  |

Notes:
- 2738: For 3G, GSM 11.11 was divided into two parts: a platform comprised of basic physical, electrical and logical specification (31.101) and an application specification (31.102)
- 2739: Defines a generic Terminal/Integrated Circuit Card (ICC) interface. Is independent of 3G USIM application => platform for any IC card application. Ensures interoperability between ICC and terminal independently of manufacturer, card issuer or operator. / Text3: 31.101 (Since 10/2000, ETSI EP SCP is responsible for the generic Terminal/Integrated Circuit Card (ICC) interface TS 102 221)
- 2740: - / Text3: 31.102, 31.900
- 2741: Defines Universal Subscriber Identity Module (USIM) application for 3G telecom network operation & resides on UICC, an IC card specified in 31.101. UICC can be used as a multi-application card: several USIMs and/or other applications can co-exist / Text3: 31.102
- 2742: Defines and administers Application IDentifiers (AID) for UICC. AID is used to address an application in the card. Consists of Registered application provider ID (RID) & Proprietary application ID exception (PIX - according to ISO/IEC 7816-5). / Text3: 21.111, 31.110
- 2743: - / Text3: 11.14, 22.030, 22.100, 22.101
- 2744: Defines UICC - ME interface, and mandatory ME procedures for USAT. Based on GSM 11.14 (SIM Application Toolkit). Commands and procedures defined in USIM and 3G Terminal for using USAT. Service and security requirements defined in 22.100 and 22.101. / Text3: 31.111
- 2745: Defines at SIM-ME interface a basic protocol allowing SIM Toolkit applications to determine available bearers and to exchange data by selecting using the most appropriate bearer available (CS data, GPRS, SMS, Unstructured Supplementary Service Data (USSD) / Text3: 03.48, 11.10, 11.14
- 2746: Defines function and syntax of administrative commands for telecommunication IC Card used during installation, activation and de-activation of applications. Compliant to ISO/IEC 7816 series. Handed over to ETSI Project Smart Card Platform (SCP) in 2000. / Text3: ETSI TS 102 222
- 2747: High level requirements for 3GPP IC card and its interface to 3GPP terminal (USIM&UICC reqs). Service&security reqs in 322.01,22.00. USIM is a 3GPP application on an IC card. Inter-operates with 3GPP terminals and provides access to 3GPP services / Text3: 21.111
- 2748: - / Text3: 03.19
- 2749: - / Text3: 03.48, 11.11, 11.14
- 2750: No CR or new TS/TR approved under this WI / Text3: 11.18
- 2751: -
- 2752: Test spec for the interface between UICC and terminal (originally based GSM 11.10-1 clause 27). Ensures UICC - terminal interoperability independently of manufacturer, card issuer or operator. Tests for applications residing on UICC are in 31.121 / Text3: 31.120
- 2753: Application test spec originally based on GSM 11.17. Aspects related to UICC administrative management phase are not defined. Any internal technical realisation of either UICC or terminal is only specified where these are reflected over the interface. / Text3: 31.121
- 2754: Conformance Test specification for UICC defined in 31.101 with USIM defined in 31.102. / Text3: 31.122
- 2755: SIM Application Toolkit (SAT) has major impact on ME design and enhances SIM/ME interface. Contains tests for SIM/ME interface optional features (no network related signalling issues involved). Doesn't form basis for any type approval or regulatory tests. / Text3: 11.10-4
- 2756: - / Text3: 02.09, 03.20, 21.133, 22.022, 23.003, 23.007, 23.008, 23.012, 23.018, 24.007, 24.008, 24.010, 24.011, 29.002, 29.060, 33.102, 33.103, 33.105, 33.107, 35.201
- 2757: HPLMN can monitor its subscribers in VPLMN, which collects info on a defined set of monitored subscribers activities & sends it to HPLMN, which can perform service limitation control eg Operator Determined Barring (ODB) and IST to limit financial exposure / Text3: 22.031, 23.031
- 2758: HPLMN can terminate all activities of its subscriber in VPLMN, if decides (based on info via eg FIGS) that a roaming subscriber is behaving in fraudulent/suspicious way. HPLMN can terminate all subscriber activities including calls in progress. / Text3: 03.35, 22.032, 23.008, 23.016, 23.035, 29.002
- 2759: - / Text3: 29.002
- 2760: -
- 2761: WID on BSS co-ordination of Radio Resource allocation for class A GPRS services - GSM Radio Access (R99) / Text3: 03.55, 03.64, 04.18, 04.60, 05.01, 05.02, 05.08, 08.08, 23.060, 24.007, 24.008
- 2762: - / Text3: 05.10
- 2763: - / Text3: 03.55, 03.64, 04.18, 05.01, 05.02, 05.08, 24.008

| ID | WBS | Task | Duration | Start | Finish | Complete | Baseline start | Baseline finish | Baseline duration | Constraint | Resources | Work | Actual work | Text1 | Text6 | Text8 | Text12 | Text4 | Text5 |
| --- | --- | --- | --- | --- | --- | --- | --- | --- | --- | --- | --- | --- | --- | --- | --- | --- | --- | --- | --- |
| 2764 | 703.2 | **General Packet Radio Service enahancements** | 261d? | 1999-01-01 A | 1999-12-31 A | 100% | 1999-01-01 | 1999-12-31 | 261d? |  | S1,S2,SMG1,SMG2,SMG7,N1,N2,N3,N4,T2 | 8352h | 8352h | GPRS enhancements | R99 | Alain |  |  |  |
| 2765 | 703.2.1 | General Packet Radio Service | 261d? | 1999-01-01 A | 1999-12-31 A | 100% | 1999-01-01 | 1999-12-31 | 261d? | start no earlier than 1999-01-01 | S1,S2,SMG1,SMG2,SMG7,N1,N2,N3,N4,T2 | 2088h | 2088h | GPRS | R99 | Alain |  |  |  |
| 2766 | 703.2.2 | GPRS2 | 261d? | 1999-01-01 A | 1999-12-31 A | 100% | 1999-01-01 | 1999-12-31 | 261d? | start no earlier than 1999-01-01 | SMG1,N2 | 2088h | 2088h | GPRS2 | R99 |  |  |  |  |
| 2767 | 703.2.3 | GPRS Tunnelling Protocol enhancement | 261d? | 1999-01-01 A | 1999-12-31 A | 100% | 1999-01-01 | 1999-12-31 | 261d? | start no earlier than 1999-01-01 | N4,N2 | 2088h | 2088h | GTP_enhancement | R99 | Kimmo |  |  |  |
| 2768 | 703.3 | **Enhanced Data rates for GSM Evolution - Phase 1** | 261d? | 1999-01-01 A | 1999-12-31 A | 100% | 1999-01-01 | 1999-12-31 | 261d? |  | SMG2,SMG1,SMG3,SMG4,SMG7,SMG9,SMG10,N1,N3,T2 | 25056h | 25056h | EDGE - Phase 1 | R99 | Maurice |  |  |  |
| 2769 | 703.3.1 | Enhanced Data rates for GSM Evolution | 261d? | 1999-01-01 A | 1999-12-31 A | 100% | 1999-01-01 | 1999-12-31 | 261d? | start no earlier than 1999-01-01 | SMG2,SMG1,SMG3,SMG4,SMG7,SMG9,SMG10,N1,N3,T2 | 2088h | 2088h | EDGE | R99 | Maurice |  |  |  |
| 2770 | 703.3.2 | EDGE-Layer1 | 261d? | 1999-01-01 A | 1999-12-31 A | 100% | 1999-01-01 | 1999-12-31 | 261d? | start no earlier than 1999-01-01 | SMG2 | 2088h | 2088h | EDGE-Layer1 | R99 |  |  |  |  |
| 2771 | 703.3.3 | High Speed Circuit Switched Data | 261d? | 1999-01-01 A | 1999-12-31 A | 100% | 1999-01-01 | 1999-12-31 | 261d? | start no earlier than 1999-01-01 | SMG1,SMG2,SMG7 | 2088h | 2088h | HSCSD | R99 |  |  |  |  |
| 2772 | 703.3.4 | Enhanced Circuit Switched Data - Phase 1 | 261d? | 1999-01-01 A | 1999-12-31 A | 100% | 1999-01-01 | 1999-12-31 | 261d? | start no earlier than 1999-01-01 | S1,SMG | 2088h | 2088h | ECSD | R99 | Alain |  |  |  |
| 2773 | 703.3.5 | EDGE-Enhanced Circuit Switched Data | 261d? | 1999-01-01 A | 1999-12-31 A | 100% | 1999-01-01 | 1999-12-31 | 261d? | start no earlier than 1999-01-01 | SMG2 | 2088h | 2088h | EDGE-ECSD | R99 |  |  |  |  |
| 2774 | 703.3.6 | Enhanced GPRS - Phase 1 | 261d? | 1999-01-01 A | 1999-12-31 A | 100% | 1999-01-01 | 1999-12-31 | 261d? | start no earlier than 1999-01-01 | SMG,N1 | 2088h | 2088h | EGPRS | R99 |  |  |  |  |
| 2775 | 703.3.7 | EDGE-EGPRS | 261d? | 1999-01-01 A | 1999-12-31 A | 100% | 1999-01-01 | 1999-12-31 | 261d? | start no earlier than 1999-01-01 | SMG2 | 2088h | 2088h | EDGE-EGPRS | R99 |  |  |  |  |
| 2776 | 703.3.8 | Packet Flow Context (PFC) | 261d? | 1999-01-01 A | 1999-12-31 A | 100% | 1999-01-01 | 1999-12-31 | 261d? | start no earlier than 1999-01-01 | SMG2 | 2088h | 2088h | PFC | R99 |  |  |  |  |
| 2777 | 703.3.9 | Support for EGPRS in ANSI-136 networks and EDGE COMPACT | 261d? | 1999-01-01 A | 1999-12-31 A | 100% | 1999-01-01 | 1999-12-31 | 261d? | start no earlier than 1999-01-01 | SMG | 2088h | 2088h | EDGE-Compact | R99 |  |  |  |  |
| 2778 | 703.3.10 | EGPRS COMPACT | 261d? | 1999-01-01 A | 1999-12-31 A | 100% | 1999-01-01 | 1999-12-31 | 261d? | start no earlier than 1999-01-01 | SMG | 2088h | 2088h | EGPRS-Compact | R99 |  |  |  |  |
| 2779 | 703.3.11 | COMPACT | 261d? | 1999-01-01 A | 1999-12-31 A | 100% | 1999-01-01 | 1999-12-31 | 261d? | start no earlier than 1999-01-01 | SMG,N1 | 2088h | 2088h | COMPACT | R99 |  |  |  |  |
| 2780 | 703.4 | GSM_400 | 261d? | 1999-01-01 A | 1999-12-31 A | 100% | 1999-01-01 | 1999-12-31 | 261d? | start no earlier than 1999-01-01 | SMG2,SMG7,T2 | 2088h | 2088h | GSM_400 | R99 | Paolo |  |  |  |
| 2781 | 703.5 | GSM_450 | 261d? | 1999-01-01 A | 1999-12-31 A | 100% | 1999-01-01 | 1999-12-31 | 261d? | start no earlier than 1999-01-01 | SMG2 | 2088h | 2088h | GSM_450 | R99 |  |  |  |  |
| 2782 | 703.6 | GSM_700 | 261d? | 1999-01-01 A | 1999-12-31 A | 100% | 1999-01-01 | 1999-12-31 | 261d? | start no earlier than 1999-01-01 | SMG2 | 2088h | 2088h | GSM_700 | R99 |  |  |  |  |
| 2783 | 703.7 | Deleted - GERAN | 261d? | 1999-01-01 A | 1999-12-31 A | 100% | 1999-01-01 | 1999-12-31 | 261d? | start no earlier than 1999-01-01 | SMG2,S2 | 2088h | 2088h | GERAN | R99 | Maurice | SP-06 |  |  |
| 2784 | 704 | **GSM Features transposed to UMTS** | 261d? | 1999-01-01 A | 1999-12-31 A | 100% | 1999-01-01 | 1999-12-31 | 261d? |  | S1,S3,T2,N2,N4 | 16704h | 16704h |  | R99 | Alain |  |  |  |
| 2785 | 704.1 | Cell Broadcast Service | 261d? | 1999-01-01 A | 1999-12-31 A | 100% | 1999-01-01 | 1999-12-31 | 261d? | start no earlier than 1999-01-01 | T2 | 2088h | 2088h | CBS | R99 |  |  |  |  |
| 2786 | 704.2 | **GSM mobile number portability euro MNP / North American MNP** | 261d? | 1999-01-01 A | 1999-12-31 A | 100% | 1999-01-01 | 1999-12-31 | 261d? |  | S1,N2,N4 | 4176h | 4176h | MNP | R99 | Alain |  |  |  |
| 2787 | 704.2.1 | Mobile Number Portability | 261d? | 1999-01-01 A | 1999-12-31 A | 100% | 1999-01-01 | 1999-12-31 | 261d? | start no earlier than 1999-01-01 | N2,N4 | 2088h | 2088h | MNP | R99 | Kimmo |  |  |  |
| 2788 | 704.3 | Automatic establishment of roaming relations | 261d? | 1999-01-01 A | 1999-12-31 A | 100% | 1999-01-01 | 1999-12-31 | 261d? | start no earlier than 1999-01-01 | S1 | 2088h | 2088h |  | R99 | Alain |  | Telecom Italia | enrico.scarrone@telecomitalia.it |
| 2789 | 704.4 | Advanced addressing | 261d? | 1999-01-01 A | 1999-12-31 A | 100% | 1999-01-01 | 1999-12-31 | 261d? | start no earlier than 1999-01-01 | S1 | 2088h | 2088h |  | R99 | Alain |  |  |  |
| 2790 | 704.5 | UMTS numbering, addressing and identities | 261d? | 1999-01-01 A | 1999-12-31 A | 100% | 1999-01-01 | 1999-12-31 | 261d? | start no earlier than 1999-01-01 | S1 | 2088h | 2088h |  | R99 | Alain |  |  |  |
| 2791 | 704.6 | Lawful Interception | 261d? | 1999-01-01 A | 1999-12-31 A | 100% | 1999-01-01 | 1999-12-31 | 261d? | start no earlier than 1999-01-01 | S3 | 2088h | 2088h | LI | R99 | Dionisio |  |  |  |

Notes:
- 2764: GPRS was introduced in Release 97. Release 99 brings a number of essential corrections e.g. on Downlink Power Control, Timing Advance procedure, Cell reselection delay time, PBCCH scheduling, PTCCH mapping, etc. / Text3: 05.02, 05.05, 05.08, 05.10, 05.50, 11.21, 23.064, 24.008, 24.060
- 2765: - / Text3: 02.60, 03.22, 03.64, 04.18, 04.60, 04.64, 04.65, 05.01, 05.02, 05.05, 05.08, 05.10, 08.08, 08.18, 11.10-1, 11.21, 22.041, 22.060, 23.003, 23.007, 23.060, 23.107, 23.122, 24.007, 24.008, 27.007, 27.060, 29.002, 29.016, 29.018, 29.060, 29.061
- 2766: Introduction of EGPRS (S1) + Introduction of Reserved Service Labels in the APN (N2) / Text3: 02.60, 23.003
- 2767: - / Text3: 23.003, 23.008, 29.060
- 2768: EDGE is independent of the frequency bands, so it can be deployed e.g. in 900 and 1900 MHz bands. The new physical layer based on 8-PSK modulation is introduced and EGPRS and ECSD facilitate the new modulation in single and multi slot constellation. / Text3: 10.59, 02.34, 02.60, 03.30, 05.10, 05.50, 11.26
- 2769: - / Text3: 02.34, 03.10, 03.20, 03.64, 04.03, 04.04, 04.06, 04.08, 04.18, 04.21, 04.22, 04.60, 04.64, 05.01, 05.02, 05.03, 05.04, 05.05, 05.08, 05.10, 05.50, 07.01, 07.02, 07.03, 08.08, 08.20, 08.58, 08.60, 09.07, 09.18, 11.10-1, 11.11, 11.21, 11.26, 23.034, 24.008,
- 2770: - / Text3: 05.05, 05.10, 05.50
- 2771: No additional features for R99. / Text3: 02.34, 04.18, 11.10-1
- 2772: ECSD supports both transparent and non-transparent services, up to 64 kbit/s and 57.6 kbit/s respectively. See Tdoc SMG2 670/99 ECSD Concept Evaluation for more info / Text3: 05.02, 08.58, 22.034
- 2773: - / Text3: 05.03
- 2774: - / Text3: 02.07, 03.64, 04.14, 04.18, 04.60, 05.05, 05.08, 24.008
- 2775: - / Text3: 05.03, 05.05, 05.08
- 2776: - / Text3: 04.18
- 2777: Support for EGPRS in ANSI-136 networks and EDGE Compact (for ANSI-136 networks only). COMPACT = Deployment of services in spectrum below 1 MHz / Text3: 03.22, 03.30, 03.64, 05.01, 05.02, 05.03, 05.05, 05.08, 05.10
- 2778: COMPACT = Deployment of services in spectrum below 1 MHz / Text3: 04.18, 05.02
- 2779: COMPACT = Deployment of services in spectrum below 1 MHz / Text3: 03.22, 04.18, 04.60, 05.08, 23.122, 24.008
- 2780: GSM in the 400 MHz bands allows to deploy GSM within frequency bands in the range 450 to 500 MHz, previously used for analogue cellular systems. See Tdoc SMG2 190/99 and 595/99 for further info. / Text3: 02.17, 03.22, 03.30, 04.04, 04.18, 04.60, 05.01, 05.02, 05.05, 05.08, 05.10, 05.50, 08.18, 08.58, 11.21, 24.008, 27.007
- 2781: - / Text3: 03.22, 03.30, 05.01, 05.05, 05.08
- 2782: - / Text3: 05.05
- 2783: No CR or new TS/TR approved under this WI / Text3: G2: 04.18 CR#A248 , 04.60 CR#B090
- 2784: -
- 2785: Moved to CT1 at TSG-T closure. Applicability of the Cell Broadcast Service (as defined for GSM network) to 3G networks / Text3: 23.041
- 2786: R98 MNP: mobile subscriber ability to change PLMN operator within the same country whilst retaining its original MS ISDN number (MSISDN). IMSI is changed, only MSISDN is kept. R99 adds requirements for North American Service Provider Number Portability. / Text3: 22.066
- 2787: - / Text3: 23.018, 23.066, 29.002
- 2788: framework for commercial and technical interworking between UMTS Home Environments and Serving Networks who have no direct prior commercial agreements with each other. / Text3: 22.101, 22.971
- 2789: - / Text3: 22.101, 22.75U, 22.975
- 2790: Also new requirements for Single and Multiple Numbering scheme was added (CR#20 and 21). Deleted the term International Mobile User Identifier (IMUI) and changed IMSI (International Mobile Station Identifier=>International Mobile Subscriber Identity. / Text3: 22.101
- 2791: Defines an interception system in UMTS that supports a number of regional interception regulations. Regional interception requirements shall be met in using specific (regional) mediation functions allowing only required information to be transported. / Text3: 33.106, 33.107

| ID | WBS | Task | Duration | Start | Finish | Complete | Baseline start | Baseline finish | Baseline duration | Constraint | Resources | Work | Actual work | Text1 | Text6 | Text8 |
| --- | --- | --- | --- | --- | --- | --- | --- | --- | --- | --- | --- | --- | --- | --- | --- | --- |
| 2792 | 705 | **Charging** | 261d? | 1999-01-01 A | 1999-12-31 A | 100% | 1999-01-01 | 1999-12-31 | 261d? |  | S1,S5 | 6264h | 6264h | CH | R99 | Alain |
| 2793 | 705.1 | Charging | 261d? | 1999-01-01 A | 1999-12-31 A | 100% | 1999-01-01 | 1999-12-31 | 261d? | start no earlier than 1999-01-01 | S1 | 2088h | 2088h | Charging | R99 | Alain |
| 2794 | 705.2 | OAM Charging Management | 261d? | 1999-01-01 A | 1999-12-31 A | 100% | 1999-01-01 | 1999-12-31 | 261d? | start no earlier than 1999-01-01 | S5 | 2088h | 2088h | OAMCH, CH | R99 | Dionisio |
| 2795 | 706 | **Operations, Administration, Maintenance and Provisioning (OAM&P)** | 261d? | 1999-01-01 A | 1999-12-31 A | 100% | 1999-01-01 | 1999-12-31 | 261d? |  | S5 | 12528h | 12528h | OAM | R99 | Dionisio |
| 2796 | 706.1 | OAM Principles and High-level Requirements | 261d? | 1999-01-01 A | 1999-12-31 A | 100% | 1999-01-01 | 1999-12-31 | 261d? | start no earlier than 1999-01-01 | S5 | 2088h | 2088h | PR, Princs_&_Reqs_(PR) | R99 | Dionisio |
| 2797 | 706.2 | OAM Architecture | 261d? | 1999-01-01 A | 1999-12-31 A | 100% | 1999-01-01 | 1999-12-31 | 261d? | start no earlier than 1999-01-01 | S5 | 2088h | 2088h | OAMAR, AR, Telecom_Management_Arch_(AR) | R99 | Dionisio |
| 2798 | 706.3 | OAM Configuration Management | 261d? | 1999-01-01 A | 1999-12-31 A | 100% | 1999-01-01 | 1999-12-31 | 261d? | start no earlier than 1999-01-01 | S5 | 2088h | 2088h | OAMCM, CM | R99 | Dionisio |
| 2799 | 706.4 | OAM Fault Management | 261d? | 1999-01-01 A | 1999-12-31 A | 100% | 1999-01-01 | 1999-12-31 | 261d? | start no earlier than 1999-01-01 | S5 | 2088h | 2088h | OAMFM | R99 | Dionisio |
| 2800 | 706.5 | OAM Performance Management | 261d? | 1999-01-01 A | 1999-12-31 A | 100% | 1999-01-01 | 1999-12-31 | 261d? | start no earlier than 1999-01-01 | S5 | 2088h | 2088h | OAMPM, PM | R99 | Dionisio |
| 2801 | 707 | Vocabulary | 261d? | 1999-01-01 A | 1999-12-31 A | 100% | 1999-01-01 | 1999-12-31 | 261d? | start no earlier than 1999-01-01 | S1 | 2088h | 2088h | Vocabulary | R99 | Alain |
| 2802 | 708 | Emergency | 261d? | 1999-01-01 A | 1999-12-31 A | 100% | 1999-01-01 | 1999-12-31 | 261d? | start no earlier than 1999-01-01 | S1 | 2088h | 2088h | Emergency | R99 | Alain |
| 2803 | 709 | GSM General Bearer Services (GBS) and interworking scenarios support in UMTS | 261d? | 1999-01-01 A | 1999-12-31 A | 100% | 1999-01-01 | 1999-12-31 | 261d? | start no earlier than 1999-01-01 | S1 | 2088h | 2088h | GSM_to_UMTS_Evol | R99 | Alain |
| 2804 | 710 | GPRS_Mobile_IP_interworking | 261d? | 1999-01-01 A | 1999-12-31 A | 100% | 1999-01-01 | 1999-12-31 | 261d? | start no earlier than 1999-01-01 | N3 | 2088h | 2088h | GPRS_Mobile_IP_interworking | R99 |  |
| 2805 | 711 | GSM/UMTS interworking | 261d? | 1999-01-01 A | 1999-12-31 A | 100% | 1999-01-01 | 1999-12-31 | 261d? | start no earlier than 1999-01-01 | N1,N2,N4,R3,S1,SMG | 2088h | 2088h | 2G3Ginterworking | R99 | Frederic |
| 2806 | 712 | Handover | 261d? | 1999-01-01 A | 1999-12-31 A | 100% | 1999-01-01 | 1999-12-31 | 261d? | start no earlier than 1999-01-01 | S1,SMG2,N1,N2,N4 | 2088h | 2088h | Handover | R99 | Alain |
| 2807 | 713 | 2G3Ghandover | 261d? | 1999-01-01 A | 1999-12-31 A | 100% | 1999-01-01 | 1999-12-31 | 261d? | start no earlier than 1999-01-01 | SMG2 | 2088h | 2088h | 2G3Ghandover | R99 |  |
| 2808 | 714 | Service Provider Name Indication | 261d? | 1999-01-01 A | 1999-12-31 A | 100% | 1999-01-01 | 1999-12-31 | 261d? | start no earlier than 1999-01-01 | S1 | 2088h | 2088h | SPANME | R99 | Alain |
| 2809 | 715 | Data & Data_CleanUp | 261d? | 1999-01-01 A | 1999-12-31 A | 100% | 1999-01-01 | 1999-12-31 | 261d? | start no earlier than 1999-01-01 | SMG1 | 2088h | 2088h | Data, Data_CleanUp | R99 |  |
| 2810 | 716 | Unstructured Supplementary Service Data | 261d? | 1999-01-01 A | 1999-12-31 A | 100% | 1999-01-01 | 1999-12-31 | 261d? | start no earlier than 1999-01-01 | SMG1,N4 | 2088h | 2088h | USSD | R99 | Kimmo |
| 2811 | 717 | Man-Machine Interface (MMI) of the User Equipment (UE) | 261d? | 1999-01-01 A | 1999-12-31 A | 100% | 1999-01-01 | 1999-12-31 | 261d? | start no earlier than 1999-01-01 | S1 | 2088h | 2088h | MMI | R99 | Alain |
| 2812 | 718 | Network Identity and Timezone (NITZ) | 261d? | 1999-01-01 A | 1999-12-31 A | 100% | 1999-01-01 | 1999-12-31 | 261d? | start no earlier than 1999-01-01 | SMG1,SMG3 | 2088h | 2088h | NITZ | R99 | Alain |
| 2813 | 719 | Operator Determined Barring for Packet Oriented Services | 261d? | 1999-01-01 A | 1999-12-31 A | 100% | 1999-01-01 | 1999-12-31 | 261d? | start no earlier than 1999-01-01 | S1 | 2088h | 2088h | ODB_Enh. | R99 | Alain |
| 2814 | 720 | Packet Flow Management | 261d? | 1999-01-01 A | 1999-12-31 A | 100% | 1999-01-01 | 1999-12-31 | 261d? | start no earlier than 1999-01-01 | SMG2 | 2088h | 2088h | Packet_Flow_Management | R99 |  |
| 2815 | 721 | GPRS_Point-To-Multipoint Group call | 261d? | 1999-01-01 A | 1999-12-31 A | 100% | 1999-01-01 | 1999-12-31 | 261d? | start no earlier than 1999-01-01 | SMG1 | 2088h | 2088h | GPRS_PTMG | R99 |  |

Notes:
- 2792: -
- 2793: WID SP-99271 Charging and accounting / Text3: 22.115, 23.121
- 2794: WID SP-99581 SA5 Year 2000 Work plan / Text3: 32.005, 32.015
- 2795: WID SP-99581 SA5 Year 2000 Work plan
- 2796: WID SP-99581 SA5 Year 2000 Work plan / Text3: 32.101
- 2797: WID SP-99581 SA5 Year 2000 Work plan / Text3: 32.101, 32.102
- 2798: WID SP-99273 Configuration management / Text3: 32.106, 32.106-1, 32.106-2, 32.106-3, 32.106-4, 32.106-5, 32.106-6, 32.106-7, 32.106-8
- 2799: WID SP-99272 Fault management / Text3: 32.111, 32.111-1, 32.111-2, 32.111-3, 32.111-4
- 2800: WID SP-99274 Performance management / Text3: 12.04, 32.104
- 2801: - / Text3: 21.905
- 2802: - / Text3: 22.101
- 2803: UMTS shall support GSM General Bearer Services (GBS) and interworking scenarios as specified in 02.02 / Text3: 22.105
- 2804: - / Text3: 29.061
- 2805: - / Text3: 03.22, 04.18, 04.60, 05.02, 05.08, 05.10, 08.08, 08.18, 08.58, 09.08, 22.011, 23.003, 23.009, 23.014, 23.034, 23.122, 24.007, 24.008, 24.011, 24.080, 29.108
- 2806: - / Text3: 04.18, 08.08, 08.58, 22.129, 23.009, 29.002, 29.010
- 2807: - / Text3: 04.18, 04.60, 05.02, 05.08, 05.10, 08.08, 29.010
- 2808: Service Provider Name Indication included in R98 (02.07) was not carried into R99 (22.101), but is in the SIM/USIM specification for R99 / Text3: 22.101
- 2809: - / Text3: 02.01, 02.02, 02.04, 02.34
- 2810: No additional features for R99. / Text3: 02.04, 02.90, 23.090, 29.002
- 2811: Data services streamlining + Support for Anonymous Call Rejection / Text3: 22.030
- 2812: - / Text3: 02.42, 04.08
- 2813: Remove ODB for Packet Oriented Services from R99 / Text3: 22.041
- 2814: - / Text3: 08.18
- 2815: - / Text3: 02.60

| ID | WBS | Task | Duration | Start | Finish | Complete | Baseline start | Baseline finish | Baseline duration | Constraint | Resources | Work | Actual work | Text6 | Text8 |
| --- | --- | --- | --- | --- | --- | --- | --- | --- | --- | --- | --- | --- | --- | --- | --- |
| 2816 | 722 | **Call Forwarding** | 261d? | 1999-01-01 A | 1999-12-31 A | 100% | 1999-01-01 | 1999-12-31 | 261d? |  | SMG1,N2,N4 | 8352h | 8352h | R99 | Kimmo |
| 2817 | 722.1 | Call Forwarding enhancements | 261d? | 1999-01-01 A | 1999-12-31 A | 100% | 1999-01-01 | 1999-12-31 | 261d? | start no earlier than 1999-01-01 | N4,N2 | 2088h | 2088h | R99 | Kimmo |
| 2818 | 722.2 | Call_Forwarding | 261d? | 1999-01-01 A | 1999-12-31 A | 100% | 1999-01-01 | 1999-12-31 | 261d? | start no earlier than 1999-01-01 | SMG1,N2 | 2088h | 2088h | R99 | Kimmo |
| 2819 | 722.3 | Call_Forwarding_Enhancements | 261d? | 1999-01-01 A | 1999-12-31 A | 100% | 1999-01-01 | 1999-12-31 | 261d? | start no earlier than 1999-01-01 | N4 | 2088h | 2088h | R99 | Kimmo |
| 2820 | 723 | **Quality of Service** | 261d? | 1999-01-01 A | 1999-12-31 A | 100% | 1999-01-01 | 1999-12-31 | 261d? |  | S2,T2,N1,N2,N4 | 10440h | 10440h | R99 | Maurice |
| 2821 | 723.1 | End-to-end UMTS Quality of Service management | 261d? | 1999-01-01 A | 1999-12-31 A | 100% | 1999-01-01 | 1999-12-31 | 261d? | start no earlier than 1999-01-01 | S2,T2,N1,N2,N4 | 2088h | 2088h | R99 | Maurice |
| 2822 | 723.2 | End-to-end QoS for PS Domain including IMS | 261d? | 1999-01-01 A | 1999-12-31 A | 100% | 1999-01-01 | 1999-12-31 | 261d? | start no earlier than 1999-01-01 | S2 | 2088h | 2088h | R99 | Maurice |
| 2823 | 723.3 | GPRS-enhanced_QoS | 261d? | 1999-01-01 A | 1999-12-31 A | 100% | 1999-01-01 | 1999-12-31 | 261d? | start no earlier than 1999-01-01 | T2 | 2088h | 2088h | R99 |  |
| 2824 | 723.4 | QoS_enhancements | 261d? | 1999-01-01 A | 1999-12-31 A | 100% | 1999-01-01 | 1999-12-31 | 261d? | start no earlier than 1999-01-01 | N2,N1,N4 | 2088h | 2088h | R99 | Kimmo |
| 2825 | 724 | Support of Localised Service Area | 261d? | 1999-01-01 A | 1999-12-31 A | 100% | 1999-01-01 | 1999-12-31 | 261d? | start no earlier than 1999-01-01 | SMG2,SMG3,SMG7,N2 | 2088h | 2088h | R99 | Maurice |
| 2826 | 725 | Transcoder_location | 261d? | 1999-01-01 A | 1999-12-31 A | 100% | 1999-01-01 | 1999-12-31 | 261d? | start no earlier than 1999-01-01 | S2 | 2088h | 2088h | R99 | Maurice |
| 2827 | 726 | Antenna_test_methods | 261d? | 1999-01-01 A | 1999-12-31 A | 100% | 1999-01-01 | 1999-12-31 | 261d? | start no earlier than 1999-01-01 | SMG2 | 2088h | 2088h | R99 |  |
| 2828 | 727 | WBAMR / high quality speech in UMTS Phase 1 but not in R99 | 261d? | 1999-01-01 A | 1999-12-31 A | 100% | 1999-01-01 | 1999-12-31 | 261d? | start no earlier than 1999-01-01 | S1 | 2088h | 2088h | R99 | Alain |
| 2829 | 728 | **Codec** | 261d? | 1999-01-01 A | 1999-12-31 A | 100% | 1999-01-01 | 1999-12-31 | 261d? |  | S4 | 14616h | 14616h | R99 | Paolo |
| 2830 | 728.1 | Codec(s)_for_Multimedia_Telephony_Service | 261d? | 1999-01-01 A | 1999-12-31 A | 100% | 1999-01-01 | 1999-12-31 | 261d? | start no earlier than 1999-01-01 | S4 | 2088h | 2088h | R99 | Paolo |
| 2831 | 728.2 | QoS for Speech and Multimedia Codec | 261d? | 1999-01-01 A | 1999-12-31 A | 100% | 1999-01-01 | 1999-12-31 | 261d? | start no earlier than 1999-01-01 | S4 | 2088h | 2088h | R99 | Paolo |
| 2832 | 728.3 | Tandem Free Operation - Adaptive Multi-Rate codec types | 261d? | 1999-01-01 A | 1999-12-31 A | 100% | 1999-01-01 | 1999-12-31 | 261d? | start no earlier than 1999-01-01 | S4 | 2088h | 2088h | R99 | Paolo |
| 2833 | 728.4 | Noise Suppression for AMR | 261d? | 1999-01-01 A | 1999-12-31 A | 100% | 1999-01-01 | 1999-12-31 | 261d? | start no earlier than 1999-01-01 | S4 | 2088h | 2088h | R99 | Paolo |
| 2834 | 728.5 | Out-of-Band Transcoder | 261d? | 1999-01-01 A | 1999-12-31 A | 100% | 1999-01-01 | 1999-12-31 | 261d? | start no earlier than 1999-01-01 | N1 | 2088h | 2088h | R99 | Frederic |
| 2835 | 728.6 | Out-of-Band Transcoder Control | 261d? | 1999-01-01 A | 1999-12-31 A | 100% | 1999-01-01 | 1999-12-31 | 261d? | start no earlier than 1999-01-01 | N1 | 2088h | 2088h | R99 | Frederic |
| 2836 | 729 | Advanced Speech Call Items enhancements | 261d? | 1999-01-01 A | 1999-12-31 A | 100% | 1999-01-01 | 1999-12-31 | 261d? | start no earlier than 1999-01-01 | SMG1,SMG2,SMG3,SMG7,SMG9,N1,C1,N4,S1,T2 | 2088h | 2088h | R99 | Alain |
| 2837 | 730 | Call Control improvements | 261d? | 1999-01-01 A | 1999-12-31 A | 100% | 1999-01-01 | 1999-12-31 | 261d? | start no earlier than 1999-01-01 | N1 | 2088h | 2088h | R99 | Frederic |
| 2838 | 731 | Multimedia | 261d? | 1999-01-01 A | 1999-12-31 A | 100% | 1999-01-01 | 1999-12-31 | 261d? | start no earlier than 1999-01-01 | N1,N3 | 2088h | 2088h | R99 | Frederic |
| 2839 | 732 | Sub-System Number allocation for RANAP, RNSAP | 261d? | 1999-01-01 A | 1999-12-31 A | 100% | 1999-01-01 | 1999-12-31 | 261d? | start no earlier than 1999-01-01 | N2 | 2088h | 2088h | R99 | Frederic |
| 2840 | 733 | Intranet / ISP access with DHCP end-to-end | 261d? | 1999-01-01 A | 1999-12-31 A | 100% | 1999-01-01 | 1999-12-31 | 261d? | start no earlier than 1999-01-01 | N3 | 2088h | 2088h | R99 | Gwiho |
| 2841 | 734 | Point_to_Multipoint_Services | 261d? | 1999-01-01 A | 1999-12-31 A | 100% | 1999-01-01 | 1999-12-31 | 261d? | start no earlier than 1999-01-01 | N3 | 2088h | 2088h | R99 | Gwiho |
| 2842 | 735 | Facsimile | 261d? | 1999-01-01 A | 1999-12-31 A | 100% | 1999-01-01 | 1999-12-31 | 261d? | start no earlier than 1999-01-01 | S1 | 2088h | 2088h | R99 | Alain |
| 2843 | 736 | Realtime_NT_FAX_in_UMTS | 261d? | 1999-01-01 A | 1999-12-31 A | 100% | 1999-01-01 | 1999-12-31 | 261d? | start no earlier than 1999-01-01 | N3 | 2088h | 2088h | R99 | Gwiho |
| 2844 | 737 | Gateway Location Register (GLR) - Mobile Application Part (MAP) specification | 261d? | 1999-01-01 A | 1999-12-31 A | 100% | 1999-01-01 | 1999-12-31 | 261d? | start no earlier than 1999-01-01 | N4 | 2088h | 2088h | R99 | Kimmo |
| 2845 | 738 | Multiple Subscriber Profile phase 2 | 261d? | 1999-01-01 A | 1999-12-31 A | 100% | 1999-01-01 | 1999-12-31 | 261d? | start no earlier than 1999-01-01 | S1,N4 | 2088h | 2088h | R99 | Alain |
| 2846 | 739 | Prepaging | 261d? | 1999-01-01 A | 1999-12-31 A | 100% | 1999-01-01 | 1999-12-31 | 261d? | start no earlier than 1999-01-01 | N2,N4 | 2088h | 2088h | R99 | Kimmo |
| 2847 | 740 | Downlink Advanced Receiver Performance | 261d? | 1999-01-01 A | 1999-12-31 A | 100% | 1999-01-01 | 1999-12-31 | 261d? | start no earlier than 1999-01-01 | SMG | 2088h | 2088h | R99 |  |
| 2848 | 741 | Harmonized Standard | 261d? | 1999-01-01 A | 1999-12-31 A | 100% | 1999-01-01 | 1999-12-31 | 261d? | start no earlier than 1999-01-01 | SMG2 | 2088h | 2088h | R99 |  |
| 2849 | 742 | Streamlining of specifications | 261d? | 1999-01-01 A | 1999-12-31 A | 100% | 1999-01-01 | 1999-12-31 | 261d? | start no earlier than 1999-01-01 | N3 | 2088h | 2088h | R99 | Gwiho |
| 2850 | 743 | R99_Service_Clean_up | 261d? | 1999-01-01 A | 1999-12-31 A | 100% | 1999-01-01 | 1999-12-31 | 261d? | start no earlier than 1999-01-01 | N3 | 2088h | 2088h | R99 | Gwiho |

Notes:
- 2816: -
- 2817: No additional features for R99. / Text1: CF_enhancements / Text3: 23.078, 23.079, 23.082, 29.002, 29.078
- 2818: - / Text1: Call_Forwarding / Text3: 02.82, 29.002
- 2819: - / Text1: Call_Forwarding_Enhancements / Text3: 23.082
- 2820: WID SMG 98-0781 End To End UMTS QoS Management
- 2821: WID SMG 98-0781 End To End UMTS QoS Management / Text1: QoS / Text3: 23.107, 23.907, 24.008
- 2822: - / Text1: E2EQoS / Text3: 23.060, 23.170
- 2823: AT-commands for Enhanced QoS Support management / Text1: GPRS-enhanced_QoS / Text3: 27.007
- 2824: - / Text1: QoS_enhancements / Text3: 23.008, 23.016, 24.008, 29.002, 29.060
- 2825: Mechanism which can be used as a platform for providing special tariffs and/or special set of service features for certain subscribers within a regionally restricted area or areas. No additional features for R99. / Text1: SoLSA / Text3: 04.08, 04.18, 08.08, 11.10-1, 29.002
- 2826: UE location identification: background information and associated primitives 2. Transcoder location at the core network and source depending coding belonging to the non-access stratum. / Text1: Transcoder_location / Text3: 23.110
- 2827: - / Text1: Antenna_test_methods / Text3: 03.30
- 2828: Add requirement for high quality speech in UMTS Phase 1 but not in R99 / Text1: WBAMR / Text3: 22.105
- 2829: -
- 2830: - / Text1: Multimedia_Codec, CSM, WI2MMC, Codec(s)_for_CS_MM_Tel._Serv, Codec(s)_for_MM_Tel_Service, Codec_for_Multimedia_Telephony / Text3: 26.911, 26.104, 26.111
- 2831: - / Text1: QoS_for_Speech_&_MM_Codecs_/_AMR / Text3: 26.102, 26.912
- 2832: UMTS_AMR2 is default Codec Type in R99 dual_mode terminals / Text1: TFOAMR / Text3: 26.103
- 2833: Combination of the AMR speech codec and the Noise Suppression function. TS 06.77 and TR 06.78 only apply to GSM. They apply to UMTS from Rel-4 onwards, when they were converted to TS 26.077 and TR 26.078. / Text1: AMRNS / Text3: 06.77, 06.78
- 2834: Transcoder handling in the CN at inter-system handover and relocation + Introduction of UMTS AMR / Text1: OoBT / Text3: 23.009, 24.008
- 2835: 24.008 CR#0572 in NP-020220 was approved under this WI / Text1: OoBTC / Text3: 24.008 CR#0572 in NP-020220
- 2836: - / Text1: ASCI / Text3: 02.30, 02.68, 03.68, 03.69, 04.18, 08.08, 11.10-1, 11.11, 23.067, 23.094, 24.008, 24.067, 27.007, 29.002
- 2837: Minor improvements to 24.007 and 24.008 to increase the number of simultaneous calls/sessions from the present 7: the TI value is increased (NP-99441). / Text1: CC_Related_items / Text3: 24.007, 24.008
- 2838: - / Text1: Multimedia / Text3: 24.008, 27.001, 29.007
- 2839: Sub-System Number allocation for Radio Access Network Application Part, Radio Network Subsystem Application Part / Text1: SSN_allocation / Text3: 23.003
- 2840: Access to an Intranet/ISP with DHCP end to end / Text1: ISPaccess / Text3: 29.061
- 2841: Support for the IP-Multicast protocol / Text1: Point_to_Multipoint_Services / Text3: 29.061
- 2842: - / Text1: FAX / Text3: 22.003, 22.100
- 2843: Asynchronous Interface for real-time NT Fax + Introduction of Asynchronous interface for Real-time non-transparent FAX / Text1: Realtime_NT_FAX_in_UMTS / Text3: 27.001, 27.003
- 2844: - / Text1: GLR / Text3: 29.120
- 2845: - / Text1: MSP2 / Text3: 22.097, 23.072, 23.083, 23.084, 23.091, 23.093, 23.097
- 2846: - / Text1: Prepaging / Text3: 23.018, 23.082, 29.002
- 2847: Re-definition of channel quality measure used for AMR link adaptation for DARP MS / Text3: 05.09
- 2848: - / Text1: HS / Text3: 13.21
- 2849: - / Text1: Streamlining / Text3: 27.060, 29.061
- 2850: - / Text1: R99_Service_Clean_up / Text3: 03.10, 27.001, 27.002, 27.003, 27.060, 29.007, 29.061

| ID | WBS | Task | Type | Duration | Start | Finish | Complete | Baseline start | Baseline finish | Baseline duration | Constraint | Resources | Work | Actual work | Text1 | Text6 | Text8 | Text3 | Text12 | Text4 | Text5 |
| --- | --- | --- | --- | --- | --- | --- | --- | --- | --- | --- | --- | --- | --- | --- | --- | --- | --- | --- | --- | --- | --- |
| 2851 | 744 | **(Small) Technical Enhancements and Improvements for R99** |  | 261d? | 1999-01-01 A | 1999-12-31 A | 100% | 1999-01-01 | 1999-12-31 | 261d? |  | N3 | 6264h | 6264h | TEI | R99 | Gwiho |  |  |  |  |
| 2852 | 744.1 | TEI_[CS_Data] |  | 261d? | 1999-01-01 A | 1999-12-31 A | 100% | 1999-01-01 | 1999-12-31 | 261d? | start no earlier than 1999-01-01 | N3 | 2088h | 2088h | TEI_[CS_Data] | R99 | Gwiho |  |  |  |  |
| 2853 | 744.2 | TEI_[GPRS] |  | 261d? | 1999-01-01 A | 1999-12-31 A | 100% | 1999-01-01 | 1999-12-31 | 261d? | start no earlier than 1999-01-01 | N3 | 2088h | 2088h | TEI_[GPRS] | R99 | Gwiho |  |  |  |  |
| 2854 | 745 | **R99 UE Conformance Testing** |  | 261d? | 1999-01-01 A | 1999-12-31 A | 100% | 1999-01-01 | 1999-12-31 | 261d? |  | R5,T1 | 4176h | 4176h | TEI_Test | R99 | Ingbert | 34.108, 34.121, 34.122, 34.123-1, 34.123-2, 34.123-3 |  |  |  |
| 2855 | 745.1 | Deleted - RTEI |  | 261d? | 1999-01-01 A | 1999-12-31 A | 100% | 1999-01-01 | 1999-12-31 | 261d? | start no earlier than 1999-01-01 | T1 | 2088h | 2088h | RTEI | R99 | Ingbert | 34.123-1 CR#0650, 0651, 34.123-3 CR#0148, 0149, 0150 | TP-06 |  |  |
| 2856 | 745.2 | Common test environments for User Equipment (UE); Conformance testing | milestone | 0d? | 1999-01-01 A | 1999-01-01 A | 100% | 1999-01-01 | 1999-01-01 | 0d? | start no earlier than 1999-01-01 | R5,T1 |  |  | TEI_Test | R99 | Ingbert | 34.108 |  |  |  |
| 2857 | 745.3 | Terminal conformance specification, Radio transmission and reception (FDD) | milestone | 0d? | 1999-01-01 A | 1999-01-01 A | 100% | 1999-01-01 | 1999-01-01 | 0d? | start no earlier than 1999-01-01 | R5,T1 |  |  | TEI_Test | R99 | Ingbert | 34.121 |  |  |  |
| 2858 | 745.4 | Terminal conformance specification, Radio transmission and reception (TDD) | milestone | 0d? | 1999-01-01 A | 1999-01-01 A | 100% | 1999-01-01 | 1999-01-01 | 0d? | start no earlier than 1999-01-01 | R5,T1 |  |  | TEI_Test | R99 | Ingbert | 34.122 |  |  |  |
| 2859 | 745.5 | UE conformance specification; Part 1: Protocol conformance specification | milestone | 0d? | 1999-01-01 A | 1999-01-01 A | 100% | 1999-01-01 | 1999-01-01 | 0d? | start no earlier than 1999-01-01 | R5,T1 |  |  | TEI_Test | R99 | Ingbert | 34.123-1 |  |  |  |
| 2860 | 745.6 | UE conformance specification; Part 2: Implementation Conformance Statement (ICS) specification | milestone | 0d? | 1999-01-01 A | 1999-01-01 A | 100% | 1999-01-01 | 1999-01-01 | 0d? | start no earlier than 1999-01-01 | R5,T1 |  |  | TEI_Test | R99 | Ingbert | 34.123-2 |  |  |  |
| 2861 | 745.7 | UE conformance specification; Part 3: Abstract test suites (ATSs) | milestone | 0d? | 1999-01-01 A | 1999-01-01 A | 100% | 1999-01-01 | 1999-01-01 | 0d? | start no earlier than 1999-01-01 | R5,T1 |  |  | TEI_Test | R99 | Ingbert | 34.123-3 |  |  |  |
| 2862 | 746 | Deleted - Dual Tone Multi-Frequency signalling : Support in the whole 3GPP system |  | 261d? | 1999-01-01 A | 1999-12-31 A | 100% | 1999-01-01 | 1999-12-31 | 261d? | start no earlier than 1999-01-01 | N1 | 2088h | 2088h | DTMF | R99 | Frederic | 23.014 CR#0004 | NP-06 |  |  |
| 2863 | 747 | Deleted - Intersystem_Change |  | 261d? | 1999-01-01 A | 1999-12-31 A | 100% | 1999-01-01 | 1999-12-31 | 261d? | start no earlier than 1999-01-01 | SMG | 2088h | 2088h | Intersystem_Change | R99 |  | 04.18 CR#A243 | SMG |  |  |
| 2864 | 748 | Deleted - Long_Forwardedto_Numbers |  | 261d? | 1999-01-01 A | 1999-12-31 A | 100% | 1999-01-01 | 1999-12-31 | 261d? | start no earlier than 1999-01-01 | N2 | 2088h | 2088h | Long_Forwardedto_Numbers | R99 | Kimmo | 29.002 | NP-06 |  |  |
| 2865 | 749 | Deleted - RANimp-FSEarlyUE |  | 261d? | 1999-01-01 A | 1999-12-31 A | 100% | 1999-01-01 | 1999-12-31 | 261d? | start no earlier than 1999-01-01 | R3 | 2088h | 2088h | RANimp-FSEarlyUE | R99 | Juha | 25.413 CR#0520, 0538, 0565, 0563, 0541, 0540, 0539, 0547 | RP-06 |  |  |
| 2866 | 750 | Release 1999 Studies |  | 261d? | 1999-01-01 A | 1999-12-31 A | 100% | 1999-01-01 | 1999-12-31 | 261d? |  | S1,T2 | 2088h | 2088h |  | R99 | Alain |  |  |  |  |
| 2867 | 751 | Advanced Addressing/Numbering |  | 261d? | 1999-01-01 A | 1999-12-31 A | 100% | 1999-01-01 | 1999-12-31 | 261d? | start no earlier than 1999-01-01 | S1 | 2088h | 2088h | Numbering | R99 | Alain | 22.975 |  | Vodafone | mona.mustapha@vodafone.com |
| 2868 | 752 | Combined GSM and Mobile IP mobility handling in UMTS IP CN |  | 261d? | 1999-01-01 A | 1999-12-31 A | 100% | 1999-01-01 | 1999-12-31 | 261d? | start no earlier than 1999-01-01 | S2 | 2088h | 2088h |  | R99 | Maurice | 23.923 |  |  |  |
| 2869 | 753 | UE Capabilities Requirements |  | 261d? | 1999-01-01 A | 1999-12-31 A | 100% | 1999-01-01 | 1999-12-31 | 261d? | start no earlier than 1999-01-01 | T2 | 2088h | 2088h | UCR | R99 |  | 21.904 |  |  |  |
| 2870 | 754 | Electrical safety requirements and regulations |  | 261d? | 1999-01-01 A | 1999-12-31 A | 100% | 1999-01-01 | 1999-12-31 | 261d? | start no earlier than 1999-01-01 | T2 | 2088h | 2088h |  | R99 |  | 34.907 |  |  |  |
| 2871 | 755 | Specific Absorbtion Rate (SAR) requirements and regulations in different regions |  | 261d? | 1999-01-01 A | 1999-12-31 A | 100% | 1999-01-01 | 1999-12-31 | 261d? | start no earlier than 1999-01-01 | T2 | 2088h | 2088h |  | R99 |  | 34.925 |  |  |  |
| 2872 | 756 | Multi-mode UE issues |  | 261d? | 1999-01-01 A | 1999-12-31 A | 100% | 1999-01-01 | 1999-12-31 | 261d? | start no earlier than 1999-01-01 | T2 | 2088h | 2088h |  | R99 |  | 21.810, 21.910 |  |  |  |
| 2873 | 757 | Provision of fax service in GSM and UMTS |  | 261d? | 1999-01-01 A | 1999-12-31 A | 100% | 1999-01-01 | 1999-12-31 | 261d? | start no earlier than 1999-01-01 | T2 | 2088h | 2088h |  | R99 |  | 22.945 |  | Ericsson | peter.bleckert@ericsson.com |
| 2874 | 758 | Separating Radio Resources and Mobility Management specific parts of the MS Classmark |  | 650d | 2003-09-19 A | 2006-03-16 A | 100% | 2003-09-19 | 2006-03-16 | 650d |  | T2 | 5200h | 5200h |  | R99 |  | 23.814 |  |  |  |

Notes:
- 2851: -
- 2852: -
- 2853: -
- 2854: Specifies Conformance Tests for a 3G UE to be recognised as 3GPP-standard compliant. A 3GPP-external body, GCF (Global Certification Forum), delivers certificates to prove that a UE has correctly passed tests and is then conform to the 3GPP standard.
- 2855: No CR or new TS/TR approved under this WI
- 2856: -
- 2857: measurement procedures for the conformance test of the UE that contain transmitting characteristics, receiving characteristics and performance requirements in addition to requirements for support of RRM (Radio Resource Management) in FDD mode.
- 2858: measurement procedures for the conformance test of the UE that contain transmitting characteristics, receiving characteristics and performance requirements in addition to requirements for support of RRM (Radio Resource Management) in TDD mode.
- 2859: TS 34.123, composed of three parts, actually specifies the protocol conformance testing for the 3G UE. Part 1 describes the overall test structure.
- 2860: Part 2 contains the applicability of each test case defined as the Implementation Conformance Statement (ICS) proforma, in compliance with the relevant requirements, and in accordance with the relevant guidance given in ISO/IEC 9646-7 and ETS 300 406.
- 2861: Part 3 specifies the protocol conformance testing in TTCN for the 3G UE at the Uu interface. It defines the TTCN test specification and design considerations in Abstract Test Suites based on the test cases specified in prose in part 1.
- 2862: No CR or new TS/TR approved under this WI
- 2863: No CR or new TS/TR approved under this WI
- 2864: -
- 2865: No CR or new TS/TR approved under this WI
- 2866: -
- 2867: Study on requirements for numbering and addressing for UMTS
- 2868: -
- 2869: Moved to CT1 at TSG-T closure
- 2870: Moved to RAN4 at TSG-T closure. TR summarizes differences between international and national standards relevant to IEC60950 and refers to regulations for conformity assessment due to different regulatory environments in different countries / regions.
- 2871: Moved to RAN4 at TSG-T closure.
- 2872: Moved to CT1 at TSG-T closure. Consequences on roaming capabilities and service availability (e.g. handover) of multi-mode UEs while roaming in various regions with various network configurations. Case studies for each of the possible scenarios in specs
- 2873: CP#27: Moved to C1 on closure of T2; see TP-050062. CP#28: C1->C3
- 2874: CP#27: change of WG as a result of closure of CN and T.
